# Outline ELEXON Plan_kc

Schedule from MS Project, 2022-10-31 to 2027-12-23, status date 2025-05-06, A marks actual dates.

## Calendars

- Standard: Mon-Fri 08:00-12:00, 13:00-17:00; Sat-Sun off.

## Resources

| Resource |
| --- |
| PMO |
| SI |
| PPC |
| Lead Workstream |
| CPT |
| PP |
| SI Design |
| SI Design |
| SI Design |
| Design |
| SI DevOps |
| SI Test |
| PSG |
| DAG |
| TMAG |
| CCAG |
| Code drafters (SRO Design Team |
| Code Bodies) |
| CCAG PM |
| Programme Participants |
| Code drafters |
| CDWG |
| SRO Design Team |
| Code Bodies |
| Ofgem |
| Elexon resources TBC |
| LDP Programme Manager |
| SRO Client Programme Director |
| IPA |
| LDP |
| SRO |
| )) |
| ? |
| TBC |
| OOC |
| MHHSP |
| Adrian Page |
| Amy Clayton |
| Anand Kaveripatna |
| Berlinda Kugara |
| Cesar Lopes |
| Charlie Blanks |
| Chetan Ubale |
| Daniel Callender |
| Daniel Gee |
| David Hollinshead |
| Dean Bailey |
| Dominic Mooney |
| Elayaraja Jeyaraman |
| Georgi Rabotov |
| Giles Clayden |
| Helen Richardson |
| Ishti Bhatti |
| Jafer Shah |
| Jason Brogden |
| John Edmonds Bell |
| John Wiggins |
| Karthikeyan Ganesan |
| Kasimali Hajiyani |
| Kate Goodman |
| Keegan Moodley |
| Keith Clark |
| Keith Lawlor |
| kevin Davis |
| Kishore Konduru |
| Kyle Abraham |
| Mahjabeen Newaz |
| Martin Freeman |
| Matt Hall |
| Matthew Breen |
| Michael Inije |
| Michael Walton |
| Ming Li |
| Nathalia Revlien |
| Nick Sewell |
| Nigel Hunt |
| Oskar Cahill |
| Paul Pettitt |
| Rakhee Shah |
| Rebecca Farooq |
| Renu Rathor |
| Robert Short |
| Robert Topley |
| Saadia Sajjad |
| Sean Tuffy |
| Shaid Hussain |
| Sharmeen Shaikh |
| Simon Berry |
| Steve Bradford |
| Steve Weston |
| Taaran Suri |
| Waseem Mohammed |
| Zak Hussain |
| berli |
| SI Migration |
| v |
| Andrew Margan |
| Lee Cox |
| DIP SP |
| DIPS SP |
| DIPSP |
| Ian Smith |
| N/A |
| SIT Component Integration Testing 2 Preparation Complete (incl. approval of SI SIT Component Integration Test Readiness Report) |
| Nich |
| Nicola Farley |
| Warren Fulton |
| Richard Puddephatt |
| Matthew Bray |
| Programme |
| LDSOs |
| Ben Wickins |
| paul |
| LDSO |
| Simon chidwick |
| Stuart Scott |
| MHHS Programme |
| Claire Silk |
| Laura Kennedy |
| Rowan B |
| FD |
| MB |
| AM |
| Roger Robar |
| Laura Kennedy. |

## Schedule

| ID | WBS | Task | Type | Duration | Start | Finish | Complete | Remaining | Baseline start | Baseline finish | Baseline duration | Baseline 1 start | Baseline 1 finish | Total slack | Constraint | Baseline cost | Responsible | Involved | Update Version | MHHS Resource Name | Sched Status | RAG | Text9 | Task Status | Future RAG |
| --- | --- | --- | --- | --- | --- | --- | --- | --- | --- | --- | --- | --- | --- | --- | --- | --- | --- | --- | --- | --- | --- | --- | --- | --- | --- |
| 1 | 1 | **PROGRAMME PLAN.** |  | 1344d? | 2022-10-31 A | 2027-12-23 | 66% | 455.72d? | 2022-10-31 | 2027-12-23 | 1195d |  |  |  |  | -0 | N/A | N/A | 5.0 | N/A |  |  |  |  |  |
| 2 | 1.1 | MHHS Programme Start | milestone | 0d | 2022-10-31 A | 2022-10-31 A | 100% |  | 2022-10-31 | 2022-10-31 | 0d |  |  |  |  |  | N/A | N/A | 5.7 | N/A | Complete | COMPLETE |  |  |  |
| 3 | 1.2 | **PROGRAMME MANAGEMENT** |  | 1089d | 2022-10-31 A | 2026-12-31 | 57% | 471.77d | 2022-10-31 | 2026-12-31 | 1089d | 2022-10-31 | 2026-12-31 | 255d |  |  | N/A | N/A | 5.0 | N/A |  |  |  |  |  |
| 4 | 1.2.1 | **Programme Management** |  | 1089d | 2022-10-31 A | 2026-12-31 | 56% | 477d | 2022-10-31 | 2026-12-31 | 1089d | 2022-10-31 | 2026-12-31 | 255d |  |  | N/A | N/A | 5.0 | N/A |  |  | Programme Management | M10 |  |
| 5 | 1.2.1.1 | Sprint-based prioritisation planning and execution |  | 1089d | 2022-10-31 A | 2026-12-31 | 56% | 477d | 2022-10-31 | 2026-12-31 | 1089d | 2022-10-31 | 2026-12-31 | 255d | finish no earlier than 2026-12-31 |  | PMO | CPT | 5.0 | N/A | Green | GREEN | Programme Management |  |  |
| 6 | 1.2.1.2 | Programme governance secretariat |  | 1089d | 2022-10-31 A | 2026-12-31 | 56% | 477d | 2022-10-31 | 2026-12-31 | 1089d | 2022-10-31 | 2026-12-31 | 255d |  |  | PMO | CPT | 5.0 | N/A | Green | GREEN | Programme Management |  |  |
| 7 | 1.2.1.3 | RAID management and reporting |  | 1089d | 2022-10-31 A | 2026-12-31 | 56% | 477d | 2022-10-31 | 2026-12-31 | 1089d | 2022-10-31 | 2026-12-31 | 255d |  |  | PMO | CPT | 5.0 | N/A | Green | GREEN | Programme Management |  |  |
| 8 | 1.2.1.4 | Tracking against Programme outcomes and KPIs |  | 1089d | 2022-10-31 A | 2026-12-31 | 56% | 477d | 2022-10-31 | 2026-12-31 | 1089d | 2022-10-31 | 2026-12-31 | 255d |  |  | PMO | CPT | 5.0 | N/A | Green | GREEN | Programme Management |  |  |
| 9 | 1.2.1.5 | Change control and reporting |  | 1089d | 2022-10-31 A | 2026-12-31 | 56% | 477d | 2022-10-31 | 2026-12-31 | 1089d | 2022-10-31 | 2026-12-31 | 255d |  |  | PMO | CPT | 5.0 | N/A | Green | GREEN | Programme Management |  |  |
| 10 | 1.2.1.6 | Ongoing identification of lessons learned relating to the PMO and implementation of improvements |  | 1089d | 2022-10-31 A | 2026-12-31 | 56% | 477d | 2022-10-31 | 2026-12-31 | 1089d | 2022-10-31 | 2026-12-31 | 255d |  |  | PMO | CPT | 5.0 | N/A | Green | GREEN | Programme Management |  |  |
| 11 | 1.2.2 | **Programme Internal Assurance Reviews** |  | 1089d | 2022-10-31 A | 2026-12-31 | 56% | 477d | 2022-10-31 | 2026-12-31 | 1089d | 2022-10-31 | 2026-12-31 | 255d |  |  | N/A | N/A | 5.0 | N/A |  |  | Programme Management | M9 | D18A - Quarterly Assurance Report |
| 12 | 1.2.2.1 | Programme Internal Assurance Reviews |  | 1089d | 2022-10-31 A | 2026-12-31 | 56% | 477d | 2022-10-31 | 2026-12-31 | 1089d | 2022-10-31 | 2026-12-31 | 255d |  |  | CPT | PMO | 5.0 | N/A | Green | GREEN | Programme Management |  | D18A - Quarterly Assurance Report |
| 13 | 1.2.3 | **Engagement with PPs** |  | 1089d | 2022-10-31 A | 2026-12-31 | 56% | 476.86d | 2022-10-31 | 2026-12-31 | 1089d | 2022-10-31 | 2026-12-31 | 255d |  |  | N/A | N/A | 5.0 | N/A |  |  | Programme Management | M5,M6 |  |
| 14 | 1.2.3.1 | Ongoing PP liaison activities |  | 1089d | 2022-10-31 A | 2026-12-31 | 56% | 477d | 2022-10-31 | 2026-12-31 | 1089d | 2022-10-31 | 2026-12-31 | 255d |  |  | PPC | CPT | 5.0 | N/A | Green | GREEN | Programme Management |  |  |
| 15 | 1.2.3.2 | Milestone and Control Point objective setting |  | 1089d | 2022-10-31 A | 2026-12-31 | 56% | 477d | 2022-10-31 | 2026-12-31 | 1089d | 2022-10-31 | 2026-12-31 | 255d |  |  | PPC | CPT | 5.0 | N/A | Green | GREEN | Programme Management |  |  |
| 16 | 1.2.3.3 | Reporting |  | 1089d | 2022-10-31 A | 2026-12-31 | 56% | 477d | 2022-10-31 | 2026-12-31 | 1089d | 2022-10-31 | 2026-12-31 | 255d |  |  | PPC |  | 5.0 | N/A | Green | GREEN | Programme Management |  |  |
| 17 | 1.2.3.4 | **PP Engagement Events** |  | 1089d | 2022-10-31 A | 2026-12-31 | 56% | 477d | 2022-10-31 | 2026-12-31 | 1089d | 2022-10-31 | 2026-12-31 | 255d |  |  | N/A | N/A | 5.0 | N/A |  |  | Programme Management |  |  |
| 18 | 1.2.3.4.1 | Bilateral meetings |  | 1089d | 2022-10-31 A | 2026-12-31 | 56% | 477d | 2022-10-31 | 2026-12-31 | 1089d | 2022-10-31 | 2026-12-31 | 255d |  |  | PPC | CPT | 5.0 | N/A | Green | GREEN | Programme Management |  |  |
| 19 | 1.2.3.4.2 | Monthly webinars |  | 1089d | 2022-10-31 A | 2026-12-31 | 56% | 477d | 2022-10-31 | 2026-12-31 | 1089d | 2022-10-31 | 2026-12-31 | 255d |  |  | PPC | CPT | 5.0 | N/A | Green | GREEN | Programme Management |  |  |
| 20 | 1.2.3.4.3 | Open days |  | 1089d | 2022-10-31 A | 2026-12-31 | 56% | 477d | 2022-10-31 | 2026-12-31 | 1089d | 2022-10-31 | 2026-12-31 | 255d |  |  | PPC | CPT | 5.0 | N/A | Green | GREEN | Programme Management |  |  |
| 21 | 1.2.3.5 | **PP Communications** |  | 1088d | 2022-10-31 A | 2026-12-30 | 56% | 476d | 2022-10-31 | 2026-12-30 | 1088d | 2022-10-31 | 2026-12-30 | 256d |  |  | N/A | N/A | 5.0 | N/A |  |  | Programme Management |  |  |
| 22 | 1.2.3.5.1 | The Clock updates (weekly) |  | 1088d | 2022-10-31 A | 2026-12-30 | 56% | 476d | 2022-10-31 | 2026-12-30 | 1088d | 2022-10-31 | 2026-12-30 | 256d |  |  | PPC |  | 5.0 | N/A | Green | GREEN | Programme Management |  |  |
| 23 | 1.2.3.5.2 | Maintain and update content on public-facing Portal (and ongoing feedback reviews to identify and implement Portal improvements) |  | 1088d | 2022-10-31 A | 2026-12-30 | 56% | 476d | 2022-10-31 | 2026-12-30 | 1088d | 2022-10-31 | 2026-12-30 | 256d |  |  | PPC |  | 5.0 | N/A | Green | GREEN | Programme Management |  |  |
| 24 | 1.2.4 | **Code Change Support / Other Programme Alignment** |  | 1089d | 2022-10-31 A | 2026-12-31 | 56% | 477d | 2022-10-31 | 2026-12-31 | 1089d | 2022-10-31 | 2026-12-31 | 255d |  |  | N/A | N/A | 5.0 | N/A |  |  | Programme Management | M6 | D17 - Code Change Report & Recommendations |
| 25 | 1.2.4.1 | Support DCC/BEIS on SEC change |  | 1089d | 2022-10-31 A | 2026-12-31 | 56% | 477d | 2022-10-31 | 2026-12-31 | 1089d | 2022-10-31 | 2026-12-31 | 255d |  |  | CPT |  | 5.0 | N/A | Green | GREEN | Programme Management |  |  |
| 26 | 1.2.4.2 | Support on Smart Meters Act changes |  | 1089d | 2022-10-31 A | 2026-12-31 | 56% | 477d | 2022-10-31 | 2026-12-31 | 1089d | 2022-10-31 | 2026-12-31 | 255d |  |  | CPT |  | 5.0 | N/A | Green | GREEN | Programme Management |  |  |
| 27 | 1.2.4.3 | Support DCC/RECCo on CSS change |  | 1089d | 2022-10-31 A | 2026-12-31 | 56% | 477d | 2022-10-31 | 2026-12-31 | 1089d | 2022-10-31 | 2026-12-31 | 255d |  |  | CPT |  | 5.0 | N/A | Green | GREEN | Programme Management |  |  |
| 28 | 1.2.4.4 | Support Elexon on BSC change |  | 1089d | 2022-10-31 A | 2026-12-31 | 56% | 477d | 2022-10-31 | 2026-12-31 | 1089d | 2022-10-31 | 2026-12-31 | 255d |  |  | CPT |  | 5.0 | N/A | Green | GREEN | Programme Management |  |  |
| 29 | 1.2.4.5 | Support code change inside & outside CCIAG |  | 1089d | 2022-10-31 A | 2026-12-31 | 56% | 477d | 2022-10-31 | 2026-12-31 | 1089d | 2022-10-31 | 2026-12-31 | 255d |  |  | CPT |  | 5.0 | N/A | Green | GREEN | Programme Management |  |  |
| 30 | 1.2.4.6 | Support code change inside & outside CCAG |  | 1089d | 2022-10-31 A | 2026-12-31 | 56% | 477d | 2022-10-31 | 2026-12-31 | 1089d | 2022-10-31 | 2026-12-31 | 255d |  |  | CPT |  | 5.0 | N/A | Green | GREEN | Programme Management |  |  |

| ID | WBS | Task | Type | Duration | Start | Finish | Predecessors | Complete | Remaining | Baseline start | Baseline finish | Baseline duration | Baseline 1 start | Baseline 1 finish | Total slack | Constraint | Baseline cost | Responsible | Involved | Text9 | Task Status | Update Version | MHHS Resource Name | Sched Status | RAG | Future RAG | MHHS Programme Phase | Text29 | Artefact ID | Milestone ID | Tier |
| --- | --- | --- | --- | --- | --- | --- | --- | --- | --- | --- | --- | --- | --- | --- | --- | --- | --- | --- | --- | --- | --- | --- | --- | --- | --- | --- | --- | --- | --- | --- | --- |
| 31 | 1.2.5 | **Programme Replan Baseline** |  | 163d | 2022-10-31 A | 2023-06-14 A |  | 100% |  | 2022-10-31 | 2023-06-14 | 163d | 2022-10-31 | 2023-06-14 |  |  |  | N/A | N/A | Programme Management | M5+ | 5.0 | N/A |  |  |  |  |  |  |  |  |
| 32 | 1.2.5.1 | Round 3 consultation preparation |  | 32d | 2022-10-31 A | 2022-12-13 A |  | 100% |  | 2022-10-31 | 2022-12-13 | 32d | 2022-10-31 | 2022-12-13 |  |  |  | PMO | CPT | Programme Management |  | 5.0 | N/A | Complete | COMPLETE |  |  |  |  |  |  |
| 33 | 1.2.5.2 | PSG decision to launch Round 3 consultation | milestone | 0d | 2022-12-07 A | 2022-12-07 A | 32FS-5d | 100% |  | 2022-12-07 | 2022-12-07 | 0d | 2022-12-07 | 2022-12-07 |  |  |  | PMO | PPC | Programme Management |  | 5.0 | N/A | Complete | COMPLETE |  |  |  |  |  |  |
| 34 | 1.2.5.3 | Round 3 consultation (incl. walkthroughs and Q&A) |  | 35d | 2022-12-14 A | 2023-01-31 A | 33FS+5d | 100% |  | 2022-12-14 | 2023-01-31 | 35d | 2022-12-14 | 2023-01-31 |  |  |  | PP | PMO, PPC,IPA | Programme Management |  | 5.0 | N/A | Complete | COMPLETE |  |  |  |  |  |  |
| 35 | 1.2.5.4 | Review and uplift of foundational testing documents to align with replan approach |  | 92d | 2022-12-14 A | 2023-04-20 A | 34SS | 100% |  | 2022-12-14 | 2023-04-20 | 92d | 2022-12-14 | 2023-04-20 |  |  |  | SI Test | CPT | Programme Management |  | 5.0 | N/A | Complete | COMPLETE |  |  |  |  |  |  |
| 36 | 1.2.5.5 | Round 3 consultation responses analysis (incl. identification of SIT volunteers) |  | 10d | 2023-02-01 A | 2023-02-14 A | 34 | 100% |  | 2023-02-01 | 2023-02-14 | 10d | 2023-02-01 | 2023-02-14 |  |  |  | PMO | CPT | Programme Management |  | 5.0 | N/A | Complete | COMPLETE |  |  |  |  |  |  |
| 37 | 1.2.5.6 | Replan re-drafting and supporting artefact updates (incl. engagement with Ofgem) |  | 26d | 2023-02-15 A | 2023-03-22 A | 36 | 100% |  | 2023-02-15 | 2023-03-22 | 26d | 2023-02-15 | 2023-03-22 |  |  |  | PMO | CPT,IPA,Ofgem | Programme Management |  | 5.0 | N/A | Complete | COMPLETE |  |  |  |  |  |  |
| 38 | 1.2.5.7 | Draft Replan Change Request |  | 31d | 2023-02-15 A | 2023-03-29 A | 36 | 100% |  | 2023-02-15 | 2023-03-29 | 31d | 2023-02-15 | 2023-03-29 |  |  |  | PMO | CPT | Programme Management |  | 5.0 | N/A | Complete | COMPLETE |  |  |  |  |  |  |
| 39 | 1.2.5.8 | PSG decision to issue CR for industry impact assessment | milestone | 0d | 2023-04-05 A | 2023-04-05 A | 38FS+5d | 100% |  | 2023-04-05 | 2023-04-05 | 0d | 2023-04-05 | 2023-04-05 |  |  |  | PMO | CPT | Programme Management |  | 5.0 | N/A | Complete | COMPLETE |  |  |  |  |  |  |
| 40 | 1.2.5.9 | Industry impact assessment |  | 10d | 2023-04-06 A | 2023-04-19 A | 39 | 100% |  | 2023-04-06 | 2023-04-19 | 10d | 2023-04-06 | 2023-04-19 |  |  |  | PP | PMO,PPC | Programme Management |  | 5.0 | N/A | Complete | COMPLETE |  |  |  |  |  |  |
| 41 | 1.2.5.10 | Replan playbacks (to assist PPs in impact assessment) |  | 5d | 2023-04-11 A | 2023-04-17 A | 40SS+3d | 100% |  | 2023-04-11 | 2023-04-17 | 5d | 2023-04-11 | 2023-04-17 |  |  |  | CPT | PPC,PP | Programme Management |  | 5.0 | N/A | Complete | COMPLETE |  |  |  |  |  |  |
| 42 | 1.2.5.11 | Industry impact assessment responses analysis |  | 5d | 2023-04-20 A | 2023-04-26 A | 40 | 100% |  | 2023-04-20 | 2023-04-26 | 5d | 2023-04-20 | 2023-04-26 |  |  |  | PMO | CPT | Programme Management |  | 5.0 | N/A | Complete | COMPLETE |  |  |  |  |  |  |
| 43 | 1.2.5.12 | Extraordinary PSG decision to agree baseline recommendation | milestone | 0d | 2023-05-03 A | 2023-05-03 A | 42FS+5d | 100% |  | 2023-05-03 | 2023-05-03 | 0d | 2023-05-03 | 2023-05-03 |  |  |  | CPT | PMO,PP | Programme Management |  | 5.0 | N/A | Complete | COMPLETE |  |  |  |  |  |  |
| 44 | 1.2.5.13 | Programme Replan playbacks and drop-in sessions |  | 5d | 2023-06-08 A | 2023-06-14 A |  | 100% |  | 2023-06-08 | 2023-06-14 | 5d | 2023-06-08 | 2023-06-14 |  |  |  | PMO | PPC, PP | Programme Management |  | 5.0 | N/A | Complete | COMPLETE |  |  |  |  |  |  |
| 45 | 1.3 | **DESIGN, BUILD & TEST (PIT)** |  | 1221d? | 2022-10-31 A | 2027-07-05 |  | 84% | 191.98d? | 2022-10-31 | 2027-07-05 | 1101d | 2022-10-31 | 2027-01-18 | 123d |  | -0 | N/A | N/A | DBT |  |  | N/A |  |  | 1 May 2022 - 31 Jul 2023 | Design, Build & Test (PIT) | DAG |  |  |  |
| 46 | 1.3.1 | **Design Baseline & Enduring PP Support** |  | 1101d | 2022-10-31 A | 2027-01-18 |  | 79% | 230.57d | 2022-10-31 | 2027-01-18 | 1101d | 2022-10-31 | 2027-01-18 | 243d |  | -0 | N/A | N/A | DBT |  | 5.0 | N/A |  |  |  | Design, Build & Test (PIT) |  |  |  |  |
| 47 | 1.3.1.1 | Physical design baselined (M5) | milestone | 0d | 2022-10-31 A | 2022-10-31 A |  | 100% |  | 2022-10-31 | 2022-10-31 | 0d | 2022-10-31 | 2022-10-31 |  |  |  | SRO Design | SI Design,PP,IPA | DBT |  | 5.0 | Paul Pettitt | Complete | COMPLETE |  | Design, Build & Test (PIT) | PSG | MHHS-ART001 | T1-DB-1000 | T1 |
| 48 | 1.3.1.2 | **M5 Design Work-Off Plan Implementation & Approval** |  | 79d | 2022-10-31 A | 2023-02-16 A |  | 100% |  | 2022-10-31 | 2023-02-16 | 79d | 2022-10-31 | 2023-02-16 |  |  |  | N/A | N/A | DBT |  | 5.0 | N/A |  |  |  | Design, Build & Test (PIT) |  |  |  |  |
| 49 | 1.3.1.2.1 | Implementation of M5 design Work-Off Plan |  | 74d | 2022-10-31 A | 2023-02-09 A | 47 | 100% |  | 2022-10-31 | 2023-02-09 | 74d | 2022-10-31 | 2023-02-09 |  |  |  | SI Design | PP | DBT |  | 5.0 | Paul Pettitt | Complete | COMPLETE |  | Design, Build & Test (PIT) |  |  |  |  |
| 50 | 1.3.1.2.2 | M5 design Work-Off Plan completion approved | milestone | 0d | 2023-02-16 A | 2023-02-16 A | 49FS+5d | 100% |  | 2023-02-16 | 2023-02-16 | 0d | 2023-02-16 | 2023-02-16 |  |  |  | SI Design | PP | DBT |  | 5.0 | Paul Pettitt | Complete | COMPLETE |  | Design, Build & Test (PIT) | DAG |  | T3-DB-0014 | T3 |
| 51 | 1.3.1.3 | **Enduring PP Design Support** |  | 1089d | 2022-10-31 A | 2026-12-31 A |  | 100% |  | 2022-10-31 | 2026-12-31 | 1089d | 2022-10-31 | 2026-12-31 |  |  |  | N/A | N/A | DBT |  | 5.0 | N/A |  |  |  | Design, Build & Test (PIT) |  |  |  |  |
| 52 | 1.3.1.3.1 | Design playbacks and drop-in sessions |  | 45d | 2022-10-31 A | 2022-12-30 A | 47 | 100% |  | 2022-10-31 | 2022-12-30 | 45d | 2022-10-31 | 2022-12-30 |  |  |  | SI Design | PMO,PPC, SRO Design | DBT |  | 5.0 | Paul Pettitt | Complete | COMPLETE |  | Design, Build & Test (PIT) |  |  |  |  |
| 53 | 1.3.1.3.2 | Support participants on E2E MHHS Design |  | 1089d | 2022-10-31 A | 2026-12-31 A | 47 | 100% |  | 2022-10-31 | 2026-12-31 | 1089d | 2022-10-31 | 2026-12-31 |  |  |  | SI Design | PP | DBT |  | 5.0 | Paul Pettitt | Complete | COMPLETE |  | Design, Build & Test (PIT) |  |  |  |  |
| 54 | 1.3.1.3.3 | DIP Onboarding Support |  | 70d | 2022-11-14 A | 2023-02-17 A |  | 100% |  | 2022-11-14 | 2023-02-17 | 70d | 2022-11-14 | 2023-02-17 |  | must start on 2022-11-14 |  | SI Design | SRO Design | DBT |  | 5.0 | Paul Pettitt | Complete | COMPLETE |  | Design, Build & Test (PIT) |  |  |  |  |
| 55 | 1.3.1.3.4 | iServer Launch | milestone | 0d | 2023-02-16 A | 2023-02-16 A | 50 | 100% |  | 2023-02-16 | 2023-02-16 | 0d | 2023-02-16 | 2023-02-16 |  |  |  | SI Design | PP | DBT |  | 5.0 | Paul Pettitt | Complete | COMPLETE |  | Design, Build & Test (PIT) |  |  |  |  |

| ID | WBS | Task | Type | Duration | Start | Finish | Predecessors | Complete | Remaining | Baseline start | Baseline finish | Baseline duration | Baseline 1 start | Baseline 1 finish | Total slack | Constraint | Baseline cost | Responsible | Involved | Text9 | Update Version | MHHS Resource Name | MHHS Programme Phase | Sched Status | RAG | Milestone ID | Text29 | Tier |
| --- | --- | --- | --- | --- | --- | --- | --- | --- | --- | --- | --- | --- | --- | --- | --- | --- | --- | --- | --- | --- | --- | --- | --- | --- | --- | --- | --- | --- |
| 56 | 1.3.1.4 | **Establish Design Change Management Processes** |  | 1101d | 2022-10-31 A | 2027-01-18 |  | 54% | 509.36d | 2022-10-31 | 2027-01-18 | 1101d | 2022-10-31 | 2027-01-18 | 243d |  |  | N/A | N/A | DBT | 5.0 | N/A | Design, Build & Test (PIT) |  |  |  |  |  |
| 57 | 1.3.1.4.1 | Internal review of internal change management processes |  | 35d | 2022-10-31 A | 2022-12-16 A |  | 100% |  | 2022-10-31 | 2022-12-16 | 35d | 2022-10-31 | 2022-12-16 |  |  |  | SRO | SI Design | DBT | 5.0 | Paul Pettitt | Design, Build & Test (PIT) | Complete | COMPLETE |  |  |  |
| 58 | 1.3.1.4.2 | SRO approval of internal change management processes | milestone | 0d | 2022-12-16 A | 2022-12-16 A | 57FF | 100% |  | 2022-12-16 | 2022-12-16 | 0d | 2022-12-16 | 2022-12-16 |  |  |  | SRO | SI Design | DBT | 5.0 | Paul Pettitt | Design, Build & Test (PIT) | Complete | COMPLETE |  |  |  |
| 59 | 1.3.1.4.3 | Change Process Webinar | milestone | 0d | 2023-01-16 A | 2023-01-16 A |  | 100% |  | 2023-01-16 | 2023-01-16 | 0d | 2023-01-16 | 2023-01-16 |  | must start on 2023-01-16 |  | SI Design | PP | DBT | 5.0 | Paul Pettitt | Design, Build & Test (PIT) | Complete | COMPLETE |  |  |  |
| 60 | 1.3.1.4.4 | Enduring change management process approved | milestone | 0d | 2023-02-16 A | 2023-02-16 A | 50FF | 100% |  | 2023-02-16 | 2023-02-16 | 0d | 2023-02-16 | 2023-02-16 |  |  |  | SI Design | PP | DBT | 5.0 | Paul Pettitt | Design, Build & Test (PIT) | Complete | COMPLETE | T3-DB-0016 | DAG | T3 |
| 61 | 1.3.1.4.5 | Maintain E2E MHHS Design (post-M5 design change management processes operational) |  | 1022d | 2023-02-17 A | 2027-01-18 | 60 | 52% | 489d | 2023-02-17 | 2027-01-18 | 1022d | 2023-02-17 | 2027-01-18 | 243d |  |  | SI Design | PP | DBT | 5.0 | Paul Pettitt | Design, Build & Test (PIT) | Green | GREEN |  |  |  |
| 62 | 1.3.1.5 | **Design Authority Mobilisation** |  | 29d | 2022-12-14 A | 2023-01-23 A |  | 100% |  | 2022-12-14 | 2023-01-23 | 29d | 2022-12-14 | 2023-01-23 |  |  |  | N/A | N/A | DBT | 5.0 | N/A | Design, Build & Test (PIT) |  |  |  |  |  |
| 63 | 1.3.1.5.1 | Design Authority ToR approved | milestone | 0d | 2022-12-14 A | 2022-12-14 A |  | 100% |  | 2022-12-14 | 2022-12-14 | 0d | 2022-12-14 | 2022-12-14 |  | must start on 2022-12-14 |  | SI Design | PP | DBT | 5.0 | Paul Pettitt | Design, Build & Test (PIT) | Complete | COMPLETE | T3-DB-0010 | DAG | T3 |
| 64 | 1.3.1.5.2 | Inaugural Design Authority | milestone | 0d | 2023-01-23 A | 2023-01-23 A | 63FS+29d | 100% |  | 2023-01-23 | 2023-01-23 | 0d | 2023-01-23 | 2023-01-23 |  |  |  | SI Design | PP | DBT | 5.0 | Paul Pettitt | Design, Build & Test (PIT) | Complete | COMPLETE |  |  |  |
| 65 | 1.3.1.6 | **Network Operation Services Adaptor Procurement** |  | 0d | 2023-05-23 A | 2023-05-23 A |  | 100% |  | 2023-05-23 | 2023-05-23 | 0d | 2023-02-01 | 2025-03-14 |  |  | -0 | N/A | N/A | DBT | 5.0 | N/A | Design, Build & Test (PIT) |  |  |  |  |  |
| 66 | 1.3.1.6.1 | All SIT LDSOs have procured their adapter providers | milestone | 0d | 2023-05-23 A | 2023-05-23 A | 626SS | 100% |  | 2023-05-23 | 2023-05-23 | 0d | 2023-05-23 | 2023-05-23 |  |  |  | SI Design | PP | DBT | 5.0 | Paul Pettitt | Design, Build & Test (PIT) | Complete | COMPLETE | T3-DB-0020 | DAG | T3 |
| 67 | 1.3.2 | **PP Mobilisation** |  | 67d | 2022-10-31 A | 2023-01-31 A |  | 100% |  | 2022-10-31 | 2023-01-31 | 67d | 2022-10-31 | 2023-01-31 |  |  |  | N/A | N/A | DBT | 5.0 | N/A | Design, Build & Test (PIT) |  |  |  |  |  |
| 68 | 1.3.2.1 | Set up governance |  | 67d | 2022-10-31 A | 2023-01-31 A |  | 100% |  | 2022-10-31 | 2023-01-31 | 67d | 2022-10-31 | 2023-01-31 |  |  |  | PP |  | DBT | 5.0 | PP | Design, Build & Test (PIT) | Complete | COMPLETE |  |  |  |
| 69 | 1.3.2.2 | Set up reporting |  | 67d | 2022-10-31 A | 2023-01-31 A |  | 100% |  | 2022-10-31 | 2023-01-31 | 67d | 2022-10-31 | 2023-01-31 |  |  |  | PP |  | DBT | 5.0 | PP | Design, Build & Test (PIT) | Complete | COMPLETE |  |  |  |
| 70 | 1.3.2.3 | Obtain funding |  | 67d | 2022-10-31 A | 2023-01-31 A |  | 100% |  | 2022-10-31 | 2023-01-31 | 67d | 2022-10-31 | 2023-01-31 |  |  |  | PP |  | DBT | 5.0 | PP | Design, Build & Test (PIT) | Complete | COMPLETE |  |  |  |
| 71 | 1.3.2.4 | Earmark resources |  | 67d | 2022-10-31 A | 2023-01-31 A |  | 100% |  | 2022-10-31 | 2023-01-31 | 67d | 2022-10-31 | 2023-01-31 |  |  |  | PP |  | DBT | 5.0 | PP | Design, Build & Test (PIT) | Complete | COMPLETE |  |  |  |
| 72 | 1.3.2.5 | Mobilise initial team |  | 67d | 2022-10-31 A | 2023-01-31 A |  | 100% |  | 2022-10-31 | 2023-01-31 | 67d | 2022-10-31 | 2023-01-31 |  |  |  | PP |  | DBT | 5.0 | PP | Design, Build & Test (PIT) | Complete | COMPLETE |  |  |  |
| 73 | 1.3.3 | **PIT Stub Specification and Delivery** |  | 435d | 2022-10-31 A | 2024-06-28 A |  | 100% |  | 2022-10-31 | 2024-06-28 | 430d | 2022-10-31 | 2023-05-31 |  |  | -0 | N/A | N/A | DBT | 5.0 | N/A | Design, Build & Test (PIT) |  |  |  |  |  |
| 74 | 1.3.3.1 | **DIP Simulator** |  | 108d | 2022-10-31 A | 2023-03-29 A |  | 100% |  | 2022-10-31 | 2023-03-29 | 108d | 2022-10-31 | 2023-03-29 |  |  |  | N/A | N/A | DBT | 5.0 | N/A | Design, Build & Test (PIT) |  |  |  |  |  |
| 75 | 1.3.3.1.1 | Build & Test |  | 95d | 2022-10-31 A | 2023-03-10 A | 47 | 100% |  | 2022-10-31 | 2023-03-10 | 95d | 2022-10-31 | 2023-03-10 |  |  |  | SI DevOps |  | DBT | 5.0 | Rebecca Farooq | Design, Build & Test (PIT) | Complete | COMPLETE |  |  |  |
| 76 | 1.3.3.1.2 | UAT |  | 85d | 2022-11-14 A | 2023-03-10 A | 75SS+10d | 100% |  | 2022-11-14 | 2023-03-10 | 85d | 2022-11-14 | 2023-03-10 |  |  |  | SI Test |  | DBT | 5.0 | Rebecca Farooq | Design, Build & Test (PIT) | Complete | COMPLETE |  |  |  |
| 77 | 1.3.3.1.3 | Beta test |  | 95d | 2022-10-31 A | 2023-03-10 A | 75SS | 100% |  | 2022-10-31 | 2023-03-10 | 95d | 2022-10-31 | 2023-03-10 |  |  |  | PP | SI Test | DBT | 5.0 | Rebecca Farooq | Design, Build & Test (PIT) | Complete | COMPLETE |  |  |  |
| 78 | 1.3.3.1.4 | Prepare for release |  | 18d | 2023-03-06 A | 2023-03-29 A | 77FS-5d | 100% |  | 2023-03-06 | 2023-03-29 | 18d | 2023-03-06 | 2023-03-29 |  |  |  | SI DevOps |  | DBT | 5.0 | Rebecca Farooq | Design, Build & Test (PIT) | Complete | COMPLETE |  |  |  |
| 79 | 1.3.3.1.5 | DIP Simulator released | milestone | 0d | 2023-03-29 A | 2023-03-29 A | 78FF | 100% |  | 2023-03-29 | 2023-03-29 | 0d | 2023-03-29 | 2023-03-29 |  | start no earlier than 2023-01-30 |  | SI DevOps |  | DBT | 5.0 | Rebecca Farooq | Design, Build & Test (PIT) | Complete | COMPLETE | T3-DB-0018 | SITAG | T3 |

| ID | WBS | Task | Type | Duration | Start | Finish | Predecessors | Complete | Baseline start | Baseline finish | Baseline duration | Baseline 1 start | Baseline 1 finish | Constraint | Baseline cost | Responsible | Involved | Text9 | Update Version | MHHS Resource Name | MHHS Programme Phase | Sched Status | RAG | Milestone ID | Text29 | Tier |
| --- | --- | --- | --- | --- | --- | --- | --- | --- | --- | --- | --- | --- | --- | --- | --- | --- | --- | --- | --- | --- | --- | --- | --- | --- | --- | --- |
| 80 | 1.3.3.2 | **DIP Simulator Uplifts** |  | 257d | 2023-07-06 A | 2024-06-28 A |  | 100% | 2023-07-06 | 2024-06-28 | 252d |  |  |  | -0 | N/A | N/A | DBT | 5.1 | N/A | Design, Build & Test (PIT) |  |  |  |  |  |
| 81 | 1.3.3.2.1 | DIP Simulator uplifted to align with design releases - design/build/test |  | 27d | 2023-07-06 A | 2023-08-11 A | 117 | 100% | 2023-07-06 | 2023-08-11 | 27d |  |  |  |  | SI DevOps |  | DBT | 5.1 | Rebecca Farooq | Design, Build & Test (PIT) | Complete | COMPLETE |  |  |  |
| 82 | 1.3.3.2.2 | DIP Simulator uplifted to align with Interim Release 2 | milestone | 0d | 2023-08-11 A | 2023-08-11 A | 81 | 100% | 2023-08-11 | 2023-08-11 | 0d |  |  |  |  | SI DevOps |  | DBT | 5.1 | Rebecca Farooq | Design, Build & Test (PIT) | Complete | COMPLETE | T3-DB-0035 | SITAG | T3 |
| 83 | 1.3.3.2.3 | DIP Simulator uplifted to align with design releases - design/build/test |  | 20d | 2023-10-09 A | 2023-11-03 A | 126FS+2d | 100% | 2023-10-09 | 2023-11-03 | 20d |  |  |  |  | SI DevOps |  | DBT | 5.3 | Rebecca Farooq | Design, Build & Test (PIT) | Complete | COMPLETE |  |  |  |
| 84 | 1.3.3.2.4 | DIP Simulator uplifted to align with Interim Release 5 | milestone | 0d | 2023-11-03 A | 2023-11-03 A | 83 | 100% | 2023-11-03 | 2023-11-03 | 0d |  |  |  |  | SI DevOps |  | DBT | 5.11 | Rebecca Farooq | Design, Build & Test (PIT) | Complete | COMPLETE | T3-DB-0039 | SITAG | T3 |
| 85 | 1.3.3.2.5 | DIP Simulator uplifted to align with design releases - design/build/test |  | 37d | 2024-02-01 A | 2024-03-22 A | 134 | 100% | 2024-02-01 | 2024-03-22 | 37d |  |  |  |  | SI DevOps | PP,SRO,Testing | DBT | 5.14 | Matthew Bray | Design, Build & Test (PIT) | Complete | COMPLETE |  |  |  |
| 86 | 1.3.3.2.6 | DIP Simulator uplifted to align with Interim Release 7 | milestone | 0d | 2024-03-22 A | 2024-03-22 A | 85 | 100% | 2024-03-22 | 2024-03-22 | 0d |  |  |  |  | SI DevOps | PP,SRO,Testing | DBT | 5.14 | Matthew Bray | Design, Build & Test (PIT) | Complete | COMPLETE | T3-DB-0182 | SITAG | T3 |
| 87 | 1.3.3.2.7 | DIP Simulator uplifted to align with design releases - design/build/test |  | 57d | 2024-04-04 A | 2024-06-21 A | 138 | 100% | 2024-04-04 | 2024-06-21 | 57d |  |  |  |  | SI DevOps | PP,SRO,Testing | DBT | 5.14 | Matthew Bray | Design, Build & Test (PIT) | Complete | COMPLETE |  |  |  |
| 88 | 1.3.3.2.8 | DIP Simulator uplifted to align with Interim Release 8 | milestone | 0d | 2024-06-28 A | 2024-06-28 A | 87FS+5d | 100% | 2024-06-28 | 2024-06-28 | 0d |  |  |  |  | SI DevOps | PP,SRO,Testing | DBT | 5.28 | Matthew Bray | Design, Build & Test (PIT) | Complete | COMPLETE | T3-DB-0183 | SITAG | T3 |
| 89 | 1.3.3.3 | **Data Generator** |  | 130d | 2022-12-01 A | 2023-05-31 A |  | 100% | 2022-12-01 | 2023-05-31 | 130d | 2022-12-01 | 2023-05-31 |  |  | N/A | N/A | DBT | 5.0 | N/A | Design, Build & Test (PIT) |  |  |  |  |  |
| 90 | 1.3.3.3.1 | Design | manual | 15d | 2022-12-01 A | 2022-12-21 A |  | 100% | 2022-12-01 | 2022-12-21 | 15d | 2022-12-01 | 2022-12-21 |  |  | SI DevOps |  | DBT | 5.0 | Rebecca Farooq | Design, Build & Test (PIT) | Complete | COMPLETE |  |  |  |
| 91 | 1.3.3.3.2 | Build & Test |  | 50d | 2023-02-16 A | 2023-04-26 A | 90FS+40d | 100% | 2023-02-16 | 2023-04-26 | 50d | 2023-02-16 | 2023-04-26 |  |  | SI DevOps |  | DBT | 5.0 | Rebecca Farooq | Design, Build & Test (PIT) | Complete | COMPLETE |  |  |  |
| 92 | 1.3.3.3.3 | UAT |  | 10d | 2023-04-27 A | 2023-05-10 A | 91 | 100% | 2023-04-27 | 2023-05-10 | 10d | 2023-04-27 | 2023-05-10 |  |  | SI Test |  | DBT | 5.0 | Rebecca Farooq | Design, Build & Test (PIT) | Complete | COMPLETE |  |  |  |
| 93 | 1.3.3.3.4 | Beta test |  | 45d | 2023-03-30 A | 2023-05-31 A | 91FS-20d, 95FF | 100% | 2023-03-30 | 2023-05-31 | 45d | 2023-03-30 | 2023-05-31 |  |  | PP | SI Test | DBT | 5.0 | Rebecca Farooq | Design, Build & Test (PIT) | Complete | COMPLETE |  |  |  |
| 94 | 1.3.3.3.5 | Prepare for release |  | 24d | 2023-04-27 A | 2023-05-30 A | 92SS | 100% | 2023-04-27 | 2023-05-30 | 24d | 2023-04-27 | 2023-05-30 |  |  | SI DevOps |  | DBT | 5.0 | Rebecca Farooq | Design, Build & Test (PIT) | Complete | COMPLETE |  |  |  |
| 95 | 1.3.3.3.6 | Data Generator released | milestone | 0d | 2023-05-31 A | 2023-05-31 A | 94FS+1d | 100% | 2023-05-31 | 2023-05-31 | 0d | 2023-05-31 | 2023-05-31 |  |  | SI DevOps |  | DBT | 5.0 | Rebecca Farooq | Design, Build & Test (PIT) | Complete | COMPLETE | T3-DB-0022 | SITAG | T3 |
| 96 | 1.3.4 | **Design Artefact Releases** |  | 566d? | 2023-02-22 A | 2025-04-23 A |  | 100% | 2023-02-22 | 2024-11-13 | 398d | 2023-02-22 | 2023-09-29 |  | -0 | N/A | N/A | DBT | 5.0 | N/A | Design, Build & Test (PIT) |  |  |  | DAG |  |
| 97 | 1.3.4.1 | **Interim release 1** |  | 79d | 2023-02-22 A | 2023-06-12 A |  | 100% | 2023-02-22 | 2023-06-12 | 79d | 2023-02-22 | 2023-06-28 |  |  | N/A | N/A | DBT | 5.0 | N/A | Design, Build & Test (PIT) |  |  |  |  |  |
| 98 | 1.3.4.1.1 | Prioritise DINs and CR |  | 1d | 2023-02-22 A | 2023-02-22 A |  | 100% | 2023-02-22 | 2023-02-22 | 1d | 2023-02-22 | 2023-02-22 | must start on 2023-02-22 |  | SI Design |  | DBT | 5.0 | Paul Pettitt | Design, Build & Test (PIT) | Complete | COMPLETE |  |  |  |
| 99 | 1.3.4.1.2 | **Industry input session** |  | 7d | 2023-02-23 A | 2023-03-03 A |  | 100% | 2023-02-23 | 2023-03-03 | 7d | 2023-02-23 | 2023-03-03 |  |  | N/A | N/A | DBT | 5.0 | N/A | Design, Build & Test (PIT) |  |  |  |  |  |
| 100 | 1.3.4.1.2.1 | Raise a CR covering prioritized assessment cluster |  | 1d | 2023-02-23 A | 2023-02-23 A | 98 | 100% | 2023-02-23 | 2023-02-23 | 1d | 2023-02-23 | 2023-02-23 |  |  | SI Design |  | DBT | 5.0 | Paul Pettitt | Design, Build & Test (PIT) | Complete | COMPLETE |  |  |  |
| 101 | 1.3.4.1.2.2 | Organize Industry Input session to go through significant items to reach consensus |  | 1d | 2023-02-23 A | 2023-02-23 A | 100SS | 100% | 2023-02-23 | 2023-02-23 | 1d | 2023-02-23 | 2023-02-23 |  |  | SI Design | PP | DBT | 5.0 | Paul Pettitt,Berlinda Kugara | Design, Build & Test (PIT) | Complete | COMPLETE |  |  |  |
| 102 | 1.3.4.1.2.3 | Conduct Meeting |  | 1d | 2023-03-03 A | 2023-03-03 A | 101FS+5d | 100% | 2023-03-03 | 2023-03-03 | 1d | 2023-03-03 | 2023-03-03 |  |  | SI Design | PP | DBT | 5.0 | Paul Pettitt,Berlinda Kugara | Design, Build & Test (PIT) | Complete | COMPLETE |  |  |  |
| 103 | 1.3.4.1.3 | Update baselined artefacts |  | 10d | 2023-03-24 A | 2023-04-06 A |  | 100% | 2023-03-24 | 2023-04-06 | 10d | 2023-03-24 | 2023-04-06 |  |  | SI Design |  | DBT | 5.0 | Paul Pettitt | Design, Build & Test (PIT) | Complete | COMPLETE |  |  |  |

Notes:
- 84: Action: 26/7/23 - forecast changed from 15/12/23 - 3/11/23 - Changed from Interim Release 6 to 5. Updated in milestone register

| ID | WBS | Task | Type | Duration | Start | Finish | Predecessors | Complete | Baseline start | Baseline finish | Baseline duration | Baseline 1 start | Baseline 1 finish | Constraint | Baseline cost | Responsible | Involved | Text9 | Update Version | MHHS Resource Name | MHHS Programme Phase | Sched Status | RAG | Milestone ID | Text29 | Tier | Action |
| --- | --- | --- | --- | --- | --- | --- | --- | --- | --- | --- | --- | --- | --- | --- | --- | --- | --- | --- | --- | --- | --- | --- | --- | --- | --- | --- | --- |
| 104 | 1.3.4.1.4 | **Participant review and impact assess changes** |  | 18d | 2023-04-14 A | 2023-05-09 A |  | 100% | 2023-04-14 | 2023-05-09 | 18d | 2023-04-14 | 2023-05-09 |  |  | N/A | N/A | DBT | 5.0 | N/A | Design, Build & Test (PIT) |  |  |  |  |  |  |
| 105 | 1.3.4.1.4.1 | Issue Redline Version of documents |  | 1d | 2023-04-14 A | 2023-04-14 A | 103FS+5d | 100% | 2023-04-14 | 2023-04-14 | 1d | 2023-04-14 | 2023-04-14 |  |  | SI Design |  | DBT | 5.0 | Paul Pettitt | Design, Build & Test (PIT) | Complete | COMPLETE |  |  |  |  |
| 106 | 1.3.4.1.4.2 | Participants provide review comments to common log |  | 17d | 2023-04-17 A | 2023-05-09 A | 105 | 100% | 2023-04-17 | 2023-05-09 | 17d | 2023-04-17 | 2023-05-09 |  |  | PP |  | DBT | 5.0 | Paul Pettitt | Design, Build & Test (PIT) | Complete | COMPLETE |  |  |  |  |
| 107 | 1.3.4.1.5 | **Assurance review** |  | 19d | 2023-05-10 A | 2023-06-05 A |  | 100% | 2023-05-10 | 2023-06-05 | 19d | 2023-05-10 | 2023-06-05 |  |  | N/A | N/A | DBT | 5.0 | N/A | Design, Build & Test (PIT) |  |  |  |  |  |  |
| 108 | 1.3.4.1.5.1 | SI Design Review and Respond to Comments |  | 5d | 2023-05-10 A | 2023-05-16 A | 106 | 100% | 2023-05-10 | 2023-05-16 | 5d | 2023-05-10 | 2023-05-16 |  |  | SI Design |  | DBT | 5.0 | Paul Pettitt | Design, Build & Test (PIT) | Complete | COMPLETE |  |  |  |  |
| 109 | 1.3.4.1.5.2 | Prep for Assurance Review Meeting |  | 7d | 2023-05-17 A | 2023-05-25 A | 108 | 100% | 2023-05-17 | 2023-05-25 | 7d | 2023-05-17 | 2023-05-25 |  |  | SI Design |  | DBT | 5.0 | Paul Pettitt | Design, Build & Test (PIT) | Complete | COMPLETE |  |  |  |  |
| 110 | 1.3.4.1.5.3 | Conduct Assurance Review Meeting |  | 1d | 2023-05-26 A | 2023-05-26 A | 109 | 100% | 2023-05-26 | 2023-05-26 | 1d | 2023-05-26 | 2023-05-26 |  |  | SI Design |  | DBT | 5.0 | Paul Pettitt | Design, Build & Test (PIT) | Complete | COMPLETE |  |  |  |  |
| 111 | 1.3.4.1.5.4 | Update Artefacts following Assurance Review |  | 6d | 2023-05-29 A | 2023-06-05 A | 110 | 100% | 2023-05-29 | 2023-06-05 | 6d | 2023-05-29 | 2023-06-05 |  |  | SI Design |  | DBT | 5.0 | Paul Pettitt | Design, Build & Test (PIT) | Complete | COMPLETE |  |  |  |  |
| 112 | 1.3.4.1.6 | PSG Approval of interim release plan |  | 1d | 2023-06-08 A | 2023-06-08 A |  | 100% | 2023-06-08 | 2023-06-08 | 1d |  |  | must start on 2023-06-08 |  | PP | SI Design | DBT | 5.1 | Paul Pettitt | Design, Build & Test (PIT) | Complete | COMPLETE |  |  |  |  |
| 113 | 1.3.4.1.7 | Publish updated baselined artefacts | milestone | 0d | 2023-06-06 A | 2023-06-12 A | 111 | 100% | 2023-06-06 | 2023-06-12 | 5d | 2023-06-15 | 2023-06-21 |  |  | SI Design |  | DBT | 5.0 | Paul Pettitt | Design, Build & Test (PIT) | Complete | COMPLETE |  |  |  |  |
| 114 | 1.3.4.1.8 | Interim release 1 Go live | milestone | 0d | 2023-06-12 A | 2023-06-12 A | 113 | 100% | 2023-06-12 | 2023-06-12 | 0d | 2023-06-28 | 2023-06-28 |  |  | SI Design |  | DBT | 5.0 | Paul Pettitt | Design, Build & Test (PIT) | Complete | COMPLETE | T3-DB-0095 | DAG | T3 |  |
| 115 | 1.3.4.2 | **Interim release 2** |  | 27d | 2023-05-30 A | 2023-07-05 A |  | 100% | 2023-05-30 | 2023-07-05 | 27d | 2023-05-24 | 2023-07-28 |  |  | N/A | N/A | DBT | 5.0 | N/A | Design, Build & Test (PIT) |  |  |  |  |  |  |
| 116 | 1.3.4.2.1 | Update baselined artefacts |  | 27d | 2023-05-30 A | 2023-07-05 A |  | 100% | 2023-05-30 | 2023-07-05 | 27d |  |  | must start on 2023-05-30 |  | SI Design | PP | DBT | 5.1 | Paul Pettitt | Design, Build & Test (PIT) | Complete | COMPLETE |  |  |  |  |
| 117 | 1.3.4.2.2 | Interim release 2 Go live | milestone | 0d | 2023-07-05 A | 2023-07-05 A | 116 | 100% | 2023-07-05 | 2023-07-05 | 0d | 2023-07-28 | 2023-07-28 |  |  | SI Design |  | DBT | 5.0 | Paul Pettitt | Design, Build & Test (PIT) | Complete | COMPLETE | T3-DB-0096 | DAG | T3 |  |
| 118 | 1.3.4.3 | **Interim release 3** |  | 35d | 2023-06-15 A | 2023-08-02 A |  | 100% | 2023-06-15 | 2023-08-02 | 35d | 2023-06-29 | 2023-09-29 |  |  | N/A | N/A | DBT | 5.0 | N/A | Design, Build & Test (PIT) |  |  |  |  |  |  |
| 119 | 1.3.4.3.1 | Update baselined artefacts |  | 35d | 2023-06-15 A | 2023-08-02 A |  | 100% | 2023-06-15 | 2023-08-02 | 35d |  |  | must start on 2023-06-15 |  | SI Design | PP | DBT | 5.1 | Paul Pettitt | Design, Build & Test (PIT) | Complete | COMPLETE |  |  |  |  |
| 120 | 1.3.4.3.2 | Interim release 3 Go live | milestone | 0d | 2023-08-02 A | 2023-08-02 A | 119 | 100% | 2023-08-02 | 2023-08-02 | 0d | 2023-09-29 | 2023-09-29 |  |  | SI Design |  | DBT | 5.0 | Paul Pettitt | Design, Build & Test (PIT) | Complete | COMPLETE | T3-DB-0097 | DAG | T3 |  |
| 121 | 1.3.4.4 | **Interim release 4** |  | 36d | 2023-07-12 A | 2023-08-30 A |  | 100% | 2023-07-12 | 2023-08-30 | 36d |  |  |  |  | N/A | N/A | DBT | 5.1 | N/A | Design, Build & Test (PIT) |  |  |  |  |  |  |
| 122 | 1.3.4.4.1 | Update baselined artefacts |  | 36d | 2023-07-12 A | 2023-08-30 A |  | 100% | 2023-07-12 | 2023-08-30 | 36d |  |  | must start on 2023-07-12 |  | SI Design | PP | DBT | 5.1 | Paul Pettitt | Design, Build & Test (PIT) | Complete | COMPLETE |  |  |  |  |
| 123 | 1.3.4.4.2 | Interim release 4 Go live | milestone | 0d | 2023-08-30 A | 2023-08-30 A | 122 | 100% | 2023-08-30 | 2023-08-30 | 0d |  |  |  |  | SI Design |  | DBT | 5.1 | Paul Pettitt | Design, Build & Test (PIT) | Complete | COMPLETE | T3-DB-0081 | DAG | T3 |  |
| 124 | 1.3.4.5 | **Interim release 5** |  | 147d | 2023-08-17 A | 2024-03-08 A |  | 100% | 2023-08-17 | 2024-03-08 | 147d |  |  |  | -0 | N/A | N/A | DBT | 5.1 | N/A | Design, Build & Test (PIT) |  |  |  |  |  |  |
| 125 | 1.3.4.5.1 | Update baselined artefacts |  | 35d | 2023-08-17 A | 2023-10-04 A |  | 100% | 2023-08-17 | 2023-10-04 | 35d |  |  | must start on 2023-08-17 |  | SI Design | PP | DBT | 5.1 | Paul Pettitt | Design, Build & Test (PIT) | Complete | COMPLETE |  |  |  |  |
| 126 | 1.3.4.5.2 | Interim release 5 Go live | milestone | 0d | 2023-10-04 A | 2023-10-04 A | 125 | 100% | 2023-10-04 | 2023-10-04 | 0d |  |  |  |  | SI Design |  | DBT | 5.1 | Paul Pettitt | Design, Build & Test (PIT) | Complete | COMPLETE | T3-DB-0083 | DAG | T3 | 11/8 - successor is SIT functional (starts in march) |
| 127 | 1.3.4.5.3 | Interim Release 5 Deployed to SIT |  | 10d | 2024-02-26 A | 2024-03-08 A | 126FS+102d | 100% | 2024-02-26 | 2024-03-08 | 10d |  |  |  |  | SI Testing | PP | DBT | 5.16 |  |  | Complete | COMPLETE |  |  |  |  |

| ID | WBS | Task | Type | Duration | Start | Finish | Predecessors | Complete | Baseline start | Baseline finish | Baseline duration | Constraint | Baseline cost | Responsible | Involved | Text9 | Update Version | MHHS Resource Name | MHHS Programme Phase | Sched Status | RAG | Milestone ID | Text29 | Tier | Action | Task Status |
| --- | --- | --- | --- | --- | --- | --- | --- | --- | --- | --- | --- | --- | --- | --- | --- | --- | --- | --- | --- | --- | --- | --- | --- | --- | --- | --- |
| 128 | 1.3.4.6 | **Interim release 6** |  | 192d | 2023-09-14 A | 2024-06-07 A |  | 100% | 2023-09-14 | 2024-06-07 | 192d |  | -0 | N/A | N/A | DBT | 5.1 | N/A | Design, Build & Test (PIT) |  |  |  |  |  |  |  |
| 129 | 1.3.4.6.1 | Update baselined artefacts |  | 35d | 2023-09-14 A | 2023-11-01 A |  | 100% | 2023-09-14 | 2023-11-01 | 32d | must start on 2023-09-14 |  | SI Design | PP | DBT | 5.1 | Paul Pettitt | Design, Build & Test (PIT) | Complete | COMPLETE |  |  |  |  |  |
| 130 | 1.3.4.6.2 | Interim release 6 Go live | milestone | 0d | 2023-11-01 A | 2023-11-01 A | 129 | 100% | 2023-11-01 | 2023-11-01 | 0d |  |  | SI Design |  | DBT | 5.11 | Paul Pettitt | Design, Build & Test (PIT) | Complete | COMPLETE | T3-DB-0085 | DAG | T3 |  |  |
| 131 | 1.3.4.6.3 | Interim Release 6 Deployed to SIT |  | 10d | 2024-05-27 A | 2024-06-07 A | 130FS+147d | 100% | 2024-05-27 | 2024-06-07 | 10d |  |  | SI Testing | PP | DBT | 5.16 |  |  | Complete | COMPLETE |  |  |  |  |  |
| 132 | 1.3.4.7 | **Interim release 7** |  | 168d | 2023-10-18 A | 2024-06-07 A |  | 100% | 2023-10-18 | 2024-06-07 | 168d |  | -0 | N/A | N/A | DBT | 5.5 | N/A | Design, Build & Test (PIT) |  |  |  |  |  |  |  |
| 133 | 1.3.4.7.1 | Update baselined artefacts |  | 76d | 2023-10-18 A | 2024-01-31 A |  | 100% | 2023-10-18 | 2024-01-31 | 76d | start no earlier than 2023-10-18 |  | SI Design | PP | DBT | 5.5 | Paul Pettitt | Design, Build & Test (PIT) | Complete | COMPLETE |  |  |  |  |  |
| 134 | 1.3.4.7.2 | Interim release 7 Go live | milestone | 0d | 2024-01-31 A | 2024-01-31 A | 133 | 100% | 2024-01-31 | 2024-01-31 | 0d |  |  | SI Design | PP | DBT | 5.14 | Paul Pettitt | Design, Build & Test (PIT) | Complete | COMPLETE | T3-DB-0098 | DAG | T3 | 4/8 - add as t3 milestones. Awaiting approval at TMAG |  |
| 135 | 1.3.4.7.3 | Interim Release 7 Deployed to SIT |  | 10d | 2024-05-27 A | 2024-06-07 A | 134FS+82d | 100% | 2024-05-27 | 2024-06-07 | 10d |  |  | SI Testing | PP | DBT | 5.16 |  |  | Complete | COMPLETE |  |  |  |  |  |
| 136 | 1.3.4.8 | **Interim release 8** |  | 311d? | 2024-02-14 A | 2025-04-23 A |  | 100% | 2024-02-14 | 2024-11-13 | 143d |  | -0 | N/A | N/A | DBT | 5.5 | N/A | Design, Build & Test (PIT) |  |  |  | DAG |  |  |  |
| 137 | 1.3.4.8.1 | Update baselined artefacts |  | 36d | 2024-02-14 A | 2024-04-03 A |  | 100% | 2024-02-14 | 2024-04-03 | 36d | start no earlier than 2024-02-14 |  | SI Design | PP | DBT | 5.5 | Paul Pettitt | Design, Build & Test (PIT) | Complete | COMPLETE |  |  |  |  |  |
| 138 | 1.3.4.8.2 | Interim release 8 Go live | milestone | 0d | 2024-04-03 A | 2024-04-03 A | 137 | 100% | 2024-04-03 | 2024-04-03 | 0d | start no earlier than 2024-01-10 |  | SI Design | PP | DBT | 5.14 | Paul Pettitt | Design, Build & Test (PIT) | Complete | COMPLETE | T3-DB-0099 | DAG | T3 | 4/8 - add as t3 milestones. Awaiting approval at TMAG |  |
| 139 | 1.3.4.8.3 | **Interim Release 8.3 - Maintenance Window** |  | 11d | 2024-10-07 A | 2024-10-21 A |  | 100% | 2024-10-07 | 2024-10-21 | 0d |  |  | Design |  | DBT | 6.0 |  |  |  |  |  |  |  |  | -686.67 |
| 140 | 1.3.4.8.3.1 | Interim Release 8.3 'effective from date' to SIT A | milestone | 0d | 2024-10-21 A | 2024-10-21 A | 138FS+143d | 100% | 2024-10-21 | 2024-10-21 | 10d |  |  | SI Testing | PP | DBT | 5.16 | Roger Robar |  | Complete | COMPLETE |  |  |  |  |  |
| 141 | 1.3.4.8.3.2 | Interim Release 8.3 'effective from date' to SIT B | milestone | 0d | 2024-10-07 A | 2024-10-07 A | 140SS-11d | 100% | 2024-10-07 | 2024-10-07 | 0d |  |  | Design |  | DBT | 5.16 |  |  | Complete | COMPLETE |  |  |  |  |  |
| 142 | 1.3.4.8.4 | **Interim Release 8.4** |  | 49d | 2024-09-25 A | 2024-12-02 A |  | 100% | 2024-09-25 | 2024-11-13 | 0d |  |  | Design |  | DBT | 6.1 | Paul Pettitt |  |  |  |  | DAG |  |  | -694.67 |
| 143 | 1.3.4.8.4.1 | Update baselined artefacts |  | 8d | 2024-09-25 A | 2024-10-04 A |  | 100% | 2024-09-25 | 2024-10-04 | 0d | start no earlier than 2024-09-25 |  | Design |  | DBT | 6.1 | Paul Pettitt |  | Complete | COMPLETE |  |  |  |  |  |
| 144 | 1.3.4.8.4.2 | Interim Release 8.4 Published | milestone | 0d | 2024-10-16 A | 2024-10-16 A | 143FS+8d | 100% | 2024-10-16 | 2024-10-16 | 0d | start no earlier than 2024-10-09 |  | Design |  | DBT | 6.1 | Paul Pettitt |  | Complete | COMPLETE | T3-DB-0184 | DAG | T3 |  |  |
| 145 | 1.3.4.8.4.3 | Interim Release 8.4 Deployed to SIT by Participants |  | 6d | 2024-11-25 A | 2024-12-02 A | 144FS+25d | 100% | 2024-11-13 | 2024-11-13 | 0d |  |  | Design |  | DBT | 6.12 | Paul Pettitt |  | Complete | COMPLETE |  |  |  |  |  |
| 146 | 1.3.4.8.5 | **Interim Release 8.5** |  | 71d | 2024-10-16 A | 2025-01-22 A |  | 100% | 2024-10-16 | 2024-12-04 | 0d |  |  | Design |  | DBT | 6.11 | Paul Pettitt |  |  |  |  | DAG |  |  | -728.67 |
| 147 | 1.3.4.8.5.1 | Update baselined artefacts |  | 8d | 2024-10-16 A | 2024-10-25 A |  | 100% | 2024-10-16 | 2024-10-25 | 0d | start no earlier than 2024-10-16 |  | Design |  | DBT | 6.11 | Paul Pettitt |  | Complete | COMPLETE |  |  |  |  |  |
| 148 | 1.3.4.8.5.2 | Interim Release 8.5 Published | milestone | 0d | 2024-11-06 A | 2024-11-06 A | 147FS+8d | 100% | 2024-11-06 | 2024-11-06 | 0d |  |  | Design |  | DBT | 6.11 | Paul Pettitt |  | Complete | COMPLETE | T3-DB-0185 | DAG | T3 |  |  |
| 149 | 1.3.4.8.5.3 | Interim Release 8.5 Deployed to SIT by Participants |  | 3d | 2025-01-20 A | 2025-01-22 A | 148FS+52d | 100% | 2024-12-04 | 2024-12-04 | 0d |  |  | Design |  | DBT | 6.12 | Paul Pettitt |  | Complete | COMPLETE |  |  |  |  |  |
| 150 | 1.3.4.8.6 | **Interim Release 8.6** |  | 45d? | 2024-11-21 A | 2025-01-22 A |  | 100% | 2024-11-21 | 2025-01-22 | 0d |  |  | Design |  | DBT | 6.14 | Paul Pettitt |  |  |  |  | DAG |  |  | -769.67 |
| 151 | 1.3.4.8.6.1 | Update baselined artefacts |  | 2d? | 2024-11-21 A | 2024-11-22 A |  | 100% | 2024-11-21 | 2024-11-22 | 0d | start no earlier than 2024-11-21 |  | Design |  | DBT | 6.14 | Paul Pettitt |  | Complete | COMPLETE |  |  |  |  |  |
| 152 | 1.3.4.8.6.2 | Interim Release 8.6 Published |  | 1d? | 2024-11-25 A | 2024-11-25 A | 151 | 100% | 2024-11-25 | 2024-11-25 | 0d |  |  | Design |  | DBT | 6.14 | Paul Pettitt |  | Complete | COMPLETE |  |  |  |  |  |
| 153 | 1.3.4.8.6.3 | Interim Release 8.6 Deployed to SIT by Participants |  | 3d | 2025-01-20 A | 2025-01-22 A | 152FS+39d | 100% | 2025-01-20 | 2025-01-22 | 0d |  |  | Design |  | DBT | 6.14 | Paul Pettitt |  | Complete | COMPLETE | T3-TE-0187 | DAG | T3 |  |  |

| ID | WBS | Task | Type | Duration | Start | Finish | Predecessors | Complete | Baseline start | Baseline finish | Baseline duration | Baseline 1 start | Baseline 1 finish | Constraint | Responsible | Text9 | Task Status | Update Version | MHHS Resource Name | Text29 | Sched Status | RAG | Milestone ID | Tier | Involved | MHHS Programme Phase | Action |
| --- | --- | --- | --- | --- | --- | --- | --- | --- | --- | --- | --- | --- | --- | --- | --- | --- | --- | --- | --- | --- | --- | --- | --- | --- | --- | --- | --- |
| 154 | 1.3.4.8.7 | **Interim Release 8.7** |  | 5d | 2025-01-20 A | 2025-01-24 A |  | 100% | 2025-01-20 | 2025-01-27 | 0d |  |  |  | Design | DBT | -769.67 | 6.16 | Paul Pettitt | DAG |  |  |  |  |  |  |  |
| 155 | 1.3.4.8.7.1 | Update baselined artefacts |  | 2d | 2025-01-20 A | 2025-01-21 A |  | 100% | 2025-01-20 | 2025-01-21 | 0d |  |  | start no earlier than 2025-01-20 | Design | DBT |  | 6.16 | Paul Pettitt |  | Complete | COMPLETE |  |  |  |  |  |
| 156 | 1.3.4.8.7.2 | Interim Release 8.7 Published |  | 1d | 2025-01-22 A | 2025-01-22 A | 155 | 100% | 2025-01-22 | 2025-01-22 | 0d |  |  |  | Design | DBT |  | 6.16 | Paul Pettitt |  | Complete | COMPLETE |  |  |  |  |  |
| 157 | 1.3.4.8.7.3 | Interim Release 8.7 Deployed to SIT by Participants |  | 3d | 2025-01-22 A | 2025-01-24 A | 156FS-1d | 100% | 2025-01-23 | 2025-01-27 | 0d |  |  |  | Design | DBT |  | 6.16 | Paul Pettitt | DAG | Complete | COMPLETE | T3-TE-0188 | T3 |  |  |  |
| 158 | 1.3.4.8.8 | **Interim Release 8.8** |  | 26d | 2025-02-05 A | 2025-03-12 A |  | 100% | 2025-02-05 | 2025-03-12 | 0d |  |  |  | Design | DBT | -829.67 | 6.18 | Paul Pettitt | DAG | Overdue Start |  |  |  |  |  |  |
| 159 | 1.3.4.8.8.1 | Update baselined artefacts |  | 4d | 2025-02-05 A | 2025-02-10 A |  | 100% | 2025-02-05 | 2025-02-10 | 0d |  |  | start no earlier than 2025-02-05 | Design | DBT |  | 6.18 | Paul Pettitt |  | Complete | COMPLETE |  |  |  |  |  |
| 160 | 1.3.4.8.8.2 | Interim Release 8.8 Published |  | 1d | 2025-02-12 A | 2025-02-12 A | 159FS+1d | 100% | 2025-02-12 | 2025-02-12 | 0d |  |  |  | Design | DBT |  | 6.18 | Paul Pettitt |  | Complete | COMPLETE |  |  |  |  |  |
| 161 | 1.3.4.8.8.3 | Interim Release 8.8 Deployed to SIT by Participants |  | 20d | 2025-02-13 A | 2025-03-12 A | 160 | 100% | 2025-02-13 | 2025-03-12 | 0d |  |  |  | Design | DBT |  | 6.18 | Paul Pettitt | DAG | Complete | COMPLETE |  |  |  |  |  |
| 162 | 1.3.4.8.9 | **Interim Release 8.9** |  | 45d | 2025-02-05 A | 2025-04-08 A |  | 100% | 2025-02-05 | 2025-03-12 | 0d |  |  |  | Design | DBT | -829.67 | 6.21 | Paul Pettitt | DAG |  |  |  |  |  |  |  |
| 163 | 1.3.4.8.9.1 | Update baselined artefacts |  | 4d | 2025-02-05 A | 2025-02-10 A |  | 100% | 2025-02-05 | 2025-02-10 | 0d |  |  | start no earlier than 2025-02-05 | Design | DBT |  | 6.21 | Paul Pettitt |  | Complete | COMPLETE |  |  |  |  |  |
| 164 | 1.3.4.8.9.2 | Interim Release 8.9 Published | milestone | 0d | 2025-03-11 A | 2025-03-11 A | 163FS+1d | 100% | 2025-02-12 | 2025-02-12 | 0d |  |  | finish no earlier than 2025-03-26 | Design | DBT |  | 6.21 | Paul Pettitt |  | Complete | COMPLETE |  |  |  |  |  |
| 165 | 1.3.4.8.9.3 | Interim Release 8.9 Deployed to SIT by Participants |  | 20d | 2025-03-12 A | 2025-04-08 A | 164 | 100% | 2025-03-12 | 2025-04-08 | 0d |  |  |  | Design | DBT |  | 6.21 | Paul Pettitt | DAG | Complete | COMPLETE |  |  |  |  |  |
| 166 | 1.3.4.8.10 | **Interim Release 8.10** |  | 56d | 2025-02-05 A | 2025-04-23 A |  | 100% | 2025-02-05 | 2025-03-12 | 0d |  |  |  | Design | DBT | -829.67 | 6.21 | Paul Pettitt | DAG | Overdue Start |  |  |  |  |  |  |
| 167 | 1.3.4.8.10.1 | Update baselined artefacts |  | 4d | 2025-02-05 A | 2025-02-10 A |  | 100% | 2025-02-05 | 2025-02-10 | 0d |  |  | start no earlier than 2025-02-05 | Design | DBT |  | 6.21 | Paul Pettitt |  | Complete | COMPLETE |  |  |  |  |  |
| 168 | 1.3.4.8.10.2 | Interim Release 8.10 Published |  | 1d | 2025-03-26 A | 2025-03-26 A | 167FS+1d | 100% | 2025-02-12 | 2025-02-12 | 0d |  |  | finish no earlier than 2025-03-26 | Design | DBT |  | 6.21 | Paul Pettitt |  | Complete | COMPLETE |  |  |  |  |  |
| 169 | 1.3.4.8.10.3 | Interim Release 8.10 Deployed to SIT by Participants |  | 20d | 2025-03-27 A | 2025-04-23 A | 168 | 100% | 2025-03-27 | 2025-04-23 | 0d |  |  | finish no earlier than 2025-03-27 | Design | DBT |  | 6.21 | Paul Pettitt | DAG | Complete | COMPLETE |  |  |  |  |  |
| 170 | 1.3.5 | **Queries Support / Knowledgebase & Tool Roll-Out (Systems)** |  | 325d | 2023-01-03 A | 2024-04-01 A |  | 100% | 2023-01-03 | 2024-04-01 | 325d | 2023-01-03 | 2024-04-01 |  | N/A | DBT |  | 5.0 | N/A |  |  |  |  |  | N/A | Design, Build & Test (PIT) |  |
| 171 | 1.3.5.1 | **Query Management** |  | 325d | 2023-01-03 A | 2024-04-01 A |  | 100% | 2023-01-03 | 2024-04-01 | 325d | 2023-01-03 | 2024-04-01 |  | N/A | DBT |  | 5.0 | N/A |  |  |  |  |  | N/A | Design, Build & Test (PIT) |  |
| 172 | 1.3.5.1.1 | Respond to Participant Queries |  | 325d | 2023-01-03 A | 2024-04-01 A |  | 100% | 2023-01-03 | 2024-04-01 | 325d | 2023-01-03 | 2024-04-01 | must start on 2023-01-03 | SI Design | DBT |  | 5.0 | Paul Pettitt |  | Complete | COMPLETE |  |  | PP | Design, Build & Test (PIT) | 11/8 - runs out to end of the programme |
| 173 | 1.3.5.1.2 | Respond to Programme Queries |  | 325d | 2023-01-03 A | 2024-04-01 A | 172SS | 100% | 2023-01-03 | 2024-04-01 | 325d | 2023-01-03 | 2024-04-01 |  | SI Design | DBT |  | 5.0 | Paul Pettitt |  | Complete | COMPLETE |  |  | PP | Design, Build & Test (PIT) | 11/8 - runs out to end of the programme |
| 174 | 1.3.5.2 | **Query Support tooling (FreshDesk)** |  | 23d | 2023-06-01 A | 2023-07-03 A |  | 100% | 2023-06-01 | 2023-07-03 | 23d | 2023-06-01 | 2023-07-03 |  | N/A | DBT |  | 5.0 | N/A |  |  |  |  |  | N/A | Design, Build & Test (PIT) |  |
| 175 | 1.3.5.2.1 | Migrate to Standalone Freshdesk |  | 10d | 2023-06-01 A | 2023-06-14 A |  | 100% | 2023-06-01 | 2023-06-14 | 10d | 2023-06-01 | 2023-06-14 | must start on 2023-06-01 | SI Design | DBT |  | 5.0 | Paul Pettitt |  | Complete | COMPLETE |  |  |  | Design, Build & Test (PIT) |  |
| 176 | 1.3.5.2.2 | Develop reporting dashboard |  | 5d | 2023-06-15 A | 2023-06-21 A | 175 | 100% | 2023-06-15 | 2023-06-21 | 5d | 2023-06-15 | 2023-06-21 |  | SI Design | DBT |  | 5.0 | Paul Pettitt |  | Complete | COMPLETE |  |  |  | Design, Build & Test (PIT) |  |
| 177 | 1.3.5.2.3 | Issue to SRO for Review |  | 5d | 2023-06-22 A | 2023-06-28 A | 176 | 100% | 2023-06-22 | 2023-06-28 | 5d | 2023-06-22 | 2023-06-28 |  | SI Design | DBT |  | 5.0 | Paul Pettitt |  | Complete | COMPLETE |  |  |  | Design, Build & Test (PIT) |  |
| 178 | 1.3.5.2.4 | Update following review |  | 2d | 2023-06-29 A | 2023-06-30 A | 177 | 100% | 2023-06-29 | 2023-06-30 | 2d | 2023-06-29 | 2023-06-30 |  | SI Design | DBT |  | 5.0 | Paul Pettitt |  | Complete | COMPLETE |  |  |  | Design, Build & Test (PIT) |  |
| 179 | 1.3.5.2.5 | Sign off |  | 1d | 2023-07-03 A | 2023-07-03 A | 178 | 100% | 2023-07-03 | 2023-07-03 | 1d | 2023-07-03 | 2023-07-03 |  | SI Design | DBT |  | 5.0 | Paul Pettitt |  | Complete | COMPLETE |  |  |  | Design, Build & Test (PIT) |  |

| ID | WBS | Task | Duration | Start | Finish | Predecessors | Complete | Remaining | Baseline start | Baseline finish | Baseline duration | Baseline 1 start | Baseline 1 finish | Total slack | Free slack | Constraint | Baseline cost | Responsible | Involved | Text9 | Update Version | MHHS Resource Name | MHHS Programme Phase | Sched Status | RAG | Text29 | Task Status |
| --- | --- | --- | --- | --- | --- | --- | --- | --- | --- | --- | --- | --- | --- | --- | --- | --- | --- | --- | --- | --- | --- | --- | --- | --- | --- | --- | --- |
| 180 | 1.3.5.3 | **KnowledgeBase Development** | 72d | 2023-06-01 A | 2023-09-08 A |  | 100% |  | 2023-06-01 | 2023-09-08 | 72d | 2023-06-01 | 2023-09-08 |  |  |  |  | N/A | N/A | DBT | 5.0 | N/A | Design, Build & Test (PIT) |  |  |  |  |
| 181 | 1.3.5.3.1 | Define Scope of KB | 1d | 2023-06-01 A | 2023-06-01 A | 175SS | 100% |  | 2023-06-01 | 2023-06-01 | 1d | 2023-06-01 | 2023-06-01 |  |  |  |  | SI Design |  | DBT | 5.0 | Paul Pettitt | Design, Build & Test (PIT) | Complete | COMPLETE |  |  |
| 182 | 1.3.5.3.2 | Capture Existing KB artefacts | 20d | 2023-06-02 A | 2023-06-29 A | 181 | 100% |  | 2023-06-02 | 2023-06-29 | 20d | 2023-06-02 | 2023-06-29 |  |  |  |  | SI Design |  | DBT | 5.0 | Paul Pettitt | Design, Build & Test (PIT) | Complete | COMPLETE |  |  |
| 183 | 1.3.5.3.3 | Tag artefacts | 5d | 2023-06-30 A | 2023-07-06 A | 182 | 100% |  | 2023-06-30 | 2023-07-06 | 5d | 2023-06-30 | 2023-07-06 |  |  |  |  | SI Design |  | DBT | 5.0 | Paul Pettitt | Design, Build & Test (PIT) | Complete | COMPLETE |  |  |
| 184 | 1.3.5.3.4 | Develop Participant Interfaces | 20d | 2023-07-07 A | 2023-08-03 A | 183 | 100% |  | 2023-07-07 | 2023-08-03 | 20d | 2023-07-07 | 2023-08-03 |  |  |  |  | SI Design |  | DBT | 5.0 | Paul Pettitt | Design, Build & Test (PIT) | Complete | COMPLETE |  |  |
| 185 | 1.3.5.3.5 | Promote to Collaboration Portal | 21d | 2023-08-04 A | 2023-09-01 A | 184 | 100% |  | 2023-08-04 | 2023-09-01 | 21d | 2023-08-04 | 2023-09-01 |  |  |  |  | SI Design |  | DBT | 5.0 | Paul Pettitt | Design, Build & Test (PIT) | Complete | COMPLETE |  |  |
| 186 | 1.3.5.3.6 | Link into FreshDesk | 5d | 2023-09-04 A | 2023-09-08 A | 185 | 100% |  | 2023-09-04 | 2023-09-08 | 5d | 2023-09-04 | 2023-09-08 |  |  |  |  | SI Design |  | DBT | 5.0 | Paul Pettitt | Design, Build & Test (PIT) | Complete | COMPLETE |  |  |
| 187 | 1.3.6 | **PP Design, Build & Test (DBT)** | 1221d? | 2022-10-31 A | 2027-07-05 |  | 77% | 285.49d? | 2022-10-31 | 2027-07-05 | 495d | 2022-10-31 | 2026-02-16 | 123d |  |  | -0 | N/A | N/A | DBT | 5.0 | N/A | Design, Build & Test (PIT) |  |  | DAG |  |
| 188 | 1.3.6.1 | **PP Impact Assessment, Planning & Procurement** | 110d | 2022-10-31 A | 2023-03-31 A |  | 100% |  | 2022-10-31 | 2023-03-31 | 110d | 2022-10-31 | 2023-03-31 |  |  |  |  | N/A | N/A | DBT | 5.0 | N/A | Design, Build & Test (PIT) |  |  |  |  |
| 189 | 1.3.6.1.1 | **PP Impact Assessment** | 67d | 2022-10-31 A | 2023-01-31 A |  | 100% |  | 2022-10-31 | 2023-01-31 | 67d | 2022-10-31 | 2023-01-31 |  |  |  |  | N/A | N/A | DBT | 5.0 | N/A | Design, Build & Test (PIT) |  |  |  |  |
| 190 | 1.3.6.1.1.1 | Develop heatmap for impact of MHHS | 67d | 2022-10-31 A | 2023-01-31 A | 47 | 100% |  | 2022-10-31 | 2023-01-31 | 67d | 2022-10-31 | 2023-01-31 |  |  |  |  | PP |  | DBT | 5.0 | PP | Design, Build & Test (PIT) | Complete | COMPLETE |  |  |
| 191 | 1.3.6.1.1.2 | Develop detailed impact assessment | 67d | 2022-10-31 A | 2023-01-31 A | 47 | 100% |  | 2022-10-31 | 2023-01-31 | 67d | 2022-10-31 | 2023-01-31 |  |  |  |  | PP |  | DBT | 5.0 | PP | Design, Build & Test (PIT) | Complete | COMPLETE |  |  |
| 192 | 1.3.6.1.2 | **PP Planning** | 67d | 2022-10-31 A | 2023-01-31 A |  | 100% |  | 2022-10-31 | 2023-01-31 | 67d | 2022-10-31 | 2023-01-31 |  |  |  |  | N/A | N/A | DBT | 5.0 | N/A | Design, Build & Test (PIT) |  |  |  |  |
| 193 | 1.3.6.1.2.1 | Develop detailed short-term plan | 23d | 2022-10-31 A | 2022-11-30 A | 47 | 100% |  | 2022-10-31 | 2022-11-30 | 23d | 2022-10-31 | 2022-11-30 |  |  |  |  | PP |  | DBT | 5.0 | PP | Design, Build & Test (PIT) | Complete | COMPLETE |  |  |
| 194 | 1.3.6.1.2.2 | Develop overall project plan for implementation | 67d | 2022-10-31 A | 2023-01-31 A | 47 | 100% |  | 2022-10-31 | 2023-01-31 | 67d | 2022-10-31 | 2023-01-31 |  |  |  |  | PP |  | DBT | 5.0 | PP | Design, Build & Test (PIT) | Complete | COMPLETE |  |  |
| 195 | 1.3.6.1.2.3 | Develop procurement plan | 67d | 2022-10-31 A | 2023-01-31 A | 47 | 100% |  | 2022-10-31 | 2023-01-31 | 67d | 2022-10-31 | 2023-01-31 |  |  |  |  | PP |  | DBT | 5.0 | PP | Design, Build & Test (PIT) | Complete | COMPLETE |  |  |
| 196 | 1.3.6.1.3 | **PP Software/Service Procurement** | 110d | 2022-10-31 A | 2023-03-31 A |  | 100% |  | 2022-10-31 | 2023-03-31 | 110d | 2022-10-31 | 2023-03-31 |  |  |  |  | N/A | N/A | DBT | 5.0 | N/A | Design, Build & Test (PIT) |  |  |  |  |
| 197 | 1.3.6.1.3.1 | Run tender process | 67d | 2022-10-31 A | 2023-01-31 A | 47 | 100% |  | 2022-10-31 | 2023-01-31 | 67d | 2022-10-31 | 2023-01-31 |  |  |  |  | PP |  | DBT | 5.0 | PP | Design, Build & Test (PIT) | Complete | COMPLETE |  |  |
| 198 | 1.3.6.1.3.2 | Select provider & sign commercials | 43d | 2023-02-01 A | 2023-03-31 A | 197 | 100% |  | 2023-02-01 | 2023-03-31 | 43d | 2023-02-01 | 2023-03-31 |  |  |  |  | PP |  | DBT | 5.0 | PP | Design, Build & Test (PIT) | Complete | COMPLETE |  |  |
| 199 | 1.3.6.2 | **Design Handover** | 850d? | 2024-04-02 A | 2027-07-05 |  | 17% | 707.96d? | 2024-09-02 | 2027-07-05 | 0d |  |  | 123d |  |  |  | Design |  | DBT | 6.1 | Helix |  |  |  |  | -694.67 |
| 200 | 1.3.6.2.1 | **Creation of the Configuration Management Database** | 14d | 2024-09-02 A | 2024-09-19 A |  | 100% |  | 2024-09-02 | 2024-09-19 | 0d |  |  |  |  |  |  | Design |  | DBT | 6.1 | Helix |  |  |  |  | -701.67 |
| 201 | 1.3.6.2.1.1 | Identify all baselined design artefacts | 9d | 2024-09-02 A | 2024-09-12 A |  | 100% |  | 2024-09-02 | 2024-09-12 | 0d |  |  |  |  | start no earlier than 2024-09-02 |  | Design |  | DBT | 6.1 | Helix |  | Complete | COMPLETE |  |  |
| 202 | 1.3.6.2.1.2 | Create CMBD | 5d | 2024-09-13 A | 2024-09-19 A | 201 | 100% |  | 2024-09-13 | 2024-09-19 | 0d |  |  |  |  |  |  | Design |  | DBT | 6.1 | Helix |  | Complete | COMPLETE |  |  |
| 203 | 1.3.6.2.2 | **Knowledge Transfer** | 86d? | 2025-01-06 A | 2025-05-05 |  | 10% | 77d? | 2024-09-02 | 2024-10-28 | 0d |  |  | 688d |  |  |  | Design |  | DBT | 6.17 | Helix |  | Overdue Start |  |  | -701.67 |
| 204 | 1.3.6.2.2.1 | Elexon to document knowledge transfer requirements | 4d | 2025-01-06 A | 2025-01-09 A |  | 100% |  | 2025-01-06 | 2025-01-09 | 0d |  |  |  |  | start no earlier than 2024-09-02 |  | Design |  | DBT | 6.17 | Helix |  | Complete | COMPLETE |  |  |
| 205 | 1.3.6.2.2.2 | Review Requirements | 5d | 2025-01-10 A | 2025-01-16 A | 204 | 100% |  | 2025-01-10 | 2025-01-16 | 0d |  |  |  |  |  |  | Design |  | DBT | 6.17 | Paul Pettitt |  | Complete | COMPLETE |  |  |
| 206 | 1.3.6.2.2.3 | Agree Success Criteria | 31d | 2025-01-17 | 2025-02-28 | 205 |  |  | 2025-01-17 | 2025-02-28 | 0d |  |  | 688d | 0d |  |  | Design |  | DBT | 6.17 | Helix / Paul Pettitt |  | Overdue Start | RED |  | -109.67 |
| 207 | 1.3.6.2.2.4 | Identify Key personel with Elexon | 3d | 2025-03-03 | 2025-03-05 | 206 |  |  | 2025-03-03 | 2025-03-05 | 0d |  |  | 688d | 0d |  |  | Design |  | DBT | 6.17 | Helix |  | Overdue Start | RED |  | -64.67 |
| 208 | 1.3.6.2.2.5 | Draft Agenda for initial meeting | 1d? | 2025-03-06 | 2025-03-06 | 207 |  |  | 2025-03-06 | 2025-03-06 | 0d |  |  | 688d | 0d |  |  | Design |  | DBT | 6.17 | Helix |  | Overdue Start | RED |  | -61.67 |
| 209 | 1.3.6.2.2.6 | Define cadence for handover sessions | 2d | 2025-03-07 | 2025-03-10 | 208 |  |  | 2025-03-07 | 2025-03-10 | 0d |  |  | 688d | 0d |  |  | Design |  | DBT | 6.17 | Helix |  | Overdue Start | RED |  | -60.67 |
| 210 | 1.3.6.2.2.7 | Share Design Information | 20d | 2025-03-11 | 2025-04-07 | 209 |  |  | 2025-03-11 | 2025-04-07 | 0d |  |  | 688d | 0d | start no earlier than 2024-09-02 |  | Design |  | DBT | 6.17 | Helix / Paul Pettitt |  | Overdue Start | RED |  | -56.67 |
| 211 | 1.3.6.2.2.8 | Conduct Initial Handover Session | 20d? | 2025-04-08 | 2025-05-05 | 210 |  |  | 2025-04-08 | 2025-05-05 | 0d |  |  | 688d |  | start no earlier than 2024-10-01 |  | Design |  | DBT | 6.17 | Helix |  | Overdue Start | RED |  | -28.67 |

Notes:
- 205: 07/05/25 - MHHS continues to work with Helix to develop the Knowledge Transfer plan. Once this is recieved and agreed, then these dates will be updated to reflect it. Currently being managed through the Account Management meetings.
- 206: 07/05/25 - MHHS continues to work with Helix to develop the Knowledge Transfer plan. Once this is recieved and agreed, then these dates will be updated to reflect it. Currently being managed through the Account Management meetings.
- 207: 07/05/25 - MHHS continues to work with Helix to develop the Knowledge Transfer plan. Once this is recieved and agreed, then these dates will be updated to reflect it. Currently being managed through the Account Management meetings.
- 208: 07/05/25 - MHHS continues to work with Helix to develop the Knowledge Transfer plan. Once this is recieved and agreed, then these dates will be updated to reflect it. Currently being managed through the Account Management meetings.
- 209: 07/05/25 - MHHS continues to work with Helix to develop the Knowledge Transfer plan. Once this is recieved and agreed, then these dates will be updated to reflect it. Currently being managed through the Account Management meetings.
- 210: 07/05/25 - MHHS continues to work with Helix to develop the Knowledge Transfer plan. Once this is recieved and agreed, then these dates will be updated to reflect it. Currently being managed through the Account Management meetings.
- 211: 07/05/25 - MHHS continues to work with Helix to develop the Knowledge Transfer plan. Once this is recieved and agreed, then these dates will be updated to reflect it. Currently being managed through the Account Management meetings.

| ID | WBS | Task | Duration | Start | Finish | Predecessors | Complete | Remaining | Baseline start | Baseline finish | Baseline duration | Baseline 1 start | Baseline 1 finish | Total slack | Free slack | Constraint | Baseline cost | Responsible | Text9 | Task Status | Update Version | Sched Status | MHHS Resource Name | RAG | Involved | MHHS Programme Phase | Text29 |
| --- | --- | --- | --- | --- | --- | --- | --- | --- | --- | --- | --- | --- | --- | --- | --- | --- | --- | --- | --- | --- | --- | --- | --- | --- | --- | --- | --- |
| 212 | 1.3.6.2.3 | **Triage Sessions** | 391d | 2024-04-02 | 2025-09-30 |  |  |  | 2024-10-01 | 2025-04-01 | 0d |  |  | 582d |  |  |  | Design | DBT | -701.67 | 6.17 | Overdue Start | Helix |  |  |  |  |
| 213 | 1.3.6.2.3.1 | Design Triage Sessions | 261d | 2024-10-01 | 2025-09-30 |  |  |  | 2024-10-01 | 2025-09-30 | 0d |  |  | 582d |  | start no earlier than 2024-10-01 |  | Design | DBT | -217.67 | 6.17 | Overdue Start | Helix | GREEN |  |  |  |
| 214 | 1.3.6.2.3.2 | Test Triage Sessions | 261d | 2024-04-02 | 2025-04-01 |  |  |  | 2024-10-01 | 2025-04-01 | 0d |  |  | 712d |  | finish no earlier than 2025-04-01 |  | Design | DBT | -399.67 | 6.17 | Overdue Start | Helix | RED |  |  |  |
| 215 | 1.3.6.2.4 | **Knowledge Base** | 9d | 2024-09-02 A | 2024-09-12 A |  | 100% |  | 2024-09-02 | 2024-09-12 | 0d |  |  |  |  |  |  | Design | DBT | -701.67 | 6.1 | Overdue Start | Helix |  |  |  |  |
| 216 | 1.3.6.2.4.1 | Document Knowledge base update process | 4d | 2024-09-02 A | 2024-09-05 A |  | 100% |  | 2024-09-02 | 2024-09-05 | 0d |  |  |  |  | start no earlier than 2024-09-02 |  | Design | DBT |  | 6.1 | Complete | Helix | COMPLETE |  |  |  |
| 217 | 1.3.6.2.4.2 | Document Design updates to Collaboration Base | 5d | 2024-09-06 A | 2024-09-12 A |  | 100% |  | 2024-09-06 | 2024-09-12 | 0d |  |  |  |  | start no earlier than 2024-09-06 |  | Design | DBT |  | 6.1 | Complete | Helix | COMPLETE |  |  |  |
| 218 | 1.3.6.2.5 | **FreshDesk** | 26d? | 2025-08-20 | 2025-09-24 |  |  |  | 2025-08-20 | 2025-09-24 | 0d |  |  | 586d |  |  |  | Design | DBT | -701.67 | 6.17 | Overdue Start | Helix / Paul Pettitt |  |  |  |  |
| 219 | 1.3.6.2.5.1 | Agree Indicative Handover of FreshDesk Calls to Service Now | 4d | 2025-08-20 | 2025-08-25 |  |  |  | 2025-08-20 | 2025-08-25 | 0d |  |  | 586d | 0d | start no earlier than 2025-08-20 |  | Design | DBT | 105.33 | 6.17 | Green | Helix | GREEN |  |  |  |
| 220 | 1.3.6.2.5.2 | Prepare Comms to Industry | 10d | 2025-08-26 | 2025-09-08 | 219 |  |  | 2025-08-26 | 2025-09-08 | 0d |  |  | 586d | 0d | start no earlier than 2025-02-07 |  | Design | DBT | 111.33 | 6.17 | Green | Paul Pettitt | GREEN |  |  |  |
| 221 | 1.3.6.2.5.3 | Issue Comms to Industry | 1d? | 2025-09-09 | 2025-09-09 | 220 |  |  | 2025-09-09 | 2025-09-09 | 0d |  |  | 586d | 0d | start no earlier than 2025-02-21 |  | Design | DBT | 125.33 | 6.17 | Green | Paul Pettitt | GREEN |  |  |  |
| 222 | 1.3.6.2.5.4 | Redirect Design Mailbox to Service Now | 1d? | 2025-09-10 | 2025-09-10 | 221 |  |  | 2025-09-10 | 2025-09-10 | 0d |  |  | 586d | 0d | start no earlier than 2025-03-03 |  | Design | DBT | 126.33 | 6.17 | Green | Paul Pettitt | GREEN |  |  |  |
| 223 | 1.3.6.2.5.5 | Archive Freshdesk calls | 5d | 2025-09-11 | 2025-09-17 | 222 |  |  | 2025-09-11 | 2025-09-17 | 0d |  |  | 586d | 0d | start no earlier than 2025-03-03 |  | Design | DBT | 127.33 | 6.17 | Green | Paul Pettitt | GREEN |  |  |  |
| 224 | 1.3.6.2.5.6 | Decommission FreshDesk | 5d | 2025-09-18 | 2025-09-24 | 223 |  |  | 2025-09-18 | 2025-09-24 | 0d |  |  | 586d |  | start no earlier than 2025-03-10 |  | Design | DBT | 134.33 | 6.17 | Green | Paul Pettitt | GREEN |  |  |  |
| 225 | 1.3.6.2.6 | **iServer** | 611d? | 2025-03-03 A | 2027-07-05 |  | 88% | 72.87d? | 2025-03-03 | 2027-07-05 | 0d |  |  |  |  |  |  | Design | DBT | -701.67 | 6.17 | Overdue Start | Paul Pettitt | GREEN |  |  |  |
| 226 | 1.3.6.2.6.1 | Gather Licensing information | 88d? | 2025-03-03 A | 2025-07-02 A |  | 100% |  | 2025-03-03 | 2025-07-02 | 0d |  |  |  |  | start no earlier than 2025-03-03 |  | Design | DBT |  | 6.17 | Complete | Paul Pettitt | COMPLETE |  |  |  |
| 227 | 1.3.6.2.6.2 | Inform Orbus of iServer support termination | 1d? | 2025-07-03 A | 2025-07-03 A | 226 | 100% |  | 2026-02-05 | 2026-02-05 | 0d |  |  |  |  |  |  | Design | DBT |  | 6.17 | Complete | Paul Pettitt | COMPLETE |  |  |  |
| 228 | 1.3.6.2.6.3 | Produce iServer decomissioning pack | 4d | 2025-07-04 A | 2025-07-09 A | 227 | 100% |  | 2026-02-06 | 2026-02-11 | 0d |  |  |  |  |  |  | Design | DBT |  | 6.17 | Complete | Paul Pettitt | COMPLETE |  |  |  |
| 229 | 1.3.6.2.6.4 | Publish iServer decommising pack on the Clock | 1d? | 2025-07-31 | 2025-07-31 | 228FS+15d |  |  | 2026-03-05 | 2026-03-05 | 0d |  |  | 625d |  |  |  | Design | DBT | 85.33 | 6.18 | Green | Paul Pettitt | GREEN |  |  |  |
| 230 | 1.3.6.2.6.5 | Clear down old information | 1d? | 2025-03-03 | 2025-03-03 |  |  |  | 2025-08-11 | 2025-08-11 | 0d |  |  | 731d | 4d |  |  | Design | DBT | -64.67 | 6.17 | Overdue Start | Paul Pettitt | GREEN |  |  |  |
| 231 | 1.3.6.2.6.6 | Clear down accounts | 2d | 2025-03-10 | 2025-03-11 | 230 |  |  | 2025-08-12 | 2025-08-13 | 0d |  |  | 727d |  | start no earlier than 2025-03-10 |  | Design | DBT | -57.67 | 6.17 | Overdue Start | Paul Pettitt | GREEN |  |  |  |
| 232 | 1.3.6.2.6.7 | Identify Collaboration Base Design Dependencies on iServer | 2d | 2025-04-01 A | 2025-04-02 A | 231 | 100% |  | 2025-08-14 | 2025-08-15 | 0d |  |  |  |  | start no earlier than 2025-04-01 |  | Design | DBT |  | 6.17 | Complete | Paul Pettitt | COMPLETE |  |  |  |
| 233 | 1.3.6.2.6.8 | Remove Design dependencies | 5d | 2025-04-03 A | 2025-04-09 | 232 | 20% | 4d | 2025-08-18 | 2025-08-22 | 0d |  |  | 701d | 0d | start no earlier than 2025-04-03 |  | Design | DBT |  | 6.17 | Overdue | Paul Pettitt | GREEN |  |  |  |
| 234 | 1.3.6.2.6.9 | Close down iServer | 5d | 2025-04-10 | 2025-04-16 | 233 |  |  | 2025-08-25 | 2025-08-29 | 0d |  |  | 701d |  | start no earlier than 2025-04-10 |  | Design | DBT | -26.67 | 6.17 | Overdue Start | Paul Pettitt | GREEN |  |  |  |
| 235 | 1.3.6.3 | **Central Systems DBT** | 325d | 2022-10-31 A | 2024-01-26 A |  | 100% |  | 2022-10-31 | 2024-01-26 | 345d | 2022-10-31 | 2024-05-13 |  |  |  | -0 | N/A | DBT | -316.67 | 5.0 |  | N/A |  | N/A | Design, Build & Test (PIT) | DAG |
| 236 | 1.3.6.3.1 | **Elexon Central Systems DBT CIT (Entering at Interval 1)** | 248d | 2022-10-31 A | 2023-10-11 A |  | 100% |  | 2022-10-31 | 2023-10-11 | 249d | 2022-10-31 | 2023-09-29 |  |  |  | -0 | N/A | DBT |  | 5.0 |  | N/A |  | N/A | Design, Build & Test (PIT) | DAG |
| 237 | 1.3.6.3.1.1 | **Design and Build** | 235d | 2022-10-31 A | 2023-09-22 A |  | 100% |  | 2022-10-31 | 2023-09-22 | 240d | 2022-10-31 | 2023-09-29 |  |  |  |  | N/A | DBT | -259.67 | 5.0 |  | N/A |  | N/A | Design, Build & Test (PIT) |  |
| 238 | 1.3.6.3.1.1.1 | Helix Design and Build | 235d | 2022-10-31 A | 2023-09-22 A | 2 | 100% |  | 2022-10-31 | 2023-09-22 | 240d | 2022-10-31 | 2023-09-29 |  |  |  |  | PP | DBT |  | 5.0 | Complete |  | COMPLETE | SI Test | Design, Build & Test (PIT) |  |

Notes:
- 212: 07/05/25 - MHHS continues to work with Helix to develop the Knowledge Transfer plan. Once this is recieved and agreed, then these dates will be updated to reflect it. Currently being managed through the Account Management meetings.
- 213: 07/05/25 - MHHS continues to work with Helix to develop the Knowledge Transfer plan. Once this is recieved and agreed, then these dates will be updated to reflect it. Currently being managed through the Account Management meetings.
- 214: 07/05/25 - MHHS continues to work with Helix to develop the Knowledge Transfer plan. Once this is recieved and agreed, then these dates will be updated to reflect it. Currently being managed through the Account Management meetings.
- 215: 07/05/25 - MHHS continues to work with Helix to develop the Knowledge Transfer plan. Once this is recieved and agreed, then these dates will be updated to reflect it. Currently being managed through the Account Management meetings.
- 216: 07/05/25 - MHHS continues to work with Helix to develop the Knowledge Transfer plan. Once this is recieved and agreed, then these dates will be updated to reflect it. Currently being managed through the Account Management meetings.
- 217: 07/05/25 - MHHS continues to work with Helix to develop the Knowledge Transfer plan. Once this is recieved and agreed, then these dates will be updated to reflect it. Currently being managed through the Account Management meetings.
- 218: 07/05/25 - MHHS continues to work with Helix to develop the Knowledge Transfer plan. Once this is recieved and agreed, then these dates will be updated to reflect it. Currently being managed through the Account Management meetings.
- 219: 07/05/25 - MHHS continues to work with Helix to develop the Knowledge Transfer plan. Once this is recieved and agreed, then these dates will be updated to reflect it. Currently being managed through the Account Management meetings.
- 220: 07/05/25 - MHHS continues to work with Helix to develop the Knowledge Transfer plan. Once this is recieved and agreed, then these dates will be updated to reflect it. Currently being managed through the Account Management meetings.
- 221: 07/05/25 - MHHS continues to work with Helix to develop the Knowledge Transfer plan. Once this is recieved and agreed, then these dates will be updated to reflect it. Currently being managed through the Account Management meetings.
- 222: 07/05/25 - MHHS continues to work with Helix to develop the Knowledge Transfer plan. Once this is recieved and agreed, then these dates will be updated to reflect it. Currently being managed through the Account Management meetings.
- 223: 07/05/25 - MHHS continues to work with Helix to develop the Knowledge Transfer plan. Once this is recieved and agreed, then these dates will be updated to reflect it. Currently being managed through the Account Management meetings.
- 224: 07/05/25 - MHHS continues to work with Helix to develop the Knowledge Transfer plan. Once this is recieved and agreed, then these dates will be updated to reflect it. Currently being managed through the Account Management meetings.

| ID | WBS | Task | Type | Duration | Start | Finish | Predecessors | Complete | Baseline start | Baseline finish | Baseline duration | Baseline 1 start | Baseline 1 finish | Constraint | Baseline cost | Responsible | Involved | Text9 | Update Version | MHHS Resource Name | MHHS Programme Phase | Text29 | Sched Status | RAG | Milestone ID | Tier | Artefact ID |
| --- | --- | --- | --- | --- | --- | --- | --- | --- | --- | --- | --- | --- | --- | --- | --- | --- | --- | --- | --- | --- | --- | --- | --- | --- | --- | --- | --- |
| 239 | 1.3.6.3.1.2 | **Test Approach & Plan** |  | 235d | 2022-10-31 A | 2023-09-22 A |  | 100% | 2022-10-31 | 2023-09-22 | 235d | 2022-10-31 | 2023-07-21 |  | -0 | N/A | N/A | DBT | 5.0 | N/A | Design, Build & Test (PIT) | DAG |  |  |  |  |  |
| 240 | 1.3.6.3.1.2.1 | Develop Test Approach & Plan |  | 180d | 2022-10-31 A | 2023-07-07 A |  | 100% | 2022-10-31 | 2023-07-07 | 180d | 2022-10-31 | 2023-07-07 |  |  | PP | SI Test | DBT | 5.0 |  | Design, Build & Test (PIT) |  | Complete | COMPLETE |  |  |  |
| 241 | 1.3.6.3.1.2.2 | Elexon Central Systems Test Approach & Plan (PIT) submitted to Programme for assurance | milestone | 0d | 2023-07-13 A | 2023-07-13 A | 240FF+4d | 100% | 2023-07-13 | 2023-07-13 | 0d | 2023-07-07 | 2023-07-07 |  |  | PP | SI Test | DBT | 5.0 |  | Design, Build & Test (PIT) | SITAG | Complete | COMPLETE | T3-DB-0029 | T3 |  |
| 242 | 1.3.6.3.1.2.3 | Elexon Central Systems Test Approach & Plan (PIT) V2 resubmitted to Programme for assurance | milestone, manual | 0d | 2023-07-27 A | 2023-07-27 A | 241FS+9d | 100% | 2023-07-27 | 2023-07-27 | 0d |  |  |  |  | PP | SI Test | DBT | 5.4 |  | Design, Build & Test (PIT) |  | Complete | COMPLETE |  |  |  |
| 243 | 1.3.6.3.1.2.4 | Elexon Central Systems Test Approach & Plan (PIT) V3 resubmitted to Programme for assurance | milestone | 0d | 2023-08-18 A | 2023-08-18 A | 242FS+17d | 100% | 2023-08-18 | 2023-08-18 | 0d |  |  |  |  | PP | SI Test | DBT | 5.4 |  | Design, Build & Test (PIT) |  | Complete | COMPLETE |  |  |  |
| 244 | 1.3.6.3.1.2.5 | Elexon Central Systems Test approach and plan MHHS Review Completed | milestone | 0d | 2023-09-22 A | 2023-09-22 A | 243FS+25d | 100% | 2023-09-22 | 2023-09-22 | 0d | 2023-07-10 | 2023-07-21 |  |  | SI Test | PP | DBT | 5.8 |  | Design, Build & Test (PIT) | SITAG | Complete | COMPLETE | T3-DB-0106 | T3 |  |
| 245 | 1.3.6.3.1.3 | **Test Readiness Report** |  | 16d | 2023-07-28 A | 2023-08-18 A |  | 100% | 2023-07-28 | 2023-08-18 | 51d | 2023-07-21 | 2023-09-29 |  |  | N/A | N/A | DBT | 5.0 | N/A | Design, Build & Test (PIT) |  |  |  |  |  |  |
| 246 | 1.3.6.3.1.3.1 | Test readiness reporting |  | 16d | 2023-07-28 A | 2023-08-18 A | 241FS+10d | 100% | 2023-07-28 | 2023-08-18 | 51d | 2023-07-21 | 2023-09-29 |  |  | PP | 109 | DBT | 5.0 |  | Design, Build & Test (PIT) |  | Complete | COMPLETE |  |  |  |
| 247 | 1.3.6.3.1.4 | **Requirements to test Traceability Matrix (RTTM)** |  | 35d | 2023-08-04 A | 2023-09-22 A |  | 100% | 2023-08-04 | 2023-09-22 | 35d | 2022-10-31 | 2023-08-18 |  | -0 | N/A | N/A | DBT | 5.0 | N/A | Design, Build & Test (PIT) |  |  |  |  |  |  |
| 248 | 1.3.6.3.1.4.1 | Elexon Central Systems RTTM submitted to Programme for assurance | milestone | 0d | 2023-08-04 A | 2023-08-04 A | 241 | 100% | 2023-08-04 | 2023-08-04 | 0d | 2023-08-04 | 2023-08-04 | start no earlier than 2023-04-28 |  | PP | SI Test | DBT | 5.0 |  | Design, Build & Test (PIT) | SITAG | Complete | COMPLETE | T3-DB-0030 | T3 | MHHS-ART009 |
| 249 | 1.3.6.3.1.4.2 | Elexon Central Systems RTTM MHHS Review Completed | milestone | 0d | 2023-09-22 A | 2023-09-22 A | 248FS+35d | 100% | 2023-09-22 | 2023-09-22 | 0d | 2023-08-07 | 2023-08-18 |  |  | SI Test | PP | DBT | 5.8 |  | Design, Build & Test (PIT) | SITAG | Complete | COMPLETE | T3-DB-0107 | T3 |  |
| 250 | 1.3.6.3.1.5 | **Test Scenarios** |  | 35d | 2023-08-04 A | 2023-09-22 A |  | 100% | 2023-08-04 | 2023-09-22 | 35d | 2022-10-31 | 2023-08-18 |  | -0 | N/A | N/A | DBT | 5.0 | N/A | Design, Build & Test (PIT) |  |  |  |  |  |  |
| 251 | 1.3.6.3.1.5.1 | Elexon Central Systems test scenarios submitted to Programme for assurance | milestone | 0d | 2023-08-04 A | 2023-08-04 A | 241 | 100% | 2023-08-04 | 2023-08-04 | 0d | 2023-08-04 | 2023-08-04 |  |  | PP | SI Test | DBT | 5.0 |  | Design, Build & Test (PIT) | SITAG | Complete | COMPLETE | T3-DB-0032 | T3 |  |
| 252 | 1.3.6.3.1.5.2 | Elexon Central Systems Test scenarios MHHS Review Completed | milestone | 0d | 2023-09-22 A | 2023-09-22 A | 251FS+35d | 100% | 2023-09-22 | 2023-09-22 | 0d | 2023-08-07 | 2023-08-18 |  |  | SI Test | PP | DBT | 5.8 |  | Design, Build & Test (PIT) | SITAG | Complete | COMPLETE | T3-DB-0108 | T3 |  |
| 253 | 1.3.6.3.1.6 | **PIT Execution** |  | 38d | 2023-08-21 A | 2023-10-11 A |  | 100% | 2023-08-21 | 2023-10-11 | 248d | 2022-10-31 | 2023-09-29 |  | -0 | N/A | N/A | DBT | 5.0 | N/A | Design, Build & Test (PIT) |  |  |  |  |  |  |
| 254 | 1.3.6.3.1.6.1 | PIT Test Execution Progress Report |  | 18d | 2023-09-04 A | 2023-09-27 A | 246FS+10d | 100% | 2023-09-04 | 2023-09-27 | 235d | 2022-10-31 | 2023-09-22 |  |  | PP | SI Test | DBT | 5.1 |  | Design, Build & Test (PIT) |  | Complete | COMPLETE |  |  |  |
| 255 | 1.3.6.3.1.6.2 | Elexon Central Systems PIT Execution |  | 28d | 2023-08-21 A | 2023-09-27 A | 246 | 100% | 2023-08-21 | 2023-09-27 | 240d | 2022-10-31 | 2023-09-29 |  |  | PP | SI Test | DBT | 5.1 |  | Design, Build & Test (PIT) |  | Complete | COMPLETE |  |  |  |
| 256 | 1.3.6.3.1.6.3 | Elexon Central Systems PIT Completion Report submitted to Programme for assurance | milestone | 0d | 2023-09-27 A | 2023-09-27 A | 255 | 100% | 2023-09-27 | 2023-09-27 | 0d | 2024-01-05 | 2024-01-05 |  |  | PP | SI Test | DBT | 5.8 |  | Design, Build & Test (PIT) | SITAG | Complete | COMPLETE | T3-DB-0109 | T3 |  |
| 257 | 1.3.6.3.1.6.4 | Elexon Central Systems PIT Completion Report MHHS Review Completed | milestone | 0d | 2023-10-11 A | 2023-10-11 A | 249, 252, 254, 256FS+10d, 244 | 100% | 2023-10-11 | 2023-10-11 | 0d |  |  |  |  | SI Test | PP | DBT | 5.8 |  | Design, Build & Test (PIT) | SITAG | Complete | COMPLETE | T3-DB-0110 | T3 |  |
| 258 | 1.3.6.3.2 | **DIP DBT CIT (Entering at Interval 1)** |  | 221d | 2023-01-02 A | 2023-11-06 A |  | 100% | 2023-01-02 | 2023-11-06 | 266d | 2022-10-31 | 2023-09-29 |  | -0 | N/A | N/A | DBT | 5.0 | N/A | Design, Build & Test (PIT) |  |  |  |  |  |  |
| 259 | 1.3.6.3.2.1 | Design |  | 80d | 2023-01-02 A | 2023-04-21 A |  | 100% | 2023-01-02 | 2023-04-21 | 80d | 2023-01-02 | 2023-04-21 | must start on 2023-01-02 |  | PP | SI Design | DBT | 5.0 |  | Design, Build & Test (PIT) |  | Complete | COMPLETE |  |  |  |
| 260 | 1.3.6.3.2.2 | Build |  | 155d | 2023-01-09 A | 2023-08-11 A | 259SS+5d | 100% | 2023-01-09 | 2023-08-11 | 155d | 2023-01-09 | 2023-08-11 |  |  | PP |  | DBT | 5.5 |  | Design, Build & Test (PIT) |  | Complete | COMPLETE |  |  |  |
| 261 | 1.3.6.3.2.3 | **Test Approach & Plan** |  | 9d | 2023-07-07 A | 2023-07-20 A |  | 100% | 2023-07-07 | 2023-07-20 | 190d | 2022-10-31 | 2023-07-21 |  |  | N/A | N/A | DBT | 5.0 | N/A | Design, Build & Test (PIT) |  |  |  |  |  |  |
| 262 | 1.3.6.3.2.3.1 | DIP Test Approach & Plan (PIT) submitted to Programme for assurance | milestone | 0d | 2023-07-07 A | 2023-07-07 A |  | 100% | 2023-07-07 | 2023-07-07 | 0d | 2023-07-07 | 2023-07-07 |  |  | PP | SI Test | DBT | 5.0 |  | Design, Build & Test (PIT) | SITAG | Complete | COMPLETE | T3-DB-0026 | T3 | MHHS-ART073 |
| 263 | 1.3.6.3.2.3.2 | DIP Test Approach & Plan (PIT) MHHS Review Completed | milestone | 0d | 2023-07-20 A | 2023-07-20 A | 262FS+9d | 100% | 2023-07-20 | 2023-07-20 | 10d | 2023-07-10 | 2023-07-21 |  |  | SI Test | PP | DBT | 5.0 |  | Design, Build & Test (PIT) |  | Complete | COMPLETE |  |  |  |

| ID | WBS | Task | Type | Duration | Start | Finish | Predecessors | Complete | Baseline start | Baseline finish | Baseline duration | Baseline 1 start | Baseline 1 finish | Constraint | Baseline cost | Responsible | Involved | Text9 | Update Version | MHHS Resource Name | MHHS Programme Phase | Sched Status | RAG | Artefact ID | Milestone ID | Text29 | Tier |
| --- | --- | --- | --- | --- | --- | --- | --- | --- | --- | --- | --- | --- | --- | --- | --- | --- | --- | --- | --- | --- | --- | --- | --- | --- | --- | --- | --- |
| 264 | 1.3.6.3.2.4 | **PIT Test Readiness Report** |  | 31d | 2023-07-21 A | 2023-09-01 A |  | 100% | 2023-07-21 | 2023-09-01 | 51d | 2023-07-21 | 2023-09-29 |  |  | N/A | N/A | DBT | 5.0 | N/A | Design, Build & Test (PIT) |  |  |  |  |  |  |
| 265 | 1.3.6.3.2.4.1 | Test readiness reporting |  | 31d | 2023-07-21 A | 2023-09-01 A | 262FS+9d | 100% | 2023-07-21 | 2023-09-01 | 51d | 2023-07-21 | 2023-09-29 |  |  | SI Test | 109 | DBT | 5.0 |  | Design, Build & Test (PIT) | Complete | COMPLETE |  |  |  |  |
| 266 | 1.3.6.3.2.5 | **Requirements to test Traceability Matrix (RTTM)** |  | 18d | 2023-08-04 A | 2023-08-30 A |  | 100% | 2023-08-04 | 2023-08-30 | 210d | 2022-10-31 | 2023-08-18 |  |  | N/A | N/A | DBT | 5.0 | N/A | Design, Build & Test (PIT) |  |  |  |  |  |  |
| 267 | 1.3.6.3.2.5.1 | DIP RTTM submitted to Programme for assurance | milestone | 0d | 2023-08-04 A | 2023-08-04 A | 262FS+15d | 100% | 2023-08-04 | 2023-08-04 | 0d | 2023-08-04 | 2023-08-04 |  |  | PP | SI Test | DBT | 5.6 |  | Design, Build & Test (PIT) | Complete | COMPLETE | MHHS-ART009 | T3-DB-0034 | SITAG | T3 |
| 268 | 1.3.6.3.2.5.2 | DIP RTTM MHHS Review Completed | milestone | 0d | 2023-08-30 A | 2023-08-30 A | 267FS+18d | 100% | 2023-08-30 | 2023-08-30 | 10d | 2023-08-07 | 2023-08-18 |  |  | SI Test | PP | DBT | 5.0 |  | Design, Build & Test (PIT) | Complete | COMPLETE |  |  |  |  |
| 269 | 1.3.6.3.2.6 | **Test Scenarios** |  | 22d | 2023-07-31 A | 2023-08-30 A |  | 100% | 2023-07-31 | 2023-08-30 | 206d | 2022-10-31 | 2023-08-18 |  |  | N/A | N/A | DBT | 5.0 | N/A | Design, Build & Test (PIT) |  |  |  |  |  |  |
| 270 | 1.3.6.3.2.6.1 | DIP PIT test scenarios submitted to Programme for assurance | milestone | 0d | 2023-07-31 A | 2023-07-31 A | 262FS+15d | 100% | 2023-07-31 | 2023-07-31 | 0d | 2023-08-04 | 2023-08-04 |  |  | PP | SI Test | DBT | 5.0 |  | Design, Build & Test (PIT) | Complete | COMPLETE |  | T3-DB-0036 | SITAG | T3 |
| 271 | 1.3.6.3.2.6.2 | DIP Test scenarios MHHS Review Completed | milestone | 0d | 2023-08-30 A | 2023-08-30 A | 270FS+22d | 100% | 2023-08-30 | 2023-08-30 | 10d | 2023-08-07 | 2023-08-18 |  |  | SI Test | PP | DBT | 5.0 |  | Design, Build & Test (PIT) | Complete | COMPLETE |  |  |  |  |
| 272 | 1.3.6.3.2.7 | **PIT execution** |  | 50d | 2023-08-29 A | 2023-11-06 A |  | 100% | 2023-08-29 | 2023-11-06 | 47d | 2022-10-31 | 2023-09-29 |  | -0 | N/A | N/A | DBT | 5.0 | N/A | Design, Build & Test (PIT) |  |  |  |  |  |  |
| 273 | 1.3.6.3.2.7.1 | PIT Test Execution Progress Report |  | 37d | 2023-09-01 A | 2023-10-23 A | 274FF, 265 | 100% | 2023-09-01 | 2023-10-23 | 37d | 2022-10-31 | 2023-09-22 | start no earlier than 2023-08-29 |  | PP | SI Test | DBT | 5.6 |  | Design, Build & Test (PIT) | Complete | COMPLETE |  |  |  |  |
| 274 | 1.3.6.3.2.7.2 | PIT Execution (Interim Release 1) |  | 30d | 2023-08-29 A | 2023-10-09 A |  | 100% | 2023-08-29 | 2023-10-09 | 24d | 2022-10-31 | 2023-09-29 | start no earlier than 2023-08-29 |  | PP | SI Test | DBT | 5.6 |  | Design, Build & Test (PIT) | Complete | COMPLETE |  |  |  |  |
| 275 | 1.3.6.3.2.7.3 | PIT Execution (Interim Release 2) |  | 10d | 2023-10-10 A | 2023-10-23 A | 274 | 100% | 2023-10-10 | 2023-10-23 | 10d |  |  |  |  | PP | SI Test | DBT | 5.6 |  | Design, Build & Test (PIT) | Complete | COMPLETE |  |  |  |  |
| 276 | 1.3.6.3.2.7.4 | DIP PIT Completion Report (Interim Release 1) submitted to Programme for assurance | milestone | 0d | 2023-10-09 A | 2023-10-09 A | 274 | 100% | 2023-10-09 | 2023-10-09 | 0d | 2024-01-05 | 2024-01-05 |  |  | PP | SI Test | DBT | 5.8 |  | Design, Build & Test (PIT) | Complete | COMPLETE |  | T3-DB-0111 | SITAG | T3 |
| 277 | 1.3.6.3.2.7.5 | DIP PIT Completion Report (Interim Release 1) MHHS Review Completed | milestone | 0d | 2023-10-23 A | 2023-10-23 A | 276FS+10d | 100% | 2023-10-23 | 2023-10-23 | 0d |  |  |  |  | SI Test | SI Test | DBT | 5.10 |  | Design, Build & Test (PIT) | Complete | COMPLETE |  | T3-DB-0112 | SITAG | T3 |
| 278 | 1.3.6.3.2.7.6 | DIP PIT Completion Report (Interim Release 2) submitted to Programme for assurance | milestone | 0d | 2023-10-23 A | 2023-10-23 A | 275, 273 | 100% | 2023-10-23 | 2023-10-23 | 0d | 2024-01-05 | 2024-01-05 |  |  | PP | SI Test | DBT | 5.10 |  | Design, Build & Test (PIT) | Complete | COMPLETE |  | T3-DB-0113 | SITAG | T3 |
| 279 | 1.3.6.3.2.7.7 | DIP PIT Completion Report (Interim Release 2) MHHS Review Completed | milestone | 0d | 2023-11-06 A | 2023-11-06 A | 278FS+10d | 100% | 2023-11-06 | 2023-11-06 | 0d |  |  |  |  | SI Test | SI Test | DBT | 5.14 |  | Design, Build & Test (PIT) | Complete | COMPLETE |  | T3-DB-0114 | SITAG | T3 |
| 280 | 1.3.6.3.3 | **DCC (DSP) DBT SIT Functional (Entering at SIT Functional)** |  | 325d | 2022-10-31 A | 2024-01-26 A |  | 100% | 2022-10-31 | 2024-01-26 | 345d | 2022-10-31 | 2024-01-05 |  | -0 | N/A | N/A | DBT | 5.18 | N/A | Design, Build & Test (PIT) |  |  |  |  |  |  |
| 281 | 1.3.6.3.3.1 | Design |  | 67d | 2022-10-31 A | 2023-01-31 A |  | 100% | 2022-10-31 | 2023-01-31 | 67d | 2022-10-31 | 2023-01-31 |  |  | PP | SI Design | DBT | 5.18 |  | Design, Build & Test (PIT) | Complete | COMPLETE |  |  |  |  |
| 282 | 1.3.6.3.3.2 | **Test Approach & Plan** |  | 20d | 2023-11-17 A | 2023-12-15 A |  | 100% | 2023-11-17 | 2023-12-15 | 20d | 2022-10-31 | 2023-10-27 |  | -0 | N/A | N/A | DBT | 5.18 | N/A | Design, Build & Test (PIT) |  |  |  |  |  |  |
| 283 | 1.3.6.3.3.2.1 | DCC Test Approach & Plan (PIT) submitted to Programme for assurance | milestone | 0d | 2023-11-17 A | 2023-11-17 A | 281FS+208d | 100% | 2023-11-17 | 2023-11-17 | 0d | 2023-10-13 | 2023-10-13 |  |  | PP | SI Test | DBT | 5.18 |  | Design, Build & Test (PIT) | Complete | COMPLETE |  | T3-DB-0068 | SITAG | T3 |
| 284 | 1.3.6.3.3.2.2 | DCC Test Approach & Plan (PIT) MHHS Review Completed | milestone | 0d | 2023-12-15 A | 2023-12-15 A | 283FS+20d | 100% | 2023-12-15 | 2023-12-15 | 0d | 2023-10-16 | 2023-10-27 |  |  | SI Test | PP | DBT | 5.18 |  | Design, Build & Test (PIT) | Complete | COMPLETE |  | T3-DB-0115 | SITAG | T3 |
| 285 | 1.3.6.3.3.3 | **Test Readiness Report** |  | 22d | 2023-12-04 A | 2024-01-02 A |  | 100% | 2023-12-04 | 2024-01-02 | 51d | 2023-10-27 | 2024-01-05 |  |  | N/A | N/A | DBT | 5.18 | N/A | Design, Build & Test (PIT) |  |  |  |  |  |  |
| 286 | 1.3.6.3.3.3.1 | Test readiness reporting |  | 22d | 2023-12-04 A | 2024-01-02 A | 283FS+10d | 100% | 2023-12-04 | 2024-01-02 | 51d | 2023-10-27 | 2024-01-05 |  |  | PP | 109 | DBT | 5.18 |  | Design, Build & Test (PIT) | Complete | COMPLETE |  |  |  |  |
| 287 | 1.3.6.3.3.4 | **Requirements to test Traceability Matrix (RTTM)** |  | 30d | 2023-12-15 A | 2024-01-26 A |  | 100% | 2023-12-15 | 2024-01-26 | 30d | 2022-10-31 | 2023-11-24 |  | -0 | N/A | N/A | DBT | 5.18 | N/A | Design, Build & Test (PIT) |  |  |  |  |  |  |
| 288 | 1.3.6.3.3.4.1 | DCC RTTM submitted to Programme for assurance | milestone | 0d | 2023-12-15 A | 2023-12-15 A | 283FS+20d | 100% | 2023-12-15 | 2023-12-15 | 0d | 2023-11-10 | 2023-11-10 | start no earlier than 2023-04-28 |  | PP | SI Test | DBT | 5.18 |  | Design, Build & Test (PIT) | Complete | COMPLETE |  | T3-DB-0074 | SITAG | T3 |
| 289 | 1.3.6.3.3.4.2 | DCC RTTM MHHS Review Completed | milestone | 0d | 2024-01-26 A | 2024-01-26 A | 288FS+30d | 100% | 2024-01-26 | 2024-01-26 | 0d | 2023-11-13 | 2023-11-24 |  |  | SI Test | PP | DBT | 5.18 |  | Design, Build & Test (PIT) | Complete | COMPLETE |  | T3-DB-0116 | SITAG | T3 |

Notes:
- 265: Action: 14/8 - Query from RG - IS this an SI Test deliverable or expected to be a DIP deliverable if so be more specific
- 279: Guidance: 6/10 - LC - Successor should be SIT Component Integration Testing 1 Preparation Complete but not linked as DIP test completion plus 10 day review breaks logic. Decision will be made to proceed without a conclusion of the report review

| ID | WBS | Task | Type | Duration | Start | Finish | Predecessors | Complete | Baseline start | Baseline finish | Baseline duration | Baseline 1 start | Baseline 1 finish | Constraint | Baseline cost | Responsible | Involved | Text9 | Update Version | MHHS Resource Name | MHHS Programme Phase | Sched Status | RAG | Milestone ID | Text29 | Tier | Artefact ID |
| --- | --- | --- | --- | --- | --- | --- | --- | --- | --- | --- | --- | --- | --- | --- | --- | --- | --- | --- | --- | --- | --- | --- | --- | --- | --- | --- | --- |
| 290 | 1.3.6.3.3.5 | **Test Scenarios** |  | 30d | 2023-12-15 A | 2024-01-26 A |  | 100% | 2023-12-15 | 2024-01-26 | 30d | 2022-10-31 | 2023-11-24 |  | -0 | N/A | N/A | DBT | 5.18 | N/A | Design, Build & Test (PIT) |  |  |  |  |  |  |
| 291 | 1.3.6.3.3.5.1 | DCC test scenarios submitted to Programme for assurance | milestone | 0d | 2023-12-15 A | 2023-12-15 A | 283FS+20d | 100% | 2023-12-15 | 2023-12-15 | 0d | 2023-11-10 | 2023-11-10 |  |  | PP | SI Test | DBT | 5.18 |  | Design, Build & Test (PIT) | Complete | COMPLETE | T3-DB-0078 | SITAG | T3 |  |
| 292 | 1.3.6.3.3.5.2 | DCC Test Scenarios MHHS Review Completed | milestone | 0d | 2024-01-26 A | 2024-01-26 A | 291FS+30d | 100% | 2024-01-26 | 2024-01-26 | 0d | 2023-11-13 | 2023-11-24 |  |  | SI Test | PP | DBT | 5.18 |  | Design, Build & Test (PIT) | Complete | COMPLETE | T3-DB-0117 | SITAG | T3 |  |
| 293 | 1.3.6.3.4 | **RECCo (EES) DBT CIT (Entering at Interval 6)** |  | 71d | 2023-10-13 A | 2024-01-19 A |  | 100% | 2023-10-13 | 2024-01-19 | 320d | 2022-10-31 | 2024-01-05 |  | -0 | N/A | N/A | DBT | 5.0 | N/A | Design, Build & Test (PIT) |  |  |  |  |  |  |
| 294 | 1.3.6.3.4.1 | **Test Approach & Plan** |  | 20d | 2023-10-13 A | 2023-11-09 A |  | 100% | 2023-10-13 | 2023-11-09 | 20d | 2022-10-31 | 2023-10-27 |  | -0 | N/A | N/A | DBT | 5.0 | N/A | Design, Build & Test (PIT) |  |  |  |  |  |  |
| 295 | 1.3.6.3.4.1.1 | EES Test Approach & Plan (PIT) submitted to Programme for assurance | milestone | 0d | 2023-10-13 A | 2023-10-13 A |  | 100% | 2023-10-13 | 2023-10-13 | 0d | 2023-10-13 | 2023-10-13 | start no earlier than 2023-10-13 |  | PP | SI Test | DBT | 5.8 |  | Design, Build & Test (PIT) | Complete | COMPLETE | T3-DB-0066 | SITAG | T3 |  |
| 296 | 1.3.6.3.4.1.2 | EES Test approach and plan (PIT) MHHS Review Completed | milestone | 0d | 2023-11-09 A | 2023-11-09 A | 295FS+20d | 100% | 2023-11-09 | 2023-11-09 | 0d | 2023-10-16 | 2023-10-27 |  |  | SI Test | PP | DBT | 5.8 |  | Design, Build & Test (PIT) | Complete | COMPLETE | T3-DB-0119 | SITAG | T3 |  |
| 297 | 1.3.6.3.4.2 | **Test Readiness Report** |  | 10d | 2023-10-27 A | 2023-11-09 A |  | 100% | 2023-10-27 | 2023-11-09 | 51d | 2023-10-27 | 2024-01-05 |  |  | N/A | N/A | DBT | 5.0 | N/A | Design, Build & Test (PIT) |  |  |  |  |  |  |
| 298 | 1.3.6.3.4.2.1 | Test readiness reporting |  | 10d | 2023-10-27 A | 2023-11-09 A | 295FS+10d | 100% | 2023-10-27 | 2023-11-09 | 51d | 2023-10-27 | 2024-01-05 |  |  | PP | 109 | DBT | 5.0 |  | Design, Build & Test (PIT) | Complete | COMPLETE |  |  |  |  |
| 299 | 1.3.6.3.4.3 | **Requirements to test Traceability Matrix (RTTM)** |  | 20d | 2023-11-02 A | 2023-11-30 A |  | 100% | 2023-11-02 | 2023-11-30 | 20d | 2022-10-31 | 2023-11-24 |  | -0 | N/A | N/A | DBT | 5.0 | N/A | Design, Build & Test (PIT) |  |  |  |  |  |  |
| 300 | 1.3.6.3.4.3.1 | EES RTTM submitted to Programme for assurance | milestone | 0d | 2023-11-02 A | 2023-11-02 A | 295FS+15d | 100% | 2023-11-02 | 2023-11-02 | 0d | 2023-11-10 | 2023-11-10 |  |  | PP | SI Test | DBT | 5.8 |  | Design, Build & Test (PIT) | Complete | COMPLETE | T3-DB-0072 | SITAG | T3 | MHHS-ART009 |
| 301 | 1.3.6.3.4.3.2 | EES RTTM MHHS Review Completed | milestone | 0d | 2023-11-30 A | 2023-11-30 A | 300FS+20d | 100% | 2023-11-30 | 2023-11-30 | 0d | 2023-11-13 | 2023-11-24 |  |  | SI Test | PP | DBT | 5.14 |  | Design, Build & Test (PIT) | Complete | COMPLETE | T3-DB-0120 | SITAG | T3 |  |
| 302 | 1.3.6.3.4.4 | **Test Scenarios** |  | 20d | 2023-11-02 A | 2023-11-30 A |  | 100% | 2023-11-02 | 2023-11-30 | 20d | 2022-10-31 | 2023-11-24 |  | -0 | N/A | N/A | DBT | 5.0 | N/A | Design, Build & Test (PIT) |  |  |  |  |  |  |
| 303 | 1.3.6.3.4.4.1 | EES test scenarios submitted to Programme for assurance | milestone | 0d | 2023-11-02 A | 2023-11-02 A | 295FS+15d | 100% | 2023-11-02 | 2023-11-02 | 0d | 2023-11-10 | 2023-11-10 |  |  | PP | SI Test | DBT | 5.8 |  | Design, Build & Test (PIT) | Complete | COMPLETE | T3-DB-0031 | SITAG | T3 |  |
| 304 | 1.3.6.3.4.4.2 | EES Test scenarios MHHS Review Completed | milestone | 0d | 2023-11-30 A | 2023-11-30 A | 303FS+20d | 100% | 2023-11-30 | 2023-11-30 | 0d | 2023-11-13 | 2023-11-24 |  |  | SI Test | PP | DBT | 5.14 |  | Design, Build & Test (PIT) | Complete | COMPLETE | T3-DB-0121 | SITAG | T3 |  |
| 305 | 1.3.6.3.4.5 | **PIT execution** |  | 51d | 2023-11-10 A | 2024-01-19 A |  | 100% | 2023-11-10 | 2024-01-19 | 320d | 2022-10-31 | 2024-01-05 |  | -0 | N/A | N/A | DBT | 5.0 | N/A | Design, Build & Test (PIT) |  |  |  |  |  |  |
| 306 | 1.3.6.3.4.5.1 | PIT Test Execution Progress Report |  | 41d | 2023-11-10 A | 2024-01-05 A | 298 | 100% | 2023-11-10 | 2024-01-05 | 41d | 2022-10-31 | 2023-12-29 |  |  | PP | SI Test | DBT | 5.0 |  | Design, Build & Test (PIT) | Complete | COMPLETE |  |  |  |  |
| 307 | 1.3.6.3.4.5.2 | PIT Execution |  | 41d | 2023-11-10 A | 2024-01-05 A | 303FS+5d | 100% | 2023-11-10 | 2024-01-05 | 310d | 2022-10-31 | 2024-01-05 |  |  | PP | SI Test | DBT | 5.0 |  | Design, Build & Test (PIT) | Complete | COMPLETE |  |  |  |  |
| 308 | 1.3.6.3.4.5.3 | EES PIT Completion Report submitted to Programme for assurance | milestone | 0d | 2024-01-05 A | 2024-01-05 A | 306, 307 | 100% | 2024-01-05 | 2024-01-05 | 0d | 2024-01-05 | 2024-01-05 |  |  | PP | SI Test | DBT | 5.14 |  | Design, Build & Test (PIT) | Complete | COMPLETE | T3-DB-0122 | SITAG | T3 |  |
| 309 | 1.3.6.3.4.5.4 | EES PIT Completion Report MHHS Review Completed | milestone | 0d | 2024-01-19 A | 2024-01-19 A | 296, 301, 304, 308FS+10d | 100% | 2024-01-19 | 2024-01-19 | 0d |  |  |  |  | SI Test | PP | DBT | 5.14 |  | Design, Build & Test (PIT) | Complete | COMPLETE | T3-DB-0123 | SITAG | T3 |  |
| 310 | 1.3.6.3.5 | **Registration Services DBT CIT (Entering at Interval 2)** |  | 70d | 2023-07-28 A | 2023-11-03 A |  | 100% | 2023-07-28 | 2023-11-03 | 70d | 2022-10-31 | 2024-02-28 |  | -0 | N/A | N/A | DBT | 5.0 | N/A | Design, Build & Test (PIT) |  |  |  |  |  |  |
| 311 | 1.3.6.3.5.1 | **Test Approach & Plan** |  | 40d | 2023-07-28 A | 2023-09-22 A |  | 100% | 2023-07-28 | 2023-09-22 | 40d | 2022-10-31 | 2023-08-11 |  | -0 | N/A | N/A | DBT | 5.0 | N/A | Design, Build & Test (PIT) |  |  |  |  |  |  |
| 312 | 1.3.6.3.5.1.1 | Registration Services Test Approach & Plan (PIT) submitted to Programme for assurance | milestone | 0d | 2023-07-28 A | 2023-07-28 A |  | 100% | 2023-07-28 | 2023-07-28 | 0d | 2023-07-28 | 2023-07-28 |  |  | PP | SI Test | DBT | 5.0 |  | Design, Build & Test (PIT) | Complete | COMPLETE | T3-DB-0028 | SITAG | T3 | MHHS-ART073 |
| 313 | 1.3.6.3.5.1.2 | Registration Services Test approach and plan MHHS Review Completed | milestone | 0d | 2023-09-22 A | 2023-09-22 A | 312FS+40d | 100% | 2023-09-22 | 2023-09-22 | 0d | 2023-07-31 | 2023-08-11 |  |  | SI Test | PP | DBT | 5.8 |  | Design, Build & Test (PIT) | Complete | COMPLETE | T3-DB-0124 | SITAG | T3 |  |

| ID | WBS | Task | Type | Duration | Start | Finish | Predecessors | Complete | Remaining | Baseline start | Baseline finish | Baseline duration | Baseline 1 start | Baseline 1 finish | Total slack | Constraint | Baseline cost | Responsible | Involved | Text9 | Update Version | MHHS Resource Name | MHHS Programme Phase | Sched Status | RAG | Artefact ID | Milestone ID | Text29 | Tier |
| --- | --- | --- | --- | --- | --- | --- | --- | --- | --- | --- | --- | --- | --- | --- | --- | --- | --- | --- | --- | --- | --- | --- | --- | --- | --- | --- | --- | --- | --- |
| 314 | 1.3.6.3.5.2 | **Test Readiness Report** |  | 20d | 2023-08-14 A | 2023-09-08 A |  | 100% |  | 2023-08-14 | 2023-09-08 | 51d | 2023-08-11 | 2023-10-20 |  |  |  | N/A | N/A | DBT | 5.0 | N/A | Design, Build & Test (PIT) |  |  |  |  |  |  |
| 315 | 1.3.6.3.5.2.1 | Test readiness reporting |  | 20d | 2023-08-14 A | 2023-09-08 A | 312FS+10d | 100% |  | 2023-08-14 | 2023-09-08 | 51d | 2023-08-11 | 2023-10-20 |  |  |  | PP | 109 | DBT | 5.0 |  | Design, Build & Test (PIT) | Complete | COMPLETE |  |  |  |  |
| 316 | 1.3.6.3.5.3 | **Requirements to test Traceability Matrix (RTTM)** |  | 20d | 2023-09-01 A | 2023-09-29 A |  | 100% |  | 2023-09-01 | 2023-09-29 | 20d | 2022-10-31 | 2023-09-15 |  |  | -0 | N/A | N/A | DBT | 5.0 | N/A | Design, Build & Test (PIT) |  |  |  |  |  |  |
| 317 | 1.3.6.3.5.3.1 | Registration Services RTTM submitted to Programme for assurance | milestone | 0d | 2023-09-01 A | 2023-09-01 A | 312FS+15d | 100% |  | 2023-09-01 | 2023-09-01 | 0d | 2023-09-01 | 2023-09-01 |  | start no earlier than 2023-04-28 |  | PP | SI Test | DBT | 5.6 |  | Design, Build & Test (PIT) | Complete | COMPLETE | MHHS-ART009 | T3-DB-0042 | SITAG | T3 |
| 318 | 1.3.6.3.5.3.2 | Registration Services RTTM MHHS Review Completed | milestone | 0d | 2023-09-29 A | 2023-09-29 A | 317FS+20d | 100% |  | 2023-09-29 | 2023-09-29 | 0d | 2023-09-04 | 2023-09-15 |  |  |  | SI Test | PP | DBT | 5.8 |  | Design, Build & Test (PIT) | Complete | COMPLETE |  | T3-DB-0125 | SITAG | T3 |
| 319 | 1.3.6.3.5.4 | **Test Scenarios** |  | 20d | 2023-09-01 A | 2023-09-29 A |  | 100% |  | 2023-09-01 | 2023-09-29 | 20d | 2022-10-31 | 2023-09-15 |  |  | -0 | N/A | N/A | DBT | 5.0 | N/A | Design, Build & Test (PIT) |  |  |  |  |  |  |
| 320 | 1.3.6.3.5.4.1 | Registration Services test scenarios submitted to Programme for assurance | milestone | 0d | 2023-09-01 A | 2023-09-01 A | 312FS+15d | 100% |  | 2023-09-01 | 2023-09-01 | 0d | 2023-09-01 | 2023-09-01 |  |  |  | PP | SI Test | DBT | 5.6 |  | Design, Build & Test (PIT) | Complete | COMPLETE |  | T3-DB-0044 | SITAG | T3 |
| 321 | 1.3.6.3.5.4.2 | Registration Services Test scenarios MHHS Review Completed | milestone | 0d | 2023-09-29 A | 2023-09-29 A | 320FS+20d | 100% |  | 2023-09-29 | 2023-09-29 | 0d | 2023-09-04 | 2023-09-15 |  |  |  | SI Test | PP | DBT | 5.8 |  | Design, Build & Test (PIT) | Complete | COMPLETE |  | T3-DB-0126 | SITAG | T3 |
| 322 | 1.3.6.3.5.5 | **PIT execution** |  | 40d | 2023-09-11 A | 2023-11-03 A |  | 100% |  | 2023-09-11 | 2023-11-03 | 40d | 2023-01-02 | 2023-10-20 |  |  | -0 | N/A | N/A | DBT | 5.0 | N/A | Design, Build & Test (PIT) |  |  |  |  |  |  |
| 323 | 1.3.6.3.5.5.1 | PIT Test Execution Progress Report |  | 33d | 2023-09-11 A | 2023-10-25 A | 315 | 100% |  | 2023-09-11 | 2023-10-25 | 30d | 2023-01-02 | 2023-10-13 |  |  |  | PP | SI Test | DBT | 5.0 |  | Design, Build & Test (PIT) | Complete | COMPLETE |  |  |  |  |
| 324 | 1.3.6.3.5.5.2 | PIT Execution |  | 30d | 2023-09-11 A | 2023-10-20 A | 320FS+5d | 100% |  | 2023-09-11 | 2023-10-20 | 30d | 2023-01-16 | 2023-10-20 |  |  |  | PP | SI Test | DBT | 5.0 |  | Design, Build & Test (PIT) | Complete | COMPLETE |  |  |  |  |
| 325 | 1.3.6.3.5.5.3 | Registration Services PIT (CIT interval 2) Completion Report submitted to Programme for assurance | milestone | 0d | 2023-10-25 A | 2023-10-25 A | 323, 324 | 100% |  | 2023-10-25 | 2023-10-25 | 0d | 2024-01-05 | 2024-01-05 |  |  |  | PP | SI Test | DBT | 5.10 |  | Design, Build & Test (PIT) | Complete | COMPLETE |  | T3-DB-0127 | SITAG | T3 |
| 326 | 1.3.6.3.5.5.4 | Registration Services PIT (CIT interval 2) Completion Report MHHS Review Completed | milestone | 0d | 2023-11-03 A | 2023-11-03 A | 313, 318, 321, 325FS+7d | 100% |  | 2023-11-03 | 2023-11-03 | 0d |  |  |  |  |  | SI Test | PP | DBT | 5.11 |  | Design, Build & Test (PIT) | Complete | COMPLETE |  | T3-DB-0128 | SITAG | T3 |
| 327 | 1.3.6.4 | **SIT Participants DBT** |  | 401d | 2023-08-11 A | 2025-02-21 |  | 89% | 45.03d | 2023-08-11 | 2024-12-20 | 495d | 2022-10-31 | 2025-03-14 | 739d |  | -0 | N/A | N/A | DBT | 5.0 | N/A | Design, Build & Test (PIT) |  |  |  |  |  |  |
| 328 | 1.3.6.4.1 | **All Data Services DBT CIT (Entering at Interval 3)** |  | 71d | 2023-08-11 A | 2023-11-17 A |  | 100% |  | 2023-08-11 | 2023-11-17 | 275d | 2022-10-31 | 2023-11-03 |  |  | -0 | N/A | N/A | DBT | 5.0 | N/A | Design, Build & Test (PIT) |  |  |  |  |  |  |
| 329 | 1.3.6.4.1.1 | **Test Approach & Plan** |  | 30d | 2023-08-11 A | 2023-09-21 A |  | 100% |  | 2023-08-11 | 2023-09-21 | 29d | 2022-10-31 | 2023-08-25 |  |  | -0 | N/A | N/A | DBT | 5.0 | N/A | Design, Build & Test (PIT) |  |  |  |  |  |  |
| 330 | 1.3.6.4.1.1.1 | All Data Services Test Approach & Plans (PIT) submitted to Programme for assurance | milestone | 0d | 2023-08-11 A | 2023-08-11 A |  | 100% |  | 2023-08-11 | 2023-08-11 | 0d | 2023-08-11 | 2023-08-11 |  | start no earlier than 2023-08-11 |  | PP | SI Test | DBT | 5.0 |  | Design, Build & Test (PIT) | Complete | COMPLETE |  | T3-DB-0038 | SITAG | T3 |
| 331 | 1.3.6.4.1.1.2 | All Data Services Test approach and plans MHHS Review Completed | milestone | 0d | 2023-09-21 A | 2023-09-21 A | 330FS+30d | 100% |  | 2023-09-21 | 2023-09-21 | 0d | 2023-08-14 | 2023-08-25 |  |  |  | SI Test | PP | DBT | 5.11 |  | Design, Build & Test (PIT) | Complete | COMPLETE |  | T3-DB-0129 | SITAG | T3 |
| 332 | 1.3.6.4.1.2 | **Test Readiness Report** |  | 11d | 2023-08-25 A | 2023-09-08 A |  | 100% |  | 2023-08-25 | 2023-09-08 | 11d | 2023-08-25 | 2023-11-03 |  |  | -0 | N/A | N/A | DBT | 5.0 | N/A | Design, Build & Test (PIT) |  |  |  |  |  |  |
| 333 | 1.3.6.4.1.2.1 | Test readiness reporting |  | 11d | 2023-08-25 A | 2023-09-08 A | 330FS+10d | 100% |  | 2023-08-25 | 2023-09-08 | 11d | 2023-08-25 | 2023-11-03 |  |  |  | PP | 109 | DBT | 5.0 |  | Design, Build & Test (PIT) | Complete | COMPLETE |  |  |  |  |
| 334 | 1.3.6.4.1.3 | **Requirements to test Traceability Matrix (RTTM)** |  | 7d | 2023-09-20 A | 2023-09-29 A |  | 100% |  | 2023-09-20 | 2023-09-29 | 5d | 2022-10-31 | 2023-10-06 |  |  | -0 | N/A | N/A | DBT | 5.0 | N/A | Design, Build & Test (PIT) |  |  |  |  |  |  |
| 335 | 1.3.6.4.1.3.1 | All Data Services RTTMs submitted to Programme for assurance | milestone | 0d | 2023-09-20 A | 2023-09-20 A | 330FS+29d | 100% |  | 2023-09-20 | 2023-09-20 | 0d | 2023-09-22 | 2023-09-22 |  |  |  | PP | SI Test | DBT | 5.7 |  | Design, Build & Test (PIT) | Complete | COMPLETE |  | T3-DB-0058 | SITAG | T3 |
| 336 | 1.3.6.4.1.3.2 | All Data Services RTTMs MHHS Review Completed | milestone | 0d | 2023-09-29 A | 2023-09-29 A | 335FS+7d | 100% |  | 2023-09-29 | 2023-09-29 | 0d | 2023-09-25 | 2023-10-06 |  |  |  | SI Test | PP | DBT | 5.8 |  | Design, Build & Test (PIT) | Complete | COMPLETE |  | T3-DB-0130 | SITAG | T3 |
| 337 | 1.3.6.4.1.4 | **Test Scenarios** |  | 6d | 2023-09-20 A | 2023-09-28 A |  | 100% |  | 2023-09-20 | 2023-09-28 | 4d | 2022-10-31 | 2023-10-06 |  |  | -0 | N/A | N/A | DBT | 5.0 | N/A | Design, Build & Test (PIT) |  |  |  |  |  |  |
| 338 | 1.3.6.4.1.4.1 | All Data Services test scenarios' submitted to Programme for assurance | milestone | 0d | 2023-09-20 A | 2023-09-20 A | 330FS+29d | 100% |  | 2023-09-20 | 2023-09-20 | 0d | 2023-09-22 | 2023-09-22 |  |  |  | PP | SI Test | DBT | 5.7 |  | Design, Build & Test (PIT) | Complete | COMPLETE |  | T3-DB-0056 | SITAG | T3 |
| 339 | 1.3.6.4.1.4.2 | All Data Services Test scenarios' MHHS Review Completed | milestone | 0d | 2023-09-28 A | 2023-09-28 A | 338FS+6d | 100% |  | 2023-09-28 | 2023-09-28 | 0d | 2023-09-25 | 2023-10-06 |  |  |  | SI Test | PP | DBT | 5.11 |  | Design, Build & Test (PIT) | Complete | COMPLETE |  | T3-DB-0131 | SITAG | T3 |

| ID | WBS | Task | Type | Duration | Start | Finish | Predecessors | Complete | Remaining | Baseline start | Baseline finish | Baseline duration | Baseline 1 start | Baseline 1 finish | Total slack | Constraint | Baseline cost | Responsible | Involved | Text9 | Update Version | MHHS Resource Name | MHHS Programme Phase | Sched Status | RAG | Milestone ID | Text29 | Tier | Artefact ID |
| --- | --- | --- | --- | --- | --- | --- | --- | --- | --- | --- | --- | --- | --- | --- | --- | --- | --- | --- | --- | --- | --- | --- | --- | --- | --- | --- | --- | --- | --- |
| 340 | 1.3.6.4.1.5 | **PIT execution** |  | 50d | 2023-09-11 A | 2023-11-17 A |  | 100% |  | 2023-09-11 | 2023-11-17 | 275d | 2022-10-31 | 2023-11-03 |  |  | -0 | N/A | N/A | DBT | 5.0 | N/A | Design, Build & Test (PIT) |  |  |  |  |  |  |
| 341 | 1.3.6.4.1.5.1 | PIT Test Execution Progress Report |  | 40d | 2023-09-11 A | 2023-11-03 A | 333 | 100% |  | 2023-09-11 | 2023-11-03 | 260d | 2022-10-31 | 2023-10-27 |  |  |  | PP | SI Test | DBT | 5.0 |  | Design, Build & Test (PIT) | Complete | COMPLETE |  |  |  |  |
| 342 | 1.3.6.4.1.5.2 | PIT Execution |  | 27d | 2023-09-28 A | 2023-11-03 A | 338FS+5d | 100% |  | 2023-09-28 | 2023-11-03 | 265d | 2022-10-31 | 2023-11-03 |  |  |  | PP | SI Test | DBT | 5.0 |  | Design, Build & Test (PIT) | Complete | COMPLETE |  |  |  |  |
| 343 | 1.3.6.4.1.5.3 | All Data Services PIT Completion Reports submitted to Programme for assurance | milestone | 0d | 2023-11-03 A | 2023-11-03 A | 341, 342 | 100% |  | 2023-11-03 | 2023-11-03 | 0d | 2024-01-05 | 2024-01-05 |  |  |  | PP | SI Test | DBT | 5.11 |  | Design, Build & Test (PIT) | Complete | COMPLETE | T3-DB-0132 | SITAG | T3 |  |
| 344 | 1.3.6.4.1.5.4 | All Data Services PIT Completion Reports MHHS Review Completed | milestone | 0d | 2023-11-17 A | 2023-11-17 A | 331, 336, 339, 343FS+10d | 100% |  | 2023-11-17 | 2023-11-17 | 0d |  |  |  |  |  | SI Test | PP | DBT | 5.13 |  | Design, Build & Test (PIT) | Complete | COMPLETE | T3-DB-0133 | SITAG | T3 |  |
| 345 | 1.3.6.4.2 | **All Metering Services DBT CIT (Entering at Interval 4)** |  | 70d | 2023-08-25 A | 2023-12-01 A |  | 100% |  | 2023-08-25 | 2023-12-01 | 285d | 2022-10-31 | 2023-11-17 |  |  | -0 | N/A | N/A | DBT | 5.0 | N/A | Design, Build & Test (PIT) |  |  |  |  |  |  |
| 346 | 1.3.6.4.2.1 | **Test Approach & Plan** |  | 40d | 2023-08-25 A | 2023-10-20 A |  | 100% |  | 2023-08-25 | 2023-10-20 | 40d | 2022-10-31 | 2023-09-08 |  |  | -0 | N/A | N/A | DBT | 5.0 | N/A | Design, Build & Test (PIT) |  |  |  |  |  |  |
| 347 | 1.3.6.4.2.1.1 | All Metering Services Test Approach & Plans (PIT) submitted to Programme for assurance | milestone | 0d | 2023-08-25 A | 2023-08-25 A |  | 100% |  | 2023-08-25 | 2023-08-25 | 0d | 2023-08-25 | 2023-08-25 |  |  |  | PP | SI Test | DBT | 5.6 |  | Design, Build & Test (PIT) | Complete | COMPLETE | T3-DB-0040 | SITAG | T3 |  |
| 348 | 1.3.6.4.2.1.2 | All Metering Services Test approach and plans MHHS Review Completed | milestone | 0d | 2023-10-20 A | 2023-10-20 A | 347FS+40d | 100% |  | 2023-10-20 | 2023-10-20 | 0d | 2023-08-28 | 2023-09-08 |  |  |  | SI Test | PP | DBT | 5.8 |  | Design, Build & Test (PIT) | Complete | COMPLETE | T3-DB-0134 | SITAG | T3 |  |
| 349 | 1.3.6.4.2.2 | **Test Readiness Report** |  | 11d | 2023-09-11 A | 2023-09-25 A |  | 100% |  | 2023-09-11 | 2023-09-25 | 51d | 2023-09-08 | 2023-11-17 |  |  |  | N/A | N/A | DBT | 5.0 | N/A | Design, Build & Test (PIT) |  |  |  |  |  |  |
| 350 | 1.3.6.4.2.2.1 | Test readiness reporting |  | 11d | 2023-09-11 A | 2023-09-25 A | 347FS+10d | 100% |  | 2023-09-11 | 2023-09-25 | 51d | 2023-09-08 | 2023-11-17 |  |  |  | PP | 109 | DBT | 5.0 |  | Design, Build & Test (PIT) | Complete | COMPLETE |  |  |  |  |
| 351 | 1.3.6.4.2.3 | **Requirements to test Traceability Matrix (RTTM)** |  | 30d | 2023-09-15 A | 2023-10-27 A |  | 100% |  | 2023-09-15 | 2023-10-27 | 30d | 2022-10-31 | 2023-09-29 |  |  | -0 | N/A | N/A | DBT | 5.0 | N/A | Design, Build & Test (PIT) |  |  |  |  |  |  |
| 352 | 1.3.6.4.2.3.1 | All Metering Services RTTMs submitted to Programme for assurance | milestone | 0d | 2023-09-15 A | 2023-09-15 A | 347FS+15d | 100% |  | 2023-09-15 | 2023-09-15 | 0d | 2023-09-15 | 2023-09-15 |  |  |  | PP | SI Test | DBT | 5.8 |  | Design, Build & Test (PIT) | Complete | COMPLETE | T3-DB-0048 | SITAG | T3 | MHHS-ART009 |
| 353 | 1.3.6.4.2.3.2 | All Metering Services MHHS Reviews Completed | milestone | 0d | 2023-10-27 A | 2023-10-27 A | 352FS+30d | 100% |  | 2023-10-27 | 2023-10-27 | 0d | 2023-09-18 | 2023-09-29 |  |  |  | SI Test | PP | DBT | 5.13 |  | Design, Build & Test (PIT) | Complete | COMPLETE | T3-DB-0135 | SITAG | T3 |  |
| 354 | 1.3.6.4.2.4 | **Test Scenarios** |  | 30d | 2023-09-15 A | 2023-10-27 A |  | 100% |  | 2023-09-15 | 2023-10-27 | 30d | 2022-10-31 | 2023-09-29 |  |  | -0 | N/A | N/A | DBT | 5.0 | N/A | Design, Build & Test (PIT) |  |  |  |  |  |  |
| 355 | 1.3.6.4.2.4.1 | All Metering Services test scenarios' submitted to Programme for assurance | milestone | 0d | 2023-09-15 A | 2023-09-15 A | 347FS+15d | 100% |  | 2023-09-15 | 2023-09-15 | 0d | 2023-09-15 | 2023-09-15 |  |  |  | PP | SI Test | DBT | 5.8 |  | Design, Build & Test (PIT) | Complete | COMPLETE | T3-DB-0050 | SITAG | T3 |  |
| 356 | 1.3.6.4.2.4.2 | All Metering Services Test scenarios' MHHS Review Completed | milestone | 0d | 2023-10-27 A | 2023-10-27 A | 355FS+30d | 100% |  | 2023-10-27 | 2023-10-27 | 0d | 2023-09-18 | 2023-09-29 |  |  |  | SI Test | PP | DBT | 5.13 |  | Design, Build & Test (PIT) | Complete | COMPLETE | T3-DB-0136 | SITAG | T3 |  |
| 357 | 1.3.6.4.2.5 | **PIT execution** |  | 50d | 2023-09-25 A | 2023-12-01 A |  | 100% |  | 2023-09-25 | 2023-12-01 | 285d | 2022-10-31 | 2023-11-17 |  |  | -0 | N/A | N/A | DBT | 5.0 | N/A | Design, Build & Test (PIT) |  |  |  |  |  |  |
| 358 | 1.3.6.4.2.5.1 | PIT Test Execution Progress Report |  | 39d | 2023-09-26 A | 2023-11-17 A | 350 | 100% |  | 2023-09-26 | 2023-11-17 | 39d | 2022-10-31 | 2023-11-10 |  |  |  | PP | SI Test | DBT | 5.0 |  | Design, Build & Test (PIT) | Complete | COMPLETE |  |  |  |  |
| 359 | 1.3.6.4.2.5.2 | PIT Execution |  | 40d | 2023-09-25 A | 2023-11-17 A | 355FS+5d | 100% |  | 2023-09-25 | 2023-11-17 | 275d | 2022-10-31 | 2023-11-17 |  |  |  | PP | SI Test | DBT | 5.0 |  | Design, Build & Test (PIT) | Complete | COMPLETE |  |  |  |  |
| 360 | 1.3.6.4.2.5.3 | All Metering Services PIT Completion Reports submitted to Programme for assurance | milestone | 0d | 2023-11-17 A | 2023-11-17 A | 358, 359 | 100% |  | 2023-11-17 | 2023-11-17 | 0d | 2024-01-05 | 2024-01-05 |  |  |  | PP | SI Test | DBT | 5.13 |  | Design, Build & Test (PIT) | Complete | COMPLETE | T3-DB-0137 | SITAG | T3 |  |
| 361 | 1.3.6.4.2.5.4 | All Metering Services PIT Completion Reports MHHS Review Completed | milestone | 0d | 2023-12-01 A | 2023-12-01 A | 348, 353, 356, 360FS+10d | 100% |  | 2023-12-01 | 2023-12-01 | 0d |  |  |  |  |  | SI Test | PP | DBT | 5.13 |  | Design, Build & Test (PIT) | Complete | COMPLETE | T3-DB-0138 | SITAG | T3 |  |
| 362 | 1.3.6.4.3 | **All SIT Programme Participants PIT (SIT Functional)** |  | 331d | 2023-11-17 A | 2025-02-21 |  | 78% | 71.76d | 2023-11-17 | 2024-12-20 | 451d | 2022-12-30 | 2024-02-16 | 739d |  | -0 | N/A | N/A | DBT | 5.0 | N/A | Design, Build & Test (PIT) |  |  |  |  |  |  |
| 363 | 1.3.6.4.3.1 | **Test Approach & Plans** |  | 40d | 2023-11-17 A | 2024-01-11 A |  | 100% |  | 2023-11-17 | 2024-01-11 | 40d | 2022-12-30 | 2023-11-30 |  |  | -0 | N/A | N/A | DBT | 5.2 | N/A | Design, Build & Test (PIT) |  |  |  |  |  |  |
| 364 | 1.3.6.4.3.1.1 | SIT Functional PIT Test Approach & Plan (PIT) submitted to Programme for assurance | milestone | 0d | 2023-11-17 A | 2023-11-17 A |  | 100% |  | 2023-11-17 | 2023-11-17 | 0d | 2023-11-16 | 2023-11-16 |  | start no earlier than 2023-11-17 |  | PP | SI Test | DBT | 5.16 |  | Design, Build & Test (PIT) | Complete | COMPLETE | T3-DB-0093 | SITAG | T3 |  |
| 365 | 1.3.6.4.3.1.2 | All SIT Functional Test approach and plans MHHS Reviews Completed | milestone | 0d | 2024-01-11 A | 2024-01-11 A | 364FS+40d | 100% |  | 2024-01-11 | 2024-01-11 | 0d | 2023-11-17 | 2023-11-30 |  |  |  | SI Test | PP | DBT | 5.8 |  | Design, Build & Test (PIT) | Complete | COMPLETE | T3-DB-0139 | SITAG | T3 |  |

| ID | WBS | Task | Type | Duration | Start | Finish | Predecessors | Complete | Baseline start | Baseline finish | Baseline duration | Baseline 1 start | Baseline 1 finish | Constraint | Baseline cost | Responsible | Involved | Text9 | Update Version | MHHS Resource Name | MHHS Programme Phase | Sched Status | RAG | Milestone ID | Text29 | Tier |
| --- | --- | --- | --- | --- | --- | --- | --- | --- | --- | --- | --- | --- | --- | --- | --- | --- | --- | --- | --- | --- | --- | --- | --- | --- | --- | --- |
| 366 | 1.3.6.4.3.2 | **Test Readiness Reports** |  | 11d | 2023-12-01 A | 2023-12-15 A |  | 100% | 2023-12-01 | 2023-12-15 | 51d | 2023-11-30 | 2024-02-08 |  |  | N/A | N/A | DBT | 5.2 | N/A | Design, Build & Test (PIT) |  |  |  |  |  |
| 367 | 1.3.6.4.3.2.1 | Test readiness reporting |  | 11d | 2023-12-01 A | 2023-12-15 A | 364FS+10d | 100% | 2023-12-01 | 2023-12-15 | 51d | 2023-11-30 | 2024-02-08 |  |  | PP | 109 | DBT | 5.2 |  | Design, Build & Test (PIT) | Complete | COMPLETE |  |  |  |
| 368 | 1.3.6.4.3.3 | **Requirements to test Traceability Matrices (RTTM)** |  | 30d | 2023-12-07 A | 2024-01-18 A |  | 100% | 2023-12-07 | 2024-01-18 | 30d | 2023-01-06 | 2024-01-05 |  | -0 | N/A | N/A | DBT | 5.2 | N/A | Design, Build & Test (PIT) |  |  |  |  |  |
| 369 | 1.3.6.4.3.3.1 | SIT Functional PIT RTTM submitted to Programme for assurance | milestone | 0d | 2023-12-07 A | 2023-12-07 A | 364FS+15d | 100% | 2023-12-07 | 2023-12-07 | 0d | 2023-12-14 | 2023-12-14 |  |  | PP | SI Test | DBT | 5.14 |  | Design, Build & Test (PIT) | Complete | COMPLETE | T3-DB-0091 | SITAG | T3 |
| 370 | 1.3.6.4.3.3.2 | All SIT Functional RTTMs MHHS Reviews Completed | milestone | 0d | 2024-01-18 A | 2024-01-18 A | 369FS+30d | 100% | 2024-01-18 | 2024-01-18 | 0d | 2023-12-15 | 2024-01-05 |  |  | SI Test | PP | DBT | 5.14 |  | Design, Build & Test (PIT) | Complete | COMPLETE | T3-DB-0140 | SITAG | T3 |
| 371 | 1.3.6.4.3.4 | **Test Scenarios** |  | 30d | 2023-12-07 A | 2024-01-18 A |  | 100% | 2023-12-07 | 2024-01-18 | 30d | 2023-01-06 | 2024-01-05 |  | -0 | N/A | N/A | DBT | 5.2 | N/A | Design, Build & Test (PIT) |  |  |  |  |  |
| 372 | 1.3.6.4.3.4.1 | SIT Functional PIT test scenarios submitted to Programme for assurance | milestone | 0d | 2023-12-07 A | 2023-12-07 A | 364FS+15d | 100% | 2023-12-07 | 2023-12-07 | 0d | 2023-12-14 | 2023-12-14 |  |  | PP | SI Test | DBT | 5.14 |  | Design, Build & Test (PIT) | Complete | COMPLETE | T3-DB-0089 | SITAG | T3 |
| 373 | 1.3.6.4.3.4.2 | All SIT Functional Test scenarios' MHHS Reviews Completed | milestone | 0d | 2024-01-18 A | 2024-01-18 A | 372FS+30d | 100% | 2024-01-18 | 2024-01-18 | 0d | 2023-12-15 | 2024-01-05 |  |  | SI Test | PP | DBT | 5.14 |  | Design, Build & Test (PIT) | Complete | COMPLETE | T3-DB-0141 | SITAG | T3 |
| 374 | 1.3.6.4.3.5 | **PIT execution** |  | 51d | 2023-12-15 A | 2024-02-23 A |  | 100% | 2023-12-15 | 2024-02-23 | 301d | 2022-12-30 | 2024-02-09 |  | -0 | N/A | N/A | DBT | 5.0 | N/A | Design, Build & Test (PIT) |  |  |  |  |  |
| 375 | 1.3.6.4.3.5.1 | PIT Test Execution Progress Reports |  | 40d | 2023-12-18 A | 2024-02-09 A | 367 | 100% | 2023-12-18 | 2024-02-09 | 40d | 2022-12-30 | 2024-02-01 |  |  | PP | SI Test | DBT | 5.0 |  | Design, Build & Test (PIT) | Complete | COMPLETE |  |  |  |
| 376 | 1.3.6.4.3.5.2 | PIT Execution |  | 41d | 2023-12-15 A | 2024-02-09 A | 372FS+5d | 100% | 2023-12-15 | 2024-02-09 | 290d | 2022-12-30 | 2024-02-09 |  |  | PP | SI Test | DBT | 5.0 |  | Design, Build & Test (PIT) | Complete | COMPLETE |  |  |  |
| 377 | 1.3.6.4.3.5.3 | All SIT Functional PIT Completion Reports submitted to Programme for Assurance | milestone | 0d | 2024-02-09 A | 2024-02-09 A | 375, 376 | 100% | 2024-02-09 | 2024-02-09 | 0d | 2024-01-05 | 2024-01-05 |  |  | PP | SI Test | DBT | 5.19 |  | Design, Build & Test (PIT) | Complete | COMPLETE | T3-DB-0087 | SITAG | T3 |
| 378 | 1.3.6.4.3.5.4 | All SIT Functional PIT Completion Reports MHHS Review Completed | milestone | 0d | 2024-02-23 A | 2024-02-23 A | 365, 370, 373, 377FS+10d | 100% | 2024-02-23 | 2024-02-23 | 0d |  |  |  |  | SI Test | PP | DBT | 5.19 |  | Design, Build & Test (PIT) | Complete | COMPLETE | T3-DB-0142 | SITAG | T3 |
| 379 | 1.3.6.4.3.6 | **All SIT Programme Participants PIT (SIT Migration)** |  | 71d | 2024-02-16 A | 2024-05-24 A |  | 100% | 2024-02-16 | 2024-05-24 | 301d |  |  |  | -0 | N/A | N/A | DBT | 5.1 | N/A | Design, Build & Test (PIT) |  |  |  |  |  |
| 380 | 1.3.6.4.3.6.1 | **Test Approach & Plans** |  | 40d | 2024-02-16 A | 2024-04-11 A |  | 100% | 2024-02-16 | 2024-04-11 | 40d |  |  |  | -0 | N/A | N/A | DBT | 5.2 | N/A | Design, Build & Test (PIT) |  |  |  |  |  |
| 381 | 1.3.6.4.3.6.1.1 | All SIT Migration PIT Test Approach & Plans submitted to Programme for assurance | milestone | 0d | 2024-02-16 A | 2024-02-16 A |  | 100% | 2024-02-16 | 2024-02-16 | 0d |  |  | start no earlier than 2024-02-16 |  | PP | SI Test | DBT | 5.8 |  | Design, Build & Test (PIT) | Complete | COMPLETE | T3-DB-0143 | SITAG | T3 |
| 382 | 1.3.6.4.3.6.1.2 | All SIT Migration PIT Test approach and plans MHHS Reviews Completed | milestone | 0d | 2024-04-11 A | 2024-04-11 A | 381FS+40d | 100% | 2024-04-11 | 2024-04-11 | 0d |  |  |  |  | SI Test | PP | DBT | 5.23 |  | Design, Build & Test (PIT) | Complete | COMPLETE | T3-DB-0144 | SITAG | T3 |
| 383 | 1.3.6.4.3.6.2 | **Test Readiness Reports** |  | 11d | 2024-03-01 A | 2024-03-15 A |  | 100% | 2024-03-01 | 2024-03-15 | 51d |  |  |  |  | N/A | N/A | DBT | 5.2 | N/A | Design, Build & Test (PIT) |  |  |  |  |  |
| 384 | 1.3.6.4.3.6.2.1 | Test readiness reporting |  | 11d | 2024-03-01 A | 2024-03-15 A | 381FS+10d | 100% | 2024-03-01 | 2024-03-15 | 51d |  |  |  |  | PP | 109 | DBT | 5.2 |  | Design, Build & Test (PIT) | Complete | COMPLETE |  |  |  |
| 385 | 1.3.6.4.3.6.3 | **Requirements to test Traceability Matrices (RTTM)** |  | 30d | 2024-03-07 A | 2024-04-18 A |  | 100% | 2024-03-07 | 2024-04-18 | 30d |  |  |  | -0 | N/A | N/A | DBT | 5.2 | N/A | Design, Build & Test (PIT) |  |  |  |  |  |
| 386 | 1.3.6.4.3.6.3.1 | All SIT Migration PIT RTTMs submitted to Programme for assurance | milestone | 0d | 2024-03-07 A | 2024-03-07 A | 381FS+15d | 100% | 2024-03-07 | 2024-03-07 | 0d |  |  |  |  | PP | SI Test | DBT | 5.23 |  | Design, Build & Test (PIT) | Complete | COMPLETE | T3-DB-0145 | SITAG | T3 |
| 387 | 1.3.6.4.3.6.3.2 | All SIT Migration RTTMs MHHS Reviews Completed | milestone | 0d | 2024-04-18 A | 2024-04-18 A | 386FS+30d | 100% | 2024-04-18 | 2024-04-18 | 0d |  |  |  |  | SI Test | PP | DBT | 5.25 |  | Design, Build & Test (PIT) | Complete | COMPLETE | T3-DB-0146 | SITAG | T3 |
| 388 | 1.3.6.4.3.6.4 | **Test Scenarios** |  | 30d | 2024-03-07 A | 2024-04-18 A |  | 100% | 2024-03-07 | 2024-04-18 | 30d |  |  |  | -0 | N/A | N/A | DBT | 5.2 | N/A | Design, Build & Test (PIT) |  |  |  |  |  |
| 389 | 1.3.6.4.3.6.4.1 | All SIT Migration PIT test scenarios submitted to Programme for assurance | milestone | 0d | 2024-03-07 A | 2024-03-07 A | 381FS+15d | 100% | 2024-03-07 | 2024-03-07 | 0d |  |  |  |  | PP | SI Test | DBT | 5.23 |  | Design, Build & Test (PIT) | Complete | COMPLETE | T3-DB-0147 | SITAG | T3 |
| 390 | 1.3.6.4.3.6.4.2 | All SIT Migration Test scenarios MHHS Reviews Completed | milestone | 0d | 2024-04-18 A | 2024-04-18 A | 389FS+30d | 100% | 2024-04-18 | 2024-04-18 | 0d |  |  |  |  | SI Test | PP | DBT | 5.25 |  | Design, Build & Test (PIT) | Complete | COMPLETE | T3-DB-0148 | SITAG | T3 |

| ID | WBS | Task | Type | Duration | Start | Finish | Predecessors | Complete | Remaining | Baseline start | Baseline finish | Baseline duration | Baseline 1 start | Baseline 1 finish | Total slack | Free slack | Constraint | Baseline cost | Responsible | Involved | Text9 | Update Version | MHHS Resource Name | MHHS Programme Phase | Sched Status | RAG | Milestone ID | Text29 | Tier | Guidance | Task Status |
| --- | --- | --- | --- | --- | --- | --- | --- | --- | --- | --- | --- | --- | --- | --- | --- | --- | --- | --- | --- | --- | --- | --- | --- | --- | --- | --- | --- | --- | --- | --- | --- |
| 391 | 1.3.6.4.3.6.5 | **PIT execution** |  | 51d | 2024-03-15 A | 2024-05-24 A |  | 100% |  | 2024-03-15 | 2024-05-24 | 301d |  |  |  |  |  | -0 | N/A | N/A | DBT | 5.1 | N/A | Design, Build & Test (PIT) |  |  |  |  |  |  |  |
| 392 | 1.3.6.4.3.6.5.1 | PIT Test Execution Progress Reports |  | 40d | 2024-03-18 A | 2024-05-10 A | 384 | 100% |  | 2024-03-18 | 2024-05-10 | 40d |  |  |  |  |  |  | PP | SI Test | DBT | 5.1 |  | Design, Build & Test (PIT) | Complete | COMPLETE |  |  |  |  |  |
| 393 | 1.3.6.4.3.6.5.2 | PIT Execution |  | 41d | 2024-03-15 A | 2024-05-10 A | 389FS+5d | 100% |  | 2024-03-15 | 2024-05-10 | 290d |  |  |  |  |  |  | PP | SI Test | DBT | 5.1 |  | Design, Build & Test (PIT) | Complete | COMPLETE |  |  |  |  |  |
| 394 | 1.3.6.4.3.6.5.3 | All SIT Migration PIT Completion Reports submitted to Programme for assurance | milestone | 0d | 2024-05-10 A | 2024-05-10 A | 392, 393 | 100% |  | 2024-05-10 | 2024-05-10 | 0d | 2024-01-05 | 2024-01-05 |  |  |  |  | PP | SI Test | DBT | 5.8 |  | Design, Build & Test (PIT) | Complete | COMPLETE | T3-DB-0149 | SITAG | T3 |  |  |
| 395 | 1.3.6.4.3.6.5.4 | All SIT Migration PIT Completion Reports MHHS Review Completed | milestone | 0d | 2024-05-24 A | 2024-05-24 A | 382, 387, 390, 394FS+10d | 100% |  | 2024-05-24 | 2024-05-24 | 0d |  |  |  |  |  |  | SI Test | PP | DBT | 5.8 |  | Design, Build & Test (PIT) | Complete | COMPLETE | T3-DB-0150 | SITAG | T3 |  |  |
| 396 | 1.3.6.4.3.7 | **All SIT Programme Participants PIT (SIT Non Functional)** |  | 161d | 2024-07-12 A | 2025-02-21 |  | 98% | 2.98d | 2024-07-12 | 2024-12-20 | 301d |  |  | 739d |  |  | -0 | N/A | N/A | DBT | 6.0 | N/A | Design, Build & Test (PIT) |  |  |  |  |  |  |  |
| 397 | 1.3.6.4.3.7.1 | **Test Approach & Plan** |  | 41d | 2024-09-27 A | 2024-11-22 A |  | 100% |  | 2024-09-27 | 2024-11-22 | 40d |  |  |  |  |  | -0 | N/A | N/A | DBT | 6.0 | N/A | Design, Build & Test (PIT) |  |  |  |  |  |  |  |
| 398 | 1.3.6.4.3.7.1.1 | SIT Non-Functional PIT Test Approach & Plan (PIT) submitted to Programme for assurance | milestone | 0d | 2024-09-27 A | 2024-09-27 A |  | 100% |  | 2024-09-27 | 2024-09-27 | 0d |  |  |  |  | start no earlier than 2024-05-10 |  | PP | SI Test | DBT | 6.0 | Roger Robar | Design, Build & Test (PIT) | Complete | COMPLETE | T3-DB-0151 | SITAG | T3 |  |  |
| 399 | 1.3.6.4.3.7.1.2 | SIT Non-Functional Test approach and plan MHHS Review Completed |  | 1d | 2024-11-21 A | 2024-11-22 A | 398FS+40d | 100% |  | 2024-11-21 | 2024-11-22 | 0d |  |  |  |  |  |  | SI Test | PP | DBT | 6.0 | Roger Robar | Design, Build & Test (PIT) | Complete | COMPLETE | T3-DB-0152 | SITAG | T3 | 6/9/24: Approved at esitag on 26/7/24 |  |
| 400 | 1.3.6.4.3.7.2 | **Test Readiness Report** |  | 13d | 2024-10-04 A | 2024-10-22 |  | 85% | 2d | 2024-10-04 | 2024-10-22 | 51d |  |  | 827d |  |  |  | N/A | N/A | DBT | 6.0 | N/A | Design, Build & Test (PIT) |  |  |  |  |  |  |  |
| 401 | 1.3.6.4.3.7.2.1 | Test readiness reporting |  | 13d | 2024-10-04 A | 2024-10-22 | 398FS+10d | 85% | 2d | 2024-10-04 | 2024-10-22 | 51d |  |  | 827d |  |  |  | PP | 109 | DBT | 6.0 |  | Design, Build & Test (PIT) | Overdue | RED |  |  |  |  |  |
| 402 | 1.3.6.4.3.7.3 | **Requirements to test Traceability Matrix (RTTM)** |  | 20d | 2024-11-01 A | 2024-11-29 A |  | 100% |  | 2024-11-01 | 2024-11-29 | 30d |  |  |  |  |  | -0 | N/A | N/A | DBT | 6.0 | N/A | Design, Build & Test (PIT) |  |  |  |  |  |  |  |
| 403 | 1.3.6.4.3.7.3.1 | SIT Non-Functional PIT RTTM submitted to Programme for assurance | milestone | 0d | 2024-11-01 A | 2024-11-01 A | 398FS+26d | 100% |  | 2024-11-01 | 2024-11-01 | 0d |  |  |  |  |  |  | PP | SI Test | DBT | 6.0 | Roger Robar | Design, Build & Test (PIT) | Complete | COMPLETE | T3-DB-0153 | SITAG | T3 |  |  |
| 404 | 1.3.6.4.3.7.3.2 | SIT Non-Functional RTTM MHHS Review Completed | milestone | 0d | 2024-11-29 A | 2024-11-29 A | 403FS+20d | 100% |  | 2024-11-29 | 2024-11-29 | 0d |  |  |  |  | start no earlier than 2024-11-29 |  | SI Test | PP | DBT | 6.0 | Roger Robar | Design, Build & Test (PIT) | Complete | COMPLETE | T3-DB-0154 | SITAG | T3 |  |  |
| 405 | 1.3.6.4.3.7.4 | **Test Scenarios** |  | 20d | 2024-11-01 A | 2024-11-29 A |  | 100% |  | 2024-11-01 | 2024-11-29 | 30d |  |  |  |  |  | -0 | N/A | N/A | DBT | 6.0 | N/A | Design, Build & Test (PIT) |  |  |  |  |  |  |  |
| 406 | 1.3.6.4.3.7.4.1 | SIT Non-Functional PIT test scenarios submitted to Programme for assurance | milestone | 0d | 2024-11-01 A | 2024-11-01 A | 398FS+26d | 100% |  | 2024-11-01 | 2024-11-01 | 0d |  |  |  |  |  |  | PP | SI Test | DBT | 6.0 | Roger Robar | Design, Build & Test (PIT) | Complete | COMPLETE | T3-DB-0155 | SITAG | T3 |  |  |
| 407 | 1.3.6.4.3.7.4.2 | SIT Non-Functional Test scenarios MHHS Review Completed | milestone | 0d | 2024-11-29 A | 2024-11-29 A | 406FS+20d | 100% |  | 2024-11-29 | 2024-11-29 | 0d |  |  |  |  |  |  | SI Test | PP | DBT | 6.0 | Roger Robar | Design, Build & Test (PIT) | Complete | COMPLETE | T3-DB-0156 | SITAG | T3 |  |  |
| 408 | 1.3.6.4.3.7.5 | **PIT execution** |  | 161d | 2024-07-12 A | 2025-02-21 A |  | 100% |  | 2024-07-12 | 2024-12-20 | 301d |  |  |  |  |  | -0 | N/A | N/A | DBT | 6.0 | N/A | Design, Build & Test (PIT) |  |  |  |  |  |  |  |
| 409 | 1.3.6.4.3.7.5.1 | PIT Test Execution Progress Report |  | 50d | 2024-07-15 A | 2024-11-21 A | 401 | 100% |  | 2024-07-15 | 2024-11-21 | 39d |  |  |  |  | finish no earlier than 2024-11-21 |  | PP | SI Test | DBT | 6.0 | Roger Robar | Design, Build & Test (PIT) | Complete | COMPLETE |  |  |  |  |  |
| 410 | 1.3.6.4.3.7.5.2 | PIT Execution |  | 44d | 2024-07-12 A | 2024-11-29 A | 406FS+5d | 100% |  | 2024-07-12 | 2024-11-29 | 290d |  |  |  |  | finish no earlier than 2024-11-29 |  | PP | SI Test | DBT | 6.0 | Roger Robar | Design, Build & Test (PIT) | Complete | COMPLETE |  |  |  |  |  |
| 411 | 1.3.6.4.3.7.5.3 | SIT Non-Functional PIT Completion Report submitted to Programme for assurance | milestone | 0d | 2024-11-29 A | 2024-11-29 A | 409, 410 | 100% |  | 2024-11-29 | 2024-11-29 | 0d | 2024-01-05 | 2024-01-05 |  |  |  |  | PP | SI Test | DBT | 6.0 | Roger Robar | Design, Build & Test (PIT) | Complete | COMPLETE | T3-DB-0157 | SITAG | T3 |  |  |
| 412 | 1.3.6.4.3.7.5.4 | SIT Non-Functional PIT Completion Report Theme 1 MHHS Review Completed | milestone | 0d | 2024-12-20 A | 2024-12-20 A | 399, 404, 407, 411FS+15d | 100% |  | 2024-12-20 | 2024-12-20 | 0d |  |  |  |  |  |  | SI Test | PP | DBT | 6.0 | Roger Robar | Design, Build & Test (PIT) | Complete | COMPLETE | T3-DB-0158 | SITAG | T3 |  |  |
| 413 | 1.3.6.4.3.7.5.5 | SIT Non-Functional PIT Completion Report Theme 2 & 3 MHHS Review Completed | milestone | 0d | 2025-02-21 A | 2025-02-21 A | 399, 404, 407, 411FS+60d | 100% |  | 2025-02-21 | 2025-02-21 | 0d |  |  |  |  |  |  | SI Test |  | DBT | 6.13 |  |  | Complete | COMPLETE | T3-DB-0186 | SITAG | T3 |  |  |
| 414 | 1.3.6.4.3.8 | **SIT Programme Participants PIT (SIT Operational Theme 1, 2, 3 (Batch 2))** |  | 146d | 2024-07-12 A | 2025-01-31 |  | 90% | 14.6d | 2024-07-12 | 2024-12-20 | 71d |  |  | 754d |  |  | -0 | N/A | N/A | DBT | 6.0 | N/A | Design, Build & Test (PIT) |  |  |  |  |  |  |  |
| 415 | 1.3.6.4.3.8.1 | **Test Approach & Plan** |  | 40d | 2024-09-27 A | 2024-11-21 |  |  | 40d | 2024-09-27 | 2024-11-21 | 40d |  |  | 805d |  |  | -0 | N/A | N/A | DBT | 6.0 | N/A | Design, Build & Test (PIT) |  |  |  |  |  |  |  |
| 416 | 1.3.6.4.3.8.1.1 | SIT Operational PIT Test Approach & Plan (PIT) submitted to Programme for assurance | milestone | 0d | 2024-09-27 A | 2024-09-27 A |  | 100% |  | 2024-09-27 | 2024-09-27 | 0d |  |  |  |  | start no earlier than 2024-09-27 |  | PP | SI Test | DBT | 6.0 | Roger Robar | Design, Build & Test (PIT) | Complete | COMPLETE | T3-DB-0159 | SITAG | T3 |  |  |
| 417 | 1.3.6.4.3.8.1.2 | SIT Operational Test approach and plan MHHS Review Completed | milestone | 0d | 2024-11-21 | 2024-11-21 | 416FS+40d |  |  | 2024-11-21 | 2024-11-21 | 0d |  |  | 805d | 51d |  |  | SI Test | PP | DBT | 6.0 | Roger Robar | Design, Build & Test (PIT) | Overdue Start | RED | T3-DB-0160 | SITAG | T3 |  | -166.29 |

Notes:
- 416: 06/05/25 - 33/34 submitted to the Programme, this however is complete because the final PP who have not submitted have a separate approach and plan arragement agreed. 5 participants have work-off plans in place with the Programme. 1 has an agreed late submission now due mid-May 2025 instead of April 2025.
- 417: 06/05/25 - 33/34 reviews completed. Programme continues to work with PPs to close out outstanding feedback on test approach and plans so drafting of the Overarching Readiness Report can proceed on schedule. 5 participants have work-off plans in place with the Programme. 1 has an agreed late submission now due mid-May 2025 instead of April 2025.

| ID | WBS | Task | Type | Duration | Start | Finish | Predecessors | Complete | Remaining | Baseline start | Baseline finish | Baseline duration | Baseline 1 start | Baseline 1 finish | Total slack | Free slack | Constraint | Baseline cost | Responsible | Involved | Text9 | Update Version | MHHS Resource Name | MHHS Programme Phase | Sched Status | RAG | Task Status | Milestone ID | Text29 | Tier |
| --- | --- | --- | --- | --- | --- | --- | --- | --- | --- | --- | --- | --- | --- | --- | --- | --- | --- | --- | --- | --- | --- | --- | --- | --- | --- | --- | --- | --- | --- | --- |
| 418 | 1.3.6.4.3.8.2 | **Test Readiness Report** |  | 13d | 2024-10-04 A | 2024-10-22 |  | 90% | 1.3d | 2024-10-04 | 2024-10-22 | 51d |  |  | 18d |  |  |  | N/A | N/A | DBT | 6.0 | N/A | Design, Build & Test (PIT) |  |  |  |  |  |  |
| 419 | 1.3.6.4.3.8.2.1 | Test readiness reporting |  | 13d | 2024-10-04 A | 2024-10-22 | 416FS+10d | 90% | 1.3d | 2024-10-04 | 2024-10-22 | 51d |  |  | 18d | 0d |  |  | PP | 109 | DBT | 6.0 |  | Design, Build & Test (PIT) | Overdue | RED |  |  |  |  |
| 420 | 1.3.6.4.3.8.3 | **Requirements to test Traceability Matrix (RTTM)** |  | 20d | 2024-11-01 | 2024-11-29 |  |  |  | 2024-11-01 | 2024-11-29 | 30d |  |  | 799d |  |  | -0 | N/A | N/A | DBT | 6.0 | N/A | Design, Build & Test (PIT) |  |  |  |  |  |  |
| 421 | 1.3.6.4.3.8.3.1 | SIT Operational PIT RTTM submitted to Programme for assurance | milestone | 0d | 2024-11-01 | 2024-11-01 | 416FS+26d |  |  | 2024-11-01 | 2024-11-01 | 0d |  |  | 799d | 0d |  |  | PP | SI Test | DBT | 6.0 | Roger Robar | Design, Build & Test (PIT) | Overdue Start | RED | -186.29 | T3-DB-0161 | SITAG | T3 |
| 422 | 1.3.6.4.3.8.3.2 | SIT Operational RTTM MHHS Review Completed | milestone | 0d | 2024-11-29 | 2024-11-29 | 421FS+20d |  |  | 2024-11-29 | 2024-11-29 | 0d |  |  | 799d | 45d |  |  | SI Test | PP | DBT | 6.0 | Roger Robar | Design, Build & Test (PIT) | Overdue Start | RED | -158.29 | T3-DB-0162 | SITAG | T3 |
| 423 | 1.3.6.4.3.8.4 | **Test Scenarios** |  | 20d | 2024-11-01 | 2024-11-29 |  |  |  | 2024-11-01 | 2024-11-29 | 30d |  |  | 16.1d |  |  | -0 | N/A | N/A | DBT | 6.0 | N/A | Design, Build & Test (PIT) |  |  |  |  |  |  |
| 424 | 1.3.6.4.3.8.4.1 | SIT Operational PIT test scenarios submitted to Programme for assurance | milestone | 0d | 2024-11-01 | 2024-11-01 | 416FS+26d |  |  | 2024-11-01 | 2024-11-01 | 0d |  |  | 16.1d | 0d |  |  | PP | SI Test | DBT | 6.0 | Roger Robar | Design, Build & Test (PIT) | Overdue Start | RED | -186.29 | T3-DB-0163 | SITAG | T3 |
| 425 | 1.3.6.4.3.8.4.2 | SIT Operational Test scenarios MHHS Review Completed | milestone | 0d | 2024-11-29 | 2024-11-29 | 424FS+20d |  |  | 2024-11-29 | 2024-11-29 | 0d |  |  | 799d | 45d |  |  | SI Test | PP | DBT | 6.0 | Roger Robar | Design, Build & Test (PIT) | Overdue Start | RED | -158.29 | T3-DB-0164 | SITAG | T3 |
| 426 | 1.3.6.4.3.8.5 | **PIT execution** |  | 146d | 2024-07-12 A | 2025-01-31 |  | 90% | 14.6d | 2024-07-12 | 2024-12-20 | 51d |  |  | 754d |  |  | -0 | N/A | N/A | DBT | 6.0 | N/A | Design, Build & Test (PIT) |  |  |  |  |  |  |
| 427 | 1.3.6.4.3.8.5.1 | PIT Test Execution Progress Report |  | 40d | 2024-07-15 A | 2024-11-21 | 419 | 90% | 4d | 2024-07-15 | 2024-11-21 | 40d |  |  | 792d | 38d |  |  | PP | SI Test | DBT | 6.0 | Roger Robar | Design, Build & Test (PIT) | Overdue | RED |  |  |  |  |
| 428 | 1.3.6.4.3.8.5.2 | PIT Execution |  | 39d | 2024-07-12 A | 2024-11-29 | 424 | 90% | 3.9d | 2024-07-12 | 2024-11-29 | 41d |  |  | 754d | 0d |  |  | PP | SI Test | DBT | 6.0 | Roger Robar | Design, Build & Test (PIT) | Overdue | RED |  |  |  |  |
| 429 | 1.3.6.4.3.8.5.3 | SIT Operational Theme 1, 2, 3 (Batch 2) PIT Completion Report submitted to Programme for assurance | milestone | 0d | 2025-01-14 | 2025-01-14 | 427, 428FS+32d |  |  | 2024-11-29 | 2024-11-29 | 0d | 2024-01-05 | 2024-01-05 | 754d | 0d |  |  | PP | SI Test | DBT | 6.0 | Roger Robar | Design, Build & Test (PIT) | Overdue Start | RED | -112.29 | T3-DB-0165 | SITAG | T3 |
| 430 | 1.3.6.4.3.8.5.4 | SIT Operational Theme 1, 2, 3 (Batch 2) PIT Completion Report MHHS Review Completed | milestone | 0d | 2025-01-31 | 2025-01-31 | 417, 422, 425, 429FS+13d |  |  | 2025-01-31 | 2025-01-31 | 0d |  |  | 754d |  |  |  | SI Test | PP | DBT | 6.0 | Roger Robar | Design, Build & Test (PIT) | Overdue Start | RED | -95.29 | T3-DB-0166 | SITAG | T3 |
| 431 | 1.3.6.4.3.9 | **SIT Programme Participants PIT (SIT Operational Theme 3 (Batch 1))** |  | 76d | 2024-09-27 A | 2025-01-10 |  |  | 76d | 2024-09-27 | 2025-01-10 | 0d |  |  | 769d |  |  |  | SI Test |  | DBT | 6.17 |  |  | Overdue Start | RED | -814.67 |  |  |  |
| 432 | 1.3.6.4.3.9.1 | **Test Approach & Plan** |  | 40d | 2024-09-27 A | 2024-11-21 A |  | 100% |  | 2024-09-27 | 2024-11-21 | 0d |  |  |  |  |  |  | SI Test |  | DBT | 6.17 | Roger Rober |  | Overdue Start |  | -814.67 |  |  |  |
| 433 | 1.3.6.4.3.9.1.1 | SIT Operational PIT Test Approach& Plan (PIT) submitted to Programme for assurance | milestone | 0d | 2024-09-27 A | 2024-09-27 A |  | 100% |  | 2024-09-27 | 2024-09-27 | 0d |  |  |  |  | start no earlier than 2024-09-27 |  | SI Test |  | DBT | 6.17 | Roger Rober |  | Complete | COMPLETE |  |  |  |  |
| 434 | 1.3.6.4.3.9.1.2 | SIT Operational Test approach and plan MHHS Review Completed | milestone | 0d | 2024-11-21 A | 2024-11-21 A | 433FS+40d | 100% |  | 2024-11-21 | 2024-11-21 | 0d |  |  |  |  |  |  | SI Test |  | DBT | 6.17 | Roger Rober |  | Complete | COMPLETE |  |  |  |  |
| 435 | 1.3.6.4.3.9.2 | **Test Readiness Report** |  | 13d | 2024-10-04 | 2024-10-22 |  |  |  | 2024-10-04 | 2024-10-22 | 0d |  |  | 787d |  |  |  | SI Test |  | DBT | 6.17 | Roger Rober |  | Overdue Start |  | -814.67 |  |  |  |
| 436 | 1.3.6.4.3.9.2.1 | Test readiness reporting |  | 13d | 2024-10-04 | 2024-10-22 | 433FS+5d |  |  | 2024-10-04 | 2024-10-22 | 0d |  |  | 787d | 0d |  |  | SI Test |  | DBT | 6.17 | Roger Rober |  | Overdue Start | RED | -214.67 |  |  |  |
| 437 | 1.3.6.4.3.9.3 | **Requirements to test Traceability Matrix (RTTM)** |  | 20d | 2024-11-01 A | 2024-11-29 A |  | 100% |  | 2024-11-01 | 2024-11-29 | 0d |  |  |  |  |  |  | SI Test |  | DBT | 6.17 | Roger Rober |  | Overdue Start |  | -814.67 |  |  |  |
| 438 | 1.3.6.4.3.9.3.1 | SIT Operational PIT RTTM submitted to Programme for assurance | milestone | 0d | 2024-11-01 A | 2024-11-01 A | 433FS+26d | 100% |  | 2024-11-01 | 2024-11-01 | 0d |  |  |  |  |  |  | SI Test |  | DBT | 6.17 | Roger Rober |  | Complete | COMPLETE |  |  |  |  |
| 439 | 1.3.6.4.3.9.3.2 | SIT Operational RTTM MHHS Review Completed | milestone | 0d | 2024-11-29 A | 2024-11-29 A | 438FS+20d | 100% |  | 2024-11-29 | 2024-11-29 | 0d |  |  |  |  |  |  | SI Test |  | DBT | 6.17 | Roger Rober |  | Complete | COMPLETE |  |  |  |  |
| 440 | 1.3.6.4.3.9.4 | **Test Scenarios** |  | 20d | 2024-11-01 A | 2024-11-29 A |  | 100% |  | 2024-11-01 | 2024-11-29 | 0d |  |  |  |  |  |  | SI Test |  | DBT | 6.17 | Roger Rober |  | Overdue Start |  | -814.67 |  |  |  |
| 441 | 1.3.6.4.3.9.4.1 | SIT Operational PIT test scenarios submitted to Programme for assurance | milestone | 0d | 2024-11-01 A | 2024-11-01 A | 433FS+26d | 100% |  | 2024-11-01 | 2024-11-01 | 0d |  |  |  |  |  |  | SI Test |  | DBT | 6.17 | Roger Rober |  | Complete | COMPLETE |  |  |  |  |
| 442 | 1.3.6.4.3.9.4.2 | SIT Operational Test scenarios MHHS Review Completed | milestone | 0d | 2024-11-29 A | 2024-11-29 A | 441FS+20d | 100% |  | 2024-11-29 | 2024-11-29 | 0d |  |  |  |  |  |  | SI Test |  | DBT | 6.17 | Roger Rober |  | Complete | COMPLETE |  |  |  |  |

Notes:
- 421: 06/05/25 - 33/34 reviews completed. Programme continues to work with the PP to recieve the final RTTM so drafting of the Overarching Readiness Report can proceed on schedule. 5 participants have work-off plans in place with the Programme. 1 has an agreed late submission now due mid-May 2025 instead of April 2025.
- 422: 06/05/25 - 33/34 reviews completed. Programme continues to work with PPs to close out outstanding feedback on RTTMs so drafting of the Overarching Readiness Report can proceed on schedule. 5 participants have work-off plans in place with the Programme. 1 has an agreed late submission now due mid-May 2025 instead of April 2025.
- 424: 06/05/25 - 33/34 reviews completed. Programme continues to work with PPs to recieve final test scenario so drafting of the Overarching Readiness Report can proceed on schedule. 5 participants have work-off plans in place with the Programme. 1 has an agreed late submission now due mid-May 2025 instead of April 2025.
- 425: 06/05/25 - 33/34 reviews completed. Programme continues to work with PPs to receive final test scenario so drafting of the Overarching Readiness Report can proceed on schedule. 5 participants have work-off plans in place with the Programme. 1 has an agreed late submission now due mid-May 2025 instead of April 2025.
- 429: 06/05/25 - 33/34 reports submitted. Programme continues to work with PPs to recieve reports so drafting of the Overarching Readiness Report can proceed on schedule. 5 participants have work-off plans in place with the Programme. 1 has an agreed late submission now due mid-May 2025 instead of April 2025.
- 430: 06/05/25 - 33/34 reports assured by the Programme. Programme continues to work with PPs to close out outstanding feedback on scenarios so drafting of the Overarching Readiness Report can proceed on schedule. 5 participants have work-off plans in place with the Programme. 1 has an agreed late submission now due mid-May 2025 instead of April 2025.

| ID | WBS | Task | Type | Duration | Start | Finish | Predecessors | Complete | Remaining | Baseline start | Baseline finish | Baseline duration | Baseline 1 start | Baseline 1 finish | Total slack | Constraint | Baseline cost | Responsible | Text9 | Task Status | Update Version | Sched Status | MHHS Resource Name | RAG | Involved | MHHS Programme Phase | Milestone ID | Text29 | Tier | Artefact ID |
| --- | --- | --- | --- | --- | --- | --- | --- | --- | --- | --- | --- | --- | --- | --- | --- | --- | --- | --- | --- | --- | --- | --- | --- | --- | --- | --- | --- | --- | --- | --- |
| 443 | 1.3.6.4.3.9.5 | **PIT execution** |  | 58d | 2024-10-23 A | 2025-01-10 |  |  | 58d | 2024-10-23 | 2025-01-10 | 0d |  |  | 769d |  |  | SI Test | DBT | -814.67 | 6.17 | Overdue Start | Roger Rober |  |  |  |  |  |  |  |
| 444 | 1.3.6.4.3.9.5.1 | PIT Test Execution Progress Report |  | 40d | 2024-10-23 | 2024-12-17 | 436 |  |  | 2024-10-23 | 2024-12-17 | 0d |  |  | 787d |  |  | SI Test | DBT | -195.67 | 6.17 | Overdue Start | Roger Rober | RED |  |  |  |  |  |  |
| 445 | 1.3.6.4.3.9.5.2 | PIT Execution |  | 39d | 2024-11-04 | 2024-12-26 | 441 |  |  | 2024-11-04 | 2024-12-26 | 0d |  |  | 780d |  |  | SI Test | DBT | -183.67 | 6.17 | Overdue Start | Roger Rober | RED |  |  |  |  |  |  |
| 446 | 1.3.6.4.3.9.5.3 | SIT Operational Theme 3 (Batch 1) PIT Completion Report submitted to Programme for assurance | milestone | 0d | 2025-01-10 A | 2025-01-10 A | 427, 428FS+30d | 100% |  | 2025-01-10 | 2025-01-10 | 0d |  |  |  |  |  | SI Test | DBT |  | 6.17 | Complete | Roger Rober | COMPLETE |  |  |  |  |  |  |
| 447 | 1.3.6.4.3.9.5.4 | SIT Operational Theme 3 (Batch 1) PIT Completion Report MHHS Review Completed | milestone | 0d | 2025-01-10 A | 2025-01-10 A | 451, 456, 459, 463, 446 | 100% |  | 2025-01-10 | 2025-01-10 | 0d |  |  |  |  |  | SI Test | DBT |  | 6.17 | Complete | Roger Rober | COMPLETE |  |  |  |  |  |  |
| 448 | 1.3.6.4.4 | **All Suppliers DBT CIT (Entering at Interval 5)** |  | 71d | 2023-09-15 A | 2023-12-22 A |  | 100% |  | 2023-09-15 | 2023-12-22 | 300d | 2022-10-31 | 2025-03-14 |  |  | -0 | N/A | DBT |  | 6.0 |  | N/A |  | N/A | Design, Build & Test (PIT) |  |  |  |  |
| 449 | 1.3.6.4.4.1 | **Test Approach & Plan** |  | 20d | 2023-09-15 A | 2023-10-12 A |  | 100% |  | 2023-09-15 | 2023-10-12 | 19d | 2022-10-31 | 2023-09-29 |  |  | -0 | N/A | DBT |  | 6.0 |  | N/A |  | N/A | Design, Build & Test (PIT) |  |  |  |  |
| 450 | 1.3.6.4.4.1.1 | All SIT Suppliers Test Approach & Plans (PIT) submitted to Programme for assurance | milestone | 0d | 2023-09-15 A | 2023-09-15 A |  | 100% |  | 2023-09-15 | 2023-09-15 | 0d | 2023-09-15 | 2023-09-15 |  | start no earlier than 2023-09-15 |  | PP | DBT |  | 6.0 | Complete |  | COMPLETE | SI Test | Design, Build & Test (PIT) | T3-DB-0046 | SITAG | T3 |  |
| 451 | 1.3.6.4.4.1.2 | All SIT Suppliers Test Approach & Plans MHHS Review Completed | milestone | 0d | 2023-10-12 A | 2023-10-12 A | 450FS+20d | 100% |  | 2023-10-12 | 2023-10-12 | 0d | 2023-09-18 | 2023-09-29 |  |  |  | SI Test | DBT |  | 6.0 | Complete |  | COMPLETE | PP | Design, Build & Test (PIT) | T3-DB-0167 | SITAG | T3 |  |
| 452 | 1.3.6.4.4.2 | **Test Readiness Report** |  | 11d | 2023-09-29 A | 2023-10-13 A |  | 100% |  | 2023-09-29 | 2023-10-13 | 51d | 2023-09-29 | 2023-12-08 |  |  |  | N/A | DBT |  | 6.0 |  | N/A |  | N/A | Design, Build & Test (PIT) |  |  |  |  |
| 453 | 1.3.6.4.4.2.1 | Test readiness reporting |  | 11d | 2023-09-29 A | 2023-10-13 A | 450FS+10d | 100% |  | 2023-09-29 | 2023-10-13 | 51d | 2023-09-29 | 2023-12-08 |  |  |  | PP | DBT |  | 6.0 | Complete |  | COMPLETE | 109 | Design, Build & Test (PIT) |  |  |  |  |
| 454 | 1.3.6.4.4.3 | **Requirements to test Traceability Matrix (RTTM)** |  | 20d | 2023-10-06 A | 2023-11-03 A |  | 100% |  | 2023-10-06 | 2023-11-03 | 21d | 2022-10-31 | 2023-10-20 |  |  | -0 | N/A | DBT |  | 6.0 |  | N/A |  | N/A | Design, Build & Test (PIT) |  |  |  |  |
| 455 | 1.3.6.4.4.3.1 | All SIT Suppliers RTTMs submitted to Programme for assurance | milestone | 0d | 2023-10-06 A | 2023-10-06 A | 450FS+16d | 100% |  | 2023-10-06 | 2023-10-06 | 1d | 2023-10-06 | 2023-10-06 |  |  |  | PP | DBT |  | 6.0 | Complete |  | COMPLETE | SI Test | Design, Build & Test (PIT) | T3-DB-0064 | SITAG | T3 | MHHS-ART009 |
| 456 | 1.3.6.4.4.3.2 | All SIT Suppliers RTTMs MHHS Review Completed | milestone | 0d | 2023-11-03 A | 2023-11-03 A | 455FS+20d | 100% |  | 2023-11-03 | 2023-11-03 | 0d | 2023-10-09 | 2023-10-20 |  |  |  | SI Test | DBT |  | 6.0 | Complete |  | COMPLETE | PP | Design, Build & Test (PIT) | T3-DB-0168 | SITAG | T3 |  |
| 457 | 1.3.6.4.4.4 | **Test Scenarios** |  | 20d | 2023-10-05 A | 2023-11-02 A |  | 100% |  | 2023-10-05 | 2023-11-02 | 20d | 2022-10-31 | 2023-10-20 |  |  | -0 | N/A | DBT |  | 6.0 |  | N/A |  | N/A | Design, Build & Test (PIT) |  |  |  |  |
| 458 | 1.3.6.4.4.4.1 | All SIT Suppliers test scenarios' submitted to Programme for assurance | milestone | 0d | 2023-10-05 A | 2023-10-05 A | 450FS+15d | 100% |  | 2023-10-05 | 2023-10-05 | 0d | 2023-10-06 | 2023-10-06 |  |  |  | PP | DBT |  | 6.0 | Complete |  | COMPLETE | SI Test | Design, Build & Test (PIT) | T3-DB-0037 | SITAG | T3 |  |
| 459 | 1.3.6.4.4.4.2 | All SIT Suppliers Test scenarios' MHHS Review Completed | milestone | 0d | 2023-11-02 A | 2023-11-02 A | 458FS+20d | 100% |  | 2023-11-02 | 2023-11-02 | 0d | 2023-10-09 | 2023-10-20 |  |  |  | SI Test | DBT |  | 6.0 | Complete |  | COMPLETE | PP | Design, Build & Test (PIT) | T3-DB-0169 | SITAG | T3 |  |
| 460 | 1.3.6.4.4.5 | **PIT execution** |  | 51d | 2023-10-13 A | 2023-12-22 A |  | 100% |  | 2023-10-13 | 2023-12-22 | 300d | 2022-10-31 | 2023-12-08 |  |  | -0 | N/A | DBT |  | 6.0 |  | N/A |  | N/A | Design, Build & Test (PIT) |  |  |  |  |
| 461 | 1.3.6.4.4.5.1 | PIT Test Execution Progress Report |  | 40d | 2023-10-16 A | 2023-12-08 A | 458FS+5d, 453 | 100% |  | 2023-10-16 | 2023-12-08 | 40d | 2022-10-31 | 2023-12-01 |  |  |  | PP | DBT |  | 6.0 | Complete |  | COMPLETE | SI Test | Design, Build & Test (PIT) |  |  |  |  |
| 462 | 1.3.6.4.4.5.2 | PIT Execution |  | 41d | 2023-10-13 A | 2023-12-08 A | 458FS+5d | 100% |  | 2023-10-13 | 2023-12-08 | 290d | 2022-10-31 | 2023-12-08 |  |  |  | PP | DBT |  | 6.0 | Complete |  | COMPLETE | SI Test | Design, Build & Test (PIT) |  |  |  |  |
| 463 | 1.3.6.4.4.5.3 | All SIT Suppliers PIT Completion Reports submitted to Programme for assurance | milestone | 0d | 2023-12-08 A | 2023-12-08 A | 462, 461 | 100% |  | 2023-12-08 | 2023-12-08 | 0d | 2024-01-05 | 2024-01-05 |  |  |  | PP | DBT |  | 6.0 | Complete |  | COMPLETE | SI Test | Design, Build & Test (PIT) | T3-DB-0170 | SITAG | T3 |  |
| 464 | 1.3.6.4.4.5.4 | All SIT Suppliers PIT Completion Reports MHHS Review Completed | milestone | 0d | 2023-12-22 A | 2023-12-22 A | 463FS+10d, 451, 456, 459 | 100% |  | 2023-12-22 | 2023-12-22 | 0d |  |  |  |  |  | SI Test | DBT |  | 6.0 | Complete |  | COMPLETE | PP | Design, Build & Test (PIT) | T3-DB-0171 | SITAG | T3 |  |
| 465 | 1.3.6.4.5 | **All LDSO Network Operations DBT CIT (Entering at Interval 5)** |  | 71d | 2023-09-15 A | 2023-12-22 A |  | 100% |  | 2023-09-15 | 2023-12-22 | 310d | 2022-10-31 | 2025-03-14 |  |  | -0 | N/A | DBT |  | 5.0 |  | N/A |  | N/A | Design, Build & Test (PIT) |  |  |  |  |
| 466 | 1.3.6.4.5.1 | **Test Approach & Plan** |  | 71d | 2023-09-15 A | 2023-12-22 A |  | 100% |  | 2023-09-15 | 2023-12-22 | 310d | 2022-10-31 | 2023-08-11 |  |  | -0 | N/A | DBT |  | 5.0 |  | N/A |  | N/A | Design, Build & Test (PIT) |  |  |  |  |
| 467 | 1.3.6.4.5.1.1 | All Network Operation Test Approach & Plans (PIT) submitted to Programme for assurance | milestone | 0d | 2023-09-15 A | 2023-09-15 A |  | 100% |  | 2023-09-15 | 2023-09-15 | 0d | 2023-07-28 | 2023-07-28 |  | start no earlier than 2023-09-15 |  | PP | DBT |  | 5.8 | Complete |  | COMPLETE | SI Test | Design, Build & Test (PIT) | T3-DB-0054 | SITAG | T3 |  |
| 468 | 1.3.6.4.5.1.2 | All Network Operation Test Approach & Plans MHHS Review Completed | milestone | 0d | 2023-10-12 A | 2023-10-12 A | 467FS+20d | 100% |  | 2023-10-12 | 2023-10-12 | 0d | 2023-07-31 | 2023-08-11 |  |  |  | SI Test | DBT |  | 5.8 | Complete |  | COMPLETE | PP | Design, Build & Test (PIT) | T3-DB-0172 | SITAG | T3 |  |

| ID | WBS | Task | Type | Duration | Start | Finish | Predecessors | Complete | Actual start | Actual finish | Baseline start | Baseline finish | Baseline duration | Baseline 1 start | Baseline 1 finish | Constraint | Baseline cost | Responsible | Involved | Text9 | Update Version | MHHS Resource Name | MHHS Programme Phase | Sched Status | RAG | Artefact ID | Milestone ID | Text29 | Tier |
| --- | --- | --- | --- | --- | --- | --- | --- | --- | --- | --- | --- | --- | --- | --- | --- | --- | --- | --- | --- | --- | --- | --- | --- | --- | --- | --- | --- | --- | --- |
| 469 | 1.3.6.4.5.1.3 | **Test Readiness Report** |  | 11d | 2023-09-29 A | 2023-10-13 A |  | 100% |  |  | 2023-09-29 | 2023-10-13 | 51d | 2023-08-11 | 2023-10-20 |  |  | N/A | N/A | DBT | 5.0 | N/A | Design, Build & Test (PIT) |  |  |  |  |  |  |
| 470 | 1.3.6.4.5.1.3.1 | Test readiness reporting |  | 11d | 2023-09-29 A | 2023-10-13 A | 467FS+10d | 100% |  |  | 2023-09-29 | 2023-10-13 | 51d | 2023-08-11 | 2023-10-20 |  |  | PP | 109 | DBT | 5.0 |  | Design, Build & Test (PIT) | Complete | COMPLETE |  |  |  |  |
| 471 | 1.3.6.4.5.1.4 | **Requirements to test Traceability Matrix (RTTM)** |  | 20d | 2023-10-05 A | 2023-11-02 A |  | 100% |  |  | 2023-10-05 | 2023-11-02 | 20d | 2022-10-31 | 2023-09-15 |  | -0 | N/A | N/A | DBT | 5.0 | N/A | Design, Build & Test (PIT) |  |  |  |  |  |  |
| 472 | 1.3.6.4.5.1.4.1 | All Network Operation RTTMs submitted to Programme for assurance | milestone | 0d | 2023-10-05 A | 2023-10-05 A | 467FS+15d | 100% |  |  | 2023-10-05 | 2023-10-05 | 0d | 2023-09-01 | 2023-09-01 | start no earlier than 2023-04-28 |  | PP | SI Test | DBT | 5.8 |  | Design, Build & Test (PIT) | Complete | COMPLETE | MHHS-ART009 | T3-DB-0062 | SITAG | T3 |
| 473 | 1.3.6.4.5.1.4.2 | All Network Operation RTTMs MHHS Review Completed | milestone | 0d | 2023-11-02 A | 2023-11-02 A | 472FS+20d | 100% |  |  | 2023-11-02 | 2023-11-02 | 0d | 2023-09-04 | 2023-09-15 |  |  | SI Test | PP | DBT | 5.14 |  | Design, Build & Test (PIT) | Complete | COMPLETE |  | T3-DB-0173 | SITAG | T3 |
| 474 | 1.3.6.4.5.1.5 | **Test Scenarios** |  | 20d | 2023-10-05 A | 2023-11-02 A |  | 100% |  |  | 2023-10-05 | 2023-11-02 | 20d | 2022-10-31 | 2023-09-15 |  | -0 | N/A | N/A | DBT | 5.0 | N/A | Design, Build & Test (PIT) |  |  |  |  |  |  |
| 475 | 1.3.6.4.5.1.5.1 | All Network Operation test scenarios' submitted to Programme for assurance | milestone | 0d | 2023-10-05 A | 2023-10-05 A | 467FS+15d | 100% |  |  | 2023-10-05 | 2023-10-05 | 0d | 2023-09-01 | 2023-09-01 |  |  | PP | SI Test | DBT | 5.8 |  | Design, Build & Test (PIT) | Complete | COMPLETE |  | T3-DB-0011 | SITAG | T3 |
| 476 | 1.3.6.4.5.1.5.2 | All Network Operation test scenarios' MHHS Review Completed | milestone | 0d | 2023-11-02 A | 2023-11-02 A | 475FS+20d | 100% |  |  | 2023-11-02 | 2023-11-02 | 0d | 2023-09-04 | 2023-09-15 |  |  | SI Test | PP | DBT | 5.14 |  | Design, Build & Test (PIT) | Complete | COMPLETE |  | T3-DB-0174 | SITAG | T3 |
| 477 | 1.3.6.4.5.1.6 | **PIT execution** |  | 51d | 2023-10-13 A | 2023-12-22 A |  | 100% |  |  | 2023-10-13 | 2023-12-22 | 310d | 2022-10-31 | 2024-01-05 |  | -0 | N/A | N/A | DBT | 5.0 | N/A | Design, Build & Test (PIT) |  |  |  |  |  |  |
| 478 | 1.3.6.4.5.1.6.1 | PIT Test Execution Progress Report |  | 40d | 2023-10-16 A | 2023-12-08 A | 475FS+5d, 470 | 100% |  |  | 2023-10-16 | 2023-12-08 | 305d | 2022-10-31 | 2023-12-29 |  |  | PP | SI Test | DBT | 5.0 |  | Design, Build & Test (PIT) | Complete | COMPLETE |  |  |  |  |
| 479 | 1.3.6.4.5.1.6.2 | PIT Execution |  | 41d | 2023-10-13 A | 2023-12-08 A | 475FS+5d | 100% |  |  | 2023-10-13 | 2023-12-08 | 310d | 2022-10-31 | 2024-01-05 |  |  | PP | SI Test | DBT | 5.0 |  | Design, Build & Test (PIT) | Complete | COMPLETE |  |  |  |  |
| 480 | 1.3.6.4.5.1.6.3 | All Network Operation PIT (CIT interval 5) Completion Reports submitted to Programme for assurance | milestone | 0d | 2023-12-08 A | 2023-12-08 A | 479, 478 | 100% |  |  | 2023-12-08 | 2023-12-08 | 0d | 2024-01-05 | 2024-01-05 |  |  | PP | SI Test | DBT | 5.0 |  | Design, Build & Test (PIT) | Complete | COMPLETE |  | T3-DB-0175 | SITAG | T3 |
| 481 | 1.3.6.4.5.1.6.4 | All Network Operation PIT (CIT interval 5) Completion Reports MHHS Review Completed | milestone | 0d | 2023-12-22 A | 2023-12-22 A | 480FS+10d, 468, 473, 476 | 100% |  |  | 2023-12-22 | 2023-12-22 | 0d |  |  |  |  | SI Test | PP | DBT | 5.15 |  | Design, Build & Test (PIT) | Complete | COMPLETE |  | T3-DB-0176 | SITAG | T3 |
| 482 | 1.3.6.4.6 | **All UMSO DBT CIT (Entering at Interval 6)** |  | 81d | 2023-09-29 | 2024-01-19 A |  | 100% | 2023-10-13 |  | 2023-09-29 | 2024-01-19 | 320d | 2022-10-31 | 2024-05-13 |  | -0 | N/A | N/A | DBT | 5.0 | N/A | Design, Build & Test (PIT) |  |  |  |  |  |  |
| 483 | 1.3.6.4.6.1 | **Test Approach & Plan** |  | 20d | 2023-10-13 A | 2023-11-09 A |  | 100% |  |  | 2023-10-13 | 2023-11-09 | 40d | 2022-10-31 | 2023-09-29 |  | -0 | N/A | N/A | DBT | 5.0 | N/A | Design, Build & Test (PIT) |  |  |  |  |  |  |
| 484 | 1.3.6.4.6.1.1 | All UMSO Test Approach & Plans (PIT) submitted to Programme for assurance | milestone | 0d | 2023-10-13 A | 2023-10-13 A |  | 100% |  |  | 2023-10-13 | 2023-10-13 | 0d | 2023-09-15 | 2023-09-15 | start no earlier than 2023-10-13 |  | PP | SI Test | DBT | 5.11 |  | Design, Build & Test (PIT) | Complete | COMPLETE |  | T3-DB-0052 | SITAG | T3 |
| 485 | 1.3.6.4.6.1.2 | All UMSO Test Approach & Plans MHHS Review Completed | milestone | 0d | 2023-11-09 A | 2023-11-09 A | 484FS+20d | 100% |  |  | 2023-11-09 | 2023-11-09 | 0d | 2023-09-18 | 2023-09-29 |  |  | SI Test | PP | DBT | 5.10 |  | Design, Build & Test (PIT) | Complete | COMPLETE |  | T3-DB-0177 | SITAG | T3 |
| 486 | 1.3.6.4.6.2 | **Test Readiness Report** |  | 11d | 2023-09-29 | 2023-10-13 |  | 100% | 2023-10-27 | 2023-11-10 | 2023-09-29 | 2023-10-13 | 11d | 2023-09-29 | 2023-12-08 |  | -0 | N/A | N/A | DBT | 5.0 | N/A | Design, Build & Test (PIT) |  |  |  |  |  |  |
| 487 | 1.3.6.4.6.2.1 | Test readiness reporting |  | 11d | 2023-10-27 A | 2023-11-10 A | 484FS+10d | 100% |  |  | 2023-10-27 | 2023-11-10 | 11d | 2023-09-29 | 2023-12-08 |  |  | PP | 109 | DBT | 5.0 |  | Design, Build & Test (PIT) | Complete | COMPLETE |  |  |  |  |
| 488 | 1.3.6.4.6.3 | **Requirements to test Traceability Matrix (RTTM)** |  | 20d | 2023-10-05 | 2023-11-01 |  | 100% | 2023-11-02 | 2023-11-30 | 2023-10-05 | 2023-11-01 | 20d | 2022-10-31 | 2023-10-20 |  | -0 | N/A | N/A | DBT | 5.0 | N/A | Design, Build & Test (PIT) |  |  |  |  |  |  |
| 489 | 1.3.6.4.6.3.1 | All UMSO RTTMs submitted to Programme for assurance | milestone | 0d | 2023-11-02 A | 2023-11-02 A | 484FS+15d | 100% |  |  | 2023-11-02 | 2023-11-02 | 0d | 2023-10-06 | 2023-10-06 |  |  | PP | SI Test | DBT | 5.12 |  | Design, Build & Test (PIT) | Complete | COMPLETE | MHHS-ART009 | T3-DB-0060 | SITAG | T3 |
| 490 | 1.3.6.4.6.3.2 | All UMSO RTTMs MHHS Review Completed | milestone | 0d | 2023-11-30 A | 2023-11-30 A | 489FS+20d | 100% |  |  | 2023-11-30 | 2023-11-30 | 0d | 2023-10-09 | 2023-10-20 |  |  | SI Test | PP | DBT | 5.12 |  | Design, Build & Test (PIT) | Complete | COMPLETE |  | T3-DB-0178 | SITAG | T3 |
| 491 | 1.3.6.4.6.4 | **Test Scenarios** |  | 20d | 2023-10-05 | 2023-11-01 |  | 100% | 2023-11-02 | 2023-11-30 | 2023-10-05 | 2023-11-01 | 20d | 2022-10-31 | 2023-10-20 |  | -0 | N/A | N/A | DBT | 5.0 | N/A | Design, Build & Test (PIT) |  |  |  |  |  |  |
| 492 | 1.3.6.4.6.4.1 | All UMSO test scenarios' submitted to Programme for assurance | milestone | 0d | 2023-11-02 A | 2023-11-02 A | 484FS+15d | 100% |  |  | 2023-11-02 | 2023-11-02 | 0d | 2023-10-06 | 2023-10-06 |  |  | PP | SI Test | DBT | 5.12 |  | Design, Build & Test (PIT) | Complete | COMPLETE |  | T3-DB-0025 | SITAG | T3 |
| 493 | 1.3.6.4.6.4.2 | All UMSO Test scenarios' MHHS Review Completed | milestone | 0d | 2023-11-30 A | 2023-11-30 A | 492FS+20d | 100% |  |  | 2023-11-30 | 2023-11-30 | 0d | 2023-10-09 | 2023-10-20 |  |  | SI Test | PP | DBT | 5.10 |  | Design, Build & Test (PIT) | Complete | COMPLETE |  | T3-DB-0179 | SITAG | T3 |

| ID | WBS | Task | Type | Duration | Start | Finish | Predecessors | Complete | Remaining | Baseline start | Baseline finish | Baseline duration | Baseline 1 start | Baseline 1 finish | Total slack | Constraint | Baseline cost | Responsible | Involved | Text9 | Update Version | MHHS Resource Name | MHHS Programme Phase | Sched Status | RAG | Milestone ID | Text29 | Tier | Task Status | Artefact ID |
| --- | --- | --- | --- | --- | --- | --- | --- | --- | --- | --- | --- | --- | --- | --- | --- | --- | --- | --- | --- | --- | --- | --- | --- | --- | --- | --- | --- | --- | --- | --- |
| 494 | 1.3.6.4.6.5 | **PIT execution** |  | 51d | 2023-11-10 A | 2024-01-19 A |  | 100% |  | 2023-11-10 | 2024-01-19 | 320d | 2022-10-31 | 2023-12-08 |  |  | -0 | N/A | N/A | DBT | 5.0 | N/A | Design, Build & Test (PIT) |  |  |  |  |  |  |  |
| 495 | 1.3.6.4.6.5.1 | PIT Test Execution Progress Report |  | 40d | 2023-11-13 A | 2024-01-05 A | 492FS+5d, 487 | 100% |  | 2023-11-13 | 2024-01-05 | 40d | 2022-10-31 | 2023-12-01 |  |  |  | PP | SI Test | DBT | 5.0 |  | Design, Build & Test (PIT) | Complete | COMPLETE |  |  |  |  |  |
| 496 | 1.3.6.4.6.5.2 | PIT Execution |  | 40d | 2023-11-10 A | 2024-01-04 A | 492FS+5d | 100% |  | 2023-11-10 | 2024-01-04 | 290d | 2022-10-31 | 2023-12-08 |  |  |  | PP | SI Test | DBT | 5.0 |  | Design, Build & Test (PIT) | Complete | COMPLETE |  |  |  |  |  |
| 497 | 1.3.6.4.6.5.3 | All UMSO PIT (CIT interval 6) Completion Reports submitted to Programme for assurance | milestone | 0d | 2024-01-05 A | 2024-01-05 A | 496, 495 | 100% |  | 2024-01-05 | 2024-01-05 | 0d | 2024-01-05 | 2024-01-05 |  |  |  | PP | SI Test | DBT | 5.10 |  | Design, Build & Test (PIT) | Complete | COMPLETE | T3-DB-0180 | SITAG | T3 |  |  |
| 498 | 1.3.6.4.6.5.4 | All UMSO PIT (CIT interval 6) Completion Reports MHHS Review Completed | milestone | 0d | 2024-01-19 A | 2024-01-19 A | 485, 490, 493, 497FS+10d | 100% |  | 2024-01-19 | 2024-01-19 | 0d |  |  |  |  |  | SI Test | PP | DBT | 5.10 |  | Design, Build & Test (PIT) | Complete | COMPLETE | T3-DB-0181 | SITAG | T3 |  |  |
| 499 | 1.3.7 | **DBT Monitoring and Assurance** |  | 842d | 2022-10-31 A | 2026-01-20 |  | 85% | 124.6d | 2022-10-31 | 2026-01-20 | 842d | 2022-10-31 | 2026-01-19 | 502d |  |  | N/A | N/A | DBT | 5.0 | N/A | Design, Build & Test (PIT) |  |  |  |  |  |  |  |
| 500 | 1.3.7.1 | **Planning and DBT Progress Monitoring of PPs** |  | 696d | 2022-10-31 A | 2025-06-30 |  | 89% | 79d | 2022-10-31 | 2025-06-30 | 696d | 2022-10-31 | 2025-06-30 | 648d |  |  | N/A | N/A | DBT | 5.0 | N/A | Design, Build & Test (PIT) |  |  |  |  |  | M9 |  |
| 501 | 1.3.7.1.1 | Monitor Non-SIT PPs Planning and DBT1 progress (to inform confirmation of Qualification Testing Tranche participants milestones) |  | 696d | 2022-10-31 A | 2025-06-30 | 193SS | 89% | 79d | 2022-10-31 | 2025-06-30 | 696d | 2022-10-31 | 2025-06-30 | 648d |  |  | Code Bodies | SI Test,PPC | DBT | 5.0 | Roger Robar | Design, Build & Test (PIT) | Green | GREEN |  |  |  |  |  |
| 502 | 1.3.7.2 | **DBT Progress Monitoring of Consequential Change** |  | 774d | 2023-02-02 A | 2026-01-20 |  | 74% | 205d | 2023-02-02 | 2026-01-20 | 774d | 2023-02-01 | 2026-01-19 | 502d |  |  | N/A | N/A | DBT | 5.0 | N/A | Design, Build & Test (PIT) |  |  |  |  |  | M9 |  |
| 503 | 1.3.7.2.1 | Monitor & report data cleanse progress |  | 774d | 2023-02-02 A | 2026-01-20 |  | 74% | 205d | 2023-02-02 | 2026-01-20 | 774d | 2023-02-01 | 2026-01-19 | 502d |  |  | SI Test | PPC | DBT | 5.0 | Matthew Breen | Design, Build & Test (PIT) | Green | GREEN |  |  |  |  |  |
| 504 | 1.3.7.3 | **Design Assurance** |  | 713d | 2022-11-14 A | 2025-08-06 |  | 89% | 76.32d | 2022-11-14 | 2025-08-06 | 713d | 2022-11-14 | 2025-08-06 | 621d |  |  | N/A | N/A | DBT | 5.0 | N/A | Design, Build & Test (PIT) |  |  |  |  |  | M9 |  |
| 505 | 1.3.7.3.1 | **Design Assurance Readiness Assessment Preparation** |  | 39d | 2023-02-28 A | 2023-04-21 A |  | 100% |  | 2023-02-28 | 2023-04-21 | 39d | 2023-02-28 | 2023-04-21 |  |  |  | N/A | N/A | DBT | 5.0 | N/A | Design, Build & Test (PIT) |  |  |  |  |  |  |  |
| 506 | 1.3.7.3.1.1 | Set up FTIG |  | 15d | 2023-04-03 A | 2023-04-21 A |  | 100% |  | 2023-04-03 | 2023-04-21 | 15d | 2023-04-03 | 2023-04-21 |  | must start on 2023-04-03 |  | SI Design |  | DBT | 5.0 | Paul Pettitt | Design, Build & Test (PIT) | Complete | COMPLETE |  |  |  |  |  |
| 507 | 1.3.7.3.1.2 | Produce Draft Questions |  | 10d | 2023-02-28 A | 2023-03-13 A |  | 100% |  | 2023-02-28 | 2023-03-13 | 10d | 2023-02-28 | 2023-03-13 |  | must start on 2023-02-28 |  | SI Design |  | DBT | 5.0 | Paul Pettitt | Design, Build & Test (PIT) | Complete | COMPLETE |  |  |  |  |  |
| 508 | 1.3.7.3.1.3 | Pilot with SRO |  | 1d | 2023-03-14 A | 2023-03-14 A | 507 | 100% |  | 2023-03-14 | 2023-03-14 | 1d | 2023-03-14 | 2023-03-14 |  |  |  | SI Design |  | DBT | 5.0 | Paul Pettitt | Design, Build & Test (PIT) | Complete | COMPLETE |  |  |  |  |  |
| 509 | 1.3.7.3.1.4 | Finalise questions |  | 10d | 2023-03-15 A | 2023-03-28 A | 508 | 100% |  | 2023-03-15 | 2023-03-28 | 10d | 2023-03-15 | 2023-03-28 |  |  |  | SI Design |  | DBT | 5.0 | Paul Pettitt | Design, Build & Test (PIT) | Complete | COMPLETE |  |  |  |  |  |
| 510 | 1.3.7.3.1.5 | Prepare on-line RA tooling |  | 10d | 2023-03-29 A | 2023-04-11 A | 509 | 100% |  | 2023-03-29 | 2023-04-11 | 10d | 2023-03-29 | 2023-04-11 |  |  |  | SI Design |  | DBT | 5.0 | Paul Pettitt | Design, Build & Test (PIT) | Complete | COMPLETE |  |  |  |  |  |
| 511 | 1.3.7.3.1.6 | Prepare webinar content |  | 5d | 2023-03-20 A | 2023-03-24 A | 507FS+4d | 100% |  | 2023-03-20 | 2023-03-24 | 5d | 2023-03-20 | 2023-03-24 |  |  |  | SI Design |  | DBT | 5.0 | Paul Pettitt | Design, Build & Test (PIT) | Complete | COMPLETE |  |  |  |  |  |
| 512 | 1.3.7.3.1.7 | Conduct webinar |  | 1d | 2023-03-30 A | 2023-03-30 A | 511FS+3d | 100% |  | 2023-03-30 | 2023-03-30 | 1d | 2023-03-30 | 2023-03-30 |  |  |  | SI Design | PP | DBT | 5.0 | Paul Pettitt | Design, Build & Test (PIT) | Complete | COMPLETE |  |  |  |  |  |
| 513 | 1.3.7.3.2 | **Participant Design Assurance Approach** |  | 43d | 2022-11-14 A | 2023-01-11 A |  | 100% |  | 2022-11-14 | 2023-01-11 | 43d | 2022-11-14 | 2023-01-11 |  |  |  | N/A | N/A | DBT | 5.0 | N/A | Design, Build & Test (PIT) |  |  |  |  |  |  |  |
| 514 | 1.3.7.3.2.1 | Develop document |  | 20d | 2022-11-14 A | 2022-12-09 A | 47FS+10d | 100% |  | 2022-11-14 | 2022-12-09 | 20d | 2022-11-14 | 2022-12-09 |  | start no earlier than 2022-11-14 |  | SI Design | PP | DBT | 5.0 | Paul Pettitt | Design, Build & Test (PIT) | Complete | COMPLETE |  |  |  |  |  |
| 515 | 1.3.7.3.2.2 | Review document |  | 18d | 2022-12-12 A | 2023-01-04 A | 514 | 100% |  | 2022-12-12 | 2023-01-04 | 18d | 2022-12-12 | 2023-01-04 |  |  |  | PP | SI Design,IPA | DBT | 5.0 | Paul Pettitt | Design, Build & Test (PIT) | Complete | COMPLETE |  |  |  |  |  |
| 516 | 1.3.7.3.2.3 | Participant Design Assurance Approach approved | milestone | 0d | 2023-01-11 A | 2023-01-11 A | 515FF+5d | 100% |  | 2023-01-11 | 2023-01-11 | 0d | 2023-01-11 | 2023-01-11 |  |  |  | SI Design | PP | DBT | 5.0 | Paul Pettitt | Design, Build & Test (PIT) | Complete | COMPLETE | T3-DB-0012 | DAG | T3 |  |  |
| 517 | 1.3.7.3.3 | **Phase 1 - SIT Volunteers (Core Providers)** |  | 145d | 2023-04-10 A | 2023-10-27 A |  | 100% |  | 2023-04-10 | 2023-10-27 | 145d | 2023-04-10 | 2023-10-27 |  |  |  | N/A | N/A | DBT | 5.0 | N/A | Design, Build & Test (PIT) |  |  |  |  |  |  |  |
| 518 | 1.3.7.3.3.1 | Send on-line questionnaire to core capability providers and current SIT volunteers (from Round 3 consultation) |  | 1d | 2023-04-10 A | 2023-04-10 A |  | 100% |  | 2023-04-10 | 2023-04-10 | 1d | 2023-04-10 | 2023-04-10 |  | must start on 2023-04-10 |  | SI Design | PP | DBT | 5.0 | Paul Pettitt | Design, Build & Test (PIT) | Complete | COMPLETE |  |  |  |  |  |
| 519 | 1.3.7.3.3.2 | Participants Provide Responses to questionnaires |  | 15d | 2023-04-11 A | 2023-05-01 A | 518 | 100% |  | 2023-04-11 | 2023-05-01 | 15d | 2023-04-11 | 2023-05-01 |  |  |  | PP |  | DBT | 5.0 | Paul Pettitt | Design, Build & Test (PIT) | Complete | COMPLETE |  |  |  |  |  |
| 520 | 1.3.7.3.3.3 | Assess on-line responses and provided evidence |  | 5d | 2023-05-02 A | 2023-05-08 A | 519 | 100% |  | 2023-05-02 | 2023-05-08 | 5d | 2023-05-02 | 2023-05-08 |  |  |  | SI Design |  | DBT | 5.0 | Paul Pettitt | Design, Build & Test (PIT) | Complete | COMPLETE |  |  |  |  |  |
| 521 | 1.3.7.3.3.4 | Bi-lateral meeting with each responder, to walk and navigate through provided materials |  | 31d | 2023-05-09 A | 2023-06-20 A | 520 | 100% |  | 2023-05-09 | 2023-06-20 | 31d | 2023-05-09 | 2023-06-20 |  |  |  | SI Design | PP | DBT | 5.0 | Paul Pettitt | Design, Build & Test (PIT) | Complete | COMPLETE |  |  |  |  |  |
| 522 | 1.3.7.3.3.5 | Plan for, create and execute deep dive assurance interviews based on agreed priorities (participants, design areas) |  | 62d | 2023-06-07 A | 2023-08-31 A | 521FS-10d | 100% |  | 2023-06-07 | 2023-08-31 | 62d | 2023-06-07 | 2023-08-01 |  |  |  | SI Design |  | DBT | 5.2 | Paul Pettitt | Design, Build & Test (PIT) | Complete | COMPLETE |  |  |  |  |  |
| 523 | 1.3.7.3.3.6 | SI endorsement of participants’ design – assurance reports |  | 43d | 2023-08-02 A | 2023-09-29 A | 522FS-22d | 100% |  | 2023-08-02 | 2023-09-29 | 43d | 2023-08-02 | 2023-08-15 |  |  |  | SI Design |  | DBT | 5.2 | Paul Pettitt | Design, Build & Test (PIT) | Complete | COMPLETE |  |  |  |  |  |
| 524 | 1.3.7.3.3.7 | Post-assurance review of recommendations take-up by assured participants |  | 44d | 2023-08-29 A | 2023-10-27 A | 523SS+19d | 100% |  | 2023-08-29 | 2023-10-27 | 20d | 2023-08-16 | 2023-10-27 |  |  |  | SI Design |  | DBT | 5.2 | Paul Pettitt | Design, Build & Test (PIT) | Complete | COMPLETE |  |  |  |  |  |
| 525 | 1.3.7.3.3.8 | Phase 1 - SIT Volunteers (Core Providers) complete | milestone | 0d | 2023-10-27 A | 2023-10-27 A | 524 | 100% |  | 2023-10-27 | 2023-10-27 | 0d | 2023-10-27 | 2023-10-27 |  |  |  | SI Design |  | DBT | 5.11 | Paul Pettitt | Design, Build & Test (PIT) | Complete | COMPLETE | T2-DB-0100 | DAG | T2 |  | MHHS-ART002 |

| ID | WBS | Task | Type | Duration | Start | Finish | Predecessors | Complete | Remaining | Baseline start | Baseline finish | Baseline duration | Baseline 1 start | Baseline 1 finish | Total slack | Constraint | Baseline cost | Responsible | Involved | Text9 | Update Version | MHHS Resource Name | MHHS Programme Phase | Sched Status | RAG | Artefact ID | Milestone ID | Text29 | Tier | Task Status | Future RAG |
| --- | --- | --- | --- | --- | --- | --- | --- | --- | --- | --- | --- | --- | --- | --- | --- | --- | --- | --- | --- | --- | --- | --- | --- | --- | --- | --- | --- | --- | --- | --- | --- |
| 526 | 1.3.7.3.4 | **Phase 2 - SIT all other participants** |  | 143d | 2023-05-08 A | 2023-11-22 A |  | 100% |  | 2023-05-08 | 2023-11-22 | 143d | 2023-05-08 | 2023-11-22 |  |  |  | N/A | N/A | DBT | 5.0 | N/A | Design, Build & Test (PIT) |  |  |  |  |  |  |  |  |
| 527 | 1.3.7.3.4.1 | Send on-line questionnaire to core capability providers and current SIT volunteers (from Round 3 consultation) |  | 1d | 2023-05-08 A | 2023-05-08 A |  | 100% |  | 2023-05-08 | 2023-05-08 | 1d | 2023-05-08 | 2023-05-08 |  | must start on 2023-05-08 |  | SI Design | PP | DBT | 5.0 | Paul Pettitt | Design, Build & Test (PIT) | Complete | COMPLETE |  |  |  |  |  |  |
| 528 | 1.3.7.3.4.2 | Participants Provide Responses to questionnaires |  | 15d | 2023-05-09 A | 2023-05-29 A | 527 | 100% |  | 2023-05-09 | 2023-05-29 | 15d | 2023-05-09 | 2023-05-29 |  |  |  | PP |  | DBT | 5.0 | Paul Pettitt | Design, Build & Test (PIT) | Complete | COMPLETE |  |  |  |  |  |  |
| 529 | 1.3.7.3.4.3 | Assess on-line responses and provided evidence |  | 5d | 2023-05-30 A | 2023-06-05 A | 528 | 100% |  | 2023-05-30 | 2023-06-05 | 5d | 2023-05-30 | 2023-06-05 |  |  |  | SI Design |  | DBT | 5.0 | Paul Pettitt | Design, Build & Test (PIT) | Complete | COMPLETE |  |  |  |  |  |  |
| 530 | 1.3.7.3.4.4 | Bi-lateral meeting with each responder, to walk and navigate through provided materials |  | 84d | 2023-06-06 A | 2023-09-29 A | 529 | 100% |  | 2023-06-06 | 2023-09-29 | 84d | 2023-06-06 | 2023-07-18 |  |  |  | SI Design | PP | DBT | 5.2 | Paul Pettitt | Design, Build & Test (PIT) | Complete | COMPLETE |  |  |  |  |  |  |
| 531 | 1.3.7.3.4.5 | Plan for, create and execute deep dive assurance interviews based on agreed priorities (participants, design areas) |  | 69d | 2023-06-27 A | 2023-09-29 A | 530SS+15d | 100% |  | 2023-06-27 | 2023-09-29 | 69d | 2023-07-05 | 2023-08-29 |  |  |  | SI Design |  | DBT | 5.2 | Paul Pettitt | Design, Build & Test (PIT) | Complete | COMPLETE |  |  |  |  |  |  |
| 532 | 1.3.7.3.4.6 | SI endorsement of participants’ design – assurance reports |  | 54d | 2023-07-18 A | 2023-09-29 A | 531SS+15d | 100% |  | 2023-07-18 | 2023-09-29 | 54d | 2023-08-30 | 2023-09-12 |  |  |  | SI Design |  | DBT | 5.2 | Paul Pettitt | Design, Build & Test (PIT) | Complete | COMPLETE |  |  |  |  |  |  |
| 533 | 1.3.7.3.4.7 | Post-assurance review of recommendations take-up by assured participants |  | 73d | 2023-08-14 A | 2023-11-22 A | 532SS+19d | 100% |  | 2023-08-14 | 2023-11-22 | 38d | 2023-09-13 | 2023-11-22 |  |  |  | SI Design |  | DBT | 5.2 | Paul Pettitt | Design, Build & Test (PIT) | Complete | COMPLETE |  |  |  |  |  |  |
| 534 | 1.3.7.3.4.8 | SIT PPs design assurance (excl Migration/Reverse Migration) complete | milestone | 0d | 2023-11-22 A | 2023-11-22 A | 533 | 100% |  | 2023-11-22 | 2023-11-22 | 0d | 2023-11-22 | 2023-11-22 |  |  |  | SI Design |  | DBT | 5.11 | Paul Pettitt | Design, Build & Test (PIT) | Complete | COMPLETE | MHHS-ART002 | T2-DB-0200 | DAG | T2 |  |  |
| 535 | 1.3.7.3.5 | **Non-SIT PPs design assurance** |  | 445d | 2023-11-23 A | 2025-08-06 |  | 75% | 111d | 2023-11-23 | 2025-08-06 | 445d | 2023-11-23 | 2025-08-06 | 621d |  |  | N/A | N/A | DBT | 5.0 | N/A | Design, Build & Test (PIT) |  |  |  |  |  |  |  |  |
| 536 | 1.3.7.3.5.1 | Non-SIT PPs design assurance (risk-based sample) |  | 445d | 2023-11-23 A | 2025-08-06 | 534 | 75% | 111d | 2023-11-23 | 2025-08-06 | 445d | 2023-11-23 | 2025-08-06 | 621d |  |  | SI Design | PPC | DBT | 5.0 | Paul Pettitt | Design, Build & Test (PIT) | Green | GREEN |  |  |  |  |  |  |
| 537 | 1.3.7.4 | **Test Assurance** |  | 629d | 2023-02-01 A | 2025-06-30 |  | 87% | 79d | 2023-02-01 | 2025-06-30 | 696d | 2022-10-31 | 2025-06-30 | 648d |  |  | N/A | N/A | DBT | 5.0 | N/A | Design, Build & Test (PIT) |  |  |  |  |  |  | M9 |  |
| 538 | 1.3.7.4.1 | Non-SIT PPs test assurance |  | 629d | 2023-02-01 A | 2025-06-30 |  | 87% | 79d | 2023-02-01 | 2025-06-30 | 629d | 2023-02-01 | 2025-06-30 | 648d |  |  | Code Bodies | PP,PPC,SI Test | DBT | 5.0 | Roger Robar | Design, Build & Test (PIT) | Green | GREEN |  |  |  |  |  |  |
| 539 | 1.3.7.5 | **Pre-Qualification Guidance (PIT Guidance)** |  | 67d | 2022-10-31 A | 2023-01-31 A |  | 100% |  | 2022-10-31 | 2023-01-31 | 67d | 2022-10-31 | 2023-01-31 |  |  |  | N/A | N/A | DBT | 5.0 | N/A | Design, Build & Test (PIT) |  |  |  |  |  |  |  |  |
| 540 | 1.3.7.5.1 | Develop document (incl. collaboration with code bodies, as required) |  | 56d | 2022-10-31 A | 2023-01-16 A |  | 100% |  | 2022-10-31 | 2023-01-16 | 56d | 2022-10-31 | 2023-01-16 |  |  |  | SI Test | Code Bodies | DBT | 5.0 |  | Design, Build & Test (PIT) | Complete | COMPLETE |  |  |  |  |  |  |
| 541 | 1.3.7.5.2 | Review, update and agree Pre-Qualification Guidance internally |  | 11d | 2023-01-17 A | 2023-01-31 A | 540 | 100% |  | 2023-01-17 | 2023-01-31 | 11d | 2023-01-17 | 2023-01-31 |  |  |  | SRO Function | IPA,SI Test | DBT | 5.0 |  | Design, Build & Test (PIT) | Complete | COMPLETE |  |  |  |  |  |  |
| 542 | 1.3.7.6 | **External Programme Dependency Management** |  | 0d | 2022-11-03 A | 2022-11-03 A |  | 100% |  | 2022-11-03 | 2022-11-03 | 0d | 2022-11-03 | 2022-11-03 |  |  |  | N/A | N/A | DBT | 5.0 | N/A | Design, Build & Test (PIT) |  |  |  |  |  |  |  |  |
| 543 | 1.3.7.6.1 | **SLC47** |  | 0d | 2022-11-03 A | 2022-11-03 A |  | 100% |  | 2022-11-03 | 2022-11-03 | 0d | 2022-11-03 | 2022-11-03 |  |  |  | N/A | N/A | DBT | 5.0 | N/A | Design, Build & Test (PIT) |  |  |  |  |  |  |  |  |
| 544 | 1.3.7.6.1.1 | SLC47 implementation date | milestone | 0d | 2022-11-03 A | 2022-11-03 A |  | 100% |  | 2022-11-03 | 2022-11-03 | 0d | 2022-11-03 | 2022-11-03 |  | start no earlier than 2022-11-03 |  | Ofgem |  | DBT | 5.0 |  | Design, Build & Test (PIT) | Complete | COMPLETE |  |  |  |  |  |  |
| 545 | 1.4 | **SYSTEMS INTEGRATION TESTING (SIT)** |  | 910d? | 2022-10-31 A | 2026-04-24 |  | 76% | 218.31d? | 2022-10-31 | 2026-04-24 | 841d | 2022-10-31 | 2026-01-19 |  |  | -0 | N/A | N/A | SIT | 5.0 | N/A | Systems Integration Testing (SIT) |  |  |  |  | SITAG |  |  | 1 Aug 2023 - 30 Sep 2024 |
| 546 | 1.4.1 | **SIT Preparation** |  | 665d? | 2022-10-31 A | 2025-05-16 |  | 99% | 2.75d? | 2022-10-31 | 2025-05-16 | 611d | 2022-10-31 | 2025-03-10 | 679d |  | -0 | N/A | N/A | SIT | 5.0 | N/A | Systems Integration Testing (SIT) |  |  |  |  | SITAG |  |  |  |
| 547 | 1.4.1.1 | **Test Artefact Development** |  | 472d | 2022-10-31 A | 2024-08-21 A |  | 100% |  | 2022-10-31 | 2024-08-21 | 472d | 2022-10-31 | 2023-09-01 |  |  | -0 | N/A | N/A | SIT | 5.0 | N/A | Systems Integration Testing (SIT) |  |  |  |  |  |  | M9 |  |
| 548 | 1.4.1.1.1 | **Environment Approach & Plan** |  | 460d | 2022-11-16 A | 2024-08-21 A |  | 100% |  | 2022-11-16 | 2024-08-21 | 460d | 2022-11-16 | 2023-06-30 |  |  | -0 | N/A | N/A | SIT | 5.0 | N/A | Systems Integration Testing (SIT) |  |  |  |  |  |  |  |  |
| 549 | 1.4.1.1.1.1 | Environment Approach & Plan approved | milestone | 0d | 2022-11-16 A | 2022-11-16 A |  | 100% |  | 2022-11-16 | 2022-11-16 | 0d | 2022-11-16 | 2022-11-16 |  | start no earlier than 2022-11-16 |  | SI Test | PP | SIT | 5.0 | Simon Berry | Systems Integration Testing (SIT) | Complete | COMPLETE | MHHS-ART139 | T3-TE-0010 | SITAG | T3 |  |  |
| 550 | 1.4.1.1.1.2 | Environment Approach & Plan - Work Off |  | 157d | 2022-11-17 A | 2023-06-23 A | 549FS+1d | 100% |  | 2022-11-17 | 2023-06-23 | 157d | 2022-11-17 | 2023-06-23 |  |  |  | SI Test | PP | SIT | 5.0 | Simon Berry | Systems Integration Testing (SIT) | Complete | COMPLETE |  |  |  |  |  |  |
| 551 | 1.4.1.1.1.3 | Environment Approach & Plan - Work Off Approved | milestone | 0d | 2023-08-16 A | 2023-08-16 A | 550FS+5d | 100% |  | 2023-08-16 | 2023-08-16 | 0d | 2023-06-30 | 2023-06-30 |  | start no earlier than 2023-08-16 |  | SI Test | PP | SIT | 5.0 | Simon Berry | Systems Integration Testing (SIT) | Complete | COMPLETE | MHHS-ART139 | T3-TE-0068 | SITAG | T3 |  |  |
| 552 | 1.4.1.1.1.4 | Environment Approach and Plan - SIT Functional | milestone | 0d | 2023-11-20 A | 2023-11-20 A |  | 100% |  | 2023-11-20 | 2023-11-20 | 0d |  |  |  | start no earlier than 2023-11-20 |  | SI Test | PP | SIT | 5.12 | Simon Berry | Systems Integration Testing (SIT) | Complete | COMPLETE | MHHS-DEL 618 | T3-TE-0090 | SITAG | T3 |  |  |
| 553 | 1.4.1.1.1.5 | Define Approach to Simulator for Non-SIT LDSO | milestone | 0d | 2023-11-15 A | 2023-11-15 A |  | 100% |  | 2023-11-15 | 2023-11-15 | 0d |  |  |  | start no earlier than 2023-11-15 |  | SI Test | PP | SIT | 5.12 | Simon Berry |  | Complete | COMPLETE |  |  |  |  |  |  |
| 554 | 1.4.1.1.1.6 | Environment Approach and Plan - Non SIT LDSO Testing | milestone | 0d | 2024-04-17 A | 2024-04-17 A |  | 100% |  | 2024-04-17 | 2024-04-17 | 0d |  |  |  | start no earlier than 2024-04-17 |  | SI Test | PP | SIT | 5.22 | Simon Berry | Systems Integration Testing (SIT) | Complete | COMPLETE | MHHS-DEL 619 | T3-TE-0091 | SITAG/QAG | T3 |  |  |
| 555 | 1.4.1.1.1.7 | Environment Approach and Plan - S and A Testing | milestone | 0d | 2024-07-17 A | 2024-07-17 A |  | 100% |  | 2024-07-17 | 2024-07-17 | 0d |  |  |  | start no earlier than 2024-07-17 |  | SI Test | PP | SIT | 5.27 | Simon Berry | Systems Integration Testing (SIT) | Complete | COMPLETE | MHHS-DEL 619 | T3-TE-0120 | SITAG/QAG | T3 |  |  |
| 556 | 1.4.1.1.1.8 | Environment Approach and Plan - SIT Non Functional | milestone | 0d | 2024-06-19 A | 2024-06-19 A |  | 100% |  | 2024-06-19 | 2024-06-19 | 0d |  |  |  | start no earlier than 2024-06-19 |  | SI Test | PP | SIT | 5.27 | Simon Berry | Systems Integration Testing (SIT) | Complete | COMPLETE | MHHS-DEL 620 | T3-TE-0092 | SITAG | T3 |  |  |
| 557 | 1.4.1.1.1.9 | Environment Approach and Plan - Sandbox | milestone | 0d | 2024-08-21 A | 2024-08-21 A |  | 100% |  | 2024-08-21 | 2024-08-21 | 0d |  |  |  | start no earlier than 2024-08-21 |  | SI Test | PP | SIT | 5.27 | Simon Berry | Systems Integration Testing (SIT) | Complete | COMPLETE | MHHS-DEL 621 | T3-TE-0093 | SITAG/QAG | T3 |  |  |

Notes:
- 546: Action: 11/3: Ask Simon B for the link (line 1312) dip onboarding to non sit ldso
- 548: Action: 16/8 - add to milestone register. Build out detail further
- 549: Action: 25/7 - Simon to provide update
- 550: Action: 25/7 - Simon to provide update
- 551: Action: 25/7 - Simon to provide update
- 552: Action: 16/8 - add to milestone register. Build out detail further
- 554: Action: 16/8 - add to milestone register. Build out detail further
- 555: Action: 16/8 - add to milestone register. Build out detail further
- 556: Action: 16/8 - add to milestone register. Build out detail further
- 557: Action: 16/8 - add to milestone register. Build out detail further

| ID | WBS | Task | Type | Duration | Start | Finish | Predecessors | Complete | Baseline start | Baseline finish | Baseline duration | Baseline 1 start | Baseline 1 finish | Constraint | Baseline cost | Responsible | Involved | Text9 | Update Version | MHHS Resource Name | MHHS Programme Phase | Sched Status | RAG | Task Status | Milestone ID | Text29 | Tier |
| --- | --- | --- | --- | --- | --- | --- | --- | --- | --- | --- | --- | --- | --- | --- | --- | --- | --- | --- | --- | --- | --- | --- | --- | --- | --- | --- | --- |
| 558 | 1.4.1.1.2 | **Overarching Test Scope (for all stages)** |  | 65d | 2022-10-31 A | 2023-01-27 A |  | 100% | 2022-10-31 | 2023-01-27 | 175d | 2022-10-31 | 2023-06-30 |  |  | N/A | N/A | SIT | 5.0 | N/A | Systems Integration Testing (SIT) |  |  |  |  |  |  |
| 559 | 1.4.1.1.2.1 | **Overarching Test Scope (excl. Migration/Reverse Migration, NFT and Ops components)** |  | 65d | 2022-10-31 A | 2023-01-27 A |  | 100% | 2022-10-31 | 2023-01-27 | 65d | 2022-10-31 | 2023-01-27 |  |  | N/A | N/A | SIT | 5.0 | N/A | Systems Integration Testing (SIT) |  |  |  |  |  |  |
| 560 | 1.4.1.1.2.1.1 | Develop document (excl Migration/Reverse Migration, NFT and Ops components) |  | 55d | 2022-10-31 A | 2023-01-13 A | 47 | 100% | 2022-10-31 | 2023-01-13 | 55d | 2022-10-31 | 2023-01-13 |  |  | SI Test |  | SIT | 5.0 |  | Systems Integration Testing (SIT) | Complete | COMPLETE |  |  |  |  |
| 561 | 1.4.1.1.2.1.2 | Review, update & agree document (excl Migration/Reverse Migration, NFT and Ops components) |  | 10d | 2023-01-16 A | 2023-01-27 A | 560 | 100% | 2023-01-16 | 2023-01-27 | 10d | 2023-01-16 | 2023-01-27 |  |  | SI Test | IPA,Code Bodies,PP | SIT | 5.0 |  | Systems Integration Testing (SIT) | Complete | COMPLETE |  |  |  |  |
| 562 | 1.4.1.1.3 | **Configuration and Release Management Approach & Plan** |  | 164d | 2022-11-01 A | 2023-06-16 A |  | 100% | 2022-11-01 | 2023-06-16 | 164d | 2022-11-01 | 2023-04-28 |  |  | N/A | N/A | SIT | 5.0 | N/A | Systems Integration Testing (SIT) |  |  | M9 |  |  |  |
| 563 | 1.4.1.1.3.1 | Develop document |  | 69d | 2022-11-01 A | 2023-06-16 A |  | 100% | 2022-11-01 | 2023-06-16 | 69d | 2022-11-01 | 2023-01-31 | start no earlier than 2022-11-01 |  | SI Test |  | SIT | 5.0 | Simon Berry | Systems Integration Testing (SIT) | Complete | COMPLETE |  |  |  |  |
| 564 | 1.4.1.1.3.2 | Review, update and agree Configuration and Release Management Approach & Plan internally |  | 63d | 2023-02-01 A | 2023-04-28 A | 563 | 100% | 2023-02-01 | 2023-04-28 | 63d | 2023-02-01 | 2023-04-28 |  |  | SRO Function | IPA,SI Test | SIT | 5.0 | Simon Berry | Systems Integration Testing (SIT) | Complete | COMPLETE |  |  |  |  |
| 565 | 1.4.1.1.4 | **Test Data Overarching Approach & Plan** |  | 179d | 2022-11-14 A | 2023-07-20 A |  | 100% | 2022-11-14 | 2023-07-20 | 179d | 2022-11-14 | 2023-05-18 |  |  | N/A | N/A | SIT | 5.0 | N/A | Systems Integration Testing (SIT) |  |  | M9 |  |  |  |
| 566 | 1.4.1.1.4.1 | Develop document |  | 20d | 2022-11-14 A | 2022-12-09 A |  | 100% | 2022-11-14 | 2022-12-09 | 20d | 2022-11-14 | 2022-12-09 | start no earlier than 2022-11-14 |  | SI Test | PP | SIT | 5.0 | Cesar Lopes | Systems Integration Testing (SIT) | Complete | COMPLETE |  |  |  |  |
| 567 | 1.4.1.1.4.2 | Document review and update |  | 155d | 2022-12-12 A | 2023-07-14 A | 566 | 100% | 2022-12-12 | 2023-07-14 | 155d | 2022-12-12 | 2023-05-17 |  |  | PP | SI Test,IPA | SIT | 5.0 | Cesar Lopes | Systems Integration Testing (SIT) | Complete | COMPLETE |  |  |  |  |
| 568 | 1.4.1.1.4.3 | Test Data Overarching Approach & Plan approved by TMAG | milestone | 0d | 2023-07-19 A | 2023-07-19 A | 567FS+3d | 100% | 2023-07-19 | 2023-07-19 | 0d | 2023-05-17 | 2023-05-17 |  |  | SRO Test | PP,IPA,Code Bodies | SIT | 5.0 | Cesar Lopes | Systems Integration Testing (SIT) | Complete | COMPLETE |  | T3-TE-0072 | SITAG | T3 |
| 569 | 1.4.1.1.4.4 | Document publication final version |  | 1d | 2023-07-20 A | 2023-07-20 A | 568 | 100% | 2023-07-20 | 2023-07-20 | 1d | 2023-05-18 | 2023-05-18 |  |  | SI Test |  | SIT | 5.0 | Cesar Lopes | Systems Integration Testing (SIT) | Complete | COMPLETE |  |  |  |  |
| 570 | 1.4.1.1.5 | **Interface Code of Connection (dates subject to DIP Service Provider's plan)** |  | 48d | 2023-03-01 A | 2023-05-05 A |  | 100% | 2023-03-01 | 2023-05-05 | 48d | 2023-03-01 | 2023-05-05 |  |  | N/A | N/A | SIT | 5.0 | N/A | Systems Integration Testing (SIT) |  |  |  |  |  |  |
| 571 | 1.4.1.1.5.1 | Develop Interface Code of Connection with DIP Service Provider |  | 43d | 2023-03-01 A | 2023-04-28 A |  | 100% | 2023-03-01 | 2023-04-28 | 43d | 2023-03-01 | 2023-04-28 | must start on 2023-03-01 |  | DIP Provider | SI Test | SIT | 5.0 |  | Systems Integration Testing (SIT) | Complete | COMPLETE |  |  |  |  |
| 572 | 1.4.1.1.5.2 | Interface Code of Connection approved at SDWG | milestone | 0d | 2023-05-05 A | 2023-05-05 A | 571FS+5d | 100% | 2023-05-05 | 2023-05-05 | 0d | 2023-05-05 | 2023-05-05 |  |  | SI Test | PP | SIT | 5.0 |  | Systems Integration Testing (SIT) | Complete | COMPLETE |  |  |  |  |
| 573 | 1.4.1.1.6 | **Test Traceability** |  | 165d | 2023-06-01 A | 2024-01-17 A |  | 100% | 2023-06-01 | 2024-01-17 | 165d | 2023-06-01 | 2023-09-01 |  | -0 | N/A | N/A | SIT | 5.0 | N/A | Systems Integration Testing (SIT) |  |  |  |  |  |  |
| 574 | 1.4.1.1.6.1 | RTM containing Method Statement Implied Requirements into Azure DevOps |  | 22d | 2023-06-01 A | 2023-06-30 A |  | 100% | 2023-06-01 | 2023-06-30 | 22d | 2023-06-01 | 2023-06-30 | must start on 2023-06-01 |  | SI Test |  | SIT | 5.0 |  | Systems Integration Testing (SIT) | Complete | COMPLETE |  |  |  |  |
| 575 | 1.4.1.1.6.2 | RTM Containing Interface Catalogue Implied Requirements |  | 27d | 2023-06-01 A | 2023-07-07 A |  | 100% | 2023-06-01 | 2023-07-07 | 27d | 2023-06-01 | 2023-07-07 | must start on 2023-06-01 |  | SI Test |  | SIT | 5.0 |  | Systems Integration Testing (SIT) | Complete | COMPLETE |  |  |  |  |
| 576 | 1.4.1.1.6.3 | SIT CIT Full Traceability & Coverage complete |  | 118d | 2023-07-10 A | 2023-12-20 A | 575, 574 | 100% | 2023-07-10 | 2023-12-20 | 110d | 2023-07-10 | 2023-07-28 |  |  | SI Test |  | SIT | 5.0 |  | Systems Integration Testing (SIT) | Complete | COMPLETE |  |  |  |  |
| 577 | 1.4.1.1.6.4 | SIT Functional Full Traceability & Coverage complete |  | 138d | 2023-07-10 A | 2024-01-17 A | 575, 574 | 100% | 2023-07-10 | 2024-01-17 | 138d | 2023-07-10 | 2023-09-01 |  |  | SI Test |  | SIT | 5.0 | Roger Robar | Systems Integration Testing (SIT) | Complete | COMPLETE |  |  |  |  |
| 578 | 1.4.1.2 | **Test Tool Development** |  | 256d? | 2022-10-31 A | 2023-10-23 A |  | 100% | 2022-10-31 | 2023-10-23 | 175d | 2022-10-31 | 2023-06-30 |  |  | N/A | N/A | SIT | 5.0 | N/A | Systems Integration Testing (SIT) |  |  |  |  |  |  |
| 579 | 1.4.1.2.1 | **Test Management Tool** |  | 256d | 2022-10-31 A | 2023-10-23 A |  | 100% | 2022-10-31 | 2023-10-23 | 175d | 2022-10-31 | 2023-06-30 |  |  | N/A | N/A | SIT | 5.0 | N/A | Systems Integration Testing (SIT) |  |  |  |  |  |  |
| 580 | 1.4.1.2.1.1 | **Test Management Tool Implementation** |  | 256d | 2022-10-31 A | 2023-10-23 A |  | 100% | 2022-10-31 | 2023-10-23 | 175d | 2022-10-31 | 2023-06-30 |  |  | N/A | N/A | SIT | 5.0 | N/A | Systems Integration Testing (SIT) |  |  |  |  |  |  |
| 581 | 1.4.1.2.1.1.1 | Requirements identification |  | 40d | 2022-10-31 A | 2022-12-23 A |  | 100% | 2022-10-31 | 2022-12-23 | 40d | 2022-10-31 | 2022-12-23 |  |  | SI DevOps | SI Test | SIT | 5.0 | Simon Berry | Systems Integration Testing (SIT) | Complete | COMPLETE |  |  |  |  |
| 582 | 1.4.1.2.1.1.2 | Development |  | 125d | 2023-01-02 A | 2023-06-23 A | 581FS+5d | 100% | 2023-01-02 | 2023-06-23 | 125d | 2023-01-02 | 2023-06-23 |  |  | SI DevOps | SI Test | SIT | 5.0 | Simon Berry | Systems Integration Testing (SIT) | Complete | COMPLETE |  |  |  |  |
| 583 | 1.4.1.2.1.1.3 | Testing |  | 125d | 2023-01-02 A | 2023-06-23 A | 582FF | 100% | 2023-01-02 | 2023-06-23 | 125d | 2023-01-02 | 2023-06-23 |  |  | SI DevOps | SI Test | SIT | 5.0 | Simon Berry | Systems Integration Testing (SIT) | Complete | COMPLETE |  |  |  |  |
| 584 | 1.4.1.2.1.1.4 | Accept tool | milestone | 0d | 2023-06-23 A | 2023-06-23 A | 583FF | 100% | 2023-06-23 | 2023-06-23 | 0d | 2023-06-23 | 2023-06-23 |  |  | SI DevOps | SI Test | SIT | 5.0 | Simon Berry | Systems Integration Testing (SIT) | Complete | COMPLETE |  |  |  |  |
| 585 | 1.4.1.2.1.1.5 | Implementation |  | 1d | 2023-10-23 A | 2023-10-23 A | 584FS+85d | 100% | 2023-10-23 | 2023-10-23 | 1d | 2023-06-30 | 2023-06-30 |  |  | SI DevOps | PPC | SIT | 5.0 | Simon Berry | Systems Integration Testing (SIT) | Complete | COMPLETE |  |  |  |  |

Notes:
- 562: Action: 1280 DIP available for Onboarding (need to add a link - non sit ldso)

| ID | WBS | Task | Duration | Start | Finish | Predecessors | Complete | Baseline start | Baseline finish | Baseline duration | Baseline 1 start | Baseline 1 finish | Constraint | Responsible | Involved | Text9 | Update Version | MHHS Resource Name | MHHS Programme Phase | Sched Status | RAG | Task Status |
| --- | --- | --- | --- | --- | --- | --- | --- | --- | --- | --- | --- | --- | --- | --- | --- | --- | --- | --- | --- | --- | --- | --- |
| 586 | 1.4.1.2.1.2 | **Test Management Tool User Guide** | 115d | 2023-01-02 A | 2023-06-09 A |  | 100% | 2023-01-02 | 2023-06-09 | 115d | 2023-01-02 | 2023-06-09 |  | N/A | N/A | SIT | 5.0 | N/A | Systems Integration Testing (SIT) |  |  |  |
| 587 | 1.4.1.2.1.2.1 | Develop document | 100d | 2023-01-02 A | 2023-05-19 A | 582SS, 583SS | 100% | 2023-01-02 | 2023-05-19 | 100d | 2023-01-02 | 2023-05-19 | start no earlier than 2023-01-02 | SI DevOps |  | SIT | 5.0 |  | Systems Integration Testing (SIT) | Complete | COMPLETE |  |
| 588 | 1.4.1.2.1.2.2 | Review, update and agree Test Management Tool User Guide internally | 15d | 2023-05-22 A | 2023-06-09 A | 587 | 100% | 2023-05-22 | 2023-06-09 | 15d | 2023-05-22 | 2023-06-09 |  | SRO Function | SI DevOps,SI Test,IPA,PPC | SIT | 5.0 |  | Systems Integration Testing (SIT) | Complete | COMPLETE |  |
| 589 | 1.4.1.2.1.3 | **Test Management Tool Configuration Guide** | 60d | 2023-01-02 A | 2023-03-24 A |  | 100% | 2023-01-02 | 2023-03-24 | 60d | 2023-01-02 | 2023-03-24 |  | N/A | N/A | SIT | 5.0 | N/A | Systems Integration Testing (SIT) |  |  |  |
| 590 | 1.4.1.2.1.3.1 | Develop document | 45d | 2023-01-02 A | 2023-03-03 A | 581 | 100% | 2023-01-02 | 2023-03-03 | 45d | 2023-01-02 | 2023-03-03 | start no earlier than 2023-01-02 | SI DevOps | SI Test,IPA | SIT | 5.0 |  | Systems Integration Testing (SIT) | Complete | COMPLETE |  |
| 591 | 1.4.1.2.1.3.2 | Review, update and agree Test Management Tool Configuration Guide internally | 15d | 2023-03-06 A | 2023-03-24 A | 590 | 100% | 2023-03-06 | 2023-03-24 | 15d | 2023-03-06 | 2023-03-24 |  | SRO Function | SI DevOps,SI Test,IPA | SIT | 5.0 |  | Systems Integration Testing (SIT) | Complete | COMPLETE |  |
| 592 | 1.4.1.2.2 | **Secure Volunteer SIT Participants** | 163d? | 2023-01-31 A | 2023-09-14 A |  | 100% | 2023-01-31 | 2023-09-14 | 0d |  |  |  |  |  | SIT | 6.0 |  |  | Overdue Start |  | -680.67 |
| 593 | 1.4.1.2.2.1 | PPs decide whether to volunteer to participate in SIT and inform Programme of decision via Round 3 Replan consultation | 1d? | 2023-01-31 A | 2023-01-31 A |  | 100% | 2023-01-31 | 2023-01-31 | 0d |  |  | finish no earlier than 2023-01-31 | SI Test |  | SIT | 6.0 |  |  | Complete | COMPLETE |  |
| 594 | 1.4.1.2.2.2 | Assurance of SIT volunteers' plans (submitted via Round 3 Replan Consultation) | 1d? | 2023-02-14 A | 2023-02-14 A |  | 100% | 2023-02-14 | 2023-02-14 | 0d |  |  | finish no earlier than 2023-02-14 | SI Test |  | SIT | 6.0 |  |  | Complete | COMPLETE |  |
| 595 | 1.4.1.2.2.3 | SIT Participant Volunteers Identified | 1d? | 2023-02-14 A | 2023-02-14 A |  | 100% | 2023-02-14 | 2023-02-14 | 0d |  |  | start no earlier than 2023-02-14 | SI Test |  | SIT | 6.0 |  |  | Complete | COMPLETE |  |
| 596 | 1.4.1.2.2.4 | Engagement with SIT volunteers | 1d? | 2023-05-23 A | 2023-05-23 A |  | 100% | 2023-05-23 | 2023-05-23 | 0d |  |  | finish no earlier than 2023-05-23 | SI Test |  | SIT | 6.0 |  |  | Complete | COMPLETE |  |
| 597 | 1.4.1.2.2.5 | SIT Participants Agreed | 1d? | 2023-05-23 A | 2023-05-23 A |  | 100% | 2023-05-23 | 2023-05-23 | 0d |  |  | start no earlier than 2023-05-23 | SI Test |  | SIT | 6.0 |  |  | Complete | COMPLETE |  |
| 598 | 1.4.1.2.2.6 | **Data Protection Impact Assessment (DPIA)** | 11d? | 2023-06-30 A | 2023-07-14 A |  | 100% | 2023-06-30 | 2023-07-14 | 0d |  |  |  | SI Test |  | SIT | 6.0 |  |  | Overdue Start |  | -680.67 |
| 599 | 1.4.1.2.2.6.1 | Conduct DPIA on Overall Test Data Approach | 1d? | 2023-06-30 A | 2023-06-30 A |  | 100% | 2023-06-30 | 2023-06-30 | 0d |  |  | finish no earlier than 2023-06-30 | SI Test |  | SIT | 6.0 |  |  | Complete | COMPLETE |  |
| 600 | 1.4.1.2.2.6.2 | Revise Overarching Test Data Approach& plan for DPIA (if required), including engagement with DWG | 1d? | 2023-07-13 A | 2023-07-13 A |  | 100% | 2023-07-13 | 2023-07-13 | 0d |  |  | finish no earlier than 2023-07-13 | SI Test |  | SIT | 6.0 |  |  | Complete | COMPLETE |  |
| 601 | 1.4.1.2.2.6.3 | Review (internal), update and approve revised Overarching Test Data Approach& Plan (if required) | 1d? | 2023-07-14 A | 2023-07-14 A |  | 100% | 2023-07-14 | 2023-07-14 | 0d |  |  | start no earlier than 2023-07-14 | SI Test |  | SIT | 6.0 |  |  | Complete | COMPLETE |  |
| 602 | 1.4.1.2.2.7 | **Data Sharing Agreements** | 30d? | 2023-08-04 A | 2023-09-14 A |  | 100% | 2023-08-04 | 2023-09-14 | 0d |  |  |  | SI Test |  | SIT | 6.0 |  |  | Overdue Start | COMPLETE | -680.67 |
| 603 | 1.4.1.2.2.7.1 | Produce Data Sharing Agreement for Industry Review | 1d? | 2023-08-04 A | 2023-08-04 A |  | 100% | 2023-08-04 | 2023-08-04 | 0d |  |  | finish no earlier than 2023-08-04 | SI Test |  | SIT | 6.0 |  |  | Complete | COMPLETE |  |
| 604 | 1.4.1.2.2.7.2 | Manage Participant Queries and Contract Agreement Execution | 1d? | 2023-09-14 A | 2023-09-14 A |  | 100% | 2023-09-14 | 2023-09-14 | 0d |  |  | finish no earlier than 2023-09-14 | SI Test |  | SIT | 6.0 |  |  | Complete | COMPLETE |  |
| 605 | 1.4.1.2.2.7.3 | Data Sharing Agreements Complete | 1d? | 2023-09-14 A | 2023-09-14 A |  | 100% | 2023-09-14 | 2023-09-14 | 0d |  |  | start no earlier than 2023-09-14 | SI Test |  | SIT | 6.0 |  |  | Complete | COMPLETE |  |
| 606 | 1.4.1.2.2.8 | **Production Data Cut & Data Obfuscation** | 55d? | 2023-06-19 A | 2023-09-01 A |  | 100% | 2023-06-19 | 2023-09-01 | 0d |  |  |  |  |  | SIT | 6.0 |  |  | Overdue Start | COMPLETE | -680.67 |
| 607 | 1.4.1.2.2.8.1 | **SI Data Cut Preparation& Infrastructure** | 45d? | 2023-06-19 A | 2023-08-18 A |  | 100% | 2023-06-19 | 2023-08-18 | 0d |  |  |  |  |  | SIT | 6.0 |  |  | Overdue Start | COMPLETE | -680.67 |
| 608 | 1.4.1.2.2.8.1.1 | SI Data Cut Planning activities (incl. pre-cut and post-cut cleansing and population approach) | 1d? | 2023-06-19 A | 2023-06-19 A |  | 100% | 2023-06-19 | 2023-06-19 | 0d |  |  | finish no earlier than 2023-06-19 | SI Test |  | SIT | 6.0 |  |  | Complete | COMPLETE |  |
| 609 | 1.4.1.2.2.8.1.2 | Set up SI database and transmission structure | 1d? | 2023-08-17 A | 2023-08-17 A |  | 100% | 2023-08-17 | 2023-08-17 | 0d |  |  | finish no earlier than 2023-08-17 | SI Test |  | SIT | 6.0 |  |  | Complete | COMPLETE |  |
| 610 | 1.4.1.2.2.8.1.3 | Mechanism for transfer of data in place | 1d? | 2023-08-18 A | 2023-08-18 A |  | 100% | 2023-08-18 | 2023-08-18 | 0d |  |  | start no earlier than 2023-08-18 | SI Test |  | SIT | 6.0 |  |  | Complete | COMPLETE |  |
| 611 | 1.4.1.2.2.8.1.4 | SI Data Cut Preparation& Infrastructure Complete | 1d? | 2023-08-18 A | 2023-08-18 A |  | 100% | 2023-08-18 | 2023-08-18 | 0d |  |  | start no earlier than 2023-08-18 | SI Test |  | SIT | 6.0 |  |  | Complete | COMPLETE |  |

| ID | WBS | Task | Type | Duration | Start | Finish | Predecessors | Complete | Remaining | Baseline start | Baseline finish | Baseline duration | Baseline 1 start | Baseline 1 finish | Total slack | Constraint | Baseline cost | Responsible | Text9 | Task Status | Update Version | Sched Status | RAG | Involved | MHHS Resource Name | MHHS Programme Phase | Milestone ID | Text29 | Tier | Artefact ID |
| --- | --- | --- | --- | --- | --- | --- | --- | --- | --- | --- | --- | --- | --- | --- | --- | --- | --- | --- | --- | --- | --- | --- | --- | --- | --- | --- | --- | --- | --- | --- |
| 612 | 1.4.1.2.2.8.2 | **Production Data Cut** |  | 55d? | 2023-06-19 A | 2023-09-01 A |  | 100% |  | 2023-06-19 | 2023-09-01 | 0d |  |  |  |  |  | SI Test | SIT | -680.67 | 6.0 | Overdue Start | COMPLETE |  |  |  |  |  |  |  |
| 613 | 1.4.1.2.2.8.2.1 | Notification of Production Data Cut issued to relevant participants |  | 1d? | 2023-06-19 A | 2023-06-19 A |  | 100% |  | 2023-06-19 | 2023-06-19 | 0d |  |  |  | start no earlier than 2023-06-19 |  | SI Test | SIT |  | 6.0 | Complete | COMPLETE |  |  |  |  |  |  |  |
| 614 | 1.4.1.2.2.8.2.2 | Coordinate relevant participants taking data cut from production systems |  | 1d? | 2023-08-11 A | 2023-08-11 A |  | 100% |  | 2023-08-11 | 2023-08-11 | 0d |  |  |  | finish no earlier than 2023-08-11 |  | SI Test | SIT |  | 6.0 | Complete | COMPLETE |  |  |  |  |  |  |  |
| 615 | 1.4.1.2.2.8.2.3 | Production data cut GONG decision |  | 1d? | 2023-08-16 A | 2023-08-16 A |  | 100% |  | 2023-08-16 | 2023-08-16 | 0d |  |  |  | start no earlier than 2023-08-16 |  | SI Test | SIT |  | 6.0 | Complete | COMPLETE |  |  |  |  |  |  |  |
| 616 | 1.4.1.2.2.8.2.4 | Relevant participants take data cut from production systems (Saturday 19 August) |  | 1d? | 2023-08-21 A | 2023-08-21 A |  | 100% |  | 2023-08-21 | 2023-08-21 | 0d |  |  |  | start no earlier than 2023-08-21 |  | SI Test | SIT |  | 6.0 | Complete | COMPLETE |  |  |  |  |  |  |  |
| 617 | 1.4.1.2.2.8.2.5 | EES transmit request data to SI |  | 1d? | 2023-08-25 A | 2023-08-25 A |  | 100% |  | 2023-08-25 | 2023-08-25 | 0d |  |  |  | finish no earlier than 2023-08-25 |  | SI Test | SIT |  | 6.0 | Complete | COMPLETE |  |  |  |  |  |  |  |
| 618 | 1.4.1.2.2.8.2.6 | Check data alignment and integrity of data cut |  | 1d? | 2023-09-01 A | 2023-09-01 A |  | 100% |  | 2023-09-01 | 2023-09-01 | 0d |  |  |  | finish no earlier than 2023-09-01 |  | SI Test | SIT |  | 6.0 | Complete | COMPLETE |  |  |  |  |  |  |  |
| 619 | 1.4.1.2.2.8.2.7 | Data cut from relevant participants' production systems completed (Saturday 19 August) |  | 1d? | 2023-08-21 A | 2023-08-21 A |  | 100% |  | 2023-08-21 | 2023-08-21 | 0d |  |  |  | start no earlier than 2023-08-21 |  | SI Test | SIT |  | 6.0 | Complete | COMPLETE |  |  |  |  |  |  |  |
| 620 | 1.4.1.2.2.8.2.8 | Production Data Cut Complete |  | 1d? | 2023-08-21 A | 2023-08-21 A |  | 100% |  | 2023-08-21 | 2023-08-21 | 0d |  |  |  | start no earlier than 2023-08-21 |  | SI Test | SIT |  | 6.0 | Complete | COMPLETE |  |  |  |  |  |  |  |
| 621 | 1.4.1.3 | **SIT Participation** |  | 147d | 2022-10-31 A | 2023-05-23 A |  | 100% |  | 2022-10-31 | 2023-05-23 | 147d | 2022-10-31 | 2023-05-23 |  |  |  | N/A | SIT |  | 5.0 |  |  | N/A | N/A | Systems Integration Testing (SIT) |  |  |  |  |
| 622 | 1.4.1.3.1 | PPs decide whether to volunteer to participate in SIT and inform Programme of decision via Round 3 Replan consultation |  | 67d | 2022-10-31 A | 2023-01-31 A | 34FF | 100% |  | 2022-10-31 | 2023-01-31 | 67d | 2022-10-31 | 2023-01-31 |  |  |  | PP | SIT |  | 5.0 | Complete | COMPLETE | SI Test,PMO |  | Systems Integration Testing (SIT) |  |  |  |  |
| 623 | 1.4.1.3.2 | Assurance of SIT volunteers' plans (submitted via Round 3 Replan Consultation) |  | 10d | 2023-02-01 A | 2023-02-14 A | 622, 34 | 100% |  | 2023-02-01 | 2023-02-14 | 10d | 2023-02-01 | 2023-02-14 |  |  |  | SI Test | SIT |  | 5.0 | Complete | COMPLETE | PP |  | Systems Integration Testing (SIT) |  |  |  |  |
| 624 | 1.4.1.3.3 | SIT Participant Volunteers Identified | milestone | 0d | 2023-02-14 A | 2023-02-14 A | 623FF | 100% |  | 2023-02-14 | 2023-02-14 | 0d | 2023-02-14 | 2023-02-14 |  |  |  | SI Test | SIT |  | 5.0 | Complete | COMPLETE | PP |  | Systems Integration Testing (SIT) | T2-TE-0100 | SITAG | T2 |  |
| 625 | 1.4.1.3.4 | Engagement with SIT volunteers |  | 147d | 2022-10-31 A | 2023-05-23 A |  | 100% |  | 2022-10-31 | 2023-05-23 | 147d | 2022-10-31 | 2023-05-23 |  |  |  | SI Test | SIT |  | 5.0 | Complete | COMPLETE | PP |  | Systems Integration Testing (SIT) |  |  |  |  |
| 626 | 1.4.1.3.5 | SIT Participants Agreed | milestone | 0d | 2023-05-23 A | 2023-05-23 A | 625, 660FS-74d | 100% |  | 2023-05-23 | 2023-05-23 | 0d | 2023-05-23 | 2023-05-23 |  |  |  | SI Test | SIT |  | 5.0 | Complete | COMPLETE | PP |  | Systems Integration Testing (SIT) | T2-TE-0150 | SITAG | T2 |  |
| 627 | 1.4.1.4 | **SIT Stage-Specific Preparation** |  | 665d? | 2022-10-31 A | 2025-05-16 |  | 99% | 3.36d? | 2022-10-31 | 2025-05-16 | 611d | 2022-10-31 | 2025-03-10 | 679d |  | -0 | N/A | SIT |  | 5.0 |  |  | N/A | N/A | Systems Integration Testing (SIT) |  | SITAG |  |  |
| 628 | 1.4.1.4.1 | **SIT Component Integration Preparation** |  | 320d | 2022-10-31 A | 2024-01-19 A |  | 100% |  | 2022-10-31 | 2024-01-19 | 321d | 2022-10-31 | 2024-01-22 |  |  | -0 | N/A | SIT |  | 5.0 |  |  | N/A | N/A | Systems Integration Testing (SIT) |  |  |  |  |
| 629 | 1.4.1.4.1.1 | **Test Approach & Plan** |  | 188d | 2022-10-31 A | 2023-07-19 A |  | 100% |  | 2022-10-31 | 2023-07-19 | 188d | 2022-10-31 | 2023-07-19 |  |  |  | N/A | SIT |  | 5.0 |  |  | N/A | N/A | Systems Integration Testing (SIT) |  |  |  |  |
| 630 | 1.4.1.4.1.1.1 | Develop document with SITWG |  | 159d | 2022-10-31 A | 2023-06-08 A |  | 100% |  | 2022-10-31 | 2023-06-08 | 159d | 2022-10-31 | 2023-05-12 |  |  |  | SI Test | SIT |  | 5.0 | Complete | COMPLETE |  |  | Systems Integration Testing (SIT) |  |  |  |  |
| 631 | 1.4.1.4.1.1.2 | Industry consultation |  | 10d | 2023-06-09 A | 2023-06-22 A | 630 | 100% |  | 2023-06-09 | 2023-06-22 | 10d |  |  |  |  |  | PP | SIT |  | 5.1 | Complete | COMPLETE |  |  | Systems Integration Testing (SIT) |  |  |  |  |
| 632 | 1.4.1.4.1.1.3 | Artefact review (via TMAG) and updates |  | 19d | 2023-06-23 A | 2023-07-19 A | 631 | 100% |  | 2023-06-23 | 2023-07-19 | 19d | 2023-06-09 | 2023-07-06 |  | finish no earlier than 2023-07-06 |  | SI Test | SIT |  | 5.0 | Complete | COMPLETE | PP,IPA,Code Bodies |  | Systems Integration Testing (SIT) |  |  |  |  |
| 633 | 1.4.1.4.1.1.4 | SIT Component Integration Testing Test Approach & Plan approved | milestone | 0d | 2023-07-19 A | 2023-07-19 A | 632 | 100% |  | 2023-07-19 | 2023-07-19 | 0d | 2023-07-19 | 2023-07-19 |  | finish no earlier than 2023-07-19 |  | SI Test | SIT |  | 5.0 | Complete | COMPLETE | PP |  | Systems Integration Testing (SIT) | T3-TE-0012 | SITAG | T3 | MHHS-ART073 |
| 634 | 1.4.1.4.1.2 | **Test Data Approach & Plan** |  | 29d | 2023-06-09 A | 2023-07-19 A |  | 100% |  | 2023-06-09 | 2023-07-19 | 29d | 2023-06-09 | 2023-07-19 |  |  |  | N/A | SIT |  | 5.0 |  |  | N/A | N/A | Systems Integration Testing (SIT) |  |  |  |  |
| 635 | 1.4.1.4.1.2.1 | Industry consultation |  | 10d | 2023-06-09 A | 2023-06-22 A | 631SS | 100% |  | 2023-06-09 | 2023-06-22 | 10d |  |  |  |  |  | PP | SIT |  | 5.1 | Complete | COMPLETE |  | Cesar Lopes | Systems Integration Testing (SIT) |  |  |  |  |
| 636 | 1.4.1.4.1.2.2 | Artefact review (via TMAG) and updates |  | 19d | 2023-06-23 A | 2023-07-19 A | 635 | 100% |  | 2023-06-23 | 2023-07-19 | 19d | 2023-06-09 | 2023-07-06 |  |  |  | SI Test | SIT |  | 5.0 | Complete | COMPLETE | PP | Cesar Lopes | Systems Integration Testing (SIT) |  |  |  |  |
| 637 | 1.4.1.4.1.2.3 | SIT Component Integration Testing Test Data Approach & Plan approved | milestone | 0d | 2023-07-19 A | 2023-07-19 A | 636 | 100% |  | 2023-07-19 | 2023-07-19 | 0d | 2023-07-19 | 2023-07-19 |  |  |  | SI Test | SIT |  | 5.0 | Complete | COMPLETE | IPA | Cesar Lopes | Systems Integration Testing (SIT) |  |  |  |  |

| ID | WBS | Task | Type | Duration | Start | Finish | Predecessors | Complete | Baseline start | Baseline finish | Baseline duration | Baseline 1 start | Baseline 1 finish | Constraint | Baseline cost | Responsible | Involved | Text9 | Update Version | MHHS Resource Name | MHHS Programme Phase | Sched Status | RAG | Artefact ID | Milestone ID | Text29 | Tier | Task Status |
| --- | --- | --- | --- | --- | --- | --- | --- | --- | --- | --- | --- | --- | --- | --- | --- | --- | --- | --- | --- | --- | --- | --- | --- | --- | --- | --- | --- | --- |
| 638 | 1.4.1.4.1.3 | **Test scenarios** |  | 173d | 2023-01-02 A | 2023-08-30 A |  | 100% | 2023-01-02 | 2023-08-30 | 173d | 2023-01-02 | 2023-06-02 |  |  | N/A | N/A | SIT | 5.0 | N/A | Systems Integration Testing (SIT) |  |  |  |  |  |  |  |
| 639 | 1.4.1.4.1.3.1 | Development of test scenarios | milestone | 0d | 2023-01-02 A | 2023-04-28 A | 630SS+45d | 100% | 2023-01-02 | 2023-04-28 | 85d | 2023-01-02 | 2023-04-28 |  |  | SI Test | PP, Code Bodies | SIT | 5.0 |  | Systems Integration Testing (SIT) | Complete | COMPLETE |  |  |  |  |  |
| 640 | 1.4.1.4.1.3.2 | Review test scenarios with SIT Working Group |  | 11d | 2023-02-01 A | 2023-08-09 A | 639SS+22d | 100% | 2023-02-01 | 2023-08-09 | 136d | 2023-02-01 | 2023-05-26 |  |  | SI Test | PP, Code Bodies, IPA | SIT | 5.0 |  | Systems Integration Testing (SIT) | Complete | COMPLETE |  |  |  |  |  |
| 641 | 1.4.1.4.1.3.3 | SIT Component Integration Testing Test scenarios approved | milestone | 0d | 2023-08-30 A | 2023-08-30 A | 640FS+15d | 100% | 2023-08-30 | 2023-08-30 | 0d | 2023-06-02 | 2023-06-02 |  |  | SI Test | PP | SIT | 5.6 |  | Systems Integration Testing (SIT) | Complete | COMPLETE | MHHS-ART148 | T3-TE-0014 | SITAG | T3 |  |
| 642 | 1.4.1.4.1.4 | **Test cases** |  | 160d | 2023-05-01 A | 2023-12-08 A |  | 100% | 2023-05-01 | 2023-12-08 | 160d | 2023-05-01 | 2023-09-01 |  |  | N/A | N/A | SIT | 5.6 | N/A | Systems Integration Testing (SIT) |  |  |  |  |  |  |  |
| 643 | 1.4.1.4.1.4.1 | **SI Test cases** |  | 160d | 2023-05-01 A | 2023-12-08 A |  | 100% | 2023-05-01 | 2023-12-08 | 160d | 2023-05-01 | 2023-09-01 |  |  | N/A | N/A | SIT | 5.6 | N/A | Systems Integration Testing (SIT) |  |  |  |  |  |  |  |
| 644 | 1.4.1.4.1.4.1.1 | **Batch 1 (CIT Intervals 1 and 2)** |  | 110d | 2023-05-01 A | 2023-09-29 A |  | 100% | 2023-05-01 | 2023-09-29 | 110d |  |  |  |  | N/A | N/A | SIT | 5.6 | N/A | Systems Integration Testing (SIT) |  |  |  |  |  |  | -290.67 |
| 645 | 1.4.1.4.1.4.1.1.1 | Develop Test cases |  | 100d | 2023-05-01 A | 2023-09-15 A | 639 | 100% | 2023-05-01 | 2023-09-15 | 100d | 2023-05-01 | 2023-07-28 |  |  | SI Test |  | SIT | 5.6 |  | Systems Integration Testing (SIT) | Complete | COMPLETE |  |  |  |  |  |
| 646 | 1.4.1.4.1.4.1.1.2 | Review Test cases with SIT Working Group |  | 9d | 2023-09-18 A | 2023-09-28 A | 645 | 100% | 2023-09-18 | 2023-09-28 | 9d | 2023-05-26 | 2023-08-25 |  |  | SI Test | PP,IPA | SIT | 5.6 |  | Systems Integration Testing (SIT) | Complete | COMPLETE |  |  |  |  |  |
| 647 | 1.4.1.4.1.4.1.1.3 | SIT Component Integration Testing Test cases Batch 1 (CIT Intervals 1 and 2) approved at ETMAG | milestone | 0d | 2023-09-29 A | 2023-09-29 A | 646FS+1d | 100% | 2023-09-29 | 2023-09-29 | 0d | 2023-09-01 | 2023-09-01 |  |  | SI Test | PP | SIT | 5.6 |  | Systems Integration Testing (SIT) | Complete | COMPLETE | MHHS-ART073 | T3-TE-0069 | SITAG | T3 |  |
| 648 | 1.4.1.4.1.4.1.2 | **Batch 2 (CIT Intervals 3 and 4)** |  | 25d | 2023-10-02 A | 2023-11-03 A |  | 100% | 2023-10-02 | 2023-11-03 | 25d |  |  |  |  | N/A | N/A | SIT | 5.6 | N/A | Systems Integration Testing (SIT) |  |  |  |  |  |  | -290.67 |
| 649 | 1.4.1.4.1.4.1.2.1 | Develop Test cases |  | 15d | 2023-10-02 A | 2023-10-20 A | 647 | 100% | 2023-10-02 | 2023-10-20 | 15d | 2023-05-01 | 2023-07-28 |  |  | SI Test |  | SIT | 5.6 |  | Systems Integration Testing (SIT) | Complete | COMPLETE |  |  |  |  |  |
| 650 | 1.4.1.4.1.4.1.2.2 | Review Test cases with SIT Working Group |  | 9d | 2023-10-23 A | 2023-11-02 A | 649 | 100% | 2023-10-23 | 2023-11-02 | 9d | 2023-05-26 | 2023-08-25 |  |  | SI Test | PP,IPA | SIT | 5.6 |  | Systems Integration Testing (SIT) | Complete | COMPLETE |  |  |  |  |  |
| 651 | 1.4.1.4.1.4.1.2.3 | SIT Component Integration Testing Test cases Batch 2 (CIT Intervals 3 and 4) approved at ETMAG | milestone | 0d | 2023-11-03 A | 2023-11-03 A | 650FS+1d | 100% | 2023-11-03 | 2023-11-03 | 0d | 2023-09-01 | 2023-09-01 |  |  | SI Test | PP | SIT | 5.11 |  | Systems Integration Testing (SIT) | Complete | COMPLETE |  | T3-TE-0104 | SITAG | T3 |  |
| 652 | 1.4.1.4.1.4.1.3 | **Batch 3 (CIT Intervals 5 and 6)** |  | 25d | 2023-11-03 A | 2023-12-08 A |  | 100% | 2023-11-03 | 2023-12-08 | 25d |  |  |  |  | N/A | N/A | SIT | 5.6 | N/A | Systems Integration Testing (SIT) |  |  |  |  |  |  | -290.67 |
| 653 | 1.4.1.4.1.4.1.3.1 | Develop Test cases |  | 15d | 2023-11-03 A | 2023-11-24 A | 651 | 100% | 2023-11-03 | 2023-11-24 | 15d | 2023-05-01 | 2023-07-28 |  |  | SI Test |  | SIT | 5.6 |  | Systems Integration Testing (SIT) | Complete | COMPLETE |  |  |  |  |  |
| 654 | 1.4.1.4.1.4.1.3.2 | Review Test cases with SIT Working Group |  | 9d | 2023-11-27 A | 2023-12-07 A | 653 | 100% | 2023-11-27 | 2023-12-07 | 9d | 2023-05-26 | 2023-08-25 |  |  | SI Test | PP,IPA | SIT | 5.6 |  | Systems Integration Testing (SIT) | Complete | COMPLETE |  |  |  |  |  |
| 655 | 1.4.1.4.1.4.1.3.3 | SIT Component Integration Testing Test cases Batch 3 (CIT Intervals 5 and 6) approved at ETMAG | milestone | 0d | 2023-12-08 A | 2023-12-08 A | 654FS+1d | 100% | 2023-12-08 | 2023-12-08 | 0d | 2023-09-01 | 2023-09-01 |  |  | SI Test | PP | SIT | 5.14 |  | Systems Integration Testing (SIT) | Complete | COMPLETE |  | T3-TE-0105 | SITAG | T3 |  |
| 656 | 1.4.1.4.1.5 | **CIT Interval 1 Preparation** |  | 283d | 2022-11-16 A | 2023-12-15 A |  | 100% | 2022-11-16 | 2023-12-15 | 278d | 2022-11-16 | 2023-10-23 |  | -0 | N/A | N/A | SIT | 5.6 | N/A | Systems Integration Testing (SIT) |  |  |  |  |  |  |  |
| 657 | 1.4.1.4.1.5.1 | **Environments (SIT A)** |  | 246d | 2022-11-16 A | 2023-10-25 A |  | 100% | 2022-11-16 | 2023-10-25 | 239d | 2022-11-16 | 2023-10-06 |  |  | N/A | N/A | SIT | 5.0 | N/A | Systems Integration Testing (SIT) |  |  |  |  |  |  |  |
| 658 | 1.4.1.4.1.5.1.1 | PPs register PKI Officers and request PKI certificates |  | 5d | 2023-10-09 A | 2023-10-13 A |  | 100% | 2023-10-09 | 2023-10-13 | 5d | 2023-08-28 | 2023-09-01 | start no earlier than 2023-10-09 |  | PP | DIP Provider | SIT | 5.5 | Simon Berry | Systems Integration Testing (SIT) | Complete | COMPLETE |  |  |  |  |  |
| 659 | 1.4.1.4.1.5.1.2 | PPs register PKI Officers and request PKI certificates Complete - Interval 1 | milestone | 0d | 2023-10-25 A | 2023-10-25 A | 658FS+8d | 100% | 2023-10-25 | 2023-10-25 | 0d |  |  |  |  | PP | DIP Provider | SIT | 5.10 | Simon Berry | Systems Integration Testing (SIT) | Complete | COMPLETE |  | T3-TE-0094 | SITAG | T3 |  |
| 660 | 1.4.1.4.1.5.1.3 | PP SIT A environment preparation (incl. security certificates and security compliance) |  | 238d | 2022-11-16 A | 2023-10-13 A | 549 | 100% | 2022-11-16 | 2023-10-13 | 208d | 2022-11-16 | 2023-09-01 |  |  | PP | SI Test | SIT | 5.8 | Simon Berry | Systems Integration Testing (SIT) | Complete | COMPLETE |  |  |  |  |  |
| 661 | 1.4.1.4.1.5.1.4 | SI coordinate SIT Participants' SIT A environment preparation |  | 238d | 2022-11-16 A | 2023-10-13 A | 660SS | 100% | 2022-11-16 | 2023-10-13 | 208d | 2022-11-16 | 2023-09-01 |  |  | SI Test | PP | SIT | 5.8 | Simon Berry | Systems Integration Testing (SIT) | Complete | COMPLETE |  |  |  |  |  |
| 662 | 1.4.1.4.1.5.1.5 | PP submit self-declaration of environment preparation complete (incl. security certificates and security compliance) to Programme for assurance | milestone | 0d | 2023-10-13 A | 2023-10-13 A | 660FF | 100% | 2023-10-13 | 2023-10-13 | 0d | 2023-09-01 | 2023-09-01 | start no earlier than 2023-10-13 |  | PP | SI Test | SIT | 5.8 | Simon Berry | Systems Integration Testing (SIT) | Complete | COMPLETE |  |  |  |  |  |
| 663 | 1.4.1.4.1.5.1.6 | SI assure PPs' self-declaration of environment preparation complete (incl. security certificates and security compliance) |  | 5d | 2023-10-16 A | 2023-10-20 A | 662FF+5d | 100% | 2023-10-16 | 2023-10-20 | 5d | 2023-09-04 | 2023-09-08 |  |  | SI Test | PP | SIT | 5.8 | Simon Berry | Systems Integration Testing (SIT) | Complete | COMPLETE |  |  |  |  |  |
| 664 | 1.4.1.4.1.5.1.7 | SIT Participants' SIT A environments ready to start connectivity proving CIT Interval 1 | milestone | 0d | 2023-09-01 A | 2023-09-01 A | 662SS | 100% | 2023-09-01 | 2023-09-01 | 0d | 2023-09-01 | 2023-09-01 |  |  | PP | PP,IPA | SIT | 5.6 | Simon Berry | Systems Integration Testing (SIT) | Complete | COMPLETE | MHHS-ART139 | T3-TE-0019 | SITAG | T3 |  |
| 665 | 1.4.1.4.1.5.1.8 | PP SIT A environment connectivity proving |  | 10d | 2023-09-04 A | 2023-09-15 A | 664 | 100% | 2023-09-04 | 2023-09-15 | 20d | 2023-09-04 | 2023-09-29 |  |  | PP | SI Test | SIT | 5.8 | Simon Berry | Systems Integration Testing (SIT) | Complete | COMPLETE |  |  |  |  |  |
| 666 | 1.4.1.4.1.5.1.9 | SI coordinate SIT Participants' SIT A environment connectivity proving |  | 10d | 2023-09-04 A | 2023-09-15 A | 665SS | 100% | 2023-09-04 | 2023-09-15 | 20d | 2023-09-04 | 2023-09-29 |  |  | SI Test | PP | SIT | 5.8 | Simon Berry | Systems Integration Testing (SIT) | Complete | COMPLETE |  |  |  |  |  |
| 667 | 1.4.1.4.1.5.1.10 | PP deployment of MHHS solution code to SIT A environments |  | 10d | 2023-09-25 A | 2023-10-06 A | 708FF | 100% | 2023-09-25 | 2023-10-06 | 10d | 2023-09-18 | 2023-09-29 |  |  | PP | SI Test | SIT | 5.0 | Simon Berry | Systems Integration Testing (SIT) | Complete | COMPLETE |  |  |  |  |  |
| 668 | 1.4.1.4.1.5.1.11 | SI coordinate deployment of MHHS solution code to SIT Participants' SIT A environments |  | 10d | 2023-09-25 A | 2023-10-06 A | 708FF | 100% | 2023-09-25 | 2023-10-06 | 10d | 2023-09-18 | 2023-09-29 |  |  | SI Test | PP | SIT | 5.0 | Simon Berry | Systems Integration Testing (SIT) | Complete | COMPLETE |  |  |  |  |  |
| 669 | 1.4.1.4.1.5.1.12 | PP submit evidence of SIT A environment connectivity proving and code deployment completion to Programme for assurance |  | 30d | 2023-09-04 A | 2023-10-13 A | 665SS | 100% | 2023-09-04 | 2023-10-13 | 20d | 2023-09-04 | 2023-09-29 |  |  | PP | SI Test | SIT | 5.8 | Simon Berry | Systems Integration Testing (SIT) | Complete | COMPLETE |  |  |  |  |  |
| 670 | 1.4.1.4.1.5.1.13 | SI assurance of SIT Participants' SIT A environment connectivity proving and code deployment completion |  | 25d | 2023-09-18 A | 2023-10-20 A | 669FF+5d | 100% | 2023-09-18 | 2023-10-20 | 25d | 2023-09-04 | 2023-10-06 |  |  | SI Test | PP | SIT | 5.8 | Simon Berry | Systems Integration Testing (SIT) | Complete | COMPLETE |  |  |  |  |  |

Notes:
- 647: Guidance: 18/8 - needs to finish on 29/9 for ETWAG / Action: 18/8 - needs to finish on 29/9 for ETWAG. Update Milestone register after approval
- 651: Guidance: 18/8 - needs to finish on 3/11 for ETWAG / Action: 18/8 - needs to finish on 29/9 for ETWAG
- 655: Guidance: 28/11 - Red because TMAG date has moved from 8/12 to 20/12 due to reduction in Dec TMAGs. No impact. No action

| ID | WBS | Task | Type | Duration | Start | Finish | Predecessors | Complete | Baseline start | Baseline finish | Baseline duration | Baseline cost | Responsible | Involved | Text9 | Task Status | Update Version | MHHS Resource Name | MHHS Programme Phase | Sched Status | RAG | Action | Milestone ID | Text29 | Tier | Artefact ID |
| --- | --- | --- | --- | --- | --- | --- | --- | --- | --- | --- | --- | --- | --- | --- | --- | --- | --- | --- | --- | --- | --- | --- | --- | --- | --- | --- |
| 671 | 1.4.1.4.1.5.2 | **Test Data - ISD Creation** |  | 9d | 2023-08-22 A | 2023-09-01 A |  | 100% | 2023-08-22 | 2023-09-01 | 9d |  | N/A | N/A | SIT | -275.67 | 5.5 | N/A | Systems Integration Testing (SIT) |  |  |  |  |  |  |  |
| 672 | 1.4.1.4.1.5.2.1 | Set-up Market Participants and DIP ID Data |  | 8d | 2023-08-22 A | 2023-08-31 A |  | 100% | 2023-08-22 | 2023-08-31 | 8d |  | SI Test Data | SI Test, DIP, Helix | SIT |  | 5.5 | Cesar Lopes | Systems Integration Testing (SIT) | Complete | COMPLETE |  |  |  |  |  |
| 673 | 1.4.1.4.1.5.2.2 | Distribute ISD Data to Participants |  | 1d | 2023-09-01 A | 2023-09-01 A | 672 | 100% | 2023-09-01 | 2023-09-01 | 1d |  | SI Test Data | SI Test, DIP, Helix | SIT |  | 5.5 | Cesar Lopes | Systems Integration Testing (SIT) | Complete | COMPLETE |  |  |  |  |  |
| 674 | 1.4.1.4.1.5.2.3 | Test Data - ISD Creation Complete | milestone | 0d | 2023-09-01 A | 2023-09-01 A | 673 | 100% | 2023-09-01 | 2023-09-01 | 0d |  | SI Test Data | SI Test, DIP, Helix | SIT |  | 5.5 | Cesar Lopes | Systems Integration Testing (SIT) | Complete | COMPLETE | 3/8 - add as t3 milestones. Awaiting approval at TMAG | T3-TE-0083 | SITAG | T3 |  |
| 675 | 1.4.1.4.1.5.3 | **Test Data - SFTP Onboarding** |  | 70d | 2023-08-21 A | 2023-11-24 A |  | 100% | 2023-08-21 | 2023-11-24 | 70d | -0 | N/A | N/A | SIT | -275.67 | 5.5 | N/A | Systems Integration Testing (SIT) |  |  |  |  |  |  |  |
| 676 | 1.4.1.4.1.5.3.1 | Create Containers and Keys for Participants |  | 3d | 2023-08-21 A | 2023-08-23 A |  | 100% | 2023-08-21 | 2023-08-23 | 3d |  | SI Test Data | SI Test | SIT |  | 5.5 | Cesar Lopes | Systems Integration Testing (SIT) | Complete | COMPLETE |  |  |  |  |  |
| 677 | 1.4.1.4.1.5.3.2 | Share SFTP Access with Participants |  | 5d | 2023-08-24 A | 2023-08-30 A | 676 | 100% | 2023-08-24 | 2023-08-30 | 5d |  | SI Test Data | SI Test, PP | SIT |  | 5.5 | Cesar Lopes | Systems Integration Testing (SIT) | Complete | COMPLETE |  |  |  |  |  |
| 678 | 1.4.1.4.1.5.3.3 | Test SFTP Connectivity |  | 5d | 2023-08-31 A | 2023-09-06 A | 677 | 100% | 2023-08-31 | 2023-09-06 | 5d |  | SI Test Data | SI Test, PP | SIT |  | 5.5 | Cesar Lopes | Systems Integration Testing (SIT) | Complete | COMPLETE |  |  |  |  |  |
| 679 | 1.4.1.4.1.5.3.4 | Test Data - SFTP Onboarding Complete | milestone | 0d | 2023-11-24 A | 2023-11-24 A | 678FS+57d | 100% | 2023-11-24 | 2023-11-24 | 0d |  | SI Test Data | SI Test, PP | SIT |  | 5.13 | Cesar Lopes | Systems Integration Testing (SIT) | Complete | COMPLETE |  | T3-TE-0084 | SITAG | T3 |  |
| 680 | 1.4.1.4.1.5.4 | **Test Data - Provide Sample Files** |  | 10d | 2023-08-21 A | 2023-09-01 A |  | 100% | 2023-08-21 | 2023-09-01 | 10d |  | N/A | N/A | SIT | -275.67 | 5.5 | N/A | Systems Integration Testing (SIT) |  |  |  |  |  |  |  |
| 681 | 1.4.1.4.1.5.4.1 | Generate Sample Files off IF Messages |  | 8d | 2023-08-21 A | 2023-08-30 A |  | 100% | 2023-08-21 | 2023-08-30 | 8d |  | SI Test Data | SI Test | SIT |  | 5.5 | Cesar Lopes | Systems Integration Testing (SIT) | Complete | COMPLETE |  |  |  |  |  |
| 682 | 1.4.1.4.1.5.4.2 | Transmit Sample Files off IF Messages to Participants (More detail needs to be planned for a POC) |  | 2d | 2023-08-31 A | 2023-09-01 A | 681 | 100% | 2023-08-31 | 2023-09-01 | 2d |  | SI Test Data | SI Test | SIT |  | 5.5 | Cesar Lopes | Systems Integration Testing (SIT) | Complete | COMPLETE |  |  |  |  |  |
| 683 | 1.4.1.4.1.5.4.3 | Test Data - Provide Sample Files Complete | milestone | 0d | 2023-09-01 A | 2023-09-01 A | 682 | 100% | 2023-09-01 | 2023-09-01 | 0d |  | SI Test Data | SI Test | SIT |  | 5.5 | Cesar Lopes | Systems Integration Testing (SIT) | Complete | COMPLETE | 3/8 - add as t3 milestones. Awaiting approval at TMAG | T3-TE-0085 | SITAG | T3 |  |
| 684 | 1.4.1.4.1.5.5 | **Test Data - Detailed SIT Data Load Guidance** |  | 65d | 2023-09-07 A | 2023-12-06 A |  | 100% | 2023-09-07 | 2023-12-06 | 62d | -0 | N/A | N/A | SIT | -275.67 | 5.5 | N/A | Systems Integration Testing (SIT) |  |  |  |  |  |  |  |
| 685 | 1.4.1.4.1.5.5.1 | Document Guidance |  | 21d | 2023-09-07 A | 2023-10-05 A | 683FS+3d | 100% | 2023-09-07 | 2023-10-05 | 16d |  | SI Test Data | SI Test | SIT |  | 5.9 | Cesar Lopes | Systems Integration Testing (SIT) | Complete | COMPLETE |  |  |  |  |  |
| 686 | 1.4.1.4.1.5.5.2 | Provide Guidance to PPs |  | 1d | 2023-10-06 A | 2023-10-06 A | 685 | 100% | 2023-10-06 | 2023-10-06 | 1d |  | SI Test Data | SI Test | SIT |  | 5.9 | Cesar Lopes | Systems Integration Testing (SIT) | Complete | COMPLETE |  |  |  |  |  |
| 687 | 1.4.1.4.1.5.5.3 | Test Data - Detailed SIT Functional Data Load Guidance Complete | milestone | 0d | 2023-12-06 A | 2023-12-06 A | 686FS+43d | 100% | 2023-12-06 | 2023-12-06 | 0d |  | SI Test Data | SI Test | SIT |  | 5.13 | Michael Inije | Systems Integration Testing (SIT) | Complete | COMPLETE |  | T3-TE-0095 | SITAG | T3 | MHHS-DEL 1545 |
| 688 | 1.4.1.4.1.5.6 | **Test Data - Population of Data Items for Testing Guidance - Draft** |  | 80d | 2023-08-17 A | 2023-12-06 A |  | 100% | 2023-08-17 | 2023-12-06 | 77d | -0 | N/A | N/A | SIT | -275.67 | 5.5 | N/A | Systems Integration Testing (SIT) |  |  |  |  |  |  |  |
| 689 | 1.4.1.4.1.5.6.1 | Document Guidance - Draft |  | 11d | 2023-08-17 A | 2023-08-31 A | 878 | 100% | 2023-08-17 | 2023-08-31 | 11d |  | SI Test Data | SI Test | SIT |  | 5.6 | Cesar Lopes | Systems Integration Testing (SIT) | Complete | COMPLETE |  |  |  |  |  |
| 690 | 1.4.1.4.1.5.6.2 | Provide Guidance to PPs - Draft |  | 1d | 2023-09-01 A | 2023-09-01 A | 689 | 100% | 2023-09-01 | 2023-09-01 | 1d |  | SI Test Data | SI Test | SIT |  | 5.6 | Cesar Lopes | Systems Integration Testing (SIT) | Complete | COMPLETE |  |  |  |  |  |
| 691 | 1.4.1.4.1.5.6.3 | Test Data - Population of Data Items for Testing Guidance - Draft Complete | milestone | 0d | 2023-12-06 A | 2023-12-06 A | 690FS+68d | 100% | 2023-12-06 | 2023-12-06 | 0d |  | SI Test Data | SI Test | SIT |  | 5.13 | Michael Inije | Systems Integration Testing (SIT) | Complete | COMPLETE |  | T3-TE-0096 | SITAG | T3 | MHHS-DEL 816 |
| 692 | 1.4.1.4.1.5.7 | **Test Data - Population of Data Items for Testing Guidance - Final** |  | 87d | 2023-08-17 A | 2023-12-15 A |  | 100% | 2023-08-17 | 2023-12-15 | 45d |  | N/A | N/A | SIT | -275.67 | 5.5 | N/A | Systems Integration Testing (SIT) |  |  |  |  |  |  |  |
| 693 | 1.4.1.4.1.5.7.1 | Update Document Guidance With PPS Feedback |  | 81d | 2023-08-17 A | 2023-12-07 A | 689SS | 100% | 2023-08-17 | 2023-12-07 | 44d |  | SI Test Data | SI Test | SIT |  | 5.5 | Michael Inije | Systems Integration Testing (SIT) | Complete | COMPLETE |  |  |  |  |  |
| 694 | 1.4.1.4.1.5.7.2 | Provide Final Guidance to PPs |  | 1d | 2023-12-08 A | 2023-12-08 A | 693 | 100% | 2023-12-08 | 2023-12-08 | 1d |  | SI Test Data | SI Test | SIT |  | 5.5 | Michael Inije | Systems Integration Testing (SIT) | Complete | COMPLETE |  |  |  |  |  |
| 695 | 1.4.1.4.1.5.7.3 | Test Data - Population of Data Items for Testing Guidance - Final Complete | milestone | 0d | 2023-12-15 A | 2023-12-15 A | 694FS+5d | 100% | 2023-12-15 | 2023-12-15 | 0d |  | SI Test Data | SI Test | SIT |  | 5.14 | Michael Inije | Systems Integration Testing (SIT) | Complete | COMPLETE |  | T3-TE-0097 | SITAG | T3 | MHHS-DEL 816 |

| ID | WBS | Task | Type | Duration | Start | Finish | Predecessors | Complete | Baseline start | Baseline finish | Baseline duration | Baseline 1 start | Baseline 1 finish | Constraint | Baseline cost | Responsible | Involved | Text9 | Update Version | MHHS Resource Name | MHHS Programme Phase | Sched Status | RAG | Artefact ID | Milestone ID | Text29 | Tier |
| --- | --- | --- | --- | --- | --- | --- | --- | --- | --- | --- | --- | --- | --- | --- | --- | --- | --- | --- | --- | --- | --- | --- | --- | --- | --- | --- | --- |
| 696 | 1.4.1.4.1.5.8 | **Test Data (SIT A) Interval 1** |  | 40d | 2023-09-04 A | 2023-10-27 A |  | 100% | 2023-09-04 | 2023-10-27 | 20d | 2023-09-04 | 2023-09-29 |  |  | N/A | N/A | SIT | 5.0 | N/A | Systems Integration Testing (SIT) |  |  |  |  |  |  |
| 697 | 1.4.1.4.1.5.8.1 | Run data allocation |  | 4d | 2023-09-04 A | 2023-09-07 A | 637, 674 | 100% | 2023-09-04 | 2023-09-07 | 4d | 2023-09-04 | 2023-09-07 |  |  | SI Test |  | SIT | 5.0 | Cesar Lopes | Systems Integration Testing (SIT) | Complete | COMPLETE |  |  |  |  |
| 698 | 1.4.1.4.1.5.8.2 | Cleanse, anonymise and populate data post cut |  | 4d | 2023-09-08 A | 2023-09-13 A | 697 | 100% | 2023-09-08 | 2023-09-13 | 4d | 2023-09-08 | 2023-09-13 |  |  | SI Test |  | SIT | 5.0 | Cesar Lopes | Systems Integration Testing (SIT) | Complete | COMPLETE |  |  |  |  |
| 699 | 1.4.1.4.1.5.8.3 | Transmit data sets to PPs |  | 3d | 2023-09-15 A | 2023-09-19 A | 698 | 100% | 2023-09-15 | 2023-09-19 | 1d | 2023-09-14 | 2023-09-15 |  |  | SI Test |  | SIT | 5.0 | Cesar Lopes | Systems Integration Testing (SIT) | Complete | COMPLETE |  |  |  |  |
| 700 | 1.4.1.4.1.5.8.4 | PP - Load test data to test environments |  | 7d | 2023-09-20 A | 2023-09-28 A | 699, 683 | 100% | 2023-09-20 | 2023-09-28 | 5d | 2023-09-18 | 2023-09-22 |  |  | PP |  | SIT | 5.0 | Cesar Lopes | Systems Integration Testing (SIT) | Complete | COMPLETE |  |  |  |  |
| 701 | 1.4.1.4.1.5.8.5 | PP Check data integrity on test environment |  | 1d | 2023-09-29 A | 2023-09-29 A | 700 | 100% | 2023-09-29 | 2023-09-29 | 5d | 2023-09-25 | 2023-09-29 |  |  | PP |  | SIT | 5.0 | Cesar Lopes | Systems Integration Testing (SIT) | Complete | COMPLETE |  |  |  |  |
| 702 | 1.4.1.4.1.5.8.6 | PP submit self-declaration to Programme to confirm loading & verification of test data | milestone | 0d | 2023-09-29 A | 2023-09-29 A | 701FF | 100% | 2023-09-29 | 2023-09-29 | 0d | 2023-09-29 | 2023-09-29 |  |  | PP | SI Test | SIT | 5.0 | Cesar Lopes | Systems Integration Testing (SIT) | Complete | COMPLETE |  |  |  |  |
| 703 | 1.4.1.4.1.5.8.7 | Test Data (SIT A) Interval 1 Complete | milestone | 0d | 2023-10-27 A | 2023-10-27 A | 702FS+20d | 100% | 2023-10-27 | 2023-10-27 | 0d |  |  |  |  | SI Test | PP | SIT | 5.10 | Cesar Lopes | Systems Integration Testing (SIT) | Complete | COMPLETE | MHHS-ART148/169 | T3-TE-0073 | SITAG | T3 |
| 704 | 1.4.1.4.1.5.9 | **Other Preparation** |  | 45d | 2023-07-03 A | 2023-09-01 A |  | 100% | 2023-07-03 | 2023-09-01 | 45d | 2023-07-03 | 2023-09-01 |  |  | N/A | N/A | SIT | 5.0 | N/A | Systems Integration Testing (SIT) |  |  |  |  |  |  |
| 705 | 1.4.1.4.1.5.9.1 | Onboarding of Test Participants to Test Management Tool (Azure DevOps) |  | 45d | 2023-07-03 A | 2023-09-01 A | 664SF | 100% | 2023-07-03 | 2023-09-01 | 45d | 2023-07-03 | 2023-09-01 |  |  | SI Test | PP | SIT | 5.0 |  | Systems Integration Testing (SIT) | Complete | COMPLETE |  |  |  |  |
| 706 | 1.4.1.4.1.5.9.2 | Test Management Tool onboarding |  | 45d | 2023-07-03 A | 2023-09-01 A | 664SF | 100% | 2023-07-03 | 2023-09-01 | 45d | 2023-07-03 | 2023-09-01 |  |  | PP | SI Test | SIT | 5.0 |  | Systems Integration Testing (SIT) | Complete | COMPLETE |  |  |  |  |
| 707 | 1.4.1.4.1.5.10 | **SIT Component Integration Test Readiness Report** |  | 28d | 2023-09-14 A | 2023-10-23 A |  | 100% | 2023-09-14 | 2023-10-23 | 9d | 2023-09-11 | 2023-10-20 |  |  | N/A | N/A | SIT | 5.6 | N/A | Systems Integration Testing (SIT) |  |  |  |  |  |  |
| 708 | 1.4.1.4.1.5.10.1 | PP submit Test Readiness Report to Programme for assurance | milestone | 0d | 2023-10-20 A | 2023-10-20 A | 706, 647, 703 | 100% | 2023-10-20 | 2023-10-20 | 0d | 2023-09-29 | 2023-09-29 | start no earlier than 2023-10-09 |  | PP | SI Test | SIT | 5.6 |  | Systems Integration Testing (SIT) | Complete | COMPLETE |  |  |  |  |
| 709 | 1.4.1.4.1.5.10.2 | SI assure Test Participants' Test Readiness Reports |  | 1d | 2023-10-23 A | 2023-10-23 A | 708SS | 100% | 2023-10-23 | 2023-10-23 | 5d | 2023-10-02 | 2023-10-06 |  |  | SI Test | PP,IPA | SIT | 5.6 |  | Systems Integration Testing (SIT) | Complete | COMPLETE |  |  |  |  |
| 710 | 1.4.1.4.1.5.10.3 | SI develop Overarching SIT Component Integration Test Readiness Report |  | 23d | 2023-09-14 A | 2023-10-16 A | 633FS+40d | 100% | 2023-09-14 | 2023-10-16 | 4d | 2023-09-11 | 2023-10-06 |  |  | SI Test |  | SIT | 5.6 |  | Systems Integration Testing (SIT) | Complete | COMPLETE |  |  |  |  |
| 711 | 1.4.1.4.1.5.10.4 | Artefact review (via TMAG) and updates |  | 4d | 2023-10-17 A | 2023-10-20 A | 710 | 100% | 2023-10-17 | 2023-10-20 | 5d | 2023-10-09 | 2023-10-20 |  |  | SI Test | PP,IPA | SIT | 5.6 |  | Systems Integration Testing (SIT) | Complete | COMPLETE |  |  |  |  |
| 712 | 1.4.1.4.1.5.11 | SIT Component Integration Testing 1 Preparation Complete (incl. approval of SI SIT Component Integration Test Readiness Report) | milestone | 0d | 2023-10-27 A | 2023-10-27 A | 711FS+1d, 708, 664, 706, 703, 263, 268, 257, 277, 278, 709 | 100% | 2023-10-27 | 2023-10-27 | 0d | 2023-10-23 | 2023-10-23 |  |  | SI Test | PP,IPA | SIT | 5.11 |  | Systems Integration Testing (SIT) | Complete | COMPLETE | MHHS-ART071 | T2-TE-0250 | SITAG | T2 |
| 713 | 1.4.1.4.1.6 | **CIT Interval 2 Preparation** |  | 103d | 2023-07-03 A | 2023-11-22 A |  | 100% | 2023-07-03 | 2023-11-22 | 95d | 2022-11-16 | 2023-11-06 |  | -0 | N/A | N/A | SIT | 5.0 | N/A | Systems Integration Testing (SIT) |  |  |  |  |  |  |
| 714 | 1.4.1.4.1.6.1 | **Environments (SIT A)** |  | 43d | 2023-09-22 A | 2023-11-22 A |  | 100% | 2023-09-22 | 2023-11-22 | 35d | 2022-11-16 | 2023-10-27 |  | -0 | N/A | N/A | SIT | 5.0 | N/A | Systems Integration Testing (SIT) |  |  |  |  |  |  |
| 715 | 1.4.1.4.1.6.1.1 | SIT Participants' SIT A environments ready to start connectivity proving CIT Interval 2 | milestone | 0d | 2023-09-22 A | 2023-09-22 A |  | 100% | 2023-09-22 | 2023-09-22 | 0d | 2023-09-22 | 2023-09-22 |  |  | PP | PP,IPA | SIT | 5.6 | Simon Berry | Systems Integration Testing (SIT) | Complete | COMPLETE | MHHS-ART139 | T3-TE-0020 | SITAG | T3 |
| 716 | 1.4.1.4.1.6.1.2 | Programme Participants Ready to Start Connectivity Proving | milestone | 0d | 2023-09-22 A | 2023-09-22 A |  | 100% | 2023-09-22 | 2023-09-22 | 0d |  |  | finish no earlier than 2023-09-22 |  | PP |  | SIT | 5.10 | Simon Berry | Systems Integration Testing (SIT) | Complete | COMPLETE |  |  |  |  |
| 717 | 1.4.1.4.1.6.1.3 | Internal Connectivity Proving Phase |  | 10d | 2023-09-25 A | 2023-10-06 A | 716 | 100% | 2023-09-25 | 2023-10-06 | 10d |  |  |  |  | PP |  | SIT | 5.10 | Simon Berry | Systems Integration Testing (SIT) | Complete | COMPLETE |  |  |  |  |
| 718 | 1.4.1.4.1.6.1.4 | Internal Connectivity Proving Phase Complete | milestone | 0d | 2023-10-06 A | 2023-10-06 A | 717 | 100% | 2023-10-06 | 2023-10-06 | 0d |  |  | start no earlier than 2023-10-06 |  | PP |  | SIT | 5.10 | Simon Berry | Systems Integration Testing (SIT) | Complete | COMPLETE |  |  |  |  |
| 719 | 1.4.1.4.1.6.1.5 | DIP Onboarding Activity (1. PKI Officers and Certificates, 2. Set-up Validation, 3. End Point Creation, 4. Controlled Smoke Test ) |  | 28d | 2023-10-16 A | 2023-11-22 A | 718FS+5d | 100% | 2023-10-16 | 2023-11-22 | 20d |  |  |  |  | PP |  | SIT | 5.10 | Simon Berry | Systems Integration Testing (SIT) | Complete | COMPLETE |  |  |  |  |
| 720 | 1.4.1.4.1.6.1.6 | DIP Onboarding Complete | milestone | 0d | 2023-11-22 A | 2023-11-22 A | 719 | 100% | 2023-11-22 | 2023-11-22 | 0d |  |  |  |  | PP |  | SIT | 5.10 | Simon Berry | Systems Integration Testing (SIT) | Complete | COMPLETE |  |  |  |  |
| 721 | 1.4.1.4.1.6.1.7 | PPs Register PKI Officers and request PKI certificates Complete - Interval 2 | milestone | 0d | 2023-11-22 A | 2023-11-22 A | 720 | 100% | 2023-11-22 | 2023-11-22 | 0d |  |  |  |  | PP | DIP Provider | SIT | 5.15 | Simon Berry | Systems Integration Testing (SIT) | Complete | COMPLETE |  | T3-TE-0098 | SITAG | T3 |
| 722 | 1.4.1.4.1.6.1.8 | PP Code Deployment | milestone | 0d | 2023-10-20 A | 2023-10-20 A |  | 100% | 2023-10-20 | 2023-10-20 | 0d |  |  | start no earlier than 2023-10-20 |  | PP |  | SIT | 5.10 | Simon Berry | Systems Integration Testing (SIT) | Complete | COMPLETE |  |  |  |  |

Notes:
- 703: Action: 28/7: CH: Needs to be set-up as a reporting milestone. 31/7: Check with Cesar if has been approved so can be baselined
- 707: Action: 21/8 - Rework with Lee
- 709: Action: 21/8 - Rework with Lee
- 710: Action: 21/8 - Rework with Lee
- 711: Action: 21/8 - Rework with Lee

| ID | WBS | Task | Type | Duration | Start | Finish | Predecessors | Complete | Baseline start | Baseline finish | Baseline duration | Baseline 1 start | Baseline 1 finish | Constraint | Baseline cost | Responsible | Involved | Text9 | Update Version | MHHS Resource Name | MHHS Programme Phase | Sched Status | RAG | Artefact ID | Milestone ID | Text29 | Tier |
| --- | --- | --- | --- | --- | --- | --- | --- | --- | --- | --- | --- | --- | --- | --- | --- | --- | --- | --- | --- | --- | --- | --- | --- | --- | --- | --- | --- |
| 723 | 1.4.1.4.1.6.2 | **Test Data (SIT A) Interval 2** |  | 43d | 2023-09-20 A | 2023-11-17 A |  | 100% | 2023-09-20 | 2023-11-17 | 25d | 2023-09-18 | 2023-10-20 |  |  | N/A | N/A | SIT | 5.0 | N/A | Systems Integration Testing (SIT) |  |  |  |  |  |  |
| 724 | 1.4.1.4.1.6.2.1 | Run data allocation |  | 7d | 2023-09-20 A | 2023-09-28 A | 700SS | 100% | 2023-09-20 | 2023-09-28 | 5d | 2023-09-18 | 2023-09-22 |  |  | SI Test |  | SIT | 5.0 | Cesar Lopes | Systems Integration Testing (SIT) | Complete | COMPLETE |  |  |  |  |
| 725 | 1.4.1.4.1.6.2.2 | Cleanse and populate data post cut |  | 2d | 2023-09-29 A | 2023-10-02 A | 724 | 100% | 2023-09-29 | 2023-10-02 | 5d | 2023-09-25 | 2023-09-29 |  |  | SI Test |  | SIT | 5.0 | Cesar Lopes | Systems Integration Testing (SIT) | Complete | COMPLETE |  |  |  |  |
| 726 | 1.4.1.4.1.6.2.3 | Transmit data sets to PPs |  | 1d | 2023-10-03 A | 2023-10-03 A | 725 | 100% | 2023-10-03 | 2023-10-03 | 2d | 2023-10-02 | 2023-10-03 |  |  | SI Test |  | SIT | 5.0 | Cesar Lopes | Systems Integration Testing (SIT) | Complete | COMPLETE |  |  |  |  |
| 727 | 1.4.1.4.1.6.2.4 | PP - Load test data to test environments |  | 33d | 2023-10-04 A | 2023-11-17 A | 726 | 100% | 2023-10-04 | 2023-11-17 | 8d | 2023-10-04 | 2023-10-13 |  |  | PP |  | SIT | 5.0 | Cesar Lopes | Systems Integration Testing (SIT) | Complete | COMPLETE |  |  |  |  |
| 728 | 1.4.1.4.1.6.2.5 | PP Check data integrity on test environment |  | 15d | 2023-10-23 A | 2023-11-17 A | 727FF | 100% | 2023-10-23 | 2023-11-17 | 5d | 2023-10-16 | 2023-10-20 |  |  | PP |  | SIT | 5.0 | Cesar Lopes | Systems Integration Testing (SIT) | Complete | COMPLETE |  |  |  |  |
| 729 | 1.4.1.4.1.6.2.6 | PP submit self-declaration to Programme to confirm loading & verification of test data | milestone | 0d | 2023-11-17 A | 2023-11-17 A | 728FF | 100% | 2023-11-17 | 2023-11-17 | 0d | 2023-10-20 | 2023-10-20 |  |  | PP | SI Test | SIT | 5.0 | Cesar Lopes | Systems Integration Testing (SIT) | Complete | COMPLETE |  |  |  |  |
| 730 | 1.4.1.4.1.6.2.7 | Test Data (SIT A) Interval 2 Complete | milestone | 0d | 2023-11-17 A | 2023-11-17 A | 729 | 100% | 2023-11-17 | 2023-11-17 | 0d |  |  |  |  | SI Test | PP | SIT | 5.12 | Cesar Lopes | Systems Integration Testing (SIT) | Complete | COMPLETE | MHHS-ART148/169 | T3-TE-0074 | SITAG | T3 |
| 731 | 1.4.1.4.1.6.3 | **Other Preparation** |  | 87d | 2023-07-03 A | 2023-10-31 A |  | 100% | 2023-07-03 | 2023-10-31 | 87d | 2023-07-03 | 2023-09-22 |  | -0 | N/A | N/A | SIT | 5.0 | N/A | Systems Integration Testing (SIT) |  |  |  |  |  |  |
| 732 | 1.4.1.4.1.6.3.1 | Onboarding of Test Participants to Test Management Tool (Azure DevOps) |  | 60d | 2023-07-03 A | 2023-09-22 A | 715SF | 100% | 2023-07-03 | 2023-09-22 | 60d | 2023-07-03 | 2023-09-22 |  |  | SI Test | PP | SIT | 5.0 |  | Systems Integration Testing (SIT) | Complete | COMPLETE |  |  |  |  |
| 733 | 1.4.1.4.1.6.3.2 | Test Management Tool onboarding |  | 27d | 2023-09-25 A | 2023-10-31 A | 732 | 100% | 2023-09-25 | 2023-10-31 | 27d | 2023-07-03 | 2023-09-22 |  |  | PP | SI Test | SIT | 5.0 | Simon Berry | Systems Integration Testing (SIT) | Complete | COMPLETE |  |  |  |  |
| 734 | 1.4.1.4.1.6.4 | **SIT Component Integration Test Readiness Report** |  | 25d | 2023-10-02 A | 2023-11-03 A |  | 100% | 2023-10-02 | 2023-11-03 | 25d | 2023-10-02 | 2023-11-03 |  |  | N/A | N/A | SIT | 5.0 | N/A | Systems Integration Testing (SIT) |  |  |  |  |  |  |
| 735 | 1.4.1.4.1.6.4.1 | PP submit Test Readiness Report to Programme for assurance | milestone | 0d | 2023-10-25 A | 2023-10-25 A | 647FS+18d | 100% | 2023-10-25 | 2023-10-25 | 0d | 2023-10-20 | 2023-10-20 |  |  | PP | SI Test | SIT | 5.0 |  | Systems Integration Testing (SIT) | Complete | COMPLETE |  |  |  |  |
| 736 | 1.4.1.4.1.6.4.2 | SI assure Test Participants' Test Readiness Reports |  | 2d | 2023-10-26 A | 2023-10-27 A | 735 | 100% | 2023-10-26 | 2023-10-27 | 5d | 2023-10-23 | 2023-10-27 |  |  | SI Test | PP,IPA | SIT | 5.0 |  | Systems Integration Testing (SIT) | Complete | COMPLETE |  |  |  |  |
| 737 | 1.4.1.4.1.6.4.3 | SI develop Overarching SIT Component Integration Test Readiness Report |  | 20d | 2023-10-02 A | 2023-10-27 A | 736FF | 100% | 2023-10-02 | 2023-10-27 | 20d | 2023-10-02 | 2023-10-27 |  |  | SI Test |  | SIT | 5.0 |  | Systems Integration Testing (SIT) | Complete | COMPLETE |  |  |  |  |
| 738 | 1.4.1.4.1.6.4.4 | Artefact review (via TMAG) and updates |  | 5d | 2023-10-30 A | 2023-11-03 A | 737 | 100% | 2023-10-30 | 2023-11-03 | 5d | 2023-10-30 | 2023-11-03 |  |  | SI Test | PP,IPA | SIT | 5.0 |  | Systems Integration Testing (SIT) | Complete | COMPLETE |  |  |  |  |
| 739 | 1.4.1.4.1.6.5 | SIT Component Integration Testing 2 Preparation Complete (incl. approval of SI SIT Component Integration Test Readiness Report) | milestone | 0d | 2023-11-06 A | 2023-11-06 A | 733, 738FS+1d, 715, 326 | 100% | 2023-11-06 | 2023-11-06 | 0d | 2023-11-06 | 2023-11-06 |  |  | SI Test | PP,IPA | SIT | 5.11 |  | Systems Integration Testing (SIT) | Complete | COMPLETE | MHHS-ART071 | T2-TE-0300 | SITAG | T2 |
| 740 | 1.4.1.4.1.7 | **CIT Interval 3 Preparation** |  | 54d | 2023-10-03 A | 2023-12-15 A |  | 100% | 2023-10-03 | 2023-12-15 | 91d | 2022-11-16 | 2023-11-20 |  | -0 | N/A | N/A | SIT | 5.0 | N/A | Systems Integration Testing (SIT) |  |  |  |  |  |  |
| 741 | 1.4.1.4.1.7.1 | **PIT Test Completion Report (incl. evidence)** |  | 26d | 2023-10-13 A | 2023-11-17 A |  | 100% | 2023-10-13 | 2023-11-17 | 21d | 2023-10-13 | 2023-11-10 |  |  | N/A | N/A | SIT | 5.0 | N/A | Systems Integration Testing (SIT) |  |  |  |  |  |  |
| 742 | 1.4.1.4.1.7.1.1 | Submit draft PIT Test Completion Report (incl. evidence) and submit to Programme for assurance |  | 11d | 2023-10-13 A | 2023-10-27 A |  | 100% | 2023-10-13 | 2023-10-27 | 1d | 2023-10-13 | 2023-10-13 | must start on 2023-10-13 |  | PP | SI Test | SIT | 5.0 |  | Systems Integration Testing (SIT) | Complete | COMPLETE |  |  |  |  |
| 743 | 1.4.1.4.1.7.1.2 | Finalise PIT Test Completion Report (incl. evidence) |  | 5d | 2023-10-30 A | 2023-11-03 A | 742 | 100% | 2023-10-30 | 2023-11-03 | 15d | 2023-10-16 | 2023-11-03 |  |  | PP | SI Test | SIT | 5.0 |  | Systems Integration Testing (SIT) | Complete | COMPLETE |  |  |  |  |
| 744 | 1.4.1.4.1.7.1.3 | PP PIT Completion Report (excl. Migration/Reverse Migration) submitted to Programme for assurance CIT Interval 3 | milestone | 0d | 2023-11-03 A | 2023-11-03 A | 743, 79, 95 | 100% | 2023-11-03 | 2023-11-03 | 0d | 2023-11-03 | 2023-11-03 |  |  | PP | SI Test | SIT | 5.11 |  | Systems Integration Testing (SIT) | Complete | COMPLETE |  | T3-DB-0017 | SITAG | T3 |
| 745 | 1.4.1.4.1.7.1.4 | PP Final PIT Completion Reports assured by SI |  | 10d | 2023-11-06 A | 2023-11-17 A | 744 | 100% | 2023-11-06 | 2023-11-17 | 5d | 2023-11-06 | 2023-11-10 |  |  | SI Test | PP | SIT | 5.0 |  | Systems Integration Testing (SIT) | Complete | COMPLETE |  |  |  |  |
| 746 | 1.4.1.4.1.7.2 | **Environments (SIT A)** |  | 51d | 2023-10-06 A | 2023-12-15 A |  | 100% | 2023-10-06 | 2023-12-15 | 26d | 2022-11-16 | 2023-11-10 |  | -0 | N/A | N/A | SIT | 5.0 | N/A | Systems Integration Testing (SIT) |  |  |  |  |  |  |
| 747 | 1.4.1.4.1.7.2.1 | Programme Participants Ready to Start Connectivity Proving | milestone | 0d | 2023-10-06 A | 2023-10-06 A |  | 100% | 2023-10-06 | 2023-10-06 | 0d |  |  | start no earlier than 2023-10-06 |  | PP | PP.SI Test | SIT | 5.10 | Simon Berry | Systems Integration Testing (SIT) | Complete | COMPLETE |  |  |  |  |
| 748 | 1.4.1.4.1.7.2.2 | SIT Participants' SIT A environments ready to start connectivity proving CIT Interval 3 | milestone | 0d | 2023-10-06 A | 2023-10-06 A | 747 | 100% | 2023-10-06 | 2023-10-06 | 0d | 2023-10-06 | 2023-10-06 |  |  | PP | PP,SI Test | SIT | 5.10 | Simon Berry | Systems Integration Testing (SIT) | Complete | COMPLETE | MHHS-ART139 | T3-TE-0021 | SITAG | T3 |
| 749 | 1.4.1.4.1.7.2.3 | Internal Connectivity Proving Phase |  | 10d | 2023-10-09 A | 2023-10-20 A | 747FS+1d | 100% | 2023-10-09 | 2023-10-20 | 10d |  |  |  |  | PP | PP,SI Test | SIT | 5.10 | Simon Berry | Systems Integration Testing (SIT) | Complete | COMPLETE |  |  |  |  |
| 750 | 1.4.1.4.1.7.2.4 | Internal Connectivity Proving Phase Complete | milestone | 0d | 2023-10-20 A | 2023-10-20 A | 749 | 100% | 2023-10-20 | 2023-10-20 | 0d |  |  |  |  | PP | PP,SI Test | SIT | 5.10 | Simon Berry | Systems Integration Testing (SIT) | Complete | COMPLETE |  |  |  |  |
| 751 | 1.4.1.4.1.7.2.5 | DIP Onboarding Activity (1. PKI Officers and Certificates, 2. Set-up Validation, 3. End Point Creation, 4. Controlled Smoke Test ) |  | 35d | 2023-10-30 A | 2023-12-15 A | 750FS+5d | 100% | 2023-10-30 | 2023-12-15 | 10d |  |  |  |  | PP | PP,DIP Provider | SIT | 5.10 | Simon Berry | Systems Integration Testing (SIT) | Complete | COMPLETE |  |  |  |  |
| 752 | 1.4.1.4.1.7.2.6 | DIP Onboarding Complete | milestone | 0d | 2023-12-15 A | 2023-12-15 A | 751 | 100% | 2023-12-15 | 2023-12-15 | 0d |  |  |  |  | PP | PP,DIP Provider | SIT | 5.10 | Simon Berry | Systems Integration Testing (SIT) | Complete | COMPLETE |  |  |  |  |
| 753 | 1.4.1.4.1.7.2.7 | PPs Register PKI Officers and Request PKI certificates Complete - Interval 3 | milestone | 0d | 2023-12-15 A | 2023-12-15 A | 752FF | 100% | 2023-12-15 | 2023-12-15 | 0d | 2023-10-02 | 2023-10-06 |  |  | PP | PP,DIP Provider | SIT | 5.13 | Simon Berry | Systems Integration Testing (SIT) | Complete | COMPLETE |  | T3-TE-0099 | SITAG | T3 |
| 754 | 1.4.1.4.1.7.2.8 | PP Code Deployment | milestone | 0d | 2023-11-10 A | 2023-11-10 A | 750FS+15d | 100% | 2023-11-10 | 2023-11-10 | 0d |  |  | start no earlier than 2023-10-20 |  | PP | PP | SIT | 5.10 | Simon Berry | Systems Integration Testing (SIT) | Complete | COMPLETE |  |  |  |  |

Notes:
- 730: Action: 28/7: CH: Needs to be set-up as a reporting milestone. 31/7: Check with Cesar if has been approved so can be baselined
- 748: Action: 30/8 - lee said date is 30/10

| ID | WBS | Task | Type | Duration | Start | Finish | Predecessors | Complete | Baseline start | Baseline finish | Baseline duration | Baseline 1 start | Baseline 1 finish | Constraint | Baseline cost | Responsible | Involved | Text9 | Update Version | MHHS Resource Name | MHHS Programme Phase | Sched Status | RAG | Artefact ID | Milestone ID | Text29 | Tier |
| --- | --- | --- | --- | --- | --- | --- | --- | --- | --- | --- | --- | --- | --- | --- | --- | --- | --- | --- | --- | --- | --- | --- | --- | --- | --- | --- | --- |
| 755 | 1.4.1.4.1.7.3 | **Test Data (SIT A) Interval 3** |  | 34d | 2023-10-03 A | 2023-11-17 A |  | 100% | 2023-10-03 | 2023-11-17 | 25d | 2023-10-02 | 2023-11-03 |  |  | N/A | N/A | SIT | 5.0 | N/A | Systems Integration Testing (SIT) |  |  |  |  |  |  |
| 756 | 1.4.1.4.1.7.3.1 | Run data allocation |  | 4d | 2023-10-03 A | 2023-10-06 A | 726SS | 100% | 2023-10-03 | 2023-10-06 | 5d | 2023-10-02 | 2023-10-06 |  |  | SI Test |  | SIT | 5.0 | Cesar Lopes | Systems Integration Testing (SIT) | Complete | COMPLETE |  |  |  |  |
| 757 | 1.4.1.4.1.7.3.2 | Cleanse and populate data post cut |  | 5d | 2023-10-09 A | 2023-10-13 A | 756 | 100% | 2023-10-09 | 2023-10-13 | 5d | 2023-10-09 | 2023-10-13 |  |  | SI Test |  | SIT | 5.0 | Cesar Lopes | Systems Integration Testing (SIT) | Complete | COMPLETE |  |  |  |  |
| 758 | 1.4.1.4.1.7.3.3 | Transmit data sets to PPs |  | 2d | 2023-10-16 A | 2023-10-17 A | 757 | 100% | 2023-10-16 | 2023-10-17 | 2d | 2023-10-16 | 2023-10-17 |  |  | SI Test |  | SIT | 5.0 | Cesar Lopes | Systems Integration Testing (SIT) | Complete | COMPLETE |  |  |  |  |
| 759 | 1.4.1.4.1.7.3.4 | PP - Load test data to test environments |  | 8d | 2023-10-18 A | 2023-10-27 A | 758 | 100% | 2023-10-18 | 2023-10-27 | 8d | 2023-10-18 | 2023-10-27 |  |  | PP |  | SIT | 5.0 | Cesar Lopes | Systems Integration Testing (SIT) | Complete | COMPLETE |  |  |  |  |
| 760 | 1.4.1.4.1.7.3.5 | PP Check data integrity on test environment |  | 15d | 2023-10-30 A | 2023-11-17 A | 759 | 100% | 2023-10-30 | 2023-11-17 | 5d | 2023-10-30 | 2023-11-03 |  |  | PP |  | SIT | 5.0 | Cesar Lopes | Systems Integration Testing (SIT) | Complete | COMPLETE |  |  |  |  |
| 761 | 1.4.1.4.1.7.3.6 | PP submit self-declaration to Programme to confirm loading & verification of test data | milestone | 0d | 2023-11-17 A | 2023-11-17 A | 760FF | 100% | 2023-11-17 | 2023-11-17 | 0d | 2023-11-03 | 2023-11-03 |  |  | PP | SI Test | SIT | 5.0 | Cesar Lopes | Systems Integration Testing (SIT) | Complete | COMPLETE |  |  |  |  |
| 762 | 1.4.1.4.1.7.3.7 | Test Data (SIT A) Interval 3 Complete | milestone | 0d | 2023-11-17 A | 2023-11-17 A | 761 | 100% | 2023-11-17 | 2023-11-17 | 0d |  |  |  |  | SI Test | PP | SIT | 5.13 | Cesar Lopes | Systems Integration Testing (SIT) | Complete | COMPLETE | MHHS-ART148/169 | T3-TE-0075 | SITAG | T3 |
| 763 | 1.4.1.4.1.7.4 | **Other Preparation** |  | 25d | 2023-10-16 A | 2023-11-17 A |  | 100% | 2023-10-16 | 2023-11-17 | 60d | 2023-07-17 | 2023-10-06 |  |  | N/A | N/A | SIT | 5.0 | N/A | Systems Integration Testing (SIT) |  |  |  |  |  |  |
| 764 | 1.4.1.4.1.7.4.1 | Onboarding of Test Participants to Test Management Tool (Azure DevOps) |  | 25d | 2023-10-16 A | 2023-11-17 A |  | 100% | 2023-10-16 | 2023-11-17 | 60d | 2023-07-17 | 2023-10-06 | start no earlier than 2023-10-16 |  | SI Test | PP | SIT | 5.0 | Simon Berry | Systems Integration Testing (SIT) | Complete | COMPLETE |  |  |  |  |
| 765 | 1.4.1.4.1.7.4.2 | Test Management Tool onboarding |  | 25d | 2023-10-16 A | 2023-11-17 A |  | 100% | 2023-10-16 | 2023-11-17 | 60d | 2023-07-17 | 2023-10-06 | start no earlier than 2023-10-16 |  | PP | SI Test | SIT | 5.0 | Simon Berry | Systems Integration Testing (SIT) | Complete | COMPLETE |  |  |  |  |
| 766 | 1.4.1.4.1.7.5 | **SIT Component Integration Test Readiness Report** |  | 25d | 2023-10-16 A | 2023-11-17 A |  | 100% | 2023-10-16 | 2023-11-17 | 25d | 2023-10-16 | 2023-11-17 |  |  | N/A | N/A | SIT | 5.0 | N/A | Systems Integration Testing (SIT) |  |  |  |  |  |  |
| 767 | 1.4.1.4.1.7.5.1 | PP submit Test Readiness Report to Programme for assurance | milestone | 0d | 2023-11-03 A | 2023-11-03 A | 651 | 100% | 2023-11-03 | 2023-11-03 | 0d | 2023-11-03 | 2023-11-03 |  |  | PP | SI Test | SIT | 5.0 |  | Systems Integration Testing (SIT) | Complete | COMPLETE |  |  |  |  |
| 768 | 1.4.1.4.1.7.5.2 | SI assure Test Participants' Test Readiness Reports |  | 5d | 2023-11-06 A | 2023-11-10 A | 767FF+5d | 100% | 2023-11-06 | 2023-11-10 | 5d | 2023-11-06 | 2023-11-10 |  |  | SI Test | PP,IPA | SIT | 5.0 |  | Systems Integration Testing (SIT) | Complete | COMPLETE |  |  |  |  |
| 769 | 1.4.1.4.1.7.5.3 | SI develop Overarching SIT Component Integration Test Readiness Report |  | 20d | 2023-10-16 A | 2023-11-10 A | 768FF | 100% | 2023-10-16 | 2023-11-10 | 20d | 2023-10-16 | 2023-11-10 |  |  | SI Test |  | SIT | 5.0 |  | Systems Integration Testing (SIT) | Complete | COMPLETE |  |  |  |  |
| 770 | 1.4.1.4.1.7.5.4 | Artefact review (via TMAG) and updates |  | 5d | 2023-11-13 A | 2023-11-17 A | 769 | 100% | 2023-11-13 | 2023-11-17 | 5d | 2023-11-13 | 2023-11-17 |  |  | SI Test | PP,IPA | SIT | 5.0 |  | Systems Integration Testing (SIT) | Complete | COMPLETE |  |  |  |  |
| 771 | 1.4.1.4.1.7.6 | SIT Component Integration Testing 3 Preparation Complete (incl. approval of SI SIT Component Integration Test Readiness Report) | milestone | 0d | 2023-11-20 A | 2023-11-20 A | 770FS+1d, 744, 748, 767, 765, 762, 344 | 100% | 2023-11-20 | 2023-11-20 | 0d | 2023-11-20 | 2023-11-20 |  |  | SI Test | PP,IPA | SIT | 5.12 |  | Systems Integration Testing (SIT) | Complete | COMPLETE | MHHS-ART071 | T2-TE-0350 | SITAG | T2 |
| 772 | 1.4.1.4.1.8 | **CIT Interval 4 Preparation** |  | 36d | 2023-10-16 A | 2023-12-04 A |  | 100% | 2023-10-16 | 2023-12-04 | 36d | 2022-11-16 | 2023-12-04 |  | -0 | N/A | N/A | SIT | 5.0 | N/A | Systems Integration Testing (SIT) |  |  |  |  |  |  |
| 773 | 1.4.1.4.1.8.1 | **PIT Test Completion Report (incl. evidence)** |  | 21d | 2023-10-27 A | 2023-11-24 A |  | 100% | 2023-10-27 | 2023-11-24 | 21d | 2023-10-27 | 2023-11-24 |  |  | N/A | N/A | SIT | 5.0 | N/A | Systems Integration Testing (SIT) |  |  |  |  |  |  |
| 774 | 1.4.1.4.1.8.1.1 | Submit draft PIT Test Completion Report (incl. evidence) and submit to Programme for assurance |  | 1d | 2023-10-27 A | 2023-10-27 A |  | 100% | 2023-10-27 | 2023-10-27 | 1d | 2023-10-27 | 2023-10-27 | must start on 2023-10-27 |  | PP | SI Test | SIT | 5.0 |  | Systems Integration Testing (SIT) | Complete | COMPLETE |  |  |  |  |
| 775 | 1.4.1.4.1.8.1.2 | Finalise PIT Test Completion Report (incl. evidence) |  | 15d | 2023-10-30 A | 2023-11-17 A | 774 | 100% | 2023-10-30 | 2023-11-17 | 15d | 2023-10-30 | 2023-11-17 |  |  | PP | SI Test | SIT | 5.0 |  | Systems Integration Testing (SIT) | Complete | COMPLETE |  |  |  |  |
| 776 | 1.4.1.4.1.8.1.3 | PP PIT Completion Report (excl. Migration/Reverse Migration) submitted to Programme for assurance CIT Interval 4 | milestone | 0d | 2023-11-17 A | 2023-11-17 A | 775, 79, 95 | 100% | 2023-11-17 | 2023-11-17 | 0d | 2023-11-17 | 2023-11-17 |  |  | PP | SI Test | SIT | 5.13 |  | Systems Integration Testing (SIT) | Complete | COMPLETE |  | T3-DB-0019 | SITAG | T3 |
| 777 | 1.4.1.4.1.8.1.4 | PP Final PIT Completion Reports assured by SI |  | 5d | 2023-11-20 A | 2023-11-24 A | 776 | 100% | 2023-11-20 | 2023-11-24 | 5d | 2023-11-20 | 2023-11-24 |  |  | SI Test | PP | SIT | 5.0 |  | Systems Integration Testing (SIT) | Complete | COMPLETE |  |  |  |  |
| 778 | 1.4.1.4.1.8.2 | **Environments (SIT A)** |  | 25d | 2023-10-23 A | 2023-11-24 A |  | 100% | 2023-10-23 | 2023-11-24 | 25d | 2022-11-16 | 2023-11-24 |  | -0 | N/A | N/A | SIT | 5.0 | N/A | Systems Integration Testing (SIT) |  |  |  |  |  |  |
| 779 | 1.4.1.4.1.8.2.1 | Programme Participants Ready to Start Connectivity Proving | milestone | 0d | 2023-10-23 A | 2023-10-23 A |  | 100% | 2023-10-23 | 2023-10-23 | 0d |  |  | start no earlier than 2023-10-23 |  | PP |  | SIT | 5.10 | Simon Berry | Systems Integration Testing (SIT) | Complete | COMPLETE |  |  |  |  |
| 780 | 1.4.1.4.1.8.2.2 | SIT Participants' SIT A environments ready to start connectivity proving CIT Interval 4 | milestone | 0d | 2023-10-23 A | 2023-10-23 A | 779 | 100% | 2023-10-23 | 2023-10-23 | 0d | 2023-10-20 | 2023-10-20 |  |  | PP | PP,IPA | SIT | 5.10 | Simon Berry | Systems Integration Testing (SIT) | Complete | COMPLETE | MHHS-ART139 | T3-TE-0022 | SITAG | T3 |
| 781 | 1.4.1.4.1.8.2.3 | Internal Connectivity Proving Phase |  | 10d | 2023-10-23 A | 2023-11-03 A | 780 | 100% | 2023-10-23 | 2023-11-03 | 10d |  |  |  |  | PP |  | SIT | 5.10 | Simon Berry | Systems Integration Testing (SIT) | Complete | COMPLETE |  |  |  |  |
| 782 | 1.4.1.4.1.8.2.4 | Internal Connectivity Proving Phase Complete | milestone | 0d | 2023-11-03 A | 2023-11-03 A | 781 | 100% | 2023-11-03 | 2023-11-03 | 0d |  |  |  |  | PP |  | SIT | 5.10 | Simon Berry | Systems Integration Testing (SIT) | Complete | COMPLETE |  |  |  |  |
| 783 | 1.4.1.4.1.8.2.5 | DIP Onboarding Activity (1. PKI Officers and Certificates, 2. Set-up Validation, 3. End Point Creation, 4. Controlled Smoke Test ) |  | 10d | 2023-11-13 A | 2023-11-24 A | 782FS+5d | 100% | 2023-11-13 | 2023-11-24 | 10d |  |  |  |  | PP |  | SIT | 5.10 | Simon Berry | Systems Integration Testing (SIT) | Complete | COMPLETE |  |  |  |  |
| 784 | 1.4.1.4.1.8.2.6 | DIP Onboarding Complete | milestone | 0d | 2023-11-24 A | 2023-11-24 A | 783 | 100% | 2023-11-24 | 2023-11-24 | 0d |  |  |  |  | PP |  | SIT | 5.10 | Simon Berry | Systems Integration Testing (SIT) | Complete | COMPLETE |  |  |  |  |
| 785 | 1.4.1.4.1.8.2.7 | PPs register PKI Officers and Request PKI Certificates Complete - Interval 4 | milestone | 0d | 2023-11-24 A | 2023-11-24 A | 784 | 100% | 2023-11-24 | 2023-11-24 | 0d |  |  |  |  | PP | DIP Provider | SIT | 5.16 | Simon Berry | Systems Integration Testing (SIT) | Complete | COMPLETE |  | T3-TE-0100 | SITAG | T3 |
| 786 | 1.4.1.4.1.8.2.8 | PP Code Deployment | milestone | 0d | 2023-11-17 A | 2023-11-17 A |  | 100% | 2023-11-17 | 2023-11-17 | 0d |  |  | start no earlier than 2023-11-17 |  | PP |  | SIT | 5.10 | Simon Berry | Systems Integration Testing (SIT) | Complete | COMPLETE |  |  |  |  |

Notes:
- 762: Action: 28/7: CH: Needs to be set-up as a reporting milestone. 31/7: Check with Cesar if has been approved so can be baselined

| ID | WBS | Task | Type | Duration | Start | Finish | Predecessors | Complete | Baseline start | Baseline finish | Baseline duration | Baseline 1 start | Baseline 1 finish | Constraint | Baseline cost | Responsible | Involved | Text9 | Update Version | MHHS Resource Name | MHHS Programme Phase | Sched Status | RAG | Artefact ID | Milestone ID | Text29 | Tier |
| --- | --- | --- | --- | --- | --- | --- | --- | --- | --- | --- | --- | --- | --- | --- | --- | --- | --- | --- | --- | --- | --- | --- | --- | --- | --- | --- | --- |
| 787 | 1.4.1.4.1.8.3 | **Test Data (SIT A) Interval 4** |  | 30d | 2023-10-23 A | 2023-12-01 A |  | 100% | 2023-10-23 | 2023-12-01 | 25d | 2023-10-16 | 2023-11-17 |  |  | N/A | N/A | SIT | 5.0 | N/A | Systems Integration Testing (SIT) |  |  |  |  |  |  |
| 788 | 1.4.1.4.1.8.3.1 | Run data allocation |  | 5d | 2023-10-23 A | 2023-10-27 A | 757FS+5d | 100% | 2023-10-23 | 2023-10-27 | 5d | 2023-10-16 | 2023-10-20 |  |  | SI Test |  | SIT | 5.0 | Cesar Lopes | Systems Integration Testing (SIT) | Complete | COMPLETE |  |  |  |  |
| 789 | 1.4.1.4.1.8.3.2 | Cleanse and populate data post cut |  | 2d | 2023-10-30 A | 2023-10-31 A | 788 | 100% | 2023-10-30 | 2023-10-31 | 5d | 2023-10-23 | 2023-10-27 |  |  | SI Test |  | SIT | 5.0 | Cesar Lopes | Systems Integration Testing (SIT) | Complete | COMPLETE |  |  |  |  |
| 790 | 1.4.1.4.1.8.3.3 | Transmit data sets to PPs |  | 5d | 2023-11-01 A | 2023-11-07 A | 789 | 100% | 2023-11-01 | 2023-11-07 | 2d | 2023-10-30 | 2023-10-31 |  |  | SI Test |  | SIT | 5.0 | Cesar Lopes | Systems Integration Testing (SIT) | Complete | COMPLETE |  |  |  |  |
| 791 | 1.4.1.4.1.8.3.4 | PP - Load test data to test environments |  | 5d | 2023-11-08 A | 2023-11-14 A | 790 | 100% | 2023-11-08 | 2023-11-14 | 8d | 2023-11-01 | 2023-11-10 |  |  | PP |  | SIT | 5.0 | Cesar Lopes | Systems Integration Testing (SIT) | Complete | COMPLETE |  |  |  |  |
| 792 | 1.4.1.4.1.8.3.5 | PP Check data integrity on test environment |  | 13d | 2023-11-15 A | 2023-12-01 A | 791 | 100% | 2023-11-15 | 2023-12-01 | 5d | 2023-11-13 | 2023-11-17 |  |  | PP |  | SIT | 5.0 | Michael Inije | Systems Integration Testing (SIT) | Complete | COMPLETE |  |  |  |  |
| 793 | 1.4.1.4.1.8.3.6 | PP submit self-declaration to Programme to confirm loading & verification of test data | milestone | 0d | 2023-12-01 A | 2023-12-01 A | 792FF | 100% | 2023-12-01 | 2023-12-01 | 0d | 2023-11-17 | 2023-11-17 |  |  | PP | SI Test | SIT | 5.0 | Michael Inije | Systems Integration Testing (SIT) | Complete | COMPLETE |  |  |  |  |
| 794 | 1.4.1.4.1.8.3.7 | Test Data (SIT A) Interval 4 Complete | milestone | 0d | 2023-12-01 A | 2023-12-01 A | 793 | 100% | 2023-12-01 | 2023-12-01 | 0d |  |  |  |  | SI Test | PP | SIT | 5.13 | Michael Inije | Systems Integration Testing (SIT) | Complete | COMPLETE | MHHS-ART148/169 | T3-TE-0076 | SITAG | T3 |
| 795 | 1.4.1.4.1.8.4 | **Other Preparation** |  | 25d | 2023-10-30 A | 2023-12-01 A |  | 100% | 2023-10-30 | 2023-12-01 | 25d | 2023-07-31 | 2023-10-20 |  | -0 | N/A | N/A | SIT | 5.0 | N/A | Systems Integration Testing (SIT) |  |  |  |  |  |  |
| 796 | 1.4.1.4.1.8.4.1 | Onboarding of Test Participants to Test Management Tool (Azure DevOps) |  | 25d | 2023-10-30 A | 2023-12-01 A |  | 100% | 2023-10-30 | 2023-12-01 | 25d | 2023-07-31 | 2023-10-20 | start no earlier than 2023-10-30 |  | SI Test | PP | SIT | 5.0 | Simon Berry | Systems Integration Testing (SIT) | Complete | COMPLETE |  |  |  |  |
| 797 | 1.4.1.4.1.8.4.2 | Test Management Tool onboarding |  | 25d | 2023-10-30 A | 2023-12-01 A |  | 100% | 2023-10-30 | 2023-12-01 | 25d | 2023-07-31 | 2023-10-20 | start no earlier than 2023-10-30 |  | PP | SI Test | SIT | 5.0 | Simon Berry | Systems Integration Testing (SIT) | Complete | COMPLETE |  |  |  |  |
| 798 | 1.4.1.4.1.8.5 | **SIT Component Integration Test Readiness Report** |  | 27d | 2023-10-16 A | 2023-11-21 A |  | 100% | 2023-10-16 | 2023-11-21 | 25d | 2023-10-30 | 2023-12-01 |  |  | N/A | N/A | SIT | 5.0 | N/A | Systems Integration Testing (SIT) |  |  |  |  |  |  |
| 799 | 1.4.1.4.1.8.5.1 | PP submit Test Readiness Report to Programme for assurance | milestone | 0d | 2023-11-03 A | 2023-11-03 A | 651 | 100% | 2023-11-03 | 2023-11-03 | 0d | 2023-11-17 | 2023-11-17 |  |  | PP | SI Test | SIT | 5.0 |  | Systems Integration Testing (SIT) | Complete | COMPLETE |  |  |  |  |
| 800 | 1.4.1.4.1.8.5.2 | SI assure Test Participants' Test Readiness Reports |  | 5d | 2023-11-06 A | 2023-11-10 A | 799FF+5d | 100% | 2023-11-06 | 2023-11-10 | 5d | 2023-11-20 | 2023-11-24 |  |  | SI Test | PP,IPA | SIT | 5.0 |  | Systems Integration Testing (SIT) | Complete | COMPLETE |  |  |  |  |
| 801 | 1.4.1.4.1.8.5.3 | SI develop Overarching SIT Component Integration Test Readiness Report |  | 20d | 2023-10-16 A | 2023-11-10 A | 800FF | 100% | 2023-10-16 | 2023-11-10 | 20d | 2023-10-30 | 2023-11-24 |  |  | SI Test |  | SIT | 5.0 |  | Systems Integration Testing (SIT) | Complete | COMPLETE |  |  |  |  |
| 802 | 1.4.1.4.1.8.5.4 | Artefact review (via SITAG) and updates |  | 7d | 2023-11-13 A | 2023-11-21 A | 801 | 100% | 2023-11-13 | 2023-11-21 | 5d | 2023-11-27 | 2023-12-01 |  |  | SI Test | PP,IPA | SIT | 5.0 |  | Systems Integration Testing (SIT) | Complete | COMPLETE |  |  |  |  |
| 803 | 1.4.1.4.1.8.6 | SIT Component Integration Testing 4 Preparation Complete (incl. approval of SI SIT Component Integration Test Readiness Report) | milestone | 0d | 2023-12-04 A | 2023-12-04 A | 802FS+2d, 776, 780, 799, 794, 361FS+1d | 100% | 2023-12-04 | 2023-12-04 | 0d | 2023-12-04 | 2023-12-04 |  |  | SI Test | PP,IPA | SIT | 5.13 |  | Systems Integration Testing (SIT) | Complete | COMPLETE | MHHS-ART071 | T2-TE-0400 | SITAG | T2 |
| 804 | 1.4.1.4.1.9 | **CIT Interval 5 Preparation** |  | 53d | 2023-11-01 A | 2024-01-12 A |  | 100% | 2023-11-01 | 2024-01-12 | 55d | 2022-11-16 | 2024-01-08 |  | -0 | N/A | N/A | SIT | 5.0 | N/A | Systems Integration Testing (SIT) |  |  |  |  |  |  |
| 805 | 1.4.1.4.1.9.1 | **PIT Test Completion Report (incl. evidence)** |  | 21d | 2023-11-17 A | 2023-12-15 A |  | 100% | 2023-11-17 | 2023-12-15 | 21d | 2023-11-17 | 2023-12-15 |  |  | N/A | N/A | SIT | 5.0 | N/A | Systems Integration Testing (SIT) |  |  |  |  |  |  |
| 806 | 1.4.1.4.1.9.1.1 | Submit draft PIT Test Completion Report (incl. evidence) and submit to Programme for assurance |  | 1d | 2023-11-17 A | 2023-11-17 A |  | 100% | 2023-11-17 | 2023-11-17 | 1d | 2023-11-17 | 2023-11-17 | must start on 2023-11-17 |  | PP | SI Test | SIT | 5.0 | Lee Cox | Systems Integration Testing (SIT) | Complete | COMPLETE |  |  |  |  |
| 807 | 1.4.1.4.1.9.1.2 | Finalise PIT Test Completion Report (incl. evidence) |  | 15d | 2023-11-20 A | 2023-12-08 A | 806 | 100% | 2023-11-20 | 2023-12-08 | 15d | 2023-11-20 | 2023-12-08 |  |  | PP | SI Test | SIT | 5.0 | Lee Cox | Systems Integration Testing (SIT) | Complete | COMPLETE |  |  |  |  |
| 808 | 1.4.1.4.1.9.1.3 | PP PIT Completion Report (excl. Migration/Reverse Migration) submitted to Programme for assurance CIT Interval 5 | milestone | 0d | 2023-12-08 A | 2023-12-08 A | 807, 79, 95 | 100% | 2023-12-08 | 2023-12-08 | 0d | 2023-12-08 | 2023-12-08 |  |  | PP | SI Test | SIT | 5.14 | Lee Cox | Systems Integration Testing (SIT) | Complete | COMPLETE |  | T3-DB-0021 | SITAG | T3 |
| 809 | 1.4.1.4.1.9.1.4 | PP Final PIT Completion Reports assured by SI |  | 5d | 2023-12-11 A | 2023-12-15 A | 808 | 100% | 2023-12-11 | 2023-12-15 | 5d | 2023-12-11 | 2023-12-15 |  |  | SI Test | PP | SIT | 5.0 | Lee Cox | Systems Integration Testing (SIT) | Complete | COMPLETE |  |  |  |  |
| 810 | 1.4.1.4.1.9.2 | **Environments (SIT A)** |  | 21d | 2023-11-10 A | 2023-12-08 A |  | 100% | 2023-11-10 | 2023-12-08 | 21d | 2022-11-16 | 2023-12-15 |  | -0 | N/A | N/A | SIT | 5.0 | N/A | Systems Integration Testing (SIT) |  |  |  |  |  |  |
| 811 | 1.4.1.4.1.9.2.1 | Programme Participants Ready to Start Connectivity Proving | milestone | 0d | 2023-11-10 A | 2023-11-10 A |  | 100% | 2023-11-10 | 2023-11-10 | 0d |  |  | start no earlier than 2023-11-10 |  | PP |  | SIT | 5.10 | Simon Berry | Systems Integration Testing (SIT) | Complete | COMPLETE |  |  |  |  |
| 812 | 1.4.1.4.1.9.2.2 | SIT Participants' SIT A environments ready to start connectivity proving CIT Interval 5 | milestone | 0d | 2023-11-10 A | 2023-11-10 A | 811 | 100% | 2023-11-10 | 2023-11-10 | 0d | 2023-11-10 | 2023-11-10 |  |  | PP | PP,IPA | SIT | 5.6 | Simon Berry | Systems Integration Testing (SIT) | Complete | COMPLETE | MHHS-ART139 | T3-TE-0023 | SITAG | T3 |
| 813 | 1.4.1.4.1.9.2.3 | Internal Connectivity Proving Phase |  | 10d | 2023-11-13 A | 2023-11-24 A | 811FS+1d | 100% | 2023-11-13 | 2023-11-24 | 10d |  |  |  |  | PP |  | SIT | 5.10 | Simon Berry | Systems Integration Testing (SIT) | Complete | COMPLETE |  |  |  |  |
| 814 | 1.4.1.4.1.9.2.4 | Internal Connectivity Proving Phase Complete | milestone | 0d | 2023-11-24 A | 2023-11-24 A | 813 | 100% | 2023-11-24 | 2023-11-24 | 0d |  |  |  |  | PP |  | SIT | 5.10 | Simon Berry | Systems Integration Testing (SIT) | Complete | COMPLETE |  |  |  |  |
| 815 | 1.4.1.4.1.9.2.5 | DIP Onboarding Activity (1. PKI Officers and Certificates, 2. Set-up Validation, 3. End Point Creation, 4. Controlled Smoke Test ) |  | 10d | 2023-11-27 A | 2023-12-08 A | 814 | 100% | 2023-11-27 | 2023-12-08 | 10d |  |  |  |  | PP |  | SIT | 5.10 | Simon Berry | Systems Integration Testing (SIT) | Complete | COMPLETE |  |  |  |  |
| 816 | 1.4.1.4.1.9.2.6 | DIP Onboarding Complete | milestone | 0d | 2023-12-08 A | 2023-12-08 A | 815 | 100% | 2023-12-08 | 2023-12-08 | 0d |  |  |  |  | PP |  | SIT | 5.10 | Simon Berry | Systems Integration Testing (SIT) | Complete | COMPLETE |  |  |  |  |
| 817 | 1.4.1.4.1.9.2.7 | PPs register PKI Officers and Request PKI Certificates Complete - Interval 5 | milestone | 0d | 2023-12-08 A | 2023-12-08 A | 816 | 100% | 2023-12-08 | 2023-12-08 | 0d | 2023-11-06 | 2023-11-10 |  |  | PP | DIP Provider | SIT | 5.17 | Simon Berry | Systems Integration Testing (SIT) | Complete | COMPLETE |  | T3-TE-0101 | SITAG | T3 |
| 818 | 1.4.1.4.1.9.2.8 | PP Code Deployment | milestone | 0d | 2023-12-08 A | 2023-12-08 A | 817 | 100% | 2023-12-08 | 2023-12-08 | 0d |  |  | start no earlier than 2023-10-20 |  | PP |  | SIT | 5.10 | Simon Berry | Systems Integration Testing (SIT) | Complete | COMPLETE |  |  |  |  |

| ID | WBS | Task | Type | Duration | Start | Finish | Predecessors | Complete | Baseline start | Baseline finish | Baseline duration | Baseline 1 start | Baseline 1 finish | Constraint | Baseline cost | Responsible | Involved | Text9 | Update Version | MHHS Resource Name | MHHS Programme Phase | Sched Status | RAG | Artefact ID | Milestone ID | Text29 | Tier |
| --- | --- | --- | --- | --- | --- | --- | --- | --- | --- | --- | --- | --- | --- | --- | --- | --- | --- | --- | --- | --- | --- | --- | --- | --- | --- | --- | --- |
| 819 | 1.4.1.4.1.9.3 | **Test Data (SIT A) Interval 5** |  | 33d | 2023-11-01 A | 2023-12-15 A |  | 100% | 2023-11-01 | 2023-12-15 | 30d | 2023-10-30 | 2023-12-08 |  |  | N/A | N/A | SIT | 5.0 | N/A | Systems Integration Testing (SIT) |  |  |  |  |  |  |
| 820 | 1.4.1.4.1.9.3.1 | Run data allocation |  | 5d | 2023-11-01 A | 2023-11-07 A | 790SS | 100% | 2023-11-01 | 2023-11-07 | 10d | 2023-10-30 | 2023-11-10 |  |  | SI Test |  | SIT | 5.0 | Cesar Lopes | Systems Integration Testing (SIT) | Complete | COMPLETE |  |  |  |  |
| 821 | 1.4.1.4.1.9.3.2 | Cleanse and populate data post cut |  | 8d | 2023-11-08 A | 2023-11-17 A | 820 | 100% | 2023-11-08 | 2023-11-17 | 5d | 2023-11-13 | 2023-11-17 |  |  | SI Test |  | SIT | 5.0 | Cesar Lopes | Systems Integration Testing (SIT) | Complete | COMPLETE |  |  |  |  |
| 822 | 1.4.1.4.1.9.3.3 | Transmit data sets to PPs |  | 2d | 2023-11-20 A | 2023-11-21 A | 821 | 100% | 2023-11-20 | 2023-11-21 | 2d | 2023-11-20 | 2023-11-21 |  |  | SI Test |  | SIT | 5.0 | Cesar Lopes | Systems Integration Testing (SIT) | Complete | COMPLETE |  |  |  |  |
| 823 | 1.4.1.4.1.9.3.4 | PP - Load test data to test environments |  | 8d | 2023-11-22 A | 2023-12-01 A | 822 | 100% | 2023-11-22 | 2023-12-01 | 8d | 2023-11-22 | 2023-12-01 |  |  | PP |  | SIT | 5.0 | Michael Inije | Systems Integration Testing (SIT) | Complete | COMPLETE |  |  |  |  |
| 824 | 1.4.1.4.1.9.3.5 | PP Check data integrity on test environment |  | 10d | 2023-12-04 A | 2023-12-15 A | 823 | 100% | 2023-12-04 | 2023-12-15 | 5d | 2023-12-04 | 2023-12-08 |  |  | PP |  | SIT | 5.0 | Michael Inije | Systems Integration Testing (SIT) | Complete | COMPLETE |  |  |  |  |
| 825 | 1.4.1.4.1.9.3.6 | PP submit self-declaration to Programme to confirm loading & verification of test data | milestone | 0d | 2023-12-15 A | 2023-12-15 A | 824FF | 100% | 2023-12-15 | 2023-12-15 | 0d | 2023-12-08 | 2023-12-08 |  |  | PP | SI Test | SIT | 5.0 | Michael Inije | Systems Integration Testing (SIT) | Complete | COMPLETE |  |  |  |  |
| 826 | 1.4.1.4.1.9.3.7 | Test Data (SIT A) Interval 5 Complete | milestone | 0d | 2023-12-15 A | 2023-12-15 A | 825 | 100% | 2023-12-15 | 2023-12-15 | 0d |  |  |  |  | SI Test | PP | SIT | 5.14 | Michael Inije | Systems Integration Testing (SIT) | Complete | COMPLETE | MHHS-ART148/169 | T3-TE-0077 | SITAG | T3 |
| 827 | 1.4.1.4.1.9.4 | **Other Preparation** |  | 40d | 2023-11-20 A | 2024-01-12 A |  | 100% | 2023-11-20 | 2024-01-12 | 40d | 2023-08-21 | 2023-11-10 |  | -0 | N/A | N/A | SIT | 5.0 | N/A | Systems Integration Testing (SIT) |  |  |  |  |  |  |
| 828 | 1.4.1.4.1.9.4.1 | Onboarding of Test Participants to Test Management Tool (Azure DevOps) |  | 40d | 2023-11-20 A | 2024-01-12 A |  | 100% | 2023-11-20 | 2024-01-12 | 40d | 2023-08-21 | 2023-11-10 | start no earlier than 2023-11-20 |  | SI Test | PP | SIT | 5.0 | Simon Berry | Systems Integration Testing (SIT) | Complete | COMPLETE |  |  |  |  |
| 829 | 1.4.1.4.1.9.4.2 | Test Management Tool onboarding |  | 36d | 2023-11-20 A | 2024-01-08 A |  | 100% | 2023-11-20 | 2024-01-08 | 36d | 2023-08-21 | 2023-11-10 | start no earlier than 2023-11-20 |  | PP | SI Test | SIT | 5.0 | Simon Berry | Systems Integration Testing (SIT) | Complete | COMPLETE |  |  |  |  |
| 830 | 1.4.1.4.1.9.5 | **SIT Component Integration Test Readiness Report** |  | 35d | 2023-11-20 A | 2024-01-05 A |  | 100% | 2023-11-20 | 2024-01-05 | 35d | 2023-11-20 | 2024-01-05 |  |  | N/A | N/A | SIT | 5.0 | N/A | Systems Integration Testing (SIT) |  |  |  |  |  |  |
| 831 | 1.4.1.4.1.9.5.1 | PP submit Test Readiness Report to Programme for assurance | milestone | 0d | 2023-12-08 A | 2023-12-08 A | 655 | 100% | 2023-12-08 | 2023-12-08 | 0d | 2023-12-08 | 2023-12-08 |  |  | PP | SI Test | SIT | 5.0 | Lee Cox | Systems Integration Testing (SIT) | Complete | COMPLETE |  |  |  |  |
| 832 | 1.4.1.4.1.9.5.2 | SI assure Test Participants' Test Readiness Reports |  | 5d | 2023-12-11 A | 2023-12-15 A | 831FF+5d | 100% | 2023-12-11 | 2023-12-15 | 5d | 2023-12-11 | 2023-12-15 |  |  | SI Test | PP,IPA | SIT | 5.0 | Lee Cox | Systems Integration Testing (SIT) | Complete | COMPLETE |  |  |  |  |
| 833 | 1.4.1.4.1.9.5.3 | SI develop Overarching SIT Component Integration Test Readiness Report |  | 20d | 2023-11-20 A | 2023-12-15 A | 832FF | 100% | 2023-11-20 | 2023-12-15 | 20d | 2023-11-20 | 2023-12-15 |  |  | SI Test |  | SIT | 5.0 | Lee Cox | Systems Integration Testing (SIT) | Complete | COMPLETE |  |  |  |  |
| 834 | 1.4.1.4.1.9.5.4 | Artefact review (via SITAG) and updates |  | 15d | 2023-12-18 A | 2024-01-05 A | 833 | 100% | 2023-12-18 | 2024-01-05 | 15d | 2023-12-18 | 2024-01-05 |  |  | SI Test | PP,IPA | SIT | 5.0 | Lee Cox | Systems Integration Testing (SIT) | Complete | COMPLETE |  |  |  |  |
| 835 | 1.4.1.4.1.9.6 | SIT Component Integration Testing 5 Preparation Complete (incl. approval of SI SIT Component Integration Test Readiness Report) | milestone | 0d | 2024-01-08 A | 2024-01-08 A | 834FS+1d, 808, 812, 829, 831, 826, 481, 464 | 100% | 2024-01-08 | 2024-01-08 | 0d | 2024-01-08 | 2024-01-08 |  |  | SI Test | PP,IPA | SIT | 5.15 |  | Systems Integration Testing (SIT) | Complete | COMPLETE | MHHS-ART071 | T2-TE-0450 | SITAG | T2 |
| 836 | 1.4.1.4.1.10 | **CIT Interval 6 Preparation** |  | 45d | 2023-11-20 A | 2024-01-19 A |  | 100% | 2023-11-20 | 2024-01-19 | 46d | 2022-11-16 | 2024-01-22 |  | -0 | N/A | N/A | SIT | 5.0 | N/A | Systems Integration Testing (SIT) |  |  |  |  |  |  |
| 837 | 1.4.1.4.1.10.1 | **PIT Test Completion Report (incl. evidence)** |  | 31d | 2023-12-01 A | 2024-01-12 A |  | 100% | 2023-12-01 | 2024-01-12 | 31d | 2023-12-01 | 2024-01-12 |  |  | N/A | N/A | SIT | 5.0 | N/A | Systems Integration Testing (SIT) |  |  |  |  |  |  |
| 838 | 1.4.1.4.1.10.1.1 | Submit draft PIT Test Completion Report (incl. evidence) and submit to Programme for assurance |  | 1d | 2023-12-01 A | 2023-12-01 A |  | 100% | 2023-12-01 | 2023-12-01 | 1d | 2023-12-01 | 2023-12-01 | must start on 2023-12-01 |  | PP | SI Test | SIT | 5.0 |  | Systems Integration Testing (SIT) | Complete | COMPLETE |  |  |  |  |
| 839 | 1.4.1.4.1.10.1.2 | Finalise PIT Test Completion Report (incl. evidence) |  | 25d | 2023-12-04 A | 2024-01-05 A | 838 | 100% | 2023-12-04 | 2024-01-05 | 25d | 2023-12-04 | 2024-01-05 |  |  | PP | SI Test | SIT | 5.0 |  | Systems Integration Testing (SIT) | Complete | COMPLETE |  |  |  |  |
| 840 | 1.4.1.4.1.10.1.3 | PP PIT Completion Report (excl. Migration/Reverse Migration) submitted to Programme for assurance CIT Interval 6 | milestone | 0d | 2024-01-05 A | 2024-01-05 A | 839, 79, 95, 283, 288, 291 | 100% | 2024-01-05 | 2024-01-05 | 0d | 2024-01-05 | 2024-01-05 |  |  | PP | SI Test | SIT | 5.19 |  | Systems Integration Testing (SIT) | Complete | COMPLETE |  | T3-DB-0023 | SITAG | T3 |
| 841 | 1.4.1.4.1.10.1.4 | PP Final PIT Completion Reports assured by SI |  | 5d | 2024-01-08 A | 2024-01-12 A | 840 | 100% | 2024-01-08 | 2024-01-12 | 5d | 2024-01-08 | 2024-01-12 |  |  | SI Test | PP | SIT | 5.19 |  | Systems Integration Testing (SIT) | Complete | COMPLETE |  |  |  |  |
| 842 | 1.4.1.4.1.10.2 | **Environments (SIT A)** |  | 30d | 2023-11-24 A | 2024-01-05 A |  | 100% | 2023-11-24 | 2024-01-05 | 30d | 2022-11-16 | 2024-01-05 |  | -0 | N/A | N/A | SIT | 5.0 | N/A | Systems Integration Testing (SIT) |  |  |  |  |  |  |
| 843 | 1.4.1.4.1.10.2.1 | Programme Participants Ready to Start Connectivity Proving | milestone | 0d | 2023-11-24 A | 2023-11-24 A |  | 100% | 2023-11-24 | 2023-11-24 | 0d |  |  | start no earlier than 2023-11-24 |  | PP |  | SIT | 5.10 | Simon Berry | Systems Integration Testing (SIT) | Complete | COMPLETE |  |  |  |  |
| 844 | 1.4.1.4.1.10.2.2 | SIT Participants' SIT A environments ready to start connectivity proving CIT Interval 6 | milestone | 0d | 2023-11-24 A | 2023-11-24 A | 843 | 100% | 2023-11-24 | 2023-11-24 | 0d | 2023-11-24 | 2023-11-24 |  |  | PP | PP,IPA | SIT | 5.6 | Simon Berry | Systems Integration Testing (SIT) | Complete | COMPLETE | MHHS-ART139 | T3-TE-0024 | SITAG | T3 |
| 845 | 1.4.1.4.1.10.2.3 | Internal Connectivity Proving Phase |  | 10d | 2023-11-27 A | 2023-12-08 A | 844FS+1d | 100% | 2023-11-27 | 2023-12-08 | 10d |  |  |  |  | PP |  | SIT | 5.10 | Simon Berry | Systems Integration Testing (SIT) | Complete | COMPLETE |  |  |  |  |
| 846 | 1.4.1.4.1.10.2.4 | Internal Connectivity Proving Phase Complete | milestone | 0d | 2023-12-08 A | 2023-12-08 A | 845 | 100% | 2023-12-08 | 2023-12-08 | 0d |  |  |  |  | PP |  | SIT | 5.10 | Simon Berry | Systems Integration Testing (SIT) | Complete | COMPLETE |  |  |  |  |
| 847 | 1.4.1.4.1.10.2.5 | DIP Onboarding Activity (1. PKI Officers and Certificates, 2. Set-up Validation, 3. End Point Creation, 4. Controlled Smoke Test ) |  | 5d | 2023-12-04 A | 2023-12-08 A | 844FS+6d | 100% | 2023-12-04 | 2023-12-08 | 5d |  |  |  |  | PP |  | SIT | 5.10 | Simon Berry | Systems Integration Testing (SIT) | Complete | COMPLETE |  |  |  |  |
| 848 | 1.4.1.4.1.10.2.6 | DIP Onboarding Complete | milestone | 0d | 2023-12-08 A | 2023-12-08 A | 847 | 100% | 2023-12-08 | 2023-12-08 | 0d |  |  |  |  | PP |  | SIT | 5.10 | Simon Berry | Systems Integration Testing (SIT) | Complete | COMPLETE |  |  |  |  |
| 849 | 1.4.1.4.1.10.2.7 | PPs register PKI Officers and Request PKI Certificates Complete - Interval 6 | milestone | 0d | 2023-12-08 A | 2023-12-08 A | 848 | 100% | 2023-12-08 | 2023-12-08 | 0d | 2023-11-20 | 2023-11-24 | start no earlier than 2023-12-08 |  | PP | DIP Provider | SIT | 5.17 | Simon Berry | Systems Integration Testing (SIT) | Complete | COMPLETE |  | T3-TE-0102 | SITAG | T3 |
| 850 | 1.4.1.4.1.10.2.8 | PP Code Deployment | milestone | 0d | 2024-01-05 A | 2024-01-05 A |  | 100% | 2024-01-05 | 2024-01-05 | 0d |  |  | start no earlier than 2024-01-05 |  | PP |  | SIT | 5.10 | Simon Berry | Systems Integration Testing (SIT) | Complete | COMPLETE |  |  |  |  |

Notes:
- 826: Action: 28/7: CH: Needs to be set-up as a reporting milestone. 31/7: Check with Cesar if has been approved so can be baselined

| ID | WBS | Task | Type | Duration | Start | Finish | Predecessors | Complete | Baseline start | Baseline finish | Baseline duration | Baseline 1 start | Baseline 1 finish | Constraint | Baseline cost | Responsible | Involved | Text9 | Update Version | MHHS Resource Name | MHHS Programme Phase | Sched Status | RAG | Artefact ID | Milestone ID | Text29 | Tier |
| --- | --- | --- | --- | --- | --- | --- | --- | --- | --- | --- | --- | --- | --- | --- | --- | --- | --- | --- | --- | --- | --- | --- | --- | --- | --- | --- | --- |
| 851 | 1.4.1.4.1.10.3 | **Test Data (SIT A) Interval 6** |  | 25d | 2023-11-20 A | 2023-12-22 A |  | 100% | 2023-11-20 | 2023-12-22 | 25d | 2023-11-20 | 2023-12-22 |  |  | N/A | N/A | SIT | 5.0 | N/A | Systems Integration Testing (SIT) |  |  |  |  |  |  |
| 852 | 1.4.1.4.1.10.3.1 | Run data allocation |  | 10d | 2023-11-20 A | 2023-12-01 A | 822SS | 100% | 2023-11-20 | 2023-12-01 | 5d | 2023-11-20 | 2023-11-24 |  |  | SI Test |  | SIT | 5.0 | Michael Inije | Systems Integration Testing (SIT) | Complete | COMPLETE |  |  |  |  |
| 853 | 1.4.1.4.1.10.3.2 | Cleanse and populate data post cut |  | 1d | 2023-12-04 A | 2023-12-04 A | 852 | 100% | 2023-12-04 | 2023-12-04 | 5d | 2023-11-27 | 2023-12-01 |  |  | SI Test |  | SIT | 5.0 | Michael Inije | Systems Integration Testing (SIT) | Complete | COMPLETE |  |  |  |  |
| 854 | 1.4.1.4.1.10.3.3 | Transmit data sets to PPs |  | 1d | 2023-12-05 A | 2023-12-05 A | 853 | 100% | 2023-12-05 | 2023-12-05 | 2d | 2023-12-04 | 2023-12-05 |  |  | SI Test |  | SIT | 5.0 | Michael Inije | Systems Integration Testing (SIT) | Complete | COMPLETE |  |  |  |  |
| 855 | 1.4.1.4.1.10.3.4 | PP - Load test data to test environments |  | 8d | 2023-12-06 A | 2023-12-15 A | 854 | 100% | 2023-12-06 | 2023-12-15 | 8d | 2023-12-06 | 2023-12-15 |  |  | PP |  | SIT | 5.0 | Michael Inije | Systems Integration Testing (SIT) | Complete | COMPLETE |  |  |  |  |
| 856 | 1.4.1.4.1.10.3.5 | PP Check data integrity on test environment |  | 5d | 2023-12-18 A | 2023-12-22 A | 855 | 100% | 2023-12-18 | 2023-12-22 | 5d | 2023-12-18 | 2023-12-22 |  |  | PP |  | SIT | 5.0 | Michael Inije | Systems Integration Testing (SIT) | Complete | COMPLETE |  |  |  |  |
| 857 | 1.4.1.4.1.10.3.6 | PP submit self-declaration to Programme to confirm loading & verification of test data | milestone | 0d | 2023-12-22 A | 2023-12-22 A | 856FF | 100% | 2023-12-22 | 2023-12-22 | 0d | 2023-12-22 | 2023-12-22 |  |  | PP | SI Test | SIT | 5.0 | Michael Inije | Systems Integration Testing (SIT) | Complete | COMPLETE |  |  |  |  |
| 858 | 1.4.1.4.1.10.3.7 | Test Data (SIT A) Interval 6 Complete | milestone | 0d | 2023-12-22 A | 2023-12-22 A | 857 | 100% | 2023-12-22 | 2023-12-22 | 0d |  |  |  |  | SI Test | PP | SIT | 5.5 | Michael Inije | Systems Integration Testing (SIT) | Complete | COMPLETE | MHHS-ART148/169 | T3-TE-0078 | SITAG | T3 |
| 859 | 1.4.1.4.1.10.4 | **Other Preparation** |  | 31d | 2023-12-04 A | 2024-01-15 A |  | 100% | 2023-12-04 | 2024-01-15 | 31d | 2023-09-04 | 2023-11-24 |  | -0 | N/A | N/A | SIT | 5.0 | N/A | Systems Integration Testing (SIT) |  |  |  |  |  |  |
| 860 | 1.4.1.4.1.10.4.1 | Onboarding of Test Participants to Test Management Tool (Azure DevOps) |  | 31d | 2023-12-04 A | 2024-01-15 A |  | 100% | 2023-12-04 | 2024-01-15 | 31d | 2023-09-04 | 2023-11-24 | start no earlier than 2023-12-04 |  | SI Test | PP | SIT | 5.0 | Simon Berry | Systems Integration Testing (SIT) | Complete | COMPLETE |  |  |  |  |
| 861 | 1.4.1.4.1.10.4.2 | Test Management Tool onboarding |  | 31d | 2023-12-04 A | 2024-01-15 A |  | 100% | 2023-12-04 | 2024-01-15 | 31d | 2023-09-04 | 2023-11-24 | start no earlier than 2023-12-04 |  | PP | SI Test | SIT | 5.0 | Simon Berry | Systems Integration Testing (SIT) | Complete | COMPLETE |  |  |  |  |
| 862 | 1.4.1.4.1.10.5 | **SIT Component Integration Test Readiness Report** |  | 25d | 2023-11-20 A | 2023-12-22 A |  | 100% | 2023-11-20 | 2023-12-22 | 25d | 2023-12-18 | 2024-01-19 |  |  | N/A | N/A | SIT | 5.0 | N/A | Systems Integration Testing (SIT) |  |  |  |  |  |  |
| 863 | 1.4.1.4.1.10.5.1 | PP submit Test Readiness Report to Programme for assurance | milestone | 0d | 2023-12-08 A | 2023-12-08 A | 655 | 100% | 2023-12-08 | 2023-12-08 | 0d | 2024-01-05 | 2024-01-05 |  |  | PP | SI Test | SIT | 5.0 |  | Systems Integration Testing (SIT) | Complete | COMPLETE |  |  |  |  |
| 864 | 1.4.1.4.1.10.5.2 | SI assure Test Participants' Test Readiness Reports |  | 5d | 2023-12-11 A | 2023-12-15 A | 863FF+5d | 100% | 2023-12-11 | 2023-12-15 | 5d | 2024-01-08 | 2024-01-12 |  |  | SI Test | PP,IPA | SIT | 5.0 |  | Systems Integration Testing (SIT) | Complete | COMPLETE |  |  |  |  |
| 865 | 1.4.1.4.1.10.5.3 | SI develop Overarching SIT Component Integration Test Readiness Report |  | 20d | 2023-11-20 A | 2023-12-15 A | 864FF | 100% | 2023-11-20 | 2023-12-15 | 20d | 2023-12-18 | 2024-01-12 |  |  | SI Test |  | SIT | 5.0 |  | Systems Integration Testing (SIT) | Complete | COMPLETE |  |  |  |  |
| 866 | 1.4.1.4.1.10.5.4 | Artefact review (via TMAG) and updates |  | 5d | 2023-12-18 A | 2023-12-22 A | 865 | 100% | 2023-12-18 | 2023-12-22 | 5d | 2024-01-15 | 2024-01-19 |  |  | SI Test | PP,IPA | SIT | 5.0 |  | Systems Integration Testing (SIT) | Complete | COMPLETE |  |  |  |  |
| 867 | 1.4.1.4.1.10.6 | SIT Component Integration Testing 6 Preparation Complete (incl. approval of SI SIT Component Integration Test Readiness Report) | milestone | 0d | 2024-01-19 A | 2024-01-19 A | 866FS+1d, 840, 844, 861, 863, 858, 309, 498 | 100% | 2024-01-19 | 2024-01-19 | 0d | 2024-01-22 | 2024-01-22 |  |  | SI Test | PP,IPA | SIT | 5.15 |  | Systems Integration Testing (SIT) | Complete | COMPLETE | MHHS-ART071 | T2-TE-0500 | SITAG | T2 |
| 868 | 1.4.1.4.2 | **SIT Functional Preparation** |  | 595d? | 2022-10-31 A | 2025-02-07 A |  | 100% | 2022-10-31 | 2025-04-07 | 520d | 2022-10-31 | 2024-03-01 |  | -0 | N/A | N/A | SIT | 5.0 | N/A | Systems Integration Testing (SIT) |  |  |  |  | SITAG |  |
| 869 | 1.4.1.4.2.1 | Environment Approach and Plan - SIT Functional |  | 1d? | 2023-11-20 A | 2023-11-20 A |  | 100% | 2023-11-20 | 2023-11-20 | 0d |  |  | start no earlier than 2023-11-20 |  | SI Test |  | SIT | 6.0 |  |  | Complete | COMPLETE |  |  |  |  |
| 870 | 1.4.1.4.2.2 | **Test Approach & Plan** |  | 208d | 2022-10-31 A | 2023-08-16 A |  | 100% | 2022-10-31 | 2023-08-16 | 208d | 2022-10-31 | 2023-08-16 |  |  | N/A | N/A | SIT | 5.0 | N/A | Systems Integration Testing (SIT) |  |  |  |  |  |  |
| 871 | 1.4.1.4.2.2.1 | Develop document with SITWG |  | 179d | 2022-10-31 A | 2023-07-06 A |  | 100% | 2022-10-31 | 2023-07-06 | 179d | 2022-10-31 | 2023-07-06 | finish no earlier than 2023-07-06 |  | SI Test |  | SIT | 5.0 |  | Systems Integration Testing (SIT) | Complete | COMPLETE |  |  |  |  |
| 872 | 1.4.1.4.2.2.2 | Industry Consultation |  | 10d | 2023-07-07 A | 2023-07-20 A | 871 | 100% | 2023-07-07 | 2023-07-20 | 10d |  |  |  |  | PP |  | SIT | 5.1 |  | Systems Integration Testing (SIT) | Complete | COMPLETE |  |  |  |  |
| 873 | 1.4.1.4.2.2.3 | Artefact review (via TMAG) and updates |  | 19d | 2023-07-21 A | 2023-08-16 A | 872 | 100% | 2023-07-21 | 2023-08-16 | 19d | 2023-07-07 | 2023-08-03 | finish no earlier than 2023-08-03 |  | SI Test | PP,IPA,Code Bodies | SIT | 5.5 |  | Systems Integration Testing (SIT) | Complete | COMPLETE |  |  |  |  |
| 874 | 1.4.1.4.2.2.4 | SIT Functional Test Approach & Plan approved | milestone | 0d | 2023-08-16 A | 2023-08-16 A |  | 100% | 2023-08-16 | 2023-08-16 | 0d | 2023-08-16 | 2023-08-16 | finish no earlier than 2023-08-16 |  | SI Test | PP | SIT | 5.0 |  | Systems Integration Testing (SIT) | Complete | COMPLETE | MHHS-ART073 | T3-TE-0013 | SITAG | T3 |

Notes:
- 858: Action: 28/7: CH: Needs to be set-up as a reporting milestone. 31/7: Check with Cesar if has been approved so can be baselined

| ID | WBS | Task | Type | Duration | Start | Finish | Predecessors | Complete | Baseline start | Baseline finish | Baseline duration | Baseline 1 start | Baseline 1 finish | Constraint | Baseline cost | Responsible | Involved | Text9 | Update Version | MHHS Resource Name | MHHS Programme Phase | Sched Status | RAG | Artefact ID | Milestone ID | Text29 | Tier | Action | Guidance | Task Status |
| --- | --- | --- | --- | --- | --- | --- | --- | --- | --- | --- | --- | --- | --- | --- | --- | --- | --- | --- | --- | --- | --- | --- | --- | --- | --- | --- | --- | --- | --- | --- |
| 875 | 1.4.1.4.2.3 | **Test Data Approach & Plan** |  | 29d | 2023-07-07 A | 2023-08-16 A |  | 100% | 2023-07-07 | 2023-08-16 | 29d | 2023-07-07 | 2023-08-16 |  |  | N/A | N/A | SIT | 5.0 | N/A | Systems Integration Testing (SIT) |  |  |  |  |  |  |  |  |  |
| 876 | 1.4.1.4.2.3.1 | Industry Consultation |  | 10d | 2023-07-07 A | 2023-07-20 A | 872SS | 100% | 2023-07-07 | 2023-07-20 | 10d |  |  |  |  | PP |  | SIT | 5.1 | Cesar Lopes | Systems Integration Testing (SIT) | Complete | COMPLETE |  |  |  |  |  |  |  |
| 877 | 1.4.1.4.2.3.2 | Artefact review (via TMAG) and updates |  | 19d | 2023-07-21 A | 2023-08-16 A | 876 | 100% | 2023-07-21 | 2023-08-16 | 19d | 2023-07-07 | 2023-08-03 |  |  | SI Test |  | SIT | 5.5 | Cesar Lopes | Systems Integration Testing (SIT) | Complete | COMPLETE |  |  |  |  |  |  |  |
| 878 | 1.4.1.4.2.3.3 | SIT Functional Testing Test Data Approach & Plan approved | milestone | 0d | 2023-08-16 A | 2023-08-16 A | 877 | 100% | 2023-08-16 | 2023-08-16 | 0d | 2023-08-16 | 2023-08-16 |  |  | SI Test | PP,IPA | SIT | 5.5 | Cesar Lopes | Systems Integration Testing (SIT) | Complete | COMPLETE |  |  |  |  |  |  |  |
| 879 | 1.4.1.4.2.4 | **Test scenarios** |  | 298d | 2023-01-02 A | 2024-02-21 A |  | 100% | 2023-01-02 | 2024-02-21 | 298d | 2023-01-02 | 2023-06-02 |  | -0 | N/A | N/A | SIT | 5.0 | N/A | Systems Integration Testing (SIT) |  |  |  |  |  |  |  |  |  |
| 880 | 1.4.1.4.2.4.1 | Development of test scenarios |  | 85d | 2023-01-02 A | 2023-04-28 A | 871SS+45d | 100% | 2023-01-02 | 2023-04-28 | 85d | 2023-01-02 | 2023-04-28 |  |  | SI Test | PP, Code Bodies | SIT | 5.0 |  | Systems Integration Testing (SIT) | Complete | COMPLETE |  |  |  |  |  |  |  |
| 881 | 1.4.1.4.2.4.2 | Review test scenarios with SIT Working Group |  | 65d | 2023-08-17 A | 2023-11-15 A | 880FS+78d | 100% | 2023-08-17 | 2023-11-15 | 65d | 2023-02-01 | 2023-05-26 |  |  | SI Test | PP, Code Bodies, IPA | SIT | 5.0 |  | Systems Integration Testing (SIT) | Complete | COMPLETE |  |  |  |  |  |  |  |
| 882 | 1.4.1.4.2.4.3 | SIT Functional Testing Test scenarios (themes 1-5) approved | milestone | 0d | 2023-12-08 A | 2023-12-08 A | 881FS+17d | 100% | 2023-12-08 | 2023-12-08 | 0d | 2023-06-02 | 2023-06-02 |  |  | SI Test | PP | SIT | 5.14 |  | Systems Integration Testing (SIT) | Complete | COMPLETE | MMHS-ART073 | T3-TE-0015 | SITAG | T3 |  |  |  |
| 883 | 1.4.1.4.2.4.4 | SIT Functional Testing Test scenarios (themes 6,7,9) approved | milestone | 0d | 2024-01-17 A | 2024-01-17 A | 882FS+28d | 100% | 2024-01-17 | 2024-01-17 | 0d | 2023-06-02 | 2023-06-02 |  |  | SI Test | PP | SIT | 5.16 |  | Systems Integration Testing (SIT) | Complete | COMPLETE | MMHS-ART073 | T3-TE-0106 | SITAG | T3 |  |  |  |
| 884 | 1.4.1.4.2.4.5 | SIT Functional Testing Test scenarios (theme 8) approved | milestone | 0d | 2024-02-21 A | 2024-02-21 A | 883FS+25d | 100% | 2024-02-21 | 2024-02-21 | 0d | 2023-06-02 | 2023-06-02 |  |  | SI Test | PP | SIT | 5.14 |  | Systems Integration Testing (SIT) | Complete | COMPLETE | MMHS-ART073 | T3-TE-0107 | SITAG | T3 |  |  |  |
| 885 | 1.4.1.4.2.5 | **Test cases** |  | 465d? | 2023-05-01 A | 2025-02-07 A |  | 100% | 2023-05-01 | 2025-02-07 | 213d | 2023-05-01 | 2023-09-01 |  |  | N/A | N/A | SIT | 5.0 | N/A | Systems Integration Testing (SIT) |  |  |  |  |  |  | 25/7 - needs to be replanned |  |  |
| 886 | 1.4.1.4.2.5.1 | **SI Test cases** |  | 213d | 2023-05-01 A | 2024-02-21 A |  | 100% | 2023-05-01 | 2024-02-21 | 213d | 2023-05-01 | 2023-09-01 |  |  | N/A | N/A | SIT | 5.0 | N/A | Systems Integration Testing (SIT) |  |  |  |  |  |  | 25/7 - needs to be replanned |  |  |
| 887 | 1.4.1.4.2.5.1.1 | Development of Test cases |  | 150d | 2023-05-01 A | 2023-11-24 A | 880 | 100% | 2023-05-01 | 2023-11-24 | 150d | 2023-05-01 | 2023-07-28 |  |  | SI Test |  | SIT | 5.0 |  | Systems Integration Testing (SIT) | Complete | COMPLETE |  |  |  |  | 25/7 - needs to be replanned |  |  |
| 888 | 1.4.1.4.2.5.1.2 | Review Test cases with SIT Working Group |  | 78d | 2023-09-25 A | 2024-01-10 A | 887SS+105d | 100% | 2023-09-25 | 2024-01-10 | 78d | 2023-05-26 | 2023-08-25 |  |  | SI Test | PP,IPA | SIT | 5.0 |  | Systems Integration Testing (SIT) | Complete | COMPLETE |  |  |  |  | 25/7 - needs to be replanned |  |  |
| 889 | 1.4.1.4.2.5.1.3 | SIT Functional Testing Test Cases (themes 1-5) approved | milestone | 0d | 2024-01-17 A | 2024-01-17 A | 888FS+5d | 100% | 2024-01-17 | 2024-01-17 | 0d | 2023-09-01 | 2023-09-01 |  |  | SI Test | PP | SIT | 5.14 |  | Systems Integration Testing (SIT) | Complete | COMPLETE | MHHS-ART140 | T3-TE-0070 | SITAG | T3 |  | 2/1/24 - Approved at Dec TMAG |  |
| 890 | 1.4.1.4.2.5.1.4 | SIT Functional Testing Test cases (themes 6,7,9) approved | milestone | 0d | 2024-01-17 A | 2024-01-17 A | 889 | 100% | 2024-01-17 | 2024-01-17 | 0d | 2023-09-01 | 2023-09-01 |  |  | SI Test | PP | SIT | 5.14 |  | Systems Integration Testing (SIT) | Complete | COMPLETE | MHHS-ART140 | T3-TE-0108 | SITAG | T3 |  |  |  |
| 891 | 1.4.1.4.2.5.1.5 | SIT Functional Testing Test cases (theme 8) approved | milestone | 0d | 2024-02-21 A | 2024-02-21 A | 890FS+25d | 100% | 2024-02-21 | 2024-02-21 | 0d | 2023-09-01 | 2023-09-01 |  |  | SI Test | PP | SIT | 5.14 |  | Systems Integration Testing (SIT) | Complete | COMPLETE | MHHS-ART140 | T3-TE-0109 | SITAG | T3 |  |  |  |
| 892 | 1.4.1.4.2.5.2 | **SIT Functional Programme RTTM** |  | 74d? | 2024-07-29 A | 2024-11-07 A |  | 100% | 2024-07-29 | 2024-10-11 | 0d |  |  |  |  | SI Test |  | SIT | 6.0 | Kevin Davis |  | Overdue Start |  |  |  | SITAG |  |  |  | -687.67 |
| 893 | 1.4.1.4.2.5.2.1 | **RTTM Development** |  | 30d? | 2024-07-29 A | 2024-09-06 A |  | 100% | 2024-07-29 | 2024-09-20 | 0d |  |  |  |  | SI Test |  | SIT | 6.0 | Kevin Davis |  | Overdue Start |  |  |  | SITAG |  |  |  | -693.67 |
| 894 | 1.4.1.4.2.5.2.1.1 | Development of Manual SIT Functional RTTM |  | 30d? | 2024-07-29 A | 2024-09-06 A |  | 100% | 2024-07-29 | 2024-09-06 | 0d |  |  | start no earlier than 2024-07-29 |  | SI Test |  | SIT | 6.0 | Kevin Davis |  | Complete | COMPLETE |  |  | SITAG |  |  |  |  |
| 895 | 1.4.1.4.2.5.2.1.2 | Manual SIT Functional RTTM Complete | milestone | 0d? | 2024-09-06 A | 2024-09-06 A | 894 | 100% | 2024-09-06 | 2024-09-06 | 0d |  |  | start no earlier than 2024-07-29 |  | SI Test |  | SIT | 6.0 | Kevin Davis |  | Complete | COMPLETE |  |  | SITAG |  |  |  |  |
| 896 | 1.4.1.4.2.5.2.2 | **Gap analysis** |  | 54d? | 2024-08-26 A | 2024-11-07 A |  | 100% | 2024-08-26 | 2024-10-11 | 0d |  |  |  |  | SI Test |  | SIT | 6.0 | Kevin Davis |  | Overdue Start |  |  |  | SITAG |  |  |  | -693.67 |
| 897 | 1.4.1.4.2.5.2.2.1 | Identify gaps in test case coverage following RTTM review |  | 20d? | 2024-08-26 A | 2024-09-20 A |  | 100% | 2024-08-26 | 2024-09-20 | 0d |  |  |  |  | SI Test |  | SIT | 6.0 | Kevin Davis |  | Complete | COMPLETE |  |  | SITAG |  |  |  |  |
| 898 | 1.4.1.4.2.5.2.2.2 | Address gaps in test case coverage following RTTM review |  | 25d | 2024-09-09 A | 2024-10-11 A | 897SS+10d | 100% | 2024-09-09 | 2024-10-04 | 0d |  |  |  |  | SI Test |  | SIT | 6.0 | Kevin Davis |  | Complete | COMPLETE |  |  | SITAG |  |  |  |  |
| 899 | 1.4.1.4.2.5.2.2.3 | Gap analysis complete | milestone | 0d | 2024-10-11 A | 2024-10-11 A | 898 | 100% | 2024-10-11 | 2024-10-11 | 0d |  |  |  |  | SI Test |  | SIT | 6.11 | Kevin Davis |  | Complete | COMPLETE |  |  | SITAG |  |  |  |  |
| 900 | 1.4.1.4.2.5.2.2.4 | Test Script updates identified |  | 1d? | 2024-10-14 A | 2024-10-14 A | 899 | 100% | 2024-10-14 | 2024-10-14 | 0d |  |  |  |  | SI Test |  | SIT | 6.11 | Kevin Davis |  | Complete | COMPLETE |  |  | SITAG |  |  |  |  |
| 901 | 1.4.1.4.2.5.2.2.5 | Test Scripts updates |  | 1d | 2024-10-15 A | 2024-10-15 A | 900 | 100% | 2024-10-15 | 2024-10-15 | 0d |  |  |  |  | SI Test |  | SIT | 6.11 | Kevin Davis |  | Complete | COMPLETE |  |  | SITAG |  |  |  |  |
| 902 | 1.4.1.4.2.5.2.2.6 | RTTM Updated Additional Static RTTM WBS items |  | 10d | 2024-10-14 A | 2024-10-25 A | 900FS-1d | 100% | 2024-10-14 | 2024-10-25 | 0d |  |  |  |  | SI Test |  | SIT | 6.11 | Kevin Davis |  | Complete | COMPLETE |  |  | SITAG |  |  |  |  |
| 903 | 1.4.1.4.2.5.2.2.7 | Removal of de-scoped TCs from the RTTMs |  | 5d | 2024-10-21 A | 2024-10-25 A | 902FS-5d | 100% | 2024-10-21 | 2024-10-25 | 0d |  |  |  |  | SI Test |  | SIT | 6.11 | Kevin Davis |  | Complete | COMPLETE |  |  | SITAG |  |  |  |  |
| 904 | 1.4.1.4.2.5.2.2.8 | Update and stabilisation of all TC ADO IDs |  | 14d | 2024-10-21 A | 2024-11-07 A | 902FS-5d | 100% | 2024-10-21 | 2024-10-25 | 0d |  |  |  |  | SI Test |  | SIT | 6.12 | Kevin Davis |  | Complete | COMPLETE |  |  | SITAG |  |  |  |  |
| 905 | 1.4.1.4.2.5.2.2.9 | Addition and integration of Role tags to reqs in the Role RTTMs |  | 5d | 2024-10-21 A | 2024-10-25 A | 902FS-5d | 100% | 2024-10-21 | 2024-10-25 | 0d |  |  |  |  | SI Test |  | SIT | 6.11 | Kevin Davis |  | Complete | COMPLETE |  |  | SITAG |  |  |  |  |
| 906 | 1.4.1.4.2.5.2.2.10 | Update of the RTTM All sheet (porting of the individual RTTMs) |  | 7d | 2024-10-24 A | 2024-11-01 A | 902FS-2d | 100% | 2024-10-24 | 2024-10-25 | 0d |  |  |  |  | SI Test |  | SIT | 6.11 | Kevin Davis |  | Complete | COMPLETE |  |  | SITAG |  |  |  |  |
| 907 | 1.4.1.4.2.5.2.2.11 | Define Additional ADO Tags |  | 1d | 2024-10-23 A | 2024-10-23 A | 902FS-3d | 100% | 2024-10-23 | 2024-10-23 | 0d |  |  |  |  | SI Test |  | SIT | 6.11 | Kevin Davis |  | Complete | COMPLETE |  |  | SITAG |  |  |  |  |
| 908 | 1.4.1.4.2.5.2.2.12 | Functional RTTM ready for import into ADO | milestone | 0d | 2024-11-01 A | 2024-11-01 A | 906 | 100% | 2024-10-25 | 2024-10-25 | 0d |  |  |  |  | SI Test |  | SIT | 6.11 | Kevin Davis |  | Complete | COMPLETE |  |  | SITAG |  |  |  |  |
| 909 | 1.4.1.4.2.5.2.2.13 | Further Interative Deepdive on the requirements to testcase mapping |  | 9d | 2024-10-21 A | 2024-10-31 A | 906FS-10d | 100% | 2024-10-21 | 2024-10-31 | 0d |  |  |  |  | SI Test |  | SIT | 6.11 | Kevin Davis |  | Complete | COMPLETE |  |  | SITAG |  |  |  |  |
| 910 | 1.4.1.4.2.5.2.2.14 | Internal review |  | 5d | 2024-10-21 A | 2024-10-25 A | 909FS-9d | 100% | 2024-11-01 | 2024-11-05 | 0d |  |  |  |  | SI Test |  | SIT | 6.11 | Kevin Davis |  | Complete | COMPLETE |  |  | SITAG |  |  |  |  |
| 911 | 1.4.1.4.2.5.2.2.15 | Issue Static RTTM to Code Bodies |  | 1d? | 2024-10-29 A | 2024-10-29 A | 910FS+1d | 100% | 2024-11-06 | 2024-11-06 | 0d |  |  |  |  | SI Test |  | SIT | 6.11 | Kevin Davis |  | Complete | COMPLETE |  |  | SITAG |  |  |  |  |
| 912 | 1.4.1.4.2.5.2.2.16 | Code Body Acceptance of RTTM |  | 5d | 2024-10-30 A | 2024-11-05 A | 911 | 100% | 2024-11-07 | 2024-11-13 | 0d |  |  |  |  | Code Bodies |  | SIT | 6.11 | Kevin Davis |  | Complete | COMPLETE |  |  | SITAG |  |  |  |  |

| ID | WBS | Task | Type | Duration | Start | Finish | Predecessors | Complete | Baseline start | Baseline finish | Baseline duration | Constraint | Responsible | Text9 | Task Status | Update Version | Sched Status | MHHS Resource Name | Text29 | RAG | Milestone ID | Tier |
| --- | --- | --- | --- | --- | --- | --- | --- | --- | --- | --- | --- | --- | --- | --- | --- | --- | --- | --- | --- | --- | --- | --- |
| 913 | 1.4.1.4.2.5.3 | **Cycle 3 Test Evidence Capturing Approach** |  | 25d? | 2024-09-16 A | 2024-10-18 A |  | 100% | 2024-09-16 | 2024-10-18 | 0d |  | SI Test | SIT | -692.67 | 6.0 | Overdue Start | Ankur Pande | SITAG |  |  |  |
| 914 | 1.4.1.4.2.5.3.1 | Define guiding principles and proof of concept |  | 10d | 2024-09-16 A | 2024-09-27 A |  | 100% | 2024-09-16 | 2024-09-27 | 0d | start no earlier than 2024-09-16 | SI Test | SIT |  | 6.0 | Complete | Ankur Pande | SITAG | COMPLETE |  |  |
| 915 | 1.4.1.4.2.5.3.2 | Draft proposed test evidence capturing approach |  | 3d | 2024-09-30 A | 2024-10-02 A | 914 | 100% | 2024-09-30 | 2024-10-02 | 0d |  | SI Test | SIT |  | 6.0 | Complete | Ankur Pande | SITAG | COMPLETE |  |  |
| 916 | 1.4.1.4.2.5.3.3 | SRO review |  | 5d | 2024-10-03 A | 2024-10-09 A | 915 | 100% | 2024-10-03 | 2024-10-09 | 0d |  | SI Test | SIT |  | 6.0 | Complete | Ankur Pande | SITAG | COMPLETE |  |  |
| 917 | 1.4.1.4.2.5.3.4 | Present proposed approach |  | 1d? | 2024-10-11 A | 2024-10-11 A | 916FS+1d | 100% | 2024-10-11 | 2024-10-11 | 0d |  | SI Test | SIT |  | 6.0 | Complete | Ankur Pande | SITAG | COMPLETE |  |  |
| 918 | 1.4.1.4.2.5.3.5 | Incorporate feedback |  | 4d | 2024-10-14 A | 2024-10-17 A | 917 | 100% | 2024-10-14 | 2024-10-17 | 0d |  | SI Test | SIT |  | 6.0 | Complete | Ankur Pande | SITAG | COMPLETE |  |  |
| 919 | 1.4.1.4.2.5.3.6 | Publish proposed approach ahead of Cycle 3 start |  | 1d? | 2024-10-18 A | 2024-10-18 A | 918 | 100% | 2024-10-18 | 2024-10-18 | 0d |  | SI Test | SIT |  | 6.0 | Complete | Ankur Pande | SITAG | COMPLETE |  |  |
| 920 | 1.4.1.4.2.5.4 | **DITL Cycle 3 Pack Development** |  | 8d? | 2024-10-08 A | 2024-10-17 A |  | 100% | 2024-10-08 | 2024-10-17 | 0d |  | SI Test | SIT | 6.33 | 6.0 | No BL | Dom Mooney | SITAG |  |  |  |
| 921 | 1.4.1.4.2.5.4.1 | Programme Cycle 2 Retro |  | 1d? | 2024-10-08 A | 2024-10-08 A |  | 100% | 2024-10-08 | 2024-10-08 | 0d | start no earlier than 2024-10-08 | SI Test | SIT |  | 6.0 | Complete | Dom Mooney | SITAG | COMPLETE |  |  |
| 922 | 1.4.1.4.2.5.4.2 | Post-retro DITL Changes |  | 3d | 2024-10-09 A | 2024-10-11 A | 921 | 100% | 2024-10-09 | 2024-10-11 | 0d |  | SI Test | SIT |  | 6.0 | Complete | Dom Mooney | SITAG | COMPLETE |  |  |
| 923 | 1.4.1.4.2.5.4.3 | SRO Review |  | 2d | 2024-10-14 A | 2024-10-15 A | 922 | 100% | 2024-10-14 | 2024-10-15 | 0d |  | SI Test | SIT |  | 6.0 | Complete | Dom Mooney | SITAG | COMPLETE |  |  |
| 924 | 1.4.1.4.2.5.4.4 | Post-SRO Review Changes |  | 1d? | 2024-10-16 A | 2024-10-16 A | 923 | 100% | 2024-10-16 | 2024-10-16 | 0d |  | SI Test | SIT |  | 6.0 | Complete | Dom Mooney | SITAG | COMPLETE |  |  |
| 925 | 1.4.1.4.2.5.4.5 | Publish Cycle 3 DITL / Cycle 3 DITL Online Sessions for SIT PPs |  | 1d? | 2024-10-17 A | 2024-10-17 A | 924 | 100% | 2024-10-17 | 2024-10-17 | 0d |  | SI Test, PPs | SIT |  | 6.0 | Complete | Dom Mooney | SITAG | COMPLETE |  |  |
| 926 | 1.4.1.4.2.5.5 | **Test Script Exit Points** |  | 85d | 2024-10-14 A | 2025-02-07 A |  | 100% | 2024-10-14 | 2025-02-07 | 0d |  | SI Test | SIT | -694.67 | 6.0 | Overdue Start | Kevin Davis | SITAG |  |  |  |
| 927 | 1.4.1.4.2.5.5.1 | Implement exit points for Sprint 5 |  | 5d | 2024-10-14 A | 2024-10-18 A | 919FS-5d | 100% | 2024-10-14 | 2024-10-18 | 0d |  | SI Test | SIT |  | 6.0 | Complete | Kevin Davis | SITAG | COMPLETE |  |  |
| 928 | 1.4.1.4.2.5.5.2 | Identify exit points for Sprint 6 |  | 5d | 2024-11-07 A | 2024-11-13 A | 1551SS | 100% | 2024-10-21 | 2024-10-25 | 0d |  | SI Test | SIT |  | 6.0 | Complete | Kevin Davis | SITAG | COMPLETE |  |  |
| 929 | 1.4.1.4.2.5.5.3 | Identify exit points for Sprint 7 |  | 5d | 2024-11-08 A | 2024-11-14 A | 1552SS | 100% | 2024-11-04 | 2024-11-08 | 0d | start no earlier than 2024-11-08 | SI Test | SIT |  | 6.0 | Complete | Kevin Davis | SITAG | COMPLETE |  |  |
| 930 | 1.4.1.4.2.5.5.4 | Identify exit points for Sprint 8 |  | 5d | 2024-11-18 A | 2024-11-22 A | 1553SS | 100% | 2024-11-18 | 2024-11-22 | 0d |  | SI Test | SIT |  | 6.0 | Complete | Kevin Davis | SITAG | COMPLETE |  |  |
| 931 | 1.4.1.4.2.5.5.5 | Identify exit points for Sprint 9 |  | 5d | 2024-12-02 A | 2024-12-06 A | 1554SS | 100% | 2024-12-02 | 2024-12-06 | 0d |  | SI Test | SIT |  | 6.0 | Complete | Kevin Davis | SITAG | COMPLETE |  |  |
| 932 | 1.4.1.4.2.5.5.6 | Identify exit points for Sprint 10 |  | 5d | 2024-12-23 A | 2024-12-27 A | 1555SS | 100% | 2024-12-23 | 2024-12-27 | 0d |  | SI Test | SIT |  | 6.0 | Complete | Kevin Davis | SITAG | COMPLETE |  |  |
| 933 | 1.4.1.4.2.5.5.7 | Identify exit points for Sprint 11 |  | 5d | 2025-01-06 A | 2025-01-10 A | 1556SS | 100% | 2025-01-06 | 2025-01-10 | 0d |  | SI Test | SIT |  | 6.0 | Complete | Kevin Davis | SITAG | COMPLETE |  |  |
| 934 | 1.4.1.4.2.5.5.8 | Identify exit points for Sprint 12 |  | 5d | 2025-01-20 A | 2025-01-24 A | 1557SS | 100% | 2025-01-20 | 2025-01-24 | 0d |  | SI Test | SIT |  | 6.0 | Complete | Kevin Davis | SITAG | COMPLETE |  |  |
| 935 | 1.4.1.4.2.5.5.9 | Identify exit points for Sprint 13 |  | 5d | 2025-02-03 A | 2025-02-07 A | 1558SS | 100% | 2025-02-03 | 2025-02-07 | 0d |  | SI Test | SIT |  | 6.0 | Complete | Kevin Davis | SITAG | COMPLETE |  |  |
| 936 | 1.4.1.4.2.5.5.10 | Exit point identified and evidence capture flags updated | milestone | 0d | 2025-02-07 A | 2025-02-07 A | 935 | 100% | 2025-02-07 | 2025-02-07 | 0d |  | SI Test | SIT |  | 6.13 | Complete | Kevin Davis | SITAG | COMPLETE | T3-TE-0125 | T3 |

| ID | WBS | Task | Type | Duration | Start | Finish | Predecessors | Complete | Baseline start | Baseline finish | Baseline duration | Baseline 1 start | Baseline 1 finish | Constraint | Baseline cost | Responsible | Involved | Text9 | Update Version | MHHS Resource Name | MHHS Programme Phase | Text29 | Task Status | Sched Status | RAG | Action | Milestone ID | Tier | Artefact ID |
| --- | --- | --- | --- | --- | --- | --- | --- | --- | --- | --- | --- | --- | --- | --- | --- | --- | --- | --- | --- | --- | --- | --- | --- | --- | --- | --- | --- | --- | --- |
| 937 | 1.4.1.4.2.6 | **Environments (SIT-Staging)** |  | 10d | 2023-12-04 A | 2023-12-15 A |  | 100% | 2023-12-04 | 2023-12-15 | 323d | 2022-11-16 | 2024-02-09 |  |  | N/A | N/A | SIT | 5.0 | N/A | Systems Integration Testing (SIT) | SITAG |  |  |  |  |  |  |  |
| 938 | 1.4.1.4.2.6.1 | **SIT Functional pre-requisites** |  | 10d | 2023-12-04 A | 2023-12-15 A |  | 100% | 2023-12-04 | 2023-12-15 | 10d |  |  |  |  | N/A | N/A | SIT | 5.3 | N/A | Systems Integration Testing (SIT) | SITAG |  |  |  |  |  |  |  |
| 939 | 1.4.1.4.2.6.1.1 | **DCC** |  | 10d | 2023-12-04 A | 2023-12-15 A |  | 100% | 2023-12-04 | 2023-12-15 | 10d |  |  |  |  | N/A | N/A | SIT | 5.3 | N/A | Systems Integration Testing (SIT) | SITAG | -254.67 |  |  |  |  |  |  |
| 940 | 1.4.1.4.2.6.1.1.1 | **CSS** |  | 10d | 2023-12-04 A | 2023-12-15 A |  | 100% | 2023-12-04 | 2023-12-15 | 10d |  |  |  |  | N/A | N/A | SIT | 5.3 | N/A | Systems Integration Testing (SIT) | SITAG | -254.67 |  |  |  |  |  |  |
| 941 | 1.4.1.4.2.6.1.1.1.1 | SIT participants have requested DCC CSS PKI certificates for access to UIT-B environment |  | 10d | 2023-12-04 A | 2023-12-15 A |  | 100% | 2023-12-04 | 2023-12-15 | 10d |  |  | start no earlier than 2023-12-04 |  | SIT Participants (Suppliers & Third Parties) | PP | SIT | 5.3 | Simon Berry | Systems Integration Testing (SIT) | SITAG |  | Complete | COMPLETE |  |  |  |  |
| 942 | 1.4.1.4.2.6.1.1.1.2 | SIT participants have received DCC CSS PKI certificates for UIT-B environment | milestone | 0d | 2023-12-15 A | 2023-12-15 A | 941 | 100% | 2023-12-15 | 2023-12-15 | 0d |  |  |  |  | SIT Participants (Suppliers & Third Parties) | PP | SIT | 5.5 | Simon Berry | Systems Integration Testing (SIT) | SITAG |  | Complete | COMPLETE | 7/8 - added as a T3 milestone. Awaiting approval at TMAG | T3-TE-0088 | T3 |  |
| 943 | 1.4.1.4.2.6.1.1.2 | **DSP** |  | 10d | 2023-12-04 A | 2023-12-15 A |  | 100% | 2023-12-04 | 2023-12-15 | 10d |  |  |  |  | N/A | N/A | SIT | 5.3 | N/A | Systems Integration Testing (SIT) | SITAG | -254.67 |  |  |  |  |  |  |
| 944 | 1.4.1.4.2.6.1.1.2.1 | SIT participants have requested DCC DSP PKI certificates for access to UIT-B environment |  | 10d | 2023-12-04 A | 2023-12-15 A |  | 100% | 2023-12-04 | 2023-12-15 | 10d |  |  | start no earlier than 2023-12-04 |  | PPs in SDS Market Role | PP | SIT | 5.3 | Simon Berry | Systems Integration Testing (SIT) | SITAG |  | Complete | COMPLETE |  |  |  |  |
| 945 | 1.4.1.4.2.6.1.1.2.2 | SIT participants have received DCC DSP PKI certificates for UIT-B environment | milestone | 0d | 2023-12-15 A | 2023-12-15 A | 944 | 100% | 2023-12-15 | 2023-12-15 | 0d |  |  |  |  | PPs in SDS Market Role | PP | SIT | 5.5 | Simon Berry | Systems Integration Testing (SIT) | SITAG |  | Complete | COMPLETE | 7/8 - added as a T3 milestone. Awaiting approval at TMAG | T3-TE-0089 | T3 |  |
| 946 | 1.4.1.4.2.7 | **Stand up SIT A Environment** |  | 25d | 2024-02-05 A | 2024-03-08 A |  | 100% | 2024-02-05 | 2024-03-08 | 25d | 2024-02-05 | 2024-02-09 |  |  | N/A | N/A | SIT | 6.0 | N/A | Systems Integration Testing (SIT) | SITAG |  |  |  |  |  |  |  |
| 947 | 1.4.1.4.2.7.1 | **SIT Functional Connectivity Proving** |  | 15d | 2024-02-12 A | 2024-03-01 A |  | 100% | 2024-02-12 | 2024-03-01 | 20d |  |  |  |  | N/A | N/A | SIT | 5.5 | N/A | Systems Integration Testing (SIT) | SITAG | -288.67 |  |  |  |  |  |  |
| 948 | 1.4.1.4.2.7.1.1 | SIT Functional Connectivity Proving Period |  | 15d | 2024-02-12 A | 2024-03-01 A |  | 100% | 2024-02-12 | 2024-03-01 | 20d |  |  | start no earlier than 2024-01-08 |  | SI Test | PP | SIT | 5.19 | Simon Berry | Systems Integration Testing (SIT) | SITAG |  | Complete | COMPLETE |  |  |  |  |
| 949 | 1.4.1.4.2.7.1.2 | SIT Functional Connectivity Proving Complete | milestone | 0d | 2024-03-01 A | 2024-03-01 A | 948 | 100% | 2024-03-01 | 2024-03-01 | 0d |  |  | start no earlier than 2024-03-01 |  | SI Test | PP | SIT | 5.19 | Simon Berry | Systems Integration Testing (SIT) | SITAG |  | Complete | COMPLETE |  | T3-TE-0103 | T3 |  |
| 950 | 1.4.1.4.2.7.2 | **PP Environments (SIT A)** |  | 25d | 2024-02-05 A | 2024-03-08 A |  | 100% | 2024-02-05 | 2024-03-08 | 5d | 2024-02-05 | 2024-02-09 |  |  | N/A | N/A | SIT | 5.0 | N/A | Systems Integration Testing (SIT) | SITAG |  |  |  |  |  |  |  |
| 951 | 1.4.1.4.2.7.2.1 | Deployment of MHHS solution code to SIT A environments |  | 25d | 2024-02-05 A | 2024-03-08 A |  | 100% | 2024-02-05 | 2024-03-08 | 5d | 2024-02-05 | 2024-02-09 | start no earlier than 2024-02-05 |  | PP | SI Test | SIT | 5.0 | Simon Berry | Systems Integration Testing (SIT) | SITAG |  | Complete | COMPLETE |  |  |  |  |
| 952 | 1.4.1.4.2.7.3 | **SI Environments (SIT A)** |  | 25d | 2024-02-05 A | 2024-03-08 A |  | 100% | 2024-02-05 | 2024-03-08 | 5d | 2024-02-05 | 2024-02-09 |  |  | N/A | N/A | SIT | 5.0 | N/A | Systems Integration Testing (SIT) | SITAG |  |  |  |  |  |  |  |
| 953 | 1.4.1.4.2.7.3.1 | Coordinate deployment of MHHS solution code to SIT Participants' SIT A environments |  | 25d | 2024-02-05 A | 2024-03-08 A | 951SS | 100% | 2024-02-05 | 2024-03-08 | 5d | 2024-02-05 | 2024-02-09 |  |  | SI Test | PP | SIT | 5.0 | Simon Berry | Systems Integration Testing (SIT) | SITAG |  | Complete | COMPLETE |  |  |  |  |
| 954 | 1.4.1.4.2.8 | **Test data (SIT A)** |  | 221d? | 2023-12-18 A | 2024-10-21 A |  | 100% | 2023-12-18 | 2025-04-07 | 225d |  |  |  | -0 | N/A | N/A | SIT | 5.4 | N/A | Systems Integration Testing (SIT) | SITAG | -269.67 |  |  |  |  |  |  |
| 955 | 1.4.1.4.2.8.1 | **Cycle 1 Test data (SIT A)** |  | 55d | 2023-12-18 A | 2024-03-01 A |  | 100% | 2023-12-18 | 2024-03-01 | 55d |  |  |  | -0 | N/A | N/A | SIT | 5.4 | N/A | Systems Integration Testing (SIT) | SITAG | -269.67 |  |  |  |  |  |  |
| 956 | 1.4.1.4.2.8.1.1 | Prepare, Generate and Allocate Test Data |  | 28d | 2023-12-18 A | 2024-01-24 A | 687, 695 | 100% | 2023-12-18 | 2024-01-24 | 28d |  |  | start no earlier than 2023-12-11 |  | SI Test Data |  | SIT | 5.14 | Michael Inije | Systems Integration Testing (SIT) | SITAG |  | Complete | COMPLETE |  |  |  |  |
| 957 | 1.4.1.4.2.8.1.2 | Transmit Data Sets to PPs |  | 4d | 2024-01-26 A | 2024-01-31 A | 956FS+1d | 100% | 2024-01-26 | 2024-01-31 | 2d |  |  |  |  | SI Test Data |  | SIT | 5.14 | Michael Inije | Systems Integration Testing (SIT) | SITAG |  | Complete | COMPLETE |  |  |  |  |
| 958 | 1.4.1.4.2.8.1.3 | PP's Iterative load and data integrity check |  | 22d | 2024-02-01 A | 2024-03-01 A | 957 | 100% | 2024-02-01 | 2024-03-01 | 10d |  |  |  |  | PP |  | SIT | 5.14 | Michael Inije | Systems Integration Testing (SIT) | SITAG |  | Complete | COMPLETE |  |  |  |  |
| 959 | 1.4.1.4.2.8.1.4 | Cycle 1 - PP's confirmation that test data is ready for SIT Functional | milestone | 0d | 2024-03-01 A | 2024-03-01 A | 958 | 100% | 2024-03-01 | 2024-03-01 | 0d |  |  |  |  | SI Test Data |  | SIT | 5.18 | Michael Inije | Systems Integration Testing (SIT) | SITAG |  | Complete | COMPLETE | 2/8 - added as a T3 milestone. Awaiting approval at TMAG | T3-TE-0079 | T3 | MHHS-ART140 MHHS-ART169 |
| 960 | 1.4.1.4.2.8.2 | **Cycle 2 Test data (inc. Settlement Data) (SIT A)** |  | 57d | 2024-03-28 A | 2024-06-14 A |  | 100% | 2024-03-28 | 2024-06-14 | 47d |  |  |  | -0 | N/A | N/A | SIT | 6.0 | N/A | Systems Integration Testing (SIT) | SITAG |  |  |  |  |  |  |  |
| 961 | 1.4.1.4.2.8.2.1 | Prepare, Generate and Allocate Test Data |  | 31d | 2024-03-28 A | 2024-05-09 A | 959FS+18d | 100% | 2024-03-28 | 2024-05-09 | 31d |  |  |  |  | SI Test Data |  | SIT | 5.14 | Michael Inije | Systems Integration Testing (SIT) | SITAG |  | Complete | COMPLETE |  |  |  |  |
| 962 | 1.4.1.4.2.8.2.2 | Transmit Data Sets to PPs |  | 3d | 2024-05-10 A | 2024-05-14 A | 961 | 100% | 2024-05-10 | 2024-05-14 | 3d |  |  |  |  | SI Test Data |  | SIT | 5.14 | Michael Inije | Systems Integration Testing (SIT) | SITAG |  | Complete | COMPLETE |  |  |  |  |
| 963 | 1.4.1.4.2.8.2.3 | PP's Iterative load and data integrity check |  | 13d | 2024-05-15 A | 2024-05-31 A | 962 | 100% | 2024-05-15 | 2024-05-31 | 13d |  |  |  |  | PP |  | SIT | 5.14 | Michael Inije | Systems Integration Testing (SIT) | SITAG |  | Complete | COMPLETE |  |  |  |  |
| 964 | 1.4.1.4.2.8.2.4 | Cycle 2 - PP's confirmation that test data is ready for SIT Functional | milestone | 0d | 2024-06-14 A | 2024-06-14 A | 963FS+10d | 100% | 2024-06-14 | 2024-06-14 | 0d |  |  |  |  | SI Test Data |  | SIT | 5.27 | Michael Inije | Systems Integration Testing (SIT) | SITAG |  | Complete | COMPLETE | 2/8 - added as a T3 milestone. Awaiting approval at TMAG | T3-TE-0080 | T3 | MHHS-ART140 MHHS-ART169 |

| ID | WBS | Task | Duration | Start | Finish | Predecessors | Complete | Baseline start | Baseline finish | Baseline duration | Baseline 1 start | Baseline 1 finish | Constraint | Baseline cost | Responsible | Involved | Text9 | Update Version | MHHS Resource Name | MHHS Programme Phase | Text29 | Sched Status | RAG | Milestone ID | Tier |
| --- | --- | --- | --- | --- | --- | --- | --- | --- | --- | --- | --- | --- | --- | --- | --- | --- | --- | --- | --- | --- | --- | --- | --- | --- | --- |
| 965 | 1.4.1.4.2.8.3 | **Cycle 3 Test data (SIT A) (2)** | 71d? | 2024-07-15 A | 2024-10-21 A |  | 100% | 2024-07-15 | 2024-10-21 | 41d |  |  |  | -0 | N/A | N/A | SIT | 5.4 | N/A | Systems Integration Testing (SIT) | SITAG |  |  |  |  |
| 966 | 1.4.1.4.2.8.3.1 | Cycle 3 data requirments analysis - check Cycle 2 data for gaps Check blocked test cases | 10d? | 2024-07-15 A | 2024-07-26 A |  | 100% | 2024-07-15 | 2024-07-26 | 0d |  |  | finish no earlier than 2024-07-26 |  | SI Test Data |  | SIT | 6.0 | Michael Inije |  | SITAG | Complete | COMPLETE |  |  |
| 967 | 1.4.1.4.2.8.3.2 | Provide DCC with MPANS for deletion secure file with password | 1d? | 2024-08-12 A | 2024-08-12 A |  | 100% | 2024-08-12 | 2024-08-12 | 0d |  |  |  |  | SI Test Data |  | SIT | 6.0 | Michael Inije |  | SITAG | Complete | COMPLETE |  |  |
| 968 | 1.4.1.4.2.8.3.3 | Receive MPANS from DCC to exclude | 1d? | 2024-08-09 A | 2024-08-09 A |  | 100% | 2024-08-09 | 2024-08-09 | 0d |  |  |  |  | SI Test Data |  | SIT | 6.0 | Michael Inije |  | SITAG | Complete | COMPLETE |  |  |
| 969 | 1.4.1.4.2.8.3.4 | Exclude MPANS from allocation | 1d | 2024-08-16 A | 2024-08-16 A |  | 100% | 2024-08-16 | 2024-08-16 | 0d |  |  |  |  | SI Test Data |  | SIT | 6.0 | Michael Inije |  | SITAG | Complete | COMPLETE |  |  |
| 970 | 1.4.1.4.2.8.3.5 | Allocate Cycle 3 MPANS | 16d? | 2024-08-06 A | 2024-08-27 A |  | 100% | 2024-08-06 | 2024-08-27 | 0d |  |  |  |  | SI Test Data |  | SIT | 6.0 | Michael Inije |  | SITAG | Complete | COMPLETE |  |  |
| 971 | 1.4.1.4.2.8.3.6 | Generate Cycle 3 Data | 2d? | 2024-08-27 A | 2024-08-28 A |  | 100% | 2024-08-27 | 2024-08-28 | 0d |  |  |  |  | SI Test Data |  | SIT | 6.0 | Michael Inije |  | SITAG | Complete | COMPLETE |  |  |
| 972 | 1.4.1.4.2.8.3.7 | Check data prior to sending to DCC | 5d? | 2024-08-22 A | 2024-08-28 A |  | 100% | 2024-08-22 | 2024-08-28 | 0d |  |  |  |  | SI Test Data |  | SIT | 6.0 | Michael Inije |  | SITAG | Complete | COMPLETE |  |  |
| 973 | 1.4.1.4.2.8.3.8 | Share Cycle 3 MPAN data with DCC | 1d? | 2024-08-29 A | 2024-08-29 A |  | 100% | 2024-08-29 | 2024-08-29 | 0d |  |  |  |  | SI Test Data |  | SIT | 6.0 | Michael Inije |  | SITAG | Complete | COMPLETE |  |  |
| 974 | 1.4.1.4.2.8.3.9 | DCC - load data and create registration Id's for Cycle 3 data | 13d? | 2024-08-27 A | 2024-09-12 A |  | 100% | 2024-08-27 | 2024-09-12 | 0d |  |  |  |  | DCC |  | SIT | 6.0 | Michael Inije |  | SITAG | Complete | COMPLETE |  |  |
| 975 | 1.4.1.4.2.8.3.10 | Add registration ID's to Cycle 3 Data | 2d? | 2024-09-12 A | 2024-09-13 A |  | 100% | 2024-09-12 | 2024-09-13 | 0d |  |  |  |  | SI Test Data |  | SIT | 6.0 | Michael Inije |  | SITAG | Complete | COMPLETE |  |  |
| 976 | 1.4.1.4.2.8.3.11 | Share subset of data with St Cls for data load | 2d? | 2024-09-12 A | 2024-09-13 A |  | 100% | 2024-09-12 | 2024-09-13 | 0d |  |  |  |  | SI Test Data |  | SIT | 6.0 | Michael Inije |  | SITAG | Complete | COMPLETE |  |  |
| 977 | 1.4.1.4.2.8.3.12 | St Clements to run test with Subset of data - MPRS business process checks including Import/Export MPANS | 5d? | 2024-09-16 A | 2024-09-20 A |  | 100% | 2024-09-16 | 2024-09-20 | 0d |  |  |  |  | SCS |  | SIT | 6.0 | Michael Inije |  | SITAG | Complete | COMPLETE |  |  |
| 978 | 1.4.1.4.2.8.3.13 | Send Cycle 3 data to partcipants for early sight of data | 3d? | 2024-09-25 A | 2024-09-27 A |  | 100% | 2024-09-25 | 2024-09-27 | 0d |  |  |  |  | SI Test Data |  | SIT | 6.0 | Michael Inije |  | SITAG | Complete | COMPLETE |  |  |
| 979 | 1.4.1.4.2.8.3.14 | St Clements MPRS data load bulk files for Cycle 3 | 15d? | 2024-09-23 A | 2024-10-11 A |  | 100% | 2024-09-23 | 2024-10-11 | 0d |  |  |  |  | SCS |  | SIT | 6.0 | Michael Inije |  | SITAG | Complete | COMPLETE |  |  |
| 980 | 1.4.1.4.2.8.3.15 | New MPAN creation and load through DCC and St Clements | 1d? | 2024-10-11 A | 2024-10-11 A |  | 100% | 2024-10-11 | 2024-10-11 | 0d |  |  | start no earlier than 2024-10-11 |  | SI Test Data |  | SIT | 6.0 | Michael Inije |  | SITAG | Complete | COMPLETE |  |  |
| 981 | 1.4.1.4.2.8.3.16 | Share files with PP's and central parties | 1d | 2024-10-11 A | 2024-10-11 A |  | 100% | 2024-10-11 | 2024-10-11 | 0d |  |  | start no earlier than 2024-10-11 |  | SI Test Data |  | SIT | 6.0 | Michael Inije |  | SITAG | Complete | COMPLETE |  |  |
| 982 | 1.4.1.4.2.8.3.17 | Avanade to load data | 6d | 2024-10-14 A | 2024-10-21 A |  | 100% | 2024-10-14 | 2024-10-21 | 0d |  |  | start no earlier than 2024-10-14 |  | DIP Provider |  | SIT | 6.0 | Michael Inije |  | SITAG | Complete | COMPLETE |  |  |
| 983 | 1.4.1.4.2.8.3.18 | Helix to load data | 6d | 2024-10-14 A | 2024-10-21 A |  | 100% | 2024-10-14 | 2024-10-21 | 0d |  |  | start no earlier than 2024-10-14 |  | Helix |  | SIT | 6.0 | Michael Inije |  | SITAG | Complete | COMPLETE |  |  |
| 984 | 1.4.1.4.2.8.3.19 | PP's and central parties to load all Cycle 3 data | 6d | 2024-10-14 A | 2024-10-21 A |  | 100% | 2024-10-14 | 2024-10-21 | 0d |  |  | start no earlier than 2024-10-14 |  | PPs |  | SIT | 6.0 | Michael Inije |  | SITAG | Complete | COMPLETE |  |  |
| 985 | 1.4.1.4.2.8.3.20 | All parties to finalise data load | 1d? | 2024-10-21 A | 2024-10-21 A |  | 100% | 2024-10-21 | 2024-10-21 | 0d |  |  | start no earlier than 2024-10-21 |  | SI Data |  | SIT | 6.0 | Michael Inije |  | SITAG | Complete | COMPLETE | T3-TE-0081 | T3 |
| 986 | 1.4.1.4.2.9 | **SIT Functional Test Readiness Report** | 45d | 2024-01-01 A | 2024-03-01 A |  | 100% | 2024-01-01 | 2024-03-01 | 44d | 2024-01-01 | 2024-02-23 |  | -0 | N/A | N/A | SIT | 5.0 | N/A | Systems Integration Testing (SIT) | SITAG |  |  |  |  |
| 987 | 1.4.1.4.2.9.1 | **PP SIT Functional Test Readiness Report** | 44d | 2024-01-01 A | 2024-02-29 A |  | 100% | 2024-01-01 | 2024-02-29 | 44d | 2024-01-01 | 2024-02-09 |  | -0 | N/A | N/A | SIT | 5.0 | N/A | Systems Integration Testing (SIT) | SITAG |  |  |  |  |
| 988 | 1.4.1.4.2.9.1.1 | Develop draft Test Readiness Report and submit to Programme for assurance | 21d | 2024-01-01 A | 2024-01-29 A |  | 100% | 2024-01-01 | 2024-01-29 | 20d | 2024-01-01 | 2024-01-29 | start no earlier than 2024-01-01 |  | PP | SI Test | SIT | 5.0 |  | Systems Integration Testing (SIT) | SITAG | Complete | COMPLETE |  |  |
| 989 | 1.4.1.4.2.9.1.2 | Placing Reliance Stage 2 Review | 34d | 2024-01-15 A | 2024-02-29 A | 988SS+10d | 100% | 2024-01-15 | 2024-02-29 | 34d |  |  |  |  | SI Test | PP | SIT | 5.12 |  | Systems Integration Testing (SIT) | SITAG | Complete | COMPLETE |  |  |
| 990 | 1.4.1.4.2.9.1.3 | Finalise Test Readiness Report and submit to Programme for assurance | 9d | 2024-01-30 A | 2024-02-09 A | 988 | 100% | 2024-01-30 | 2024-02-09 | 10d | 2024-01-29 | 2024-02-09 |  |  | PP | SI Test | SIT | 5.0 |  | Systems Integration Testing (SIT) | SITAG | Complete | COMPLETE |  |  |

| ID | WBS | Task | Type | Duration | Start | Finish | Predecessors | Complete | Baseline start | Baseline finish | Baseline duration | Baseline 1 start | Baseline 1 finish | Constraint | Baseline cost | Responsible | Involved | Text9 | Update Version | MHHS Resource Name | MHHS Programme Phase | Text29 | Sched Status | RAG | Milestone ID | Tier | Artefact ID | Task Status |
| --- | --- | --- | --- | --- | --- | --- | --- | --- | --- | --- | --- | --- | --- | --- | --- | --- | --- | --- | --- | --- | --- | --- | --- | --- | --- | --- | --- | --- |
| 991 | 1.4.1.4.2.9.2 | **SI SIT Functional Test Readiness Report** |  | 40d | 2024-01-01 A | 2024-02-23 A |  | 100% | 2024-01-01 | 2024-02-23 | 40d | 2024-01-01 | 2024-02-23 |  |  | N/A | N/A | SIT | 5.0 | N/A | Systems Integration Testing (SIT) | SITAG |  |  |  |  |  |  |
| 992 | 1.4.1.4.2.9.2.1 | Assure Test Participants' Test Readiness Reports |  | 35d | 2024-01-01 A | 2024-02-16 A | 988SS, 990FF+5d | 100% | 2024-01-01 | 2024-02-16 | 35d | 2024-01-01 | 2024-02-16 |  |  | SI Test | PP,IPA | SIT | 5.0 |  | Systems Integration Testing (SIT) | SITAG | Complete | COMPLETE |  |  |  |  |
| 993 | 1.4.1.4.2.9.2.2 | Develop Overarching SIT Functional Test Readiness Report |  | 20d | 2024-01-22 A | 2024-02-16 A | 992FF | 100% | 2024-01-22 | 2024-02-16 | 20d | 2024-01-22 | 2024-02-16 |  |  | SI Test |  | SIT | 5.0 |  | Systems Integration Testing (SIT) | SITAG | Complete | COMPLETE |  |  |  |  |
| 994 | 1.4.1.4.2.9.2.3 | Artefact review (via TMAG) and updates |  | 5d | 2024-02-19 A | 2024-02-23 A | 993 | 100% | 2024-02-19 | 2024-02-23 | 5d | 2024-02-19 | 2024-02-23 |  |  | SI Test | PP,IPA | SIT | 5.0 |  | Systems Integration Testing (SIT) | SITAG | Complete | COMPLETE |  |  |  |  |
| 995 | 1.4.1.4.2.9.3 | SIT Functional Testing Preparation Complete | milestone | 0d | 2024-03-01 A | 2024-03-01 A | 994FF+5d, 874, 378, 989, 882, 889, 959 | 100% | 2024-03-01 | 2024-03-01 | 0d | 2024-03-01 | 2024-03-01 |  |  | SI Test | PP,IPA | SIT | 5.0 |  | Systems Integration Testing (SIT) | SITAG | Complete | COMPLETE | T2-TE-0550 | T2 |  |  |
| 996 | 1.4.1.4.3 | **SIT Migration Testing Preparation** |  | 595d? | 2022-10-31 A | 2025-02-07 A |  | 100% | 2022-10-31 | 2024-10-04 | 420d | 2022-11-16 | 2024-06-03 |  | -0 | N/A | N/A | SIT | 5.21 | N/A | Systems Integration Testing (SIT) | SITAG |  |  |  |  |  |  |
| 997 | 1.4.1.4.3.1 | **Test Approach & Plan** |  | 75d | 2023-09-07 A | 2023-12-20 A |  | 100% | 2023-09-07 | 2023-12-20 | 75d | 2023-09-07 | 2023-12-20 |  | -0 | N/A | N/A | SIT | 5.0 |  | Systems Integration Testing (SIT) | SITAG |  |  |  |  |  |  |
| 998 | 1.4.1.4.3.1.1 | Develop document with SITWG |  | 32d | 2023-09-07 A | 2023-10-20 A | 2819 | 100% | 2023-09-07 | 2023-10-20 | 25d | 2023-09-07 | 2023-10-11 | finish no earlier than 2023-10-11 |  | SI Test |  | SIT | 5.0 |  | Systems Integration Testing (SIT) | SITAG | Complete | COMPLETE |  |  |  |  |
| 999 | 1.4.1.4.3.1.2 | Draft document review with Code Bodies |  | 8d | 2023-10-23 A | 2023-11-01 A | 998 | 100% | 2023-10-23 | 2023-11-01 | 10d | 2023-10-12 | 2023-10-25 |  |  | SI Test | Code Bodies | SIT | 5.0 |  | Systems Integration Testing (SIT) | SITAG | Complete | COMPLETE |  |  |  |  |
| 1000 | 1.4.1.4.3.1.3 | Industry Consultation |  | 10d | 2023-11-02 A | 2023-11-15 A | 999 | 100% | 2023-11-02 | 2023-11-15 | 10d |  |  |  |  | PP |  | SIT | 5.1 |  | Systems Integration Testing (SIT) | SITAG | Complete | COMPLETE |  |  |  |  |
| 1001 | 1.4.1.4.3.1.4 | Artefact review (via TMAG) and updates |  | 25d | 2023-11-16 A | 2023-12-20 A | 1000 | 100% | 2023-11-16 | 2023-12-20 | 30d | 2023-10-26 | 2023-12-20 |  |  | SI Test | PP,IPA,Code Bodies | SIT | 5.0 |  | Systems Integration Testing (SIT) | SITAG | Complete | COMPLETE |  |  |  |  |
| 1002 | 1.4.1.4.3.1.5 | SIT Migration Testing Test Approach & Plan approved | milestone | 0d | 2023-12-20 A | 2023-12-20 A | 1001 | 100% | 2023-12-20 | 2023-12-20 | 1d | 2023-12-20 | 2023-12-20 | finish no earlier than 2023-12-20 |  | SI Test | PP | SIT | 5.14 |  | Systems Integration Testing (SIT) | SITAG | Complete | COMPLETE | T3-TE-0018 | T3 | MHHS-ART073 |  |
| 1003 | 1.4.1.4.3.2 | **Test Data Approach & Plan** |  | 35d | 2023-11-02 A | 2023-12-20 A |  | 100% | 2023-11-02 | 2023-12-20 | 35d | 2023-10-26 | 2023-12-20 |  | -0 | N/A | N/A | SIT | 5.0 | N/A | Systems Integration Testing (SIT) | SITAG |  |  |  |  |  |  |
| 1004 | 1.4.1.4.3.2.1 | Industry Consultation |  | 10d | 2023-11-02 A | 2023-11-15 A | 1000SS | 100% | 2023-11-02 | 2023-11-15 | 10d |  |  |  |  | PP |  | SIT | 5.1 | PP | Systems Integration Testing (SIT) | SITAG | Complete | COMPLETE |  |  |  |  |
| 1005 | 1.4.1.4.3.2.2 | Artefact review (via TMAG) and updates |  | 25d | 2023-11-16 A | 2023-12-20 A | 1004 | 100% | 2023-11-16 | 2023-12-20 | 30d | 2023-10-26 | 2023-12-20 |  |  | SI Test Data |  | SIT | 5.0 | Michael Inije | Systems Integration Testing (SIT) | SITAG | Complete | COMPLETE |  |  |  |  |
| 1006 | 1.4.1.4.3.2.3 | SIT Migration Test Data Test Approach & Plan approved | milestone | 0d | 2023-12-20 A | 2023-12-20 A | 1005 | 100% | 2023-12-20 | 2023-12-20 | 0d | 2023-12-20 | 2023-12-20 |  |  | SI Test Data | PP,IPA | SIT | 5.14 | Michael Inije | Systems Integration Testing (SIT) | SITAG | Complete | COMPLETE |  |  |  |  |
| 1007 | 1.4.1.4.3.3 | **Test scenarios & Test Cases** |  | 297d? | 2023-12-21 A | 2025-02-07 A |  | 100% | 2023-12-21 | 2024-10-04 | 65d | 2023-07-24 | 2024-01-17 |  | -0 | N/A | N/A | SIT | 5.16 | N/A | Systems Integration Testing (SIT) | SITAG |  |  |  |  |  |  |
| 1008 | 1.4.1.4.3.3.1 | **Theme 1** |  | 65d | 2023-12-21 A | 2024-03-20 A |  | 100% | 2023-12-21 | 2024-03-20 | 65d |  |  |  | -0 | N/A | N/A | SIT | 5.16 | N/A | Systems Integration Testing (SIT) | SITAG |  |  |  |  |  | -448.67 |
| 1009 | 1.4.1.4.3.3.1.1 | Develop Test Scenarios & Test Cases |  | 25d | 2023-12-21 A | 2024-01-24 A | 1002 | 100% | 2023-12-21 | 2024-01-24 | 25d |  |  |  |  | SI Test | SI Test, PP | SIT | 5.16 |  |  | SITAG | Complete | COMPLETE |  |  |  |  |
| 1010 | 1.4.1.4.3.3.1.2 | Industry Review Workshop |  | 1d | 2024-01-25 A | 2024-01-25 A | 1009 | 100% | 2024-01-25 | 2024-01-25 | 1d |  |  |  |  | SI Test, PP | SI Test, PP | SIT | 5.16 |  |  | SITAG | Complete | COMPLETE |  |  |  |  |
| 1011 | 1.4.1.4.3.3.1.3 | Industry Consultation Review |  | 6d | 2024-02-05 A | 2024-02-12 A | 1010FS+6d | 100% | 2024-02-05 | 2024-02-12 | 6d |  |  |  |  | SI Test, PP | SI Test, PP | SIT | 5.16 |  |  | SITAG | Complete | COMPLETE |  |  |  |  |
| 1012 | 1.4.1.4.3.3.1.4 | Review with SIT Working Group |  | 5d | 2024-02-29 A | 2024-03-06 A | 1011FS+12d | 100% | 2024-02-29 | 2024-03-06 | 5d |  |  |  |  | SI Test, PP | SI Test, PP | SIT | 5.19 |  |  | SITAG | Complete | COMPLETE |  |  |  |  |
| 1013 | 1.4.1.4.3.3.1.5 | SIT Migration Test scenarios & Test Cases Approved - Theme 1 | milestone | 0d | 2024-03-20 A | 2024-03-20 A | 1012FS+10d | 100% | 2024-03-20 | 2024-03-20 | 0d |  |  |  |  | SI Test | SI Test, PP | SIT | 5.21 |  | Systems Integration Testing (SIT) | SITAG | Complete | COMPLETE | T3-TE-0110 | T3 |  |  |
| 1014 | 1.4.1.4.3.3.2 | **Theme 2** |  | 85d | 2023-12-21 A | 2024-04-17 A |  | 100% | 2023-12-21 | 2024-04-17 | 85d |  |  |  | -0 | N/A | N/A | SIT | 5.16 | N/A | Systems Integration Testing (SIT) | SITAG |  |  |  |  |  | -448.67 |
| 1015 | 1.4.1.4.3.3.2.1 | Develop Test Scenarios & Test Cases |  | 40d | 2023-12-21 A | 2024-02-14 A | 1002 | 100% | 2023-12-21 | 2024-02-14 | 40d |  |  |  |  | SI Test | SI Test, PP | SIT | 5.16 |  |  | SITAG | Complete | COMPLETE |  |  |  |  |
| 1016 | 1.4.1.4.3.3.2.2 | Industry Review Workshop |  | 1d | 2024-02-15 A | 2024-02-15 A | 1015 | 100% | 2024-02-15 | 2024-02-15 | 1d |  |  |  |  | SI Test, PP | SI Test, PP | SIT | 5.16 |  |  | SITAG | Complete | COMPLETE |  |  |  |  |
| 1017 | 1.4.1.4.3.3.2.3 | Industry Consultation Review |  | 6d | 2024-02-26 A | 2024-03-04 A | 1016FS+6d | 100% | 2024-02-26 | 2024-03-04 | 6d |  |  |  |  | SI Test, PP | SI Test, PP | SIT | 5.19 |  |  | SITAG | Complete | COMPLETE |  |  |  |  |
| 1018 | 1.4.1.4.3.3.2.4 | Review with SIT Working Group |  | 5d | 2024-03-28 A | 2024-04-03 A | 1017FS+17d | 100% | 2024-03-28 | 2024-04-03 | 5d |  |  |  |  | SI Test, PP | SI Test, PP | SIT | 5.16 |  |  | SITAG | Complete | COMPLETE |  |  |  |  |
| 1019 | 1.4.1.4.3.3.2.5 | SIT Migration Test scenarios & Test Cases Approved - Theme 2 | milestone | 0d | 2024-04-17 A | 2024-04-17 A | 1018FS+10d | 100% | 2024-04-17 | 2024-04-17 | 0d |  |  |  |  | SI Test | SI Test, PP | SIT | 5.22 |  | Systems Integration Testing (SIT) | SITAG | Complete | COMPLETE | T3-TE-0111 | T3 |  |  |

| ID | WBS | Task | Type | Duration | Start | Finish | Predecessors | Complete | Baseline start | Baseline finish | Baseline duration | Constraint | Baseline cost | Responsible | Involved | Text9 | Task Status | Update Version | MHHS Resource Name | MHHS Programme Phase | Text29 | Sched Status | RAG | Milestone ID | Tier |
| --- | --- | --- | --- | --- | --- | --- | --- | --- | --- | --- | --- | --- | --- | --- | --- | --- | --- | --- | --- | --- | --- | --- | --- | --- | --- |
| 1020 | 1.4.1.4.3.3.3 | **Theme 3** |  | 85d | 2023-12-21 A | 2024-04-17 A |  | 100% | 2023-12-21 | 2024-04-17 | 85d |  | -0 | N/A | N/A | SIT | -448.67 | 5.16 | N/A | Systems Integration Testing (SIT) | SITAG |  |  |  |  |
| 1021 | 1.4.1.4.3.3.3.1 | Develop Test Scenarios & Test Cases |  | 55d | 2023-12-21 A | 2024-03-06 A | 1002 | 100% | 2023-12-21 | 2024-03-06 | 55d |  |  | SI Test | SI Test, PP | SIT |  | 5.19 |  |  | SITAG | Complete | COMPLETE |  |  |
| 1022 | 1.4.1.4.3.3.3.2 | Industry Review Workshop |  | 1d | 2024-03-07 A | 2024-03-07 A | 1021 | 100% | 2024-03-07 | 2024-03-07 | 1d |  |  | SI Test, PP | SI Test, PP | SIT |  | 5.16 |  |  | SITAG | Complete | COMPLETE |  |  |
| 1023 | 1.4.1.4.3.3.3.3 | Industry Consultation Review |  | 6d | 2024-03-13 A | 2024-03-20 A | 1022FS+3d | 100% | 2024-03-13 | 2024-03-20 | 6d |  |  | SI Test, PP | SI Test, PP | SIT |  | 5.16 |  |  | SITAG | Complete | COMPLETE |  |  |
| 1024 | 1.4.1.4.3.3.3.4 | Review with SIT Working Group |  | 5d | 2024-03-28 A | 2024-04-03 A | 1023FS+5d | 100% | 2024-03-28 | 2024-04-03 | 5d |  |  | SI Test, PP | SI Test, PP | SIT |  | 5.16 |  |  | SITAG | Complete | COMPLETE |  |  |
| 1025 | 1.4.1.4.3.3.3.5 | SIT Migration Test scenarios & Test Cases Approved - Theme 3 | milestone | 0d | 2024-04-17 A | 2024-04-17 A | 1024FS+10d | 100% | 2024-04-17 | 2024-04-17 | 0d |  |  | SI Test | SI Test, PP | SIT |  | 5.22 |  | Systems Integration Testing (SIT) | SITAG | Complete | COMPLETE | T3-TE-0112 | T3 |
| 1026 | 1.4.1.4.3.3.4 | **RTTM Development** |  | 17d | 2024-08-29 A | 2024-09-20 A |  | 100% | 2024-08-29 | 2024-10-04 | 0d |  |  | SI Test |  | SIT | -693.67 | 6.0 | Ankur Pande |  | SITAG |  |  |  |  |
| 1027 | 1.4.1.4.3.3.4.1 | Develop Manual SIT Migration RTTM |  | 17d | 2024-08-29 A | 2024-09-20 A |  | 100% | 2024-08-29 | 2024-09-20 | 0d | start no earlier than 2024-08-29 |  | SI Test |  | SIT |  | 6.0 | Ankur Pande |  | SITAG | Complete | COMPLETE |  |  |
| 1028 | 1.4.1.4.3.3.4.2 | Manual SIT Migration RTTM Complete | milestone | 0d | 2024-09-20 A | 2024-09-20 A | 1027 | 100% | 2024-09-20 | 2024-09-20 | 0d |  |  | SI Test |  | SIT |  | 6.0 | Ankur Pande |  | SITAG | Complete | COMPLETE |  |  |
| 1029 | 1.4.1.4.3.3.5 | **Gap analysis** |  | 107d? | 2024-09-12 A | 2025-02-07 A |  | 100% | 2024-09-12 | 2024-10-04 | 0d |  |  | SI Test |  | SIT | -693.67 | 6.0 | Ankur Pande |  | SITAG |  |  |  |  |
| 1030 | 1.4.1.4.3.3.5.1 | Identify gaps in test case coverage following RTTM review. |  | 12d | 2024-09-12 A | 2024-09-27 A | 1027SS+10d | 100% | 2024-09-12 | 2024-09-27 | 0d |  |  | SI Test |  | SIT |  | 6.0 | Ankur Pande |  | SITAG | Complete | COMPLETE |  |  |
| 1031 | 1.4.1.4.3.3.5.2 | Address gaps in test case coverage following RTTM review. |  | 17d | 2024-09-19 A | 2024-10-11 A | 1030SS+5d | 100% | 2024-09-19 | 2024-10-04 | 0d |  |  | SI Test |  | SIT |  | 6.0 | Ankur Pande |  | SITAG | Complete | COMPLETE |  |  |
| 1032 | 1.4.1.4.3.3.5.3 | Gap analysis complete | milestone | 0d? | 2024-10-11 A | 2024-10-11 A | 1031 | 100% | 2024-10-04 | 2024-10-04 | 0d |  |  | SI Test |  | SIT |  | 6.0 | Ankur Pande |  | SITAG | Complete | COMPLETE |  |  |
| 1033 | 1.4.1.4.3.3.5.4 | Test Script updates identified |  | 1d? | 2024-10-14 A | 2024-10-14 A | 1032 | 100% | 2024-10-14 | 2024-10-14 | 0d |  |  | SI Test |  | SIT |  | 6.11 | Ankur Pande |  | SITAG | Complete | COMPLETE |  |  |
| 1034 | 1.4.1.4.3.3.5.5 | Test Scripts updates |  | 16d? | 2024-10-14 A | 2024-11-04 A | 1033FS-1d | 100% | 2024-10-14 | 2024-11-04 | 0d |  |  | SI Test |  | SIT |  | 6.11 | Ankur Pande |  | SITAG | Complete | COMPLETE |  |  |
| 1035 | 1.4.1.4.3.3.5.6 | RTTM Updated |  | 1d? | 2024-10-29 A | 2024-10-29 A | 1034FS-5d | 100% | 2024-10-29 | 2024-10-29 | 0d |  |  | SI Test |  | SIT |  | 6.11 | Ankur Pande |  | SITAG | Complete | COMPLETE |  |  |
| 1036 | 1.4.1.4.3.3.5.7 | Removal of de-scoped TCs from the RTTMs |  | 2d | 2024-10-31 A | 2024-11-01 A | 1034FS-3d | 100% | 2024-10-31 | 2024-11-01 | 0d |  |  | SI Test |  | SIT |  | 6.11 | Ankur Pande |  | SITAG | Complete | COMPLETE |  |  |
| 1037 | 1.4.1.4.3.3.5.8 | Update and stabilisation of all TC ADO IDs |  | 2d | 2024-10-31 A | 2024-11-01 A | 1034FS-3d | 100% | 2024-10-31 | 2024-11-01 | 0d |  |  | SI Test |  | SIT |  | 6.11 | Ankur Pande |  | SITAG | Complete | COMPLETE |  |  |
| 1038 | 1.4.1.4.3.3.5.9 | Addition and integration of Role tags to reqs in the Role RTTMs |  | 3d | 2024-10-30 A | 2024-11-01 A | 1034FS-4d | 100% | 2024-10-30 | 2024-11-01 | 0d |  |  | SI Test |  | SIT |  | 6.11 | Ankur Pande |  | SITAG | Complete | COMPLETE |  |  |
| 1039 | 1.4.1.4.3.3.5.10 | Update of the RTTM All sheet (porting of the individual RTTMs) |  | 2d | 2024-10-31 A | 2024-11-01 A | 1034FS-3d | 100% | 2024-10-31 | 2024-11-01 | 0d |  |  | SI Test |  | SIT |  | 6.11 | Ankur Pande |  | SITAG | Complete | COMPLETE |  |  |
| 1040 | 1.4.1.4.3.3.5.11 | ADO IDs corrected |  | 1d? | 2024-11-04 A | 2024-11-04 A | 1039 | 100% | 2024-11-04 | 2024-11-04 | 0d | start no earlier than 2024-10-16 |  | SI Test |  | SIT |  | 6.11 | Ankur Pande |  | SITAG | Complete | COMPLETE |  |  |
| 1041 | 1.4.1.4.3.3.5.12 | Migration RTTM ready for import into ADO | milestone | 0d | 2024-11-04 A | 2024-11-04 A | 1040 | 100% | 2024-11-04 | 2024-11-04 | 0d |  |  | SI Test |  | SIT |  | 6.11 | Ankur Pande |  | SITAG | Complete | COMPLETE |  |  |
| 1042 | 1.4.1.4.3.3.5.13 | Issue Static RTTM to Code Bodies |  | 1d? | 2024-11-05 A | 2024-11-05 A | 1041 | 100% | 2024-11-05 | 2024-11-05 | 0d |  |  | SI Test |  | SIT |  | 6.11 | Ankur Pande |  | SITAG | Complete | COMPLETE |  |  |
| 1043 | 1.4.1.4.3.3.5.14 | Implement Code Bodies feedback on RTTM |  | 6d | 2024-11-06 A | 2024-11-13 A | 1042 | 100% | 2024-11-06 | 2024-11-13 | 0d |  |  | SI Test |  | SIT |  | 6.12 | Ankur Pande |  | SITAG | Complete | COMPLETE |  |  |
| 1044 | 1.4.1.4.3.3.5.15 | Code Body Acceptance of RTTM | milestone | 0d | 2024-11-13 A | 2024-11-13 A | 1042, 1043 | 100% | 2024-11-06 | 2024-11-13 | 0d |  |  | SI Test |  | SIT |  | 6.11 | Ankur Pande |  | SITAG | Complete | COMPLETE |  |  |

| ID | WBS | Task | Type | Duration | Start | Finish | Predecessors | Complete | Actual start | Baseline start | Baseline finish | Baseline duration | Constraint | Responsible | Text9 | Task Status | Update Version | MHHS Resource Name | Text29 | Sched Status | RAG | Milestone ID | Tier |
| --- | --- | --- | --- | --- | --- | --- | --- | --- | --- | --- | --- | --- | --- | --- | --- | --- | --- | --- | --- | --- | --- | --- | --- |
| 1045 | 1.4.1.4.3.3.5.16 | **ADO Clean-up** |  | 17d? | 2024-10-24 | 2024-11-15 A |  | 100% | 2024-10-25 | 2024-10-24 | 2024-11-15 | 0d |  | SI Test | SIT | -727.67 | 6.11 | Heath Thomas | SITAG |  |  |  |  |
| 1046 | 1.4.1.4.3.3.5.16.1 | Theme alignment |  | 1d? | 2024-10-28 A | 2024-10-28 A |  | 100% |  | 2024-10-28 | 2024-10-28 | 0d | start no earlier than 2024-10-28 | SI Test | SIT |  | 6.11 | Heath Thomas | SITAG | Complete | COMPLETE |  |  |
| 1047 | 1.4.1.4.3.3.5.16.2 | Understand Additional suffix Fields in ADO as defined by Kevin |  | 1d? | 2024-10-25 A | 2024-10-25 A |  | 100% |  | 2024-10-25 | 2024-10-25 | 0d | finish no earlier than 2024-10-25 | SI Test | SIT |  | 6.11 | Heath Thomas | SITAG | Complete | COMPLETE |  |  |
| 1048 | 1.4.1.4.3.3.5.16.3 | Correct Missing Test Case References |  | 1d? | 2024-10-28 A | 2024-10-28 A |  | 100% |  | 2024-10-28 | 2024-10-28 | 0d | start no earlier than 2024-10-28 | SI Test | SIT |  | 6.11 | Heath Thomas | SITAG | Complete | COMPLETE |  |  |
| 1049 | 1.4.1.4.3.3.5.16.4 | Load Functional RTTMs into ADO |  | 1d? | 2024-10-28 A | 2024-10-28 A |  | 100% |  | 2024-10-28 | 2024-10-28 | 0d | start no earlier than 2024-10-28 | SI Test | SIT |  | 6.11 | Heath Thomas | SITAG | Complete | COMPLETE |  |  |
| 1050 | 1.4.1.4.3.3.5.16.5 | Load Migration RTTMs into ADO |  | 1d? | 2024-11-06 A | 2024-11-06 A |  | 100% |  | 2024-11-06 | 2024-11-06 | 0d | start no earlier than 2024-11-06 | SI Test | SIT |  | 6.11 | Heath Thomas | SITAG | Complete | COMPLETE |  |  |
| 1051 | 1.4.1.4.3.3.5.16.6 | Confirm Missing fields in ADO are resolved |  | 1d? | 2024-11-07 A | 2024-11-07 A |  | 100% |  | 2024-11-07 | 2024-11-07 | 0d | finish no earlier than 2024-11-07 | SI Test | SIT |  | 6.11 | Heath Thomas | SITAG | Complete | COMPLETE |  |  |
| 1052 | 1.4.1.4.3.3.5.16.7 | Reload Functional RTTM into ADO |  | 1d? | 2024-11-07 A | 2024-11-07 A |  | 100% |  | 2024-11-07 | 2024-11-07 | 0d | start no earlier than 2024-11-07 | SI Test | SIT |  | 6.11 | Heath Thomas | SITAG | Complete | COMPLETE |  |  |
| 1053 | 1.4.1.4.3.3.5.16.8 | **ADO Design Documentation** |  | 10d? | 2024-11-04 | 2024-11-15 A |  | 100% | 2024-11-15 | 2024-11-04 | 2024-11-15 | 0d |  | SI Test | SIT | -727.67 | 6.11 | Heath Thomas | SITAG |  |  |  |  |
| 1054 | 1.4.1.4.3.3.5.16.8.1 | Produce ADO high Level Design and Data Model |  | 1d? | 2024-11-15 A | 2024-11-15 A |  | 100% |  | 2024-11-15 | 2024-11-15 | 0d | finish no earlier than 2024-11-15 | SI Test | SIT |  | 6.11 | Heath Thomas | SITAG | Complete | COMPLETE |  |  |
| 1055 | 1.4.1.4.3.3.5.16.8.2 | Produce Report derivation document |  | 1d? | 2024-11-15 A | 2024-11-15 A |  | 100% |  | 2024-11-15 | 2024-11-15 | 0d | finish no earlier than 2024-11-15 | SI Test | SIT |  | 6.11 | Heath Thomas | SITAG | Complete | COMPLETE |  |  |
| 1056 | 1.4.1.4.3.3.5.17 | **Test Case Rationalisation (Functional + Migration)** |  | 67d | 2024-11-07 A | 2025-02-07 A |  | 100% |  | 2024-11-07 | 2024-12-20 | 0d |  | SI Test | SIT | -727.67 | 6.11 | Roger Robar | SITAG |  |  |  |  |
| 1057 | 1.4.1.4.3.3.5.17.1 | Internal preliminary rationalisation workshop 1 |  | 1d | 2024-11-07 A | 2024-11-07 A | 1042FS+1d | 100% |  | 2024-11-07 | 2024-11-07 | 0d |  | SI Test | SIT |  | 6.11 | Roger Robar | SITAG | Complete | COMPLETE |  |  |
| 1058 | 1.4.1.4.3.3.5.17.2 | Baseline RTTMs | milestone | 0d | 2024-11-13 A | 2024-11-13 A | 1044, 912 | 100% |  | 2024-11-13 | 2024-11-13 | 0d |  | SI Test | SIT |  | 6.11 | Roger Robar | SITAG | Complete | COMPLETE |  |  |
| 1059 | 1.4.1.4.3.3.5.17.3 | Baseline test cases | milestone | 0d | 2024-11-13 A | 2024-11-13 A | 1044 | 100% |  | 2024-11-13 | 2024-11-13 | 0d |  | SI Test | SIT |  | 6.11 | Roger Robar | SITAG | Complete | COMPLETE |  |  |
| 1060 | 1.4.1.4.3.3.5.17.4 | Produce requirements / test case analysis doc |  | 1d | 2024-11-14 A | 2024-11-14 A | 1059 | 100% |  | 2024-11-14 | 2024-11-14 | 0d |  | SI Test | SIT |  | 6.11 | Roger Robar | SITAG | Complete | COMPLETE |  |  |
| 1061 | 1.4.1.4.3.3.5.17.5 | Internal finalisation rationalisation workshop 2 |  | 13d | 2024-11-15 A | 2024-12-03 A | 1060 | 100% |  | 2024-11-15 | 2024-12-03 | 0d |  | SI Test | SIT |  | 6.17 | Roger Robar | SITAG | Complete | COMPLETE |  |  |
| 1062 | 1.4.1.4.3.3.5.17.6 | SRO walkthrough |  | 1d | 2024-12-04 A | 2024-12-04 A | 1061 | 100% |  | 2024-12-04 | 2024-12-04 | 0d |  | SI Test | SIT |  | 6.17 | Roger Robar | SITAG | Complete | COMPLETE |  |  |
| 1063 | 1.4.1.4.3.3.5.17.7 | Code Bodies walkthrough |  | 1d | 2024-12-04 A | 2024-12-04 A | 1061 | 100% |  | 2024-12-04 | 2024-12-04 | 0d |  | SI Test | SIT |  | 6.17 | Roger Robar | SITAG | Complete | COMPLETE |  |  |
| 1064 | 1.4.1.4.3.3.5.17.8 | Send invites to PPs for walkthrough |  | 1d | 2024-12-04 A | 2024-12-04 A | 1063FS-1d | 100% |  | 2024-12-04 | 2024-12-04 | 0d |  | SI Test | SIT |  | 6.17 | Roger Robar | SITAG | Complete | COMPLETE |  |  |
| 1065 | 1.4.1.4.3.3.5.17.9 | PP walkthrough |  | 1d | 2024-12-17 A | 2024-12-17 A | 1064FS+8d | 100% |  | 2024-12-17 | 2024-12-17 | 0d |  | SI Test | SIT |  | 6.17 | Roger Robar | SITAG | Complete | COMPLETE |  |  |
| 1066 | 1.4.1.4.3.3.5.17.10 | Update requirements / test case analysis doc |  | 29d | 2024-12-05 A | 2025-01-14 A | 1064 | 100% |  | 2024-12-05 | 2025-01-14 | 0d |  | SI Test | SIT |  | 6.17 | Roger Robar | SITAG | Complete | COMPLETE |  |  |
| 1067 | 1.4.1.4.3.3.5.17.11 | SITWG Paper Day | milestone | 0d | 2025-01-14 A | 2025-01-14 A | 1066 | 100% |  | 2025-01-14 | 2025-01-14 | 0d |  | SI Test | SIT |  | 6.17 | Roger Robar | SITAG | Complete | COMPLETE |  |  |
| 1068 | 1.4.1.4.3.3.5.17.12 | SITWG recommendation on requirements / test case analysis doc | milestone | 0d | 2025-01-21 A | 2025-01-21 A | 1067FS+5d | 100% |  | 2025-01-21 | 2025-01-21 | 0d |  | SI Test | SIT |  | 6.17 | Roger Robar | SITAG | Complete | COMPLETE |  |  |
| 1069 | 1.4.1.4.3.3.5.17.13 | Issue to SITAG / SITAG paper day | milestone | 0d | 2025-01-22 A | 2025-01-22 A | 1068FS+1d | 100% |  | 2025-01-22 | 2025-01-22 | 0d |  | SI Test | SIT |  | 6.17 | Roger Robar | SITAG | Complete | COMPLETE |  |  |
| 1070 | 1.4.1.4.3.3.5.17.14 | Prepare ADO update |  | 6d | 2025-01-22 A | 2025-01-29 A | 1068 | 100% |  | 2025-01-22 | 2025-01-29 | 0d |  | SI Test | SIT |  | 6.17 | Roger Robar | SITAG | Complete | COMPLETE |  |  |
| 1071 | 1.4.1.4.3.3.5.17.15 | Sign off by SITAG | milestone | 0d | 2025-01-29 A | 2025-01-29 A | 1069FS+5d | 100% |  | 2025-01-29 | 2025-01-29 | 0d |  | SI Test | SIT |  | 6.17 | Roger Robar | SITAG | Complete | COMPLETE |  |  |
| 1072 | 1.4.1.4.3.3.5.17.16 | Update ADO |  | 7d | 2025-01-30 A | 2025-02-07 A | 1071 | 100% |  | 2025-01-30 | 2025-02-07 | 0d |  | SI Test | SIT |  | 6.17 | Roger Robar | SITAG | Complete | COMPLETE |  |  |
| 1073 | 1.4.1.4.3.3.5.17.17 | Update all ADO reporting |  | 7d | 2025-01-30 A | 2025-02-07 A | 1071 | 100% |  | 2025-01-30 | 2025-02-07 | 0d |  | SI Test | SIT |  | 6.17 | Roger Robar | SITAG | Complete | COMPLETE |  |  |
| 1074 | 1.4.1.4.3.3.5.17.18 | Update test cases |  | 7d | 2025-01-30 A | 2025-02-07 A | 1071 | 100% |  | 2025-01-30 | 2025-02-07 | 0d |  | SI Test | SIT |  | 6.17 | Roger Robar | SITAG | Complete | COMPLETE |  |  |
| 1075 | 1.4.1.4.3.3.5.17.19 | Update RTTM |  | 7d | 2025-01-30 A | 2025-02-07 A | 1071 | 100% |  | 2025-01-30 | 2025-02-07 | 0d |  | SI Test | SIT |  | 6.17 | Roger Robar | SITAG | Complete | COMPLETE |  |  |
| 1076 | 1.4.1.4.3.3.5.17.20 | Update master test case spreadsheet |  | 7d | 2025-01-30 A | 2025-02-07 A | 1071 | 100% |  | 2025-01-30 | 2025-02-07 | 0d |  | SI Test | SIT |  | 6.17 | Roger Robar | SITAG | Complete | COMPLETE |  |  |
| 1077 | 1.4.1.4.3.3.5.17.21 | Test Case Rationalisation complete | milestone | 0d | 2025-02-07 A | 2025-02-07 A | 1072, 1073, 1071, 1074, 1075, 1076 | 100% |  | 2025-02-07 | 2025-02-07 | 0d |  | SI Test | SIT |  | 6.17 | Roger Robar | SITAG | Complete | COMPLETE | T3-TE-0141 | T3 |

| ID | WBS | Task | Type | Duration | Start | Finish | Predecessors | Complete | Baseline start | Baseline finish | Baseline duration | Baseline 1 start | Baseline 1 finish | Constraint | Baseline cost | Responsible | Involved | Text9 | Update Version | MHHS Resource Name | MHHS Programme Phase | Text29 | Sched Status | RAG | Milestone ID | Tier | Artefact ID | Guidance |
| --- | --- | --- | --- | --- | --- | --- | --- | --- | --- | --- | --- | --- | --- | --- | --- | --- | --- | --- | --- | --- | --- | --- | --- | --- | --- | --- | --- | --- |
| 1078 | 1.4.1.4.3.4 | **Environments (SIT B)** |  | 435d | 2022-10-31 A | 2024-06-28 A |  | 100% | 2022-10-31 | 2024-06-28 | 420d | 2022-11-16 | 2024-05-13 |  | -0 | N/A | N/A | SIT | 5.0 | N/A | Systems Integration Testing (SIT) | SITAG |  |  |  |  |  |  |
| 1079 | 1.4.1.4.3.4.1 | **PP Environments (SIT B)** |  | 41d | 2024-05-03 A | 2024-06-28 A |  | 100% | 2024-05-03 | 2024-06-28 | 26d | 2022-11-16 | 2024-05-13 |  | -0 | N/A | N/A | SIT | 5.0 | N/A | Systems Integration Testing (SIT) | SITAG |  |  |  |  |  |  |
| 1080 | 1.4.1.4.3.4.1.1 | PP Environments available | milestone | 0d | 2024-05-03 A | 2024-05-03 A | 549 | 100% | 2024-05-03 | 2024-05-03 | 0d | 2022-11-16 | 2024-04-01 | start no earlier than 2024-05-03 |  | PP | SI Test | SIT | 5.21 | Simon Berry | Systems Integration Testing (SIT) | SITAG | Complete | COMPLETE |  |  |  |  |
| 1081 | 1.4.1.4.3.4.1.2 | PP Onboarding / Smoke test |  | 35d | 2024-05-13 A | 2024-06-28 A | 1080FS+6d | 100% | 2024-05-13 | 2024-06-28 | 20d | 2022-11-16 | 2024-04-01 |  |  | PP | SI Test | SIT | 5.21 | Simon Berry | Systems Integration Testing (SIT) | SITAG | Complete | COMPLETE |  |  |  |  |
| 1082 | 1.4.1.4.3.4.1.3 | DTN Connectivity Proving Complete |  | 5d | 2024-06-10 A | 2024-06-14 A | 1080FS+26d | 100% | 2024-06-10 | 2024-06-14 | 0d | 2024-04-15 | 2024-04-26 |  |  | PP | SI Test | SIT | 5.21 | Simon Berry | Systems Integration Testing (SIT) | SITAG | Complete | COMPLETE |  |  |  |  |
| 1083 | 1.4.1.4.3.4.1.4 | PP Code Deployment | milestone | 0d | 2024-06-14 A | 2024-06-14 A | 1082 | 100% | 2024-06-14 | 2024-06-14 | 0d | 2024-04-29 | 2024-05-13 |  |  | PP | SI Test | SIT | 5.21 | Simon Berry | Systems Integration Testing (SIT) | SITAG | Complete | COMPLETE |  |  |  |  |
| 1084 | 1.4.1.4.3.4.2 | **SI Environments (SIT B)** |  | 425d | 2022-10-31 A | 2024-06-14 A |  | 100% | 2022-10-31 | 2024-06-14 | 420d | 2022-11-16 | 2024-05-10 |  | -0 | N/A | N/A | SIT | 5.0 | N/A | Systems Integration Testing (SIT) | SITAG |  |  |  |  |  |  |
| 1085 | 1.4.1.4.3.4.2.1 | Coordinate SIT Participants' SIT B environment preparation |  | 420d | 2022-10-31 A | 2024-06-07 A |  | 100% | 2022-10-31 | 2024-06-07 | 420d | 2022-11-16 | 2024-04-01 |  |  | SI Test | PP | SIT | 5.21 | Simon Berry | Systems Integration Testing (SIT) | SITAG | Complete | COMPLETE |  |  |  |  |
| 1086 | 1.4.1.4.3.4.2.2 | Assure PPs' self-declaration of environment preparation complete (incl. security certificates and security compliance) | milestone | 0d | 2024-06-07 A | 2024-06-07 A | 1085 | 100% | 2024-06-07 | 2024-06-07 | 0d | 2022-11-16 | 2024-03-29 |  |  | SI Test | PP | SIT | 5.21 | Simon Berry | Systems Integration Testing (SIT) | SITAG | Complete | COMPLETE |  |  |  |  |
| 1087 | 1.4.1.4.3.4.2.3 | SIT Participants' SIT B environments ready to start connectivity proving (incl. certificates and security compliance) | milestone | 0d | 2024-06-05 A | 2024-06-05 A | 1080FS+24d | 100% | 2024-06-05 | 2024-06-05 | 0d | 2024-04-01 | 2024-04-01 |  |  | SI Test | PP,IPA | SIT | 5.26 | Simon Berry | Systems Integration Testing (SIT) | SITAG | Complete | COMPLETE | T3-TE-0033 | T3 |  |  |
| 1088 | 1.4.1.4.3.4.2.4 | Coordinate SIT Participants' SIT B environment connectivity proving |  | 2d | 2024-06-06 A | 2024-06-07 A | 1087 | 100% | 2024-06-06 | 2024-06-07 | 19d | 2024-04-01 | 2024-04-26 |  |  | SI Test | PP | SIT | 5.21 | Simon Berry | Systems Integration Testing (SIT) | SITAG | Complete | COMPLETE |  |  |  |  |
| 1089 | 1.4.1.4.3.4.2.5 | Coordinate deployment of MHHS solution code to SIT Participants' SIT B environments | milestone | 0d | 2024-06-14 A | 2024-06-14 A | 1083 | 100% | 2024-06-14 | 2024-06-14 | 4d | 2024-04-15 | 2024-04-26 |  |  | SI Test | PP | SIT | 5.21 | Simon Berry | Systems Integration Testing (SIT) | SITAG | Complete | COMPLETE |  |  |  |  |
| 1090 | 1.4.1.4.3.5 | **SIT Migration Test Readiness Report** |  | 44d | 2024-04-02 A | 2024-05-31 A |  | 100% | 2024-04-02 | 2024-05-31 | 44d | 2024-04-02 | 2024-05-27 |  | -0 | N/A | N/A | SIT | 5.0 | N/A | Systems Integration Testing (SIT) | SITAG |  |  |  |  |  |  |
| 1091 | 1.4.1.4.3.5.1 | **PP SIT Migration Test Readiness Report** |  | 44d | 2024-04-02 A | 2024-05-31 A |  | 100% | 2024-04-02 | 2024-05-31 | 44d | 2024-04-02 | 2024-05-13 |  | -0 | N/A | N/A | SIT | 5.0 | N/A | Systems Integration Testing (SIT) | SITAG |  |  |  |  |  |  |
| 1092 | 1.4.1.4.3.5.1.1 | Develop draft Test Readiness Report and submit to Programme for assurance |  | 20d | 2024-04-02 A | 2024-04-29 A |  | 100% | 2024-04-02 | 2024-04-29 | 20d | 2024-04-02 | 2024-04-30 | start no earlier than 2024-04-02 |  | PP | SI Test | SIT | 5.0 |  | Systems Integration Testing (SIT) | SITAG | Complete | COMPLETE |  |  |  |  |
| 1093 | 1.4.1.4.3.5.1.2 | Placing Reliance Stage 2 Review |  | 35d | 2024-04-15 A | 2024-05-31 A | 1092SS+9d | 100% | 2024-04-15 | 2024-05-31 | 35d |  |  |  |  | SI Test | PP | SIT | 5.12 |  | Systems Integration Testing (SIT) | SITAG | Complete | COMPLETE |  |  |  |  |
| 1094 | 1.4.1.4.3.5.1.3 | Finalise Test Readiness Report and submit to Programme for assurance |  | 10d | 2024-04-30 A | 2024-05-13 A | 1092 | 100% | 2024-04-30 | 2024-05-13 | 10d | 2024-04-30 | 2024-05-13 |  |  | PP | SI Test | SIT | 5.0 |  | Systems Integration Testing (SIT) | SITAG | Complete | COMPLETE |  |  |  |  |
| 1095 | 1.4.1.4.3.5.2 | **SI SIT Migration Test Readiness Report** |  | 40d | 2024-04-02 A | 2024-05-27 A |  | 100% | 2024-04-02 | 2024-05-27 | 40d | 2024-04-02 | 2024-05-27 |  |  | N/A | N/A | SIT | 5.0 | N/A | Systems Integration Testing (SIT) | SITAG |  |  |  |  |  |  |
| 1096 | 1.4.1.4.3.5.2.1 | Assure Test Participants' Test Readiness Reports |  | 35d | 2024-04-02 A | 2024-05-20 A | 1092SS, 1094FF+5d | 100% | 2024-04-02 | 2024-05-20 | 35d | 2024-04-02 | 2024-05-20 |  |  | SI Test | PP,IPA | SIT | 5.0 |  | Systems Integration Testing (SIT) | SITAG | Complete | COMPLETE |  |  |  |  |
| 1097 | 1.4.1.4.3.5.2.2 | Develop Overarching SIT Migration Test Readiness Report |  | 20d | 2024-04-23 A | 2024-05-20 A | 1096FF | 100% | 2024-04-23 | 2024-05-20 | 20d | 2024-04-23 | 2024-05-20 |  |  | SI Test |  | SIT | 5.0 |  | Systems Integration Testing (SIT) | SITAG | Complete | COMPLETE |  |  |  |  |
| 1098 | 1.4.1.4.3.5.2.3 | Artefact review (via SITAG) and updates |  | 5d | 2024-05-21 A | 2024-05-27 A | 1097 | 100% | 2024-05-21 | 2024-05-27 | 5d | 2024-05-21 | 2024-05-27 |  |  | SI Test | PP,IPA | SIT | 5.0 |  | Systems Integration Testing (SIT) | SITAG | Complete | COMPLETE |  |  |  |  |
| 1099 | 1.4.1.4.3.6 | SIT Migration Testing Preparation Complete | milestone | 0d | 2024-06-03 A | 2024-06-03 A | 1098FF+5d, 1002, 395, 1093, 1013, 1019, 1025 | 100% | 2024-06-03 | 2024-06-03 | 0d | 2024-06-03 | 2024-06-03 |  |  | SI Test | PP,IPA | SIT | 5.0 |  | Systems Integration Testing (SIT) | SITAG | Complete | COMPLETE | T2-TE-0650 | T2 |  |  |
| 1100 | 1.4.1.4.4 | **SIT Non-Functional Preparation** |  | 347d? | 2023-11-30 A | 2025-03-28 A |  | 100% | 2023-11-30 | 2025-03-14 | 193d | 2023-07-03 | 2024-08-26 |  | -0 | N/A | N/A | SIT | 5.0 | N/A | Systems Integration Testing (SIT) | SITAG |  |  |  |  |  |  |
| 1101 | 1.4.1.4.4.1 | **Test Approach & Plan** |  | 120d | 2023-11-30 A | 2024-05-15 A |  | 100% | 2023-11-30 | 2024-05-15 | 120d | 2023-11-30 | 2024-03-20 |  | -0 | N/A | N/A | SIT | 5.0 | N/A | Systems Integration Testing (SIT) | SITAG |  |  |  |  |  |  |
| 1102 | 1.4.1.4.4.1.1 | Develop document with SITWG |  | 67d | 2023-11-30 A | 2024-03-01 A |  | 100% | 2023-11-30 | 2024-03-01 | 67d | 2023-11-30 | 2024-01-10 | must start on 2023-11-30 |  | SI Test |  | SIT | 5.0 |  | Systems Integration Testing (SIT) | SITAG | Complete | COMPLETE |  |  |  |  |
| 1103 | 1.4.1.4.4.1.2 | Draft document review with Code Bodies |  | 10d | 2024-03-04 A | 2024-03-15 A | 1102 | 100% | 2024-03-04 | 2024-03-15 | 10d | 2024-01-11 | 2024-01-24 |  |  | SI Test | Code Bodies | SIT | 5.0 |  | Systems Integration Testing (SIT) | SITAG | Complete | COMPLETE |  |  |  |  |
| 1104 | 1.4.1.4.4.1.3 | Industry Consultation |  | 10d | 2024-03-18 A | 2024-03-29 A | 1103 | 100% | 2024-03-18 | 2024-03-29 | 10d |  |  |  |  | PP |  | SIT | 5.1 |  | Systems Integration Testing (SIT) | SITAG | Complete | COMPLETE |  |  |  |  |
| 1105 | 1.4.1.4.4.1.4 | Industry Assurance Review |  | 5d | 2024-04-11 A | 2024-04-17 A | 1104FS+8d | 100% | 2024-04-11 | 2024-04-17 | 5d |  |  |  |  |  |  | SIT | 5.16 |  |  | SITAG | Complete | COMPLETE |  |  |  |  |
| 1106 | 1.4.1.4.4.1.5 | SIT Non-Functional Testing Test Approach & Plan approved | milestone | 0d | 2024-05-15 A | 2024-05-15 A | 1105FS+20d | 100% | 2024-05-15 | 2024-05-15 | 0d | 2024-03-20 | 2024-03-20 |  |  | SI Test | PP | SIT | 5.30 | Roger Robar | Systems Integration Testing (SIT) | SITAG | Complete | COMPLETE | T3-TE-0026 | T3 | MHHS-ART073 | 30/7/24: Approved at esitag on 26/7/24 |

| ID | WBS | Task | Type | Duration | Start | Finish | Predecessors | Complete | Actual finish | Baseline start | Baseline finish | Baseline duration | Baseline 1 start | Baseline 1 finish | Constraint | Baseline cost | Responsible | Involved | Text9 | Update Version | MHHS Resource Name | MHHS Programme Phase | Text29 | Sched Status | RAG | Milestone ID | Tier | Task Status | Guidance |
| --- | --- | --- | --- | --- | --- | --- | --- | --- | --- | --- | --- | --- | --- | --- | --- | --- | --- | --- | --- | --- | --- | --- | --- | --- | --- | --- | --- | --- | --- |
| 1107 | 1.4.1.4.4.2 | **Test Data Approach & Plan** |  | 41d | 2024-03-20 A | 2024-05-15 A |  | 100% |  | 2024-03-20 | 2024-05-15 | 41d | 2024-01-25 | 2024-03-20 |  | -0 | N/A | N/A | SIT | 5.0 | N/A | Systems Integration Testing (SIT) | SITAG |  |  |  |  |  |  |
| 1108 | 1.4.1.4.4.2.1 | Industry Consultation |  | 14d | 2024-03-20 A | 2024-04-08 A | 1104SS+2d | 100% |  | 2024-03-20 | 2024-04-08 | 14d |  |  |  |  | PP |  | SIT | 5.1 | Michael Inije | Systems Integration Testing (SIT) | SITAG | Complete | COMPLETE |  |  |  |  |
| 1109 | 1.4.1.4.4.2.2 | Artefact review (via SITAG) and updates |  | 27d | 2024-04-09 A | 2024-05-15 A | 1108 | 100% |  | 2024-04-09 | 2024-05-15 | 27d | 2024-01-25 | 2024-03-13 |  |  | SI Test |  | SIT | 5.0 | Michael Inije | Systems Integration Testing (SIT) | SITAG | Complete | COMPLETE |  |  |  |  |
| 1110 | 1.4.1.4.4.2.3 | SIT Non-Functional Testing Test Data Approach & Plan approved | milestone | 0d | 2024-05-15 A | 2024-05-15 A | 1106FF, 1109 | 100% |  | 2024-05-15 | 2024-05-15 | 0d | 2024-03-20 | 2024-03-20 |  |  | SI Test | PP,IPA | SIT | 5.24 | Michael Inije | Systems Integration Testing (SIT) | SITAG | Complete | COMPLETE | T3-TE-0113 | T3 |  |  |
| 1111 | 1.4.1.4.4.3 | **Test scenarios & Test Cases** |  | 98d? | 2024-03-04 A | 2024-07-17 |  | 100% | 2024-09-18 | 2024-03-04 | 2024-07-17 | 123d | 2023-07-24 | 2024-01-17 |  | -0 | N/A | N/A | SIT | 5.21 | N/A | Systems Integration Testing (SIT) | SITAG |  |  |  |  |  |  |
| 1112 | 1.4.1.4.4.3.1 | **Theme 1** |  | 78d | 2024-03-04 A | 2024-06-19 A |  | 100% |  | 2024-03-04 | 2024-06-19 | 78d |  |  |  | -0 | N/A | N/A | SIT | 5.21 | N/A | Systems Integration Testing (SIT) | SITAG |  |  |  |  | -448.67 |  |
| 1113 | 1.4.1.4.4.3.1.1 | Develop Test Scenarios & Test Cases |  | 33d | 2024-03-04 A | 2024-04-17 A | 1102 | 100% |  | 2024-03-04 | 2024-04-17 | 33d |  |  |  |  | SI Test | SI Test, PP | SIT | 5.21 |  |  | SITAG | Complete | COMPLETE |  |  |  |  |
| 1114 | 1.4.1.4.4.3.1.2 | Industry Review Workshop |  | 1d | 2024-04-18 A | 2024-04-18 A | 1113 | 100% |  | 2024-04-18 | 2024-04-18 | 1d |  |  |  |  | SI Test, PP | SI Test, PP | SIT | 5.21 |  |  | SITAG | Complete | COMPLETE |  |  |  |  |
| 1115 | 1.4.1.4.4.3.1.3 | Industry Consultation Review |  | 7d | 2024-05-02 A | 2024-05-10 A | 1114FS+9d | 100% |  | 2024-05-02 | 2024-05-10 | 7d |  |  |  |  | SI Test, PP | SI Test, PP | SIT | 5.21 |  |  | SITAG | Complete | COMPLETE |  |  |  |  |
| 1116 | 1.4.1.4.4.3.1.4 | Review with NFT Working Group |  | 5d | 2024-05-31 A | 2024-06-06 A | 1115FS+14d | 100% |  | 2024-05-31 | 2024-06-06 | 5d |  |  |  |  | SI Test, PP | SI Test, PP | SIT | 5.21 |  |  | SITAG | Complete | COMPLETE |  |  |  |  |
| 1117 | 1.4.1.4.4.3.1.5 | SIT NFT Scenarios & Test Cases Approved - Theme 1 | milestone | 0d | 2024-06-19 A | 2024-06-19 A | 1116FS+9d | 100% |  | 2024-06-19 | 2024-06-19 | 0d |  |  |  |  | SI Test | SI Test, PP | SIT | 5.30 | Roger Robar | Systems Integration Testing (SIT) | SITAG | Complete | COMPLETE | T3-TE-0114 | T3 |  | 30/7/24: Approved at esitag on 26/7/24 |
| 1118 | 1.4.1.4.4.3.2 | **Theme 2** |  | 98d | 2024-03-04 A | 2024-07-17 A |  | 100% |  | 2024-03-04 | 2024-07-17 | 98d |  |  |  |  | N/A | N/A | SIT | 5.21 | N/A | Systems Integration Testing (SIT) | SITAG |  |  |  |  | -448.67 |  |
| 1119 | 1.4.1.4.4.3.2.1 | Develop Test Scenarios & Test Cases |  | 53d | 2024-03-04 A | 2024-05-15 A | 1102 | 100% |  | 2024-03-04 | 2024-05-15 | 53d |  |  |  |  | SI Test | SI Test, PP | SIT | 5.21 |  |  | SITAG | Complete | COMPLETE |  |  |  |  |
| 1120 | 1.4.1.4.4.3.2.2 | Industry Review Workshop |  | 1d | 2024-05-16 A | 2024-05-16 A | 1119 | 100% |  | 2024-05-16 | 2024-05-16 | 1d |  |  |  |  | SI Test, PP | SI Test, PP | SIT | 5.21 |  |  | SITAG | Complete | COMPLETE |  |  |  |  |
| 1121 | 1.4.1.4.4.3.2.3 | Industry Consultation Review |  | 7d | 2024-05-20 A | 2024-05-28 A | 1120FS+1d | 100% |  | 2024-05-20 | 2024-05-28 | 7d |  |  |  |  | SI Test, PP | SI Test, PP | SIT | 5.21 |  |  | SITAG | Complete | COMPLETE |  |  |  |  |
| 1122 | 1.4.1.4.4.3.2.4 | Review with NFT Working Group |  | 5d | 2024-06-28 A | 2024-07-04 A | 1121FS+22d | 100% |  | 2024-06-28 | 2024-07-04 | 5d |  |  |  |  | SI Test, PP | SI Test, PP | SIT | 5.21 |  |  | SITAG | Complete | COMPLETE |  |  |  |  |
| 1123 | 1.4.1.4.4.3.2.5 | SIT NFT Scenarios & Test Cases Approved - Theme 2 | milestone | 0d | 2024-07-17 A | 2024-07-17 A | 1122FS+9d | 100% |  | 2024-07-17 | 2024-07-17 | 0d |  |  |  |  | SI Test | SI Test, PP | SIT | 5.22 |  | Systems Integration Testing (SIT) | SITAG | Complete | COMPLETE | T3-TE-0115 | T3 |  |  |
| 1124 | 1.4.1.4.4.3.3 | **Theme 3** |  | 98d? | 2024-03-04 A | 2024-07-17 |  | 100% | 2024-09-18 | 2024-03-04 | 2024-07-17 | 123d |  |  |  | -0 | N/A | N/A | SIT | 6.0 | N/A | Systems Integration Testing (SIT) | SITAG |  |  |  |  | -448.67 |  |
| 1125 | 1.4.1.4.4.3.3.1 | Develop Test Scenarios & Test Cases |  | 63d | 2024-03-04 A | 2024-05-29 A | 1102 | 100% |  | 2024-03-04 | 2024-05-29 | 63d |  |  |  |  | SI Test | SI Test, PP | SIT | 6.0 |  |  | SITAG | Complete | COMPLETE |  |  |  |  |
| 1126 | 1.4.1.4.4.3.3.2 | Industry Review Workshop |  | 1d | 2024-05-30 A | 2024-05-30 A | 1125 | 100% |  | 2024-05-30 | 2024-05-30 | 1d |  |  |  |  | SI Test, PP | SI Test, PP | SIT | 6.0 |  |  | SITAG | Complete | COMPLETE |  |  |  |  |
| 1127 | 1.4.1.4.4.3.3.3 | Industry Consultation Review |  | 6d | 2024-06-10 A | 2024-06-17 A | 1126FS+6d | 100% |  | 2024-06-10 | 2024-06-17 | 6d |  |  |  |  | SI Test, PP | SI Test, PP | SIT | 6.0 |  |  | SITAG | Complete | COMPLETE |  |  |  |  |
| 1128 | 1.4.1.4.4.3.3.4 | Review with NFT Working Group |  | 5d | 2024-06-28 A | 2024-07-04 A | 1127FS+8d | 100% |  | 2024-06-28 | 2024-07-04 | 30d |  |  |  |  | SI Test, PP | SI Test, PP | SIT | 6.0 | Roger Robar |  | SITAG | Complete | COMPLETE |  |  |  |  |
| 1129 | 1.4.1.4.4.3.3.5 | SIT NFT Scenarios & Test Cases Approved - Theme 3 | milestone | 0d | 2024-09-18 A | 2024-09-18 A | 1128FS+9d | 100% |  | 2024-09-18 | 2024-09-18 | 0d |  |  | start no earlier than 2024-09-18 |  | SI Test | SI Test, PP | SIT | 5.30 | Roger Robar | Systems Integration Testing (SIT) | SITAG | Complete | COMPLETE | T3-TE-0116 | T3 |  | 31/7/24: baseline date change approved at esitag on 26/7/24 |
| 1130 | 1.4.1.4.4.4 | **SIT NFT Programme RTTM** |  | 45d | 2024-09-18 A | 2024-11-19 A |  | 100% |  | 2024-09-18 | 2024-10-16 | 0d |  |  |  |  | SI Test |  | SIT | 6.11 | David O'Riordan |  | SITAG |  |  |  |  | -197.67 |  |
| 1131 | 1.4.1.4.4.4.1 | Develop Manual SIT NFT RTTM |  | 30d | 2024-09-18 A | 2024-10-29 A | 1129 | 100% |  | 2024-09-18 | 2024-10-29 | 0d |  |  |  |  | SI Test |  | SIT | 6.11 | David O'Riordan |  | SITAG | Complete | COMPLETE |  |  |  |  |
| 1132 | 1.4.1.4.4.4.2 | LDP peer review |  | 10d | 2024-10-30 A | 2024-11-12 A | 1131 | 100% |  | 2024-10-30 | 2024-11-12 | 0d |  |  |  |  | SI Test |  | SIT | 6.11 | David O'Riordan |  | SITAG | Complete | COMPLETE |  |  |  |  |
| 1133 | 1.4.1.4.4.4.3 | Review with SRO |  | 5d | 2024-11-13 A | 2024-11-19 A | 1132 | 100% |  | 2024-11-13 | 2024-11-19 | 0d |  |  |  |  | SI Test |  | SIT | 6.11 | David O'Riordan |  | SITAG | Complete | COMPLETE |  |  |  |  |
| 1134 | 1.4.1.4.4.4.4 | DIP Manager / Code Bodies / Full SRO to review |  | 5d | 2024-11-13 A | 2024-11-19 A | 1132 | 100% |  | 2024-11-13 | 2024-11-19 | 0d |  |  |  |  | SI Test |  | SIT | 6.12 | David O'Riordan |  | SITAG | Complete | COMPLETE |  |  |  |  |
| 1135 | 1.4.1.4.4.4.5 | DIP Manager / Code Bodies / Full SRO acceptance of RTTM | milestone | 0d | 2024-11-19 A | 2024-11-19 A | 1134 | 100% |  | 2024-11-19 | 2024-11-19 | 0d |  |  |  |  | SI Test |  | SIT | 6.16 | David O'Riordan |  | SITAG | Complete | COMPLETE |  |  |  |  |
| 1136 | 1.4.1.4.4.4.6 | Manual SIT NFT RTTM Complete | milestone | 0d | 2024-11-19 A | 2024-11-19 A | 1133, 1134 | 100% |  | 2024-11-19 | 2024-11-19 | 0d |  |  |  |  | SI Test |  | SIT | 6.11 | David O'Riordan |  | SITAG | Complete | COMPLETE |  |  |  |  |

| ID | WBS | Task | Type | Duration | Start | Finish | Predecessors | Complete | Baseline start | Baseline finish | Baseline duration | Baseline 1 start | Baseline 1 finish | Constraint | Baseline cost | Responsible | Text9 | Task Status | Update Version | Sched Status | MHHS Resource Name | Text29 | RAG | Involved | MHHS Programme Phase | Action |
| --- | --- | --- | --- | --- | --- | --- | --- | --- | --- | --- | --- | --- | --- | --- | --- | --- | --- | --- | --- | --- | --- | --- | --- | --- | --- | --- |
| 1137 | 1.4.1.4.4.5 | **NFT (Theme 1, 2 and 3) DITL** |  | 18d | 2025-02-03 A | 2025-02-26 A |  | 100% | 2024-10-08 | 2024-10-17 | 0d |  |  |  |  | SI Test | SIT | 6.33 | 6.15 | No BL | David O'Riordan | SITAG |  |  |  |  |
| 1138 | 1.4.1.4.4.5.1 | DITL Development |  | 10d | 2025-02-03 A | 2025-02-14 A |  | 100% | 2025-02-03 | 2025-02-14 | 0d |  |  | start no earlier than 2025-02-03 |  | SI Test | SIT |  | 6.15 | Complete | David O'Riordan | SITAG | COMPLETE |  |  |  |
| 1139 | 1.4.1.4.4.5.2 | SRO Review |  | 5d | 2025-02-17 A | 2025-02-21 A | 1138 | 100% | 2025-02-17 | 2025-02-21 | 0d |  |  |  |  | SI Test | SIT |  | 6.15 | Complete | David O'Riordan | SITAG | COMPLETE |  |  |  |
| 1140 | 1.4.1.4.4.5.3 | Post-SRO Review Changes |  | 3d | 2025-02-24 A | 2025-02-26 A | 1139 | 100% | 2025-02-24 | 2025-02-26 | 0d |  |  |  |  | SI Test | SIT |  | 6.15 | Complete | David O'Riordan | SITAG | COMPLETE |  |  |  |
| 1141 | 1.4.1.4.4.5.4 | Programme DITL walkthrough with PPs on Theme 1, 2 and 3 | milestone | 0d | 2025-02-26 A | 2025-02-26 A | 1140 | 100% | 2025-02-26 | 2025-02-26 | 0d |  |  |  |  | SI Test | SIT |  | 6.15 | Complete | David O'Riordan | SITAG | COMPLETE |  |  |  |
| 1142 | 1.4.1.4.4.6 | **NFT Performance Tool Theme 1 Setup** |  | 268d? | 2024-03-04 A | 2025-03-12 A |  | 100% | 2024-03-04 | 2025-01-10 | 0d |  |  |  |  | SI Test | SIT | -205.67 | 6.1 |  | David O'Riordan | SITAG |  |  |  |  |
| 1143 | 1.4.1.4.4.6.1 | Theme 1 injection tool initial POC |  | 85d? | 2024-03-04 A | 2024-06-28 A |  | 100% | 2024-03-04 | 2024-06-28 | 0d |  |  |  |  | SI Test | SIT |  | 6.1 | Complete | David O'Riordan | SITAG | COMPLETE |  |  |  |
| 1144 | 1.4.1.4.4.6.2 | Theme 1 injection tool configuration and validation against DIP SIM (IR7.1) |  | 38d | 2024-07-01 A | 2024-08-21 A | 1143 | 100% | 2024-07-01 | 2024-08-21 | 0d |  |  |  |  | SI Test | SIT |  | 6.1 | Complete | David O'Riordan | SITAG | COMPLETE |  |  |  |
| 1145 | 1.4.1.4.4.6.3 | Theme 1 injection tool configuration and validation against DIP SIM (IR8.1) |  | 29d | 2024-08-22 A | 2024-10-01 A | 1144 | 100% | 2024-08-22 | 2024-10-01 | 0d |  |  |  |  | SI Test | SIT |  | 6.1 | Complete | David O'Riordan | SITAG | COMPLETE |  |  |  |
| 1146 | 1.4.1.4.4.6.4 | Theme 1 injection tool configuration and validation againast UIT DIP (IR8.1) |  | 11d | 2024-10-02 A | 2024-10-16 A | 1145 | 100% | 2024-10-02 | 2024-10-16 | 0d |  |  |  |  | SI Test | SIT |  | 6.1 | Complete | David O'Riordan | SITAG | COMPLETE |  |  |  |
| 1147 | 1.4.1.4.4.6.5 | Theme 1 injection tool configuration and validation against SIT-B DIP (IR8.4) |  | 3d? | 2025-03-10 A | 2025-03-12 A | 1595FS+10d | 100% | 2025-01-06 | 2025-01-08 | 0d |  |  |  |  | SI Test | SIT |  | 6.1 | Complete | David O'Riordan | SITAG | COMPLETE |  |  |  |
| 1148 | 1.4.1.4.4.7 | **Environments (SIT B)** |  | 134d | 2024-08-27 A | 2025-02-28 A |  | 100% | 2024-08-27 | 2025-01-03 | 0d | 2024-07-30 | 2024-08-05 |  | -0 | N/A | SIT |  | 5.0 |  | Heath Thomas | SITAG |  | N/A | Systems Integration Testing (SIT) |  |
| 1149 | 1.4.1.4.4.7.1 | **PP Environments (SIT B)** |  | 0d | 2024-08-27 A | 2024-08-27 A |  | 100% | 2024-08-27 | 2024-08-27 | 0d | 2024-07-30 | 2024-08-05 |  | -0 | N/A | SIT |  | 5.0 |  | Heath Thomas | SITAG |  | N/A | Systems Integration Testing (SIT) |  |
| 1150 | 1.4.1.4.4.7.1.1 | Deployment of MHHS solution code to SIT B environments | milestone | 0d | 2024-08-27 A | 2024-08-27 A |  | 100% | 2024-08-27 | 2024-08-27 | 0d | 2024-07-30 | 2024-08-05 | start no earlier than 2024-08-27 |  | PP | SIT |  | 5.21 | Complete | Heath Thomas | SITAG | COMPLETE | SI Test | Systems Integration Testing (SIT) | 26/3/24: Lee said change to SB and align to IR7 |
| 1151 | 1.4.1.4.4.7.2 | **SI Environments (SIT B)** |  | 0d | 2024-08-27 A | 2024-08-27 A |  | 100% | 2024-08-27 | 2024-08-27 | 0d | 2024-07-30 | 2024-08-05 |  | -0 | N/A | SIT |  | 5.0 |  | Heath Thomas | SITAG |  | N/A | Systems Integration Testing (SIT) |  |
| 1152 | 1.4.1.4.4.7.2.1 | Coordinate deployment of MHHS solution code to SIT Participants' SIT B environments | milestone | 0d | 2024-08-27 A | 2024-08-27 A | 1150SS | 100% | 2024-08-27 | 2024-08-27 | 0d | 2024-07-30 | 2024-08-05 |  |  | SI Test | SIT |  | 5.21 | Complete | Heath Thomas | SITAG | COMPLETE | PP | Systems Integration Testing (SIT) |  |
| 1153 | 1.4.1.4.4.7.3 | **Helix and Avanade Environments Upscale** |  | 5d | 2025-02-24 A | 2025-02-28 A |  | 100% | 2024-12-23 | 2025-01-03 | 0d |  |  |  |  | SI Test | SIT | -686.67 | 6.0 | Overdue Start | Heath Thomas | SITAG |  |  |  |  |
| 1154 | 1.4.1.4.4.7.3.1 | Environment Uplift Window (Technical Check) |  | 5d | 2025-02-24 A | 2025-02-28 A | 1595 | 100% | 2025-02-24 | 2025-02-28 | 0d |  |  |  |  | SI Test | SIT |  | 6.19 | Complete | Heath Thomas | SITAG | COMPLETE |  |  |  |
| 1155 | 1.4.1.4.4.8 | **SIT Non-Functional Execution Model** |  | 42d | 2025-01-20 A | 2025-03-18 A |  | 100% | 2025-01-20 | 2025-02-12 | 0d |  |  |  |  | SI Test | SIT | -778.67 | 6.15 | Overdue Start | David O'Riordan | SITAG |  |  |  |  |
| 1156 | 1.4.1.4.4.8.1 | **Theme 1** |  | 22d | 2025-01-20 A | 2025-02-18 A |  | 100% | 2025-01-20 | 2025-02-12 | 0d |  |  |  |  | SI Test | SIT | -778.67 | 6.15 | Overdue Start | David O'Riordan | SITAG |  |  |  |  |
| 1157 | 1.4.1.4.4.8.1.1 | Develop execution model Theme 1 |  | 3d | 2025-01-20 A | 2025-01-22 A |  | 100% | 2025-01-20 | 2025-01-22 | 0d |  |  | start no earlier than 2025-01-20 |  | SI Test | SIT |  | 6.15 | Complete | David O'Riordan | SITAG | COMPLETE |  |  |  |
| 1158 | 1.4.1.4.4.8.1.2 | SRO provide feedback |  | 5d | 2025-01-23 A | 2025-01-29 A | 1157 | 100% | 2025-01-23 | 2025-01-29 | 0d |  |  |  |  | SI Test | SIT |  | 6.15 | Complete | David O'Riordan | SITAG | COMPLETE |  |  |  |
| 1159 | 1.4.1.4.4.8.1.3 | Address SRO feedback on execution model |  | 2d | 2025-01-30 A | 2025-01-31 A | 1158 | 100% | 2025-01-30 | 2025-01-31 | 0d |  |  |  |  | SI Test | SIT |  | 6.15 | Complete | David O'Riordan | SITAG | COMPLETE |  |  |  |
| 1160 | 1.4.1.4.4.8.1.4 | Finalise execution model |  | 3d | 2025-02-03 A | 2025-02-05 A | 1159 | 100% | 2025-02-03 | 2025-02-05 | 0d |  |  |  |  | SI Test | SIT |  | 6.15 | Complete | David O'Riordan | SITAG | COMPLETE |  |  |  |
| 1161 | 1.4.1.4.4.8.1.5 | NFTWG paper day | milestone | 0d | 2025-02-11 A | 2025-02-11 A | 1160FS+4d | 100% | 2025-02-05 | 2025-02-05 | 0d |  |  |  |  | SI Test | SIT |  | 6.17 | Complete | David O'Riordan | SITAG | COMPLETE |  |  |  |
| 1162 | 1.4.1.4.4.8.1.6 | NFTWG update on execution model | milestone | 0d | 2025-02-18 A | 2025-02-18 A | 1161FS+5d | 100% | 2025-02-18 | 2025-02-18 | 0d |  |  |  |  | SI Test | SIT |  | 6.17 | Complete | David O'Riordan | SITAG | COMPLETE |  |  |  |

| ID | WBS | Task | Type | Duration | Start | Finish | Predecessors | Complete | Baseline start | Baseline finish | Baseline duration | Baseline 1 start | Baseline 1 finish | Constraint | Baseline cost | Responsible | Text9 | Task Status | Update Version | Sched Status | MHHS Resource Name | Text29 | RAG | Involved | MHHS Programme Phase | Tier | Milestone ID |
| --- | --- | --- | --- | --- | --- | --- | --- | --- | --- | --- | --- | --- | --- | --- | --- | --- | --- | --- | --- | --- | --- | --- | --- | --- | --- | --- | --- |
| 1163 | 1.4.1.4.4.8.2 | **Theme 2 & 3** |  | 42d | 2025-01-20 A | 2025-03-18 A |  | 100% | 2025-01-20 | 2025-02-12 | 0d |  |  |  |  | SI Test | SIT | -778.67 | 6.15 | Overdue Start | David O'Riordan | SITAG |  |  |  |  |  |
| 1164 | 1.4.1.4.4.8.2.1 | Develop execution model Theme 2 & 3 |  | 3d | 2025-01-20 A | 2025-01-22 A |  | 100% | 2025-01-20 | 2025-01-22 | 0d |  |  | start no earlier than 2025-01-20 |  | SI Test | SIT |  | 6.15 | Complete | David O'Riordan | SITAG | COMPLETE |  |  |  |  |
| 1165 | 1.4.1.4.4.8.2.2 | SRO provide feedback |  | 5d | 2025-01-23 A | 2025-01-29 A | 1164 | 100% | 2025-01-23 | 2025-01-29 | 0d |  |  |  |  | SI Test | SIT |  | 6.15 | Complete | David O'Riordan | SITAG | COMPLETE |  |  |  |  |
| 1166 | 1.4.1.4.4.8.2.3 | Address SRO feedback on execution model |  | 2d | 2025-01-30 A | 2025-01-31 A | 1165 | 100% | 2025-01-30 | 2025-01-31 | 0d |  |  |  |  | SI Test | SIT |  | 6.15 | Complete | David O'Riordan | SITAG | COMPLETE |  |  |  |  |
| 1167 | 1.4.1.4.4.8.2.4 | Finalise execution model |  | 3d | 2025-02-03 A | 2025-02-05 A | 1166 | 100% | 2025-02-03 | 2025-02-05 | 0d |  |  |  |  | SI Test | SIT |  | 6.15 | Complete | David O'Riordan | SITAG | COMPLETE |  |  |  |  |
| 1168 | 1.4.1.4.4.8.2.5 | NFTWG paper day | milestone | 0d | 2025-03-11 A | 2025-03-11 A | 1167FS+24d | 100% | 2025-03-11 | 2025-03-11 | 0d |  |  |  |  | SI Test | SIT |  | 6.17 | Complete | David O'Riordan | SITAG | COMPLETE |  |  |  |  |
| 1169 | 1.4.1.4.4.8.2.6 | NFTWG update on execution model | milestone | 0d | 2025-03-18 A | 2025-03-18 A | 1168FS+5d | 100% | 2025-03-18 | 2025-03-18 | 0d |  |  |  |  | SI Test | SIT |  | 6.17 | Complete | David O'Riordan | SITAG | COMPLETE |  |  |  |  |
| 1170 | 1.4.1.4.4.9 | **SIT Non-Functional Progress reporting** |  | 22d | 2025-01-23 A | 2025-02-21 A |  | 100% | 2024-12-30 | 2025-01-24 | 0d |  |  |  |  | SI Test | SIT | -778.67 | 6.14 | Overdue Start | David O'Riordan | SITAG |  |  |  |  |  |
| 1171 | 1.4.1.4.4.9.1 | Determine reporting methodology |  | 2d | 2025-01-23 A | 2025-01-24 A | 1157, 1164 | 100% | 2025-01-23 | 2025-01-24 | 0d |  |  |  |  | SI Test | SIT |  | 6.14 | Complete | David O'Riordan | SITAG | COMPLETE |  |  |  |  |
| 1172 | 1.4.1.4.4.9.2 | Implement reporting |  | 20d | 2025-01-27 A | 2025-02-21 A | 1171, 874, 412, 1117, 1123, 1129 | 100% | 2025-01-27 | 2025-02-14 | 0d | 2024-08-26 | 2024-08-26 |  |  | SI Test | SIT |  | 6.14 | Complete | David O'Riordan | SITAG | COMPLETE | PP,IPA | Systems Integration Testing (SIT) | T2 |  |
| 1173 | 1.4.1.4.4.10 | **SIT Non-Functional Test Readiness Report** |  | 48d | 2025-01-21 A | 2025-03-28 A |  | 100% | 2024-06-25 | 2025-03-07 | 44d | 2024-06-25 | 2024-08-19 |  | -0 | N/A | SIT |  | 5.0 |  | David O'Riordan | SITAG |  | N/A | Systems Integration Testing (SIT) |  |  |
| 1174 | 1.4.1.4.4.10.1 | **SIT Non-Functional Theme 1 Overarching Test Readiness Report** |  | 29d | 2025-01-21 A | 2025-02-28 A |  | 100% | 2024-06-25 | 2025-01-10 | 40d | 2024-06-25 | 2024-08-19 |  |  | N/A | SIT |  | 6.17 |  | David O'Riordan | SITAG |  | N/A | Systems Integration Testing (SIT) |  |  |
| 1175 | 1.4.1.4.4.10.1.1 | Develop Overarching SIT Non-Functional Theme 1 Overarching Test Readiness Report |  | 11d | 2025-01-21 A | 2025-02-04 A | 412 | 100% | 2025-01-21 | 2025-02-04 | 20d | 2024-07-16 | 2024-08-12 | finish no earlier than 2025-02-04 |  | SI Test | SIT |  | 6.17 | Complete | David O'Riordan | SITAG | COMPLETE |  | Systems Integration Testing (SIT) |  |  |
| 1176 | 1.4.1.4.4.10.1.2 | SRO review |  | 5d | 2025-02-05 A | 2025-02-11 A | 1175 | 100% | 2025-02-05 | 2025-02-11 | 0d |  |  | finish no earlier than 2025-02-10 |  | SI Test | SIT |  | 6.17 | Complete | David O'Riordan | SITAG | COMPLETE |  |  |  |  |
| 1177 | 1.4.1.4.4.10.1.3 | NFTWG paper day | milestone | 0d | 2025-02-11 A | 2025-02-11 A | 1176 | 100% | 2025-02-11 | 2025-02-11 | 0d |  |  | finish no earlier than 2025-02-11 |  | SI Test | SIT |  | 6.17 | Complete | David O'Riordan | SITAG | COMPLETE |  |  |  |  |
| 1178 | 1.4.1.4.4.10.1.4 | NFTWG review the Non-Functional Theme 1 Overarching Test Readiness Report | milestone | 0d | 2025-02-18 A | 2025-02-18 A | 1177FS+5d | 100% | 2025-02-18 | 2025-02-18 | 0d |  |  |  |  | SI Test | SIT |  | 6.17 | Complete | David O'Riordan | SITAG | COMPLETE |  |  |  |  |
| 1179 | 1.4.1.4.4.10.1.5 | Update Non-Functional Theme 1 Overarching Test Readiness Report following SRO / NFTWG feedback |  | 6d | 2025-02-19 A | 2025-02-26 A | 1176, 1178 | 100% | 2025-02-19 | 2025-02-26 | 0d |  |  | finish no earlier than 2025-02-26 |  | SI Test | SIT |  | 6.17 | Complete | David O'Riordan | SITAG | COMPLETE |  |  |  |  |
| 1180 | 1.4.1.4.4.10.1.6 | FTIG Recommendation | milestone | 0d | 2025-02-21 A | 2025-02-21 A | 1178FS+3d | 100% | 2025-02-21 | 2025-02-21 | 0d |  |  |  |  | SI Test | SIT |  | 6.17 | Complete | David O'Riordan |  | COMPLETE |  |  |  |  |
| 1181 | 1.4.1.4.4.10.1.7 | eSITAG paper day | milestone | 0d | 2025-02-26 A | 2025-02-26 A | 1179 | 100% | 2025-02-26 | 2025-02-26 | 0d |  |  | finish no earlier than 2025-02-21 |  | SI Test | SIT |  | 6.17 | Complete | David O'Riordan | SITAG | COMPLETE |  |  |  |  |
| 1182 | 1.4.1.4.4.10.1.8 | eSITAG approve Non-Functional Theme 1 Overarching Test Readiness Report | milestone | 0d | 2025-02-28 A | 2025-02-28 A | 1426 | 100% | 2025-02-28 | 2025-02-28 | 0d |  |  |  |  | SI Test | SIT |  | 6.17 | Complete | David O'Riordan | SITAG | COMPLETE |  |  | T3 | T3-TE-0190 |
| 1183 | 1.4.1.4.4.10.2 | **SIT Non-Functional Overarching Test Readiness Report Theme 2 & 3** |  | 28d | 2025-02-18 A | 2025-03-28 A |  | 100% | 2025-02-18 | 2025-03-28 | 0d |  |  |  |  | SI Test | SIT | -779.67 | 6.17 |  | David O'Riordan | SITAG |  |  |  |  |  |
| 1184 | 1.4.1.4.4.10.2.1 | Develop Overarching SIT Non-Functional Overarching Test Readiness Report Theme 2 & 3 |  | 11d | 2025-02-18 A | 2025-03-04 A |  | 100% | 2025-02-18 | 2025-03-04 | 0d |  |  | finish no earlier than 2025-03-04 |  | SI Test | SIT |  | 6.17 | Complete | David O'Riordan | SITAG | COMPLETE |  |  |  |  |
| 1185 | 1.4.1.4.4.10.2.2 | SRO review |  | 5d | 2025-03-05 A | 2025-03-11 A | 1184SS | 100% | 2025-03-05 | 2025-03-11 | 0d |  |  | start no earlier than 2025-03-05 |  | SI Test | SIT |  | 6.17 | Complete | David O'Riordan | SITAG | COMPLETE |  |  |  |  |
| 1186 | 1.4.1.4.4.10.2.3 | NFTWG paper day | milestone | 0d | 2025-03-11 A | 2025-03-11 A | 1185 | 100% | 2025-03-11 | 2025-03-11 | 0d |  |  | finish no earlier than 2025-03-11 |  | SI Test | SIT |  | 6.17 | Complete | David O'Riordan | SITAG | COMPLETE |  |  |  |  |
| 1187 | 1.4.1.4.4.10.2.4 | NFTWG review the Non-Functional Overarching Test Readiness Report Theme 2 & 3 | milestone | 0d | 2025-03-18 A | 2025-03-18 A | 1186FS+5d | 100% | 2025-03-18 | 2025-03-18 | 0d |  |  | finish no earlier than 2025-03-18 |  | SI Test | SIT |  | 6.17 | Complete | David O'Riordan | SITAG | COMPLETE |  |  |  |  |
| 1188 | 1.4.1.4.4.10.2.5 | Update Non-Functional Overarching Test Readiness Report Theme 2 & 3 following SRO / NFTWG feedback |  | 6d | 2025-03-19 A | 2025-03-26 A | 1185, 1187 | 100% | 2025-03-19 | 2025-03-26 | 0d |  |  |  |  | SI Test | SIT |  | 6.17 | Complete | David O'Riordan | SITAG | COMPLETE |  |  |  |  |
| 1189 | 1.4.1.4.4.10.2.6 | GLIG Recommendation | milestone | 0d | 2025-03-21 A | 2025-03-21 A | 1187FS+3d | 100% | 2025-03-21 | 2025-03-21 | 0d |  |  |  |  | SI Test | SIT |  | 6.17 | Complete | David O'Riordan |  | COMPLETE |  |  |  |  |
| 1190 | 1.4.1.4.4.10.2.7 | eSITAG paper day | milestone | 0d | 2025-03-26 A | 2025-03-26 A | 1188, 1189 | 100% | 2025-03-26 | 2025-03-26 | 0d |  |  | start no earlier than 2025-03-21 |  | SI Test | SIT |  | 6.17 | Complete | David O'Riordan | SITAG | COMPLETE |  |  |  |  |
| 1191 | 1.4.1.4.4.10.2.8 | eSITAG approve Non-Functional Overarching Test Readiness Report Theme 2 & 3 | milestone | 0d | 2025-03-28 A | 2025-03-28 A | 1190, 1427FS-1d, 1428 | 100% | 2025-03-28 | 2025-03-28 | 0d |  |  |  |  | SI Test | SIT |  | 6.17 | Complete | David O'Riordan | SITAG | COMPLETE |  |  | T3 | T3-TE-0191 |
| 1192 | 1.4.1.4.4.11 | SIT Non-Functional Testing Preparation Complete Theme 1 | milestone | 0d | 2025-02-28 A | 2025-02-28 A | 1426 | 100% | 2025-02-28 | 2025-02-28 | 0d |  |  | start no earlier than 2025-02-28 |  | SI Test | SIT |  | 6.15 | Complete | David O'Riordan | SITAG | COMPLETE |  |  | T2 | T2-TE-0700 |
| 1193 | 1.4.1.4.4.12 | SIT Non-Functional Testing Preparation Complete Theme 2 & 3 | milestone | 0d | 2025-03-28 A | 2025-03-28 A | 413FS+5d, 1427, 1428, 1169, 1172, 1147, 1141, 1136 | 100% | 2025-03-28 | 2025-03-28 | 0d |  |  |  |  | SI Test | SIT |  | 6.15 | Complete | David O'Riordan | SITAG | COMPLETE |  |  | T2 | T2-TE-1100 |

| ID | WBS | Task | Type | Duration | Start | Finish | Predecessors | Complete | Remaining | Actual start | Baseline start | Baseline finish | Baseline duration | Baseline 1 start | Baseline 1 finish | Total slack | Constraint | Baseline cost | Responsible | Involved | Text9 | Update Version | MHHS Resource Name | MHHS Programme Phase | Text29 | Sched Status | RAG | Artefact ID | Milestone ID | Tier | Task Status | Guidance |
| --- | --- | --- | --- | --- | --- | --- | --- | --- | --- | --- | --- | --- | --- | --- | --- | --- | --- | --- | --- | --- | --- | --- | --- | --- | --- | --- | --- | --- | --- | --- | --- | --- |
| 1194 | 1.4.1.4.5 | **SIT Operational Preparation** |  | 650d? | 2022-10-31 | 2025-04-25 |  | 98% | 10.23d? | 2024-02-01 | 2024-02-01 | 2025-01-31 | 283d | 2023-08-03 | 2025-03-10 | 694d |  | -0 | N/A | N/A | SIT | 5.0 | N/A | Systems Integration Testing (SIT) | SITAG |  |  |  |  |  |  |  |
| 1195 | 1.4.1.4.5.1 | **Test Approach & Plan** |  | 75d | 2024-02-01 A | 2024-05-15 A |  | 100% |  |  | 2024-02-01 | 2024-05-15 | 75d | 2024-02-01 | 2024-05-15 |  |  | -0 | N/A | N/A | SIT | 5.0 | N/A | Systems Integration Testing (SIT) | SITAG |  |  |  |  |  |  |  |
| 1196 | 1.4.1.4.5.1.1 | Develop document with SITWG |  | 25d | 2024-02-01 A | 2024-03-06 A |  | 100% |  |  | 2024-02-01 | 2024-03-06 | 25d | 2024-02-01 | 2024-03-06 |  | must start on 2024-02-01 |  | SI Test |  | SIT | 5.0 | Steve Evans | Systems Integration Testing (SIT) | SITAG | Complete | COMPLETE |  |  |  |  |  |
| 1197 | 1.4.1.4.5.1.2 | Draft document review with Code Bodies |  | 4d | 2024-03-21 A | 2024-03-26 A | 1196FS+10d | 100% |  |  | 2024-03-21 | 2024-03-26 | 10d | 2024-03-07 | 2024-03-20 |  |  |  | SI Test | Code Bodies | SIT | 5.0 | Steve Evans | Systems Integration Testing (SIT) | SITAG | Complete | COMPLETE |  |  |  |  |  |
| 1198 | 1.4.1.4.5.1.3 | Industry Consultation |  | 10d | 2024-03-27 A | 2024-04-09 A | 1197 | 100% |  |  | 2024-03-27 | 2024-04-09 | 10d |  |  |  |  |  | PP |  | SIT | 5.1 | Steve Evans | Systems Integration Testing (SIT) | SITAG | Complete | COMPLETE |  |  |  |  |  |
| 1199 | 1.4.1.4.5.1.4 | Artefact review (via SITAG) and updates |  | 26d | 2024-04-10 A | 2024-05-15 A | 1198 | 100% |  |  | 2024-04-10 | 2024-05-15 | 30d | 2024-03-21 | 2024-05-15 |  |  |  | SI Test | PP,IPA,Code Bodies | SIT | 5.0 | Steve Evans | Systems Integration Testing (SIT) | SITAG | Complete | COMPLETE |  |  |  |  |  |
| 1200 | 1.4.1.4.5.1.5 | SIT Operational Testing Test Approach & Plan approved | milestone | 0d | 2024-05-15 A | 2024-05-15 A | 1199 | 100% |  |  | 2024-05-15 | 2024-05-15 | 0d | 2024-05-15 | 2024-05-15 |  |  |  | SI Test | PP | SIT | 5.24 | Steve Evans | Systems Integration Testing (SIT) | SITAG | Complete | COMPLETE | MHHS-ART073 | T3-TE-0029 | T3 |  |  |
| 1201 | 1.4.1.4.5.2 | **Test Data Approach & Plan** |  | 36d | 2024-03-27 A | 2024-05-15 A |  | 100% |  |  | 2024-03-27 | 2024-05-15 | 36d | 2024-03-21 | 2024-05-15 |  |  | -0 | N/A | N/A | SIT | 5.0 | N/A | Systems Integration Testing (SIT) | SITAG |  |  |  |  |  |  |  |
| 1202 | 1.4.1.4.5.2.1 | Industry Consultation |  | 10d | 2024-03-27 A | 2024-04-09 A | 1198SS | 100% |  |  | 2024-03-27 | 2024-04-09 | 10d |  |  |  |  |  | PP |  | SIT | 5.1 | Michael Inije | Systems Integration Testing (SIT) | SITAG | Complete | COMPLETE |  |  |  |  |  |
| 1203 | 1.4.1.4.5.2.2 | Artefact review (via SITAG) and updates |  | 26d | 2024-04-10 A | 2024-05-15 A | 1202 | 100% |  |  | 2024-04-10 | 2024-05-15 | 26d | 2024-03-21 | 2024-05-15 |  |  |  | SI Test |  | SIT | 5.0 | Michael Inije | Systems Integration Testing (SIT) | SITAG | Complete | COMPLETE |  |  |  |  |  |
| 1204 | 1.4.1.4.5.2.3 | SIT Operational Testing Test Data Approach & Plan approved | milestone | 0d | 2024-05-15 A | 2024-05-15 A | 1203 | 100% |  |  | 2024-05-15 | 2024-05-15 | 0d | 2024-05-15 | 2024-05-15 |  |  |  | SI Test | PP,IPA | SIT | 5.0 | Michael Inije | Systems Integration Testing (SIT) | SITAG | Complete | COMPLETE |  |  |  |  |  |
| 1205 | 1.4.1.4.5.3 | **Theme 1 & 2 Test Cases Approved** |  | 108d | 2024-04-10 A | 2024-09-06 A |  | 100% |  |  | 2024-04-10 | 2025-01-31 | 116d | 2023-07-24 | 2024-01-17 |  |  | -0 | N/A | N/A | SIT | 6.18 | Michael Inije | Systems Integration Testing (SIT) | SITAG |  |  |  |  |  |  |  |
| 1206 | 1.4.1.4.5.3.1 | **Theme 1** |  | 108d | 2024-04-10 A | 2024-09-06 A |  | 100% |  |  | 2024-04-10 | 2024-09-06 | 96d |  |  |  |  | -0 | N/A | N/A | SIT | 6.0 | Michael Inije | Systems Integration Testing (SIT) | SITAG |  |  |  |  |  | -448.67 |  |
| 1207 | 1.4.1.4.5.3.1.1 | Develop Test Scenarios & Test Cases |  | 53d | 2024-04-10 A | 2024-06-21 A | 1198 | 100% |  |  | 2024-04-10 | 2024-06-21 | 16d |  |  |  |  |  | SI Test | SI Test, PP | SIT | 6.0 | Michael Inije |  | SITAG | Complete | COMPLETE |  |  |  |  |  |
| 1208 | 1.4.1.4.5.3.1.2 | Industry Review Workshop |  | 1d | 2024-06-24 A | 2024-06-24 A | 1207 | 100% |  |  | 2024-06-24 | 2024-06-24 | 1d |  |  |  |  |  | SI Test, PP | SI Test, PP | SIT | 6.0 | Michael Inije |  | SITAG | Complete | COMPLETE |  |  |  |  |  |
| 1209 | 1.4.1.4.5.3.1.3 | Industry Consultation Review |  | 6d | 2024-07-02 A | 2024-07-09 A | 1208FS+17d | 100% |  |  | 2024-07-02 | 2024-07-09 | 6d |  |  |  |  |  | SI Test, PP | SI Test, PP | SIT | 6.0 | Michael Inije |  | SITAG | Complete | COMPLETE |  |  |  |  |  |
| 1210 | 1.4.1.4.5.3.1.4 | Review with SIT Working Group |  | 5d | 2024-08-19 A | 2024-08-23 A | 1209FS+16d | 100% |  |  | 2024-08-19 | 2024-08-23 | 5d |  |  |  |  |  | SI Test, PP | SI Test, PP | SIT | 6.0 | Michael Inije |  | SITAG | Complete | COMPLETE |  |  |  |  |  |
| 1211 | 1.4.1.4.5.3.1.5 | SIT Operational Scenarios & Test Cases Approved - Theme 1 | milestone | 0d | 2024-09-06 A | 2024-09-06 A | 1210FS+10d | 100% |  |  | 2024-09-06 | 2024-09-06 | 0d |  |  |  | start no earlier than 2024-09-06 |  | SI Test | SI Test, PP | SIT | 6.0 | Michael Inije | Systems Integration Testing (SIT) | SITAG | Complete | COMPLETE |  | T3-TE-0117 | T3 |  | 31/7/24: baseline date change approved at esitag on 26/7/24 |
| 1212 | 1.4.1.4.5.3.2 | **Theme 2** |  | 107d | 2024-04-10 A | 2024-09-06 A |  | 100% |  |  | 2024-04-10 | 2024-09-06 | 71d |  |  |  |  |  | N/A | N/A | SIT | 6.0 | Michael Inije | Systems Integration Testing (SIT) | SITAG |  |  |  |  |  | -448.67 |  |
| 1213 | 1.4.1.4.5.3.2.1 | Develop Test Scenarios & Test Cases |  | 53d | 2024-04-10 A | 2024-06-21 A | 1198 | 100% |  |  | 2024-04-10 | 2024-06-21 | 31d |  |  |  | finish no earlier than 2024-06-21 |  | SI Test | SI Test, PP | SIT | 6.0 | Michael Inije |  | SITAG | Complete | COMPLETE |  |  |  |  |  |
| 1214 | 1.4.1.4.5.3.2.2 | Industry Review Workshop |  | 1d | 2024-06-24 A | 2024-06-24 A | 1213 | 100% |  |  | 2024-06-24 | 2024-06-24 | 1d |  |  |  |  |  | SI Test, PP | SI Test, PP | SIT | 6.0 | Michael Inije |  | SITAG | Complete | COMPLETE |  |  |  |  |  |
| 1215 | 1.4.1.4.5.3.2.3 | Industry Consultation Review |  | 6d | 2024-07-02 A | 2024-07-09 A | 1214FS+7d | 100% |  |  | 2024-07-02 | 2024-07-09 | 6d |  |  |  |  |  | SI Test, PP | SI Test, PP | SIT | 6.0 | Michael Inije |  | SITAG | Complete | COMPLETE |  |  |  |  |  |
| 1216 | 1.4.1.4.5.3.2.4 | Review with SIT Working Group |  | 5d | 2024-08-19 A | 2024-08-23 A | 1215FS+11d | 100% |  |  | 2024-08-19 | 2024-08-23 | 5d |  |  |  |  |  | SI Test, PP | SI Test, PP | SIT | 6.0 | Michael Inije |  | SITAG | Complete | COMPLETE |  |  |  |  |  |
| 1217 | 1.4.1.4.5.3.2.5 | SIT Operational Scenarios & Test Cases Approved - Theme 2 | milestone | 0d | 2024-09-06 A | 2024-09-06 A | 1216FS+10d | 100% |  |  | 2024-09-06 | 2024-09-06 | 0d |  |  |  |  |  | SI Test | SI Test, PP | SIT | 6.0 | Michael Inije | Systems Integration Testing (SIT) | SITAG | Complete | COMPLETE |  | T3-TE-0118 | T3 |  |  |

| ID | WBS | Task | Type | Duration | Start | Finish | Predecessors | Complete | Actual start | Baseline start | Baseline finish | Baseline duration | Baseline 1 start | Baseline 1 finish | Constraint | Baseline cost | Responsible | Involved | Text9 | Update Version | MHHS Resource Name | MHHS Programme Phase | Text29 | Sched Status | RAG | Task Status | Milestone ID | Tier |
| --- | --- | --- | --- | --- | --- | --- | --- | --- | --- | --- | --- | --- | --- | --- | --- | --- | --- | --- | --- | --- | --- | --- | --- | --- | --- | --- | --- | --- |
| 1218 | 1.4.1.4.5.4 | **Environments (SIT B)** |  | 0d | 2024-10-07 A | 2024-10-07 A |  | 100% |  | 2024-10-07 | 2024-10-07 | 0d | 2024-09-03 | 2024-09-09 |  | -0 | N/A | N/A | SIT | 5.31 | Heath Thomas | Systems Integration Testing (SIT) | SITAG |  |  |  |  |  |
| 1219 | 1.4.1.4.5.4.1 | **PP Environments (SIT B)** |  | 0d | 2024-10-07 A | 2024-10-07 A |  | 100% |  | 2024-10-07 | 2024-10-07 | 0d | 2024-09-03 | 2024-09-09 |  | -0 | N/A | N/A | SIT | 5.31 | Heath Thomas | Systems Integration Testing (SIT) | SITAG |  |  |  |  |  |
| 1220 | 1.4.1.4.5.4.1.1 | Deployment of MHHS solution code to SIT B environments | milestone | 0d | 2024-10-07 A | 2024-10-07 A | 141 | 100% |  | 2024-10-07 | 2024-10-07 | 0d | 2024-09-03 | 2024-09-09 | start no earlier than 2024-08-27 |  | PP | SI Test | SIT | 5.31 | Heath Thomas | Systems Integration Testing (SIT) | SITAG | Complete | COMPLETE |  |  |  |
| 1221 | 1.4.1.4.5.4.2 | **SI Environments (SIT B)** |  | 0d | 2024-10-07 A | 2024-10-07 A |  | 100% |  | 2024-10-07 | 2024-10-07 | 0d | 2024-09-03 | 2024-09-09 |  | -0 | N/A | N/A | SIT | 5.31 | Heath Thomas | Systems Integration Testing (SIT) | SITAG |  |  |  |  |  |
| 1222 | 1.4.1.4.5.4.2.1 | Coordinate deployment of MHHS solution code to SIT Participants' SIT B environments | milestone | 0d | 2024-10-07 A | 2024-10-07 A | 1220SS | 100% |  | 2024-10-07 | 2024-10-07 | 0d | 2024-09-03 | 2024-09-09 |  |  | SI Test | PP | SIT | 5.31 | Heath Thomas | Systems Integration Testing (SIT) | SITAG | Complete | COMPLETE |  |  |  |
| 1223 | 1.4.1.4.5.5 | **SIT Operations Manual** |  | 590d? | 2022-10-31 | 2025-01-31 A |  | 100% | 2024-08-01 | 2022-10-31 | 2025-01-31 | 0d |  |  |  |  | Helix |  | SIT | 6.13 | Helix |  |  |  |  | -755.67 |  |  |
| 1224 | 1.4.1.4.5.5.1 | **Version 1 SIT Operations Manual** |  | 35d | 2024-10-07 A | 2024-11-22 A |  | 100% |  | 2024-10-07 | 2024-11-22 | 0d |  |  |  |  | Helix |  | SIT | 6.13 | Helix |  |  |  |  | -755.67 |  |  |
| 1225 | 1.4.1.4.5.5.1.1 | Creation of SIT Operations Manual Template |  | 8d | 2024-10-07 A | 2024-10-16 A |  | 100% |  | 2024-10-07 | 2024-10-16 | 0d |  |  | start no earlier than 2024-10-07 |  | Helix |  | SIT | 6.13 | Helix |  |  | Complete | COMPLETE |  |  |  |
| 1226 | 1.4.1.4.5.5.1.2 | November TORWG Paper Day | milestone | 0d | 2024-11-07 A | 2024-11-07 A | 1225FS+16d | 100% |  | 2024-11-07 | 2024-11-07 | 0d |  |  |  |  | Helix |  | SIT | 6.13 | Helix |  |  | Complete | COMPLETE |  |  |  |
| 1227 | 1.4.1.4.5.5.1.3 | November TORWG (Timeline and Next Steps for SIT Operations Manual) | milestone | 0d | 2024-11-14 A | 2024-11-14 A | 1226FS+5d | 100% |  | 2024-11-14 | 2024-11-14 | 0d |  |  |  |  | Helix |  | SIT | 6.13 | Helix |  |  | Complete | COMPLETE |  |  |  |
| 1228 | 1.4.1.4.5.5.1.4 | SIT Operations Manual Version 1 Shared with MHHSP | milestone | 0d | 2024-11-11 A | 2024-11-11 A | 1225FS+18d | 100% |  | 2024-11-11 | 2024-11-11 | 0d |  |  |  |  | Helix |  | SIT | 6.13 | Helix |  |  | Complete | COMPLETE |  |  |  |
| 1229 | 1.4.1.4.5.5.1.5 | MHHSP provide feedback on SIT Operations Manual Version 1 |  | 9d | 2024-11-12 A | 2024-11-22 A | 1228 | 100% |  | 2024-11-12 | 2024-11-22 | 0d |  |  |  |  | Helix |  | SIT | 6.13 | Helix |  |  | Complete | COMPLETE |  |  |  |
| 1230 | 1.4.1.4.5.5.1.6 | SIT Operations Manual Version 1 Shared with Programme Participants | milestone | 0d | 2024-11-13 A | 2024-11-13 A | 1225FS+20d | 100% |  | 2024-11-13 | 2024-11-13 | 0d |  |  |  |  | Helix |  | SIT | 6.13 | Helix |  |  | Complete | COMPLETE |  |  |  |
| 1231 | 1.4.1.4.5.5.1.7 | PPs provide feedback on SIT Operations Manual Version 1 |  | 7d | 2024-11-14 A | 2024-11-22 A | 1230 | 100% |  | 2024-11-14 | 2024-11-22 | 0d |  |  |  |  | Helix |  | SIT | 6.13 | Helix |  |  | Complete | COMPLETE |  |  |  |
| 1232 | 1.4.1.4.5.5.1.8 | Programme Participants and MHHSP Feedback and Actions Received (SIT Ops Manual Version 1) | milestone | 0d | 2024-11-22 A | 2024-11-22 A | 1231, 1229 | 100% |  | 2024-11-22 | 2024-11-22 | 0d |  |  |  |  | Helix |  | SIT | 6.13 | Helix |  |  | Complete | COMPLETE |  |  |  |
| 1233 | 1.4.1.4.5.5.2 | **Version 2 SIT Operations Manual** |  | 27d | 2024-11-12 A | 2024-12-18 A |  | 100% |  | 2024-11-12 | 2024-12-18 | 0d |  |  |  |  | Helix |  | SIT | 6.13 | Helix |  |  |  |  | -755.67 |  |  |
| 1234 | 1.4.1.4.5.5.2.1 | Version 2 SIT Operations Manual (Composition) |  | 12d | 2024-11-12 A | 2024-11-27 A | 1226FS+2d | 100% |  | 2024-11-12 | 2024-11-27 | 0d |  |  |  |  | Helix |  | SIT | 6.13 | Helix |  |  | Complete | COMPLETE |  |  |  |
| 1235 | 1.4.1.4.5.5.2.2 | Version 2 SIT Operations Manual Completed | milestone | 0d | 2024-11-27 A | 2024-11-27 A | 1234 | 100% |  | 2024-11-27 | 2024-11-27 | 0d |  |  |  |  | Helix |  | SIT | 6.13 | Helix |  | MCAG | Complete | COMPLETE |  | T3-TE-0132 | T3 |
| 1236 | 1.4.1.4.5.5.2.3 | Version 2 SIT Operations Manual Shared with MHHSP & PPs for TORWG (Consultation Starts) | milestone | 0d | 2024-11-27 A | 2024-11-27 A | 1235 | 100% |  | 2024-11-27 | 2024-11-27 | 0d |  |  |  |  | Helix |  | SIT | 6.13 | Helix |  |  | Complete | COMPLETE |  |  |  |
| 1237 | 1.4.1.4.5.5.2.4 | Version 2 SIT Ops Manual - PP Consultation (Iterative Feedback Process) |  | 10d | 2024-11-28 A | 2024-12-11 A | 1236 | 100% |  | 2024-11-28 | 2024-12-11 | 0d |  |  |  |  | Helix |  | SIT | 6.13 | Helix |  |  | Complete | COMPLETE |  |  |  |
| 1238 | 1.4.1.4.5.5.2.5 | Version 2 SIT Ops Manual - PP Consultation Completed | milestone | 0d | 2024-12-11 A | 2024-12-11 A | 1237 | 100% |  | 2024-12-11 | 2024-12-11 | 0d |  |  |  |  | Helix |  | SIT | 6.13 | Helix |  |  | Complete | COMPLETE |  |  |  |
| 1239 | 1.4.1.4.5.5.2.6 | December TORWG Paper Day | milestone | 0d | 2024-12-04 A | 2024-12-04 A | 1234FS+5d | 100% |  | 2024-12-04 | 2024-12-04 | 0d |  |  |  |  | Helix |  | SIT | 6.13 | Helix |  |  | Complete | COMPLETE |  |  |  |
| 1240 | 1.4.1.4.5.5.2.7 | December TORWG (Initial Feedback, Common Themes and Comments) | milestone | 0d | 2024-12-11 A | 2024-12-11 A | 1239FS+5d | 100% |  | 2024-12-11 | 2024-12-11 | 0d |  |  |  |  | Helix |  | SIT | 6.13 | Helix |  |  | Complete | COMPLETE |  |  |  |
| 1241 | 1.4.1.4.5.5.2.8 | December Extraordinary TORWG Paper Day | milestone | 0d | 2024-12-11 A | 2024-12-11 A | 1238 | 100% |  | 2024-12-11 | 2024-12-11 | 0d |  |  |  |  | Helix |  | SIT | 6.13 | Helix |  |  | Complete | COMPLETE |  |  |  |
| 1242 | 1.4.1.4.5.5.2.9 | Publication of key themes from consultation to eTORWG |  | 2d | 2024-12-12 A | 2024-12-13 A | 1241 | 100% |  | 2024-12-12 | 2024-12-13 | 0d |  |  |  |  | Helix |  | SIT | 6.14 |  |  |  | Complete | COMPLETE |  |  |  |
| 1243 | 1.4.1.4.5.5.2.10 | December Extraordinary TORWG (Summary of Version 2 Feedback and Response Approach Shared with PPs) | milestone | 0d | 2024-12-18 A | 2024-12-18 A | 1242FS+3d | 100% |  | 2024-12-18 | 2024-12-18 | 0d |  |  |  |  | Helix |  | SIT | 6.13 | Helix |  |  | Complete | COMPLETE |  |  |  |

| ID | WBS | Task | Type | Duration | Start | Finish | Predecessors | Complete | Actual start | Actual finish | Baseline start | Baseline finish | Baseline duration | Constraint | Responsible | Text9 | Task Status | Update Version | MHHS Resource Name | Sched Status | RAG | Milestone ID | Text29 | Tier |
| --- | --- | --- | --- | --- | --- | --- | --- | --- | --- | --- | --- | --- | --- | --- | --- | --- | --- | --- | --- | --- | --- | --- | --- | --- |
| 1244 | 1.4.1.4.5.5.3 | **Version 3 (Final) SIT Operations Manual** |  | 44d | 2024-11-28 A | 2025-01-28 A |  | 100% |  |  | 2024-11-28 | 2025-01-28 | 0d |  | Helix | SIT | -755.67 | 6.13 | Helix |  |  |  |  |  |
| 1245 | 1.4.1.4.5.5.3.1 | Update SIT Operations Manual (Final) Version 3 (with Comments Received From Version 2) [Pre-Christmas Furlough] |  | 17d | 2024-11-28 A | 2024-12-20 A | 1235, 193FF | 100% |  |  | 2024-11-28 | 2024-12-20 | 0d |  | Helix | SIT |  | 6.13 | Helix | Complete | COMPLETE |  |  |  |
| 1246 | 1.4.1.4.5.5.3.2 | Update SIT Operations Manual (Final) Version 3 (with Comments Received From Version 2) [Post-Christmas Furlough] |  | 5d | 2025-01-02 A | 2025-01-08 A | 1245FS+8d | 100% |  |  | 2025-01-02 | 2025-01-08 | 0d |  | Helix | SIT |  | 6.13 | Helix | Complete | COMPLETE |  |  |  |
| 1247 | 1.4.1.4.5.5.3.3 | SIT Operations Manual (Final) Version 3 Completed | milestone | 0d | 2025-01-08 A | 2025-01-08 A | 1246 | 100% |  |  | 2025-01-08 | 2025-01-08 | 0d |  | Helix | SIT |  | 6.13 | Helix | Complete | COMPLETE | T3-TE-0133 | MCAG | T3 |
| 1248 | 1.4.1.4.5.5.3.4 | January TORWG Paper Day | milestone | 0d | 2025-01-08 A | 2025-01-08 A | 1247 | 100% |  |  | 2025-01-08 | 2025-01-08 | 0d |  | Helix | SIT |  | 6.13 | Helix | Complete | COMPLETE |  |  |  |
| 1249 | 1.4.1.4.5.5.3.5 | January TORWG (SIT Operations Manual Agreement) [Assurance Meeting] | milestone | 0d | 2025-01-15 A | 2025-01-15 A | 1248FS+5d | 100% |  |  | 2025-01-15 | 2025-01-15 | 0d |  | Helix | SIT |  | 6.13 | Helix | Complete | COMPLETE |  |  |  |
| 1250 | 1.4.1.4.5.5.3.6 | January MCAG Paper Day (Final SIT Operations Manual Submitted) | milestone | 0d | 2025-01-21 A | 2025-01-21 A | 1249FS+4d | 100% |  |  | 2025-01-21 | 2025-01-21 | 0d |  | Helix | SIT |  | 6.13 | Helix | Complete | COMPLETE |  |  |  |
| 1251 | 1.4.1.4.5.5.3.7 | January MCAG (Final SIT Operations Manual Endorsement) [Advisory Group Sign-off] | milestone | 0d | 2025-01-28 A | 2025-01-28 A | 1250FS+5d | 100% |  |  | 2025-01-28 | 2025-01-28 | 0d |  | Helix | SIT |  | 6.13 | Helix | Complete | COMPLETE | T3-TE-0135 | MCAG | T3 |
| 1252 | 1.4.1.4.5.5.4 | **Elexon / Helix Service Now Test Prep** |  | 119d? | 2024-08-01 A | 2025-01-14 A |  | 100% |  |  | 2024-07-15 | 2025-01-31 | 0d |  | Helix | SIT | -688.67 | 6.13 | Helix |  |  |  |  |  |
| 1253 | 1.4.1.4.5.5.4.1 | **Incident Management Build** |  | 75d? | 2024-08-05 A | 2024-11-15 A |  | 100% |  |  | 2024-08-05 | 2024-11-15 | 0d |  | Helix | SIT | -728.67 | 6.13 | Helix |  |  |  |  |  |
| 1254 | 1.4.1.4.5.5.4.1.1 | Build |  | 40d | 2024-08-05 A | 2024-09-27 A |  | 100% |  |  | 2024-09-27 | 2024-09-27 | 0d | finish no earlier than 2024-09-27 | Helix | SIT |  | 6.13 | Helix | Complete | COMPLETE |  |  |  |
| 1255 | 1.4.1.4.5.5.4.1.2 | Test |  | 15d | 2024-09-30 A | 2024-10-18 A | 1254 | 100% |  |  | 2024-10-18 | 2024-10-18 | 0d | finish no earlier than 2024-10-18 | Helix | SIT |  | 6.13 | Helix | Complete | COMPLETE |  |  |  |
| 1256 | 1.4.1.4.5.5.4.1.3 | Deploy |  | 20d | 2024-10-21 A | 2024-11-15 A | 1255 | 100% |  |  | 2024-11-15 | 2024-11-15 | 0d | finish no earlier than 2024-11-15 | Helix | SIT |  | 6.13 | Helix | Complete | COMPLETE |  |  |  |
| 1257 | 1.4.1.4.5.5.4.1.4 | Incident Management Build & Configuration Complete | milestone | 0d | 2024-11-15 A | 2024-11-15 A | 1256 | 100% |  |  | 2024-11-15 | 2024-11-15 | 0d |  | Helix | SIT |  | 6.13 | Helix | Complete | COMPLETE |  |  |  |
| 1258 | 1.4.1.4.5.5.4.2 | **Major Incident Management Build & Configuration** |  | 0d? | 2024-11-15 | 2024-11-15 |  | 100% | 2024-10-02 | 2025-01-14 | 2024-10-02 | 2025-01-14 | 0d |  | Helix | SIT | -728.67 | 6.13 | Helix |  |  |  |  |  |
| 1259 | 1.4.1.4.5.5.4.2.1 | Build |  | 40d | 2024-10-02 A | 2024-11-26 A |  | 100% |  |  | 2024-11-26 | 2024-11-26 | 0d | finish no earlier than 2024-11-26 | Helix | SIT |  | 6.13 | Helix | Complete | COMPLETE |  |  |  |
| 1260 | 1.4.1.4.5.5.4.2.2 | Test |  | 15d | 2024-11-27 A | 2024-12-17 A | 1259 | 100% |  |  | 2024-12-17 | 2024-12-17 | 0d | finish no earlier than 2024-12-17 | Helix | SIT |  | 6.13 | Helix | Complete | COMPLETE |  |  |  |
| 1261 | 1.4.1.4.5.5.4.2.3 | Deploy |  | 20d | 2024-12-18 A | 2025-01-14 A | 1260 | 100% |  |  | 2025-01-14 | 2025-01-14 | 0d | finish no earlier than 2025-01-14 | Helix | SIT |  | 6.13 | Helix | Complete | COMPLETE |  |  |  |
| 1262 | 1.4.1.4.5.5.4.2.4 | Major Incident Management Build & Configuration Complete | milestone | 0d | 2025-01-14 A | 2025-01-14 A | 1261 | 100% |  |  | 2025-01-14 | 2025-01-14 | 0d |  | Helix | SIT |  | 6.13 | Helix | Complete | COMPLETE |  |  |  |
| 1263 | 1.4.1.4.5.5.4.3 | **Knowledge Management Build & Configuration** |  | 75d? | 2024-10-02 A | 2025-01-14 A |  | 100% |  |  | 2024-10-02 | 2025-01-14 | 0d |  | Helix | SIT | -728.67 | 6.13 | Helix |  |  |  |  |  |
| 1264 | 1.4.1.4.5.5.4.3.1 | Build |  | 40d | 2024-10-02 A | 2024-11-26 A |  | 100% |  |  | 2024-11-26 | 2024-11-26 | 0d | finish no earlier than 2024-11-26 | Helix | SIT |  | 6.13 | Helix | Complete | COMPLETE |  |  |  |
| 1265 | 1.4.1.4.5.5.4.3.2 | Test |  | 15d | 2024-11-27 A | 2024-12-17 A | 1264 | 100% |  |  | 2024-12-17 | 2024-12-17 | 0d | finish no earlier than 2024-12-17 | Helix | SIT |  | 6.13 | Helix | Complete | COMPLETE |  |  |  |
| 1266 | 1.4.1.4.5.5.4.3.3 | Deploy |  | 20d | 2024-12-18 A | 2025-01-14 A | 1265 | 100% |  |  | 2025-01-14 | 2025-01-14 | 0d | finish no earlier than 2025-01-14 | Helix | SIT |  | 6.13 | Helix | Complete | COMPLETE |  |  |  |
| 1267 | 1.4.1.4.5.5.4.3.4 | Knowledge Management Build & Configuration Complete | milestone | 0d | 2025-01-14 A | 2025-01-14 A | 1266 | 100% |  |  | 2025-01-14 | 2025-01-14 | 0d |  | Helix | SIT |  | 6.13 | Helix | Complete | COMPLETE |  |  |  |

| ID | WBS | Task | Type | Duration | Start | Finish | Predecessors | Complete | Actual start | Actual finish | Baseline start | Baseline finish | Baseline duration | Constraint | Responsible | Text9 | Task Status | Update Version | MHHS Resource Name | Sched Status | RAG | Milestone ID | Text29 | Tier |
| --- | --- | --- | --- | --- | --- | --- | --- | --- | --- | --- | --- | --- | --- | --- | --- | --- | --- | --- | --- | --- | --- | --- | --- | --- |
| 1268 | 1.4.1.4.5.5.4.4 | **Problem Management Build & Configuration** |  | 1d? | 2024-08-01 | 2024-08-01 |  | 100% | 2024-10-02 | 2025-01-14 | 2024-10-02 | 2025-01-14 | 0d |  | Helix | SIT | -728.67 | 6.13 | Helix |  |  |  |  |  |
| 1269 | 1.4.1.4.5.5.4.4.1 | Build |  | 40d | 2024-10-02 A | 2024-11-26 A |  | 100% |  |  | 2024-11-26 | 2024-11-26 | 0d | finish no earlier than 2024-11-26 | Helix | SIT |  | 6.13 | Helix | Complete | COMPLETE |  |  |  |
| 1270 | 1.4.1.4.5.5.4.4.2 | Test |  | 15d | 2024-11-27 A | 2024-12-17 A | 1269 | 100% |  |  | 2024-12-17 | 2024-12-17 | 0d | finish no earlier than 2024-12-17 | Helix | SIT |  | 6.13 | Helix | Complete | COMPLETE |  |  |  |
| 1271 | 1.4.1.4.5.5.4.4.3 | Deploy |  | 20d | 2024-12-18 A | 2025-01-14 A | 1270 | 100% |  |  | 2025-01-14 | 2025-01-14 | 0d | finish no earlier than 2025-01-14 | Helix | SIT |  | 6.13 | Helix | Complete | COMPLETE |  |  |  |
| 1272 | 1.4.1.4.5.5.4.4.4 | Problem Management Build & Configuration Complete | milestone | 0d | 2025-01-14 A | 2025-01-14 A | 1271 | 100% |  |  | 2025-01-14 | 2025-01-14 | 0d | start no earlier than 2025-01-14 | Helix | SIT |  | 6.13 | Helix | Complete | COMPLETE |  |  |  |
| 1273 | 1.4.1.4.5.5.4.5 | **Change Management Build & Configuration** |  | 75d? | 2024-10-02 A | 2025-01-14 A |  | 100% |  |  | 2024-10-02 | 2025-01-14 | 0d |  | Helix | SIT | -728.67 | 6.13 | Helix |  |  |  |  |  |
| 1274 | 1.4.1.4.5.5.4.5.1 | Build |  | 40d | 2024-10-02 A | 2024-11-26 A |  | 100% |  |  | 2024-11-26 | 2024-11-26 | 0d | finish no earlier than 2024-11-26 | Helix | SIT |  | 6.13 | Helix | Complete | COMPLETE |  |  |  |
| 1275 | 1.4.1.4.5.5.4.5.2 | Test |  | 15d | 2024-11-27 A | 2024-12-17 A | 1274 | 100% |  |  | 2024-12-17 | 2024-12-17 | 0d | finish no earlier than 2024-12-17 | Helix | SIT |  | 6.13 | Helix | Complete | COMPLETE |  |  |  |
| 1276 | 1.4.1.4.5.5.4.5.3 | Deploy |  | 20d | 2024-12-18 A | 2025-01-14 A | 1275 | 100% |  |  | 2025-01-14 | 2025-01-14 | 0d | finish no earlier than 2025-01-14 | Helix | SIT |  | 6.13 | Helix | Complete | COMPLETE |  |  |  |
| 1277 | 1.4.1.4.5.5.4.5.4 | Change Management Build & Configuration Complete | milestone | 0d | 2025-01-14 A | 2025-01-14 A | 1276 | 100% |  |  | 2025-01-14 | 2025-01-14 | 0d | start no earlier than 2025-01-14 | Helix | SIT |  | 6.13 | Helix | Complete | COMPLETE |  |  |  |
| 1278 | 1.4.1.4.5.5.4.6 | **Service Catalogue Management Build & Configuration** |  | 75d? | 2024-10-02 A | 2025-01-14 A |  | 100% |  |  | 2024-10-02 | 2025-01-14 | 0d |  | Helix | SIT | -728.67 | 6.13 | Helix |  |  |  |  |  |
| 1279 | 1.4.1.4.5.5.4.6.1 | Build |  | 40d | 2024-10-02 A | 2024-11-26 A |  | 100% |  |  | 2024-11-26 | 2024-11-26 | 0d | finish no earlier than 2024-11-26 | Helix | SIT |  | 6.13 | Helix | Complete | COMPLETE |  |  |  |
| 1280 | 1.4.1.4.5.5.4.6.2 | Test |  | 15d | 2024-11-27 A | 2024-12-17 A | 1279 | 100% |  |  | 2024-12-17 | 2024-12-17 | 0d | finish no earlier than 2024-12-17 | Helix | SIT |  | 6.13 | Helix | Complete | COMPLETE |  |  |  |
| 1281 | 1.4.1.4.5.5.4.6.3 | Deploy |  | 20d | 2024-12-18 A | 2025-01-14 A | 1280 | 100% |  |  | 2025-01-14 | 2025-01-14 | 0d | finish no earlier than 2025-01-14 | Helix | SIT |  | 6.13 | Helix | Complete | COMPLETE |  |  |  |
| 1282 | 1.4.1.4.5.5.4.6.4 | Service Catalogue Management Build & Configuration Complete | milestone | 0d | 2025-01-14 A | 2025-01-14 A | 1281 | 100% |  |  | 2025-01-14 | 2025-01-14 | 0d | start no earlier than 2025-01-14 | Helix | SIT |  | 6.13 | Helix | Complete | COMPLETE |  |  |  |
| 1283 | 1.4.1.4.5.5.4.7 | ServiceNow SIT Ops Available | milestone | 0d? | 2025-01-14 A | 2025-01-14 A | 1257, 1262, 1267, 1272, 1277, 1282 | 100% |  |  | 2025-01-14 | 2025-01-14 | 0d | start no earlier than 2024-09-09 | Helix | SIT |  | 6.13 | Helix | Complete | COMPLETE | T3-TE-0136 | SITAG | T3 |
| 1284 | 1.4.1.4.5.5.4.8 | **Helix Service Management Documentation (Service Design Pack)** |  | 115d | 2024-08-01 A | 2025-01-08 A |  | 100% |  |  | 2024-09-09 | 2025-01-31 | 0d |  | Helix | SIT | -49.67 | 6.0 | Helix |  |  |  |  |  |
| 1285 | 1.4.1.4.5.5.4.8.1 | Document Drafting |  | 95d | 2024-08-01 A | 2024-12-11 A |  | 100% |  |  | 2024-08-01 | 2024-12-11 | 0d | finish no earlier than 2024-12-11 | Helix | SIT |  | 6.11 | Helix | Complete | COMPLETE |  |  |  |
| 1286 | 1.4.1.4.5.5.4.8.2 | Internal Elexon Review |  | 3d | 2025-01-06 A | 2025-01-08 A | 1285 | 100% |  |  | 2024-12-12 | 2024-12-16 | 0d | finish no earlier than 2024-12-16 | Helix | SIT |  | 6.11 | Helix | Complete | COMPLETE |  |  |  |
| 1287 | 1.4.1.4.5.5.4.8.3 | Elexon Service Panel Sign off | milestone | 0d | 2025-01-08 A | 2025-01-08 A | 1286 | 100% |  |  | 2024-12-20 | 2024-12-20 | 0d | start no earlier than 2024-12-20 | Helix | SIT |  | 6.11 | Helix | Complete | COMPLETE |  |  |  |
| 1288 | 1.4.1.4.5.5.5 | **Incident Management Support** |  | 1d? | 2022-10-31 | 2022-10-31 |  | 100% | 2024-12-02 | 2025-01-17 | 2022-10-31 | 2022-10-31 | 0d |  | Helix | SIT | -755.67 | 6.13 | Helix |  | 25d |  |  |  |
| 1289 | 1.4.1.4.5.5.5.1 | Identify Relevant Stakeholders to Support Incident Management Process |  | 10d | 2024-12-02 A | 2024-12-13 A |  | 100% |  |  | 2024-11-18 | 2024-11-29 | 0d | start no earlier than 2024-12-02 | Helix | SIT |  | 6.13 | Helix | Complete | COMPLETE |  |  |  |
| 1290 | 1.4.1.4.5.5.5.2 | Schedule Time to Upskill Stakeholders |  | 5d | 2024-12-16 A | 2024-12-20 A | 1289 | 100% |  |  | 2024-12-02 | 2024-12-06 | 0d |  | Helix | SIT |  | 6.13 | Helix | Complete | COMPLETE |  |  |  |
| 1291 | 1.4.1.4.5.5.5.3 | Helix Stakeholders Attendance at MHHS Defect Triage Meetings [Meeting Dates to be Confirmed] |  | 10d | 2025-01-06 A | 2025-01-17 A | 1290FS+10d | 100% |  |  | 2024-12-09 | 2024-12-20 | 0d |  | Helix | SIT |  | 6.13 | Helix | Complete | COMPLETE |  |  |  |
| 1292 | 1.4.1.4.5.5.6 | SIT Service Readiness (Elexon & Helix) Completed | milestone | 0d | 2025-01-17 A | 2025-01-17 A | 1291 | 100% |  |  | 2024-12-20 | 2024-12-20 | 0d |  | Helix | SIT |  | 6.13 | Helix | Complete | COMPLETE |  |  |  |

| ID | WBS | Task | Type | Duration | Start | Finish | Predecessors | Complete | Actual start | Actual finish | Baseline start | Baseline finish | Baseline duration | Constraint | Responsible | Text9 | Update Version | MHHS Resource Name | Sched Status | RAG | Task Status | Milestone ID | Text29 | Tier |
| --- | --- | --- | --- | --- | --- | --- | --- | --- | --- | --- | --- | --- | --- | --- | --- | --- | --- | --- | --- | --- | --- | --- | --- | --- |
| 1293 | 1.4.1.4.5.5.7 | **SIT Service Readiness (External Parties)** |  | 85d | 2024-10-07 A | 2025-01-31 A |  | 100% |  |  | 2024-09-30 | 2025-01-06 | 0d |  | Helix | SIT | 6.13 | Helix |  |  |  |  |  |  |
| 1294 | 1.4.1.4.5.5.7.1 | **Helix Engagement & Comms** |  | 71d | 2024-10-07 A | 2025-01-13 A |  | 100% |  |  | 2024-09-30 | 2025-01-06 | 0d |  | Helix | SIT | 6.13 | Helix | Green |  |  |  |  |  |
| 1295 | 1.4.1.4.5.5.7.1.1 | Engagement Execution |  | 71d | 2024-10-07 A | 2025-01-13 A |  | 100% |  |  | 2024-10-07 | 2025-01-06 | 0d | finish no earlier than 2025-01-13 | Helix | SIT | 6.13 | Helix | Complete | COMPLETE |  |  |  |  |
| 1296 | 1.4.1.4.5.5.7.1.2 | Information Gathering |  | 32d | 2024-11-29 A | 2025-01-13 A |  | 100% |  |  | 2024-10-31 | 2024-11-27 | 0d | finish no earlier than 2025-01-13 | Helix | SIT | 6.13 | Helix | Complete | COMPLETE |  |  |  |  |
| 1297 | 1.4.1.4.5.5.7.1.3 | SIT Participants Preparation |  | 9d | 2024-11-28 A | 2024-12-10 A |  | 100% |  |  | 2024-11-22 | 2025-01-06 | 0d | start no earlier than 2024-11-28 | Helix | SIT | 6.13 | Helix | Complete | COMPLETE |  |  |  |  |
| 1298 | 1.4.1.4.5.5.7.2 | SIT Service Readiness (External Parties) Completed | milestone | 0d | 2025-01-31 A | 2025-01-31 A | 1295FS+9d, 1296, 1297, 1315 | 100% |  |  | 2025-01-06 | 2025-01-06 | 0d |  | Helix | SIT | 6.13 | Helix | Complete | COMPLETE |  |  |  |  |
| 1299 | 1.4.1.4.5.5.8 | **ServiceNow Support Portal Onboarding (Helix Suppliers & SIT Participants)** |  | 78d? | 2024-10-02 A | 2025-01-17 |  | 100% |  | 2025-01-31 | 2024-10-02 | 2025-01-17 | 0d |  | Helix | SIT | 6.13 | Helix |  |  | -755.67 |  |  |  |
| 1300 | 1.4.1.4.5.5.8.1 | **ServiceNow Portal Preparation and Planning** |  | 40d? | 2024-10-02 A | 2024-11-26 A |  | 100% |  |  | 2024-10-02 | 2024-11-26 | 0d |  | Helix | SIT | 6.13 | Helix |  |  | -755.67 |  |  |  |
| 1301 | 1.4.1.4.5.5.8.1.1 | Define Supplier Requirements |  | 30d? | 2024-10-02 A | 2024-11-12 A |  | 100% |  |  | 2024-10-02 | 2024-11-12 | 0d | start no earlier than 2024-10-02 | Helix | SIT | 6.13 | Helix | Complete | COMPLETE |  |  |  |  |
| 1302 | 1.4.1.4.5.5.8.1.2 | Determine Supplier ServiceNow modules |  | 10d? | 2024-11-13 A | 2024-11-26 A | 1301 | 100% |  |  | 2024-11-13 | 2024-11-26 | 0d | finish no earlier than 2024-11-26 | Helix | SIT | 6.13 | Helix | Complete | COMPLETE |  |  |  |  |
| 1303 | 1.4.1.4.5.5.8.1.3 | Review compliance requirements, including data privacy and access limitations. |  | 10d? | 2024-11-13 A | 2024-11-26 A | 1301 | 100% |  |  | 2024-11-13 | 2024-11-26 | 0d | finish no earlier than 2024-11-26 | Helix | SIT | 6.13 | Helix | Complete | COMPLETE |  |  |  |  |
| 1304 | 1.4.1.4.5.5.8.1.4 | Conduct a security assessment to ensure the supplier complies with organisational policies. |  | 10d? | 2024-11-13 A | 2024-11-26 A | 1301 | 100% |  |  | 2024-11-13 | 2024-11-26 | 0d | finish no earlier than 2024-11-26 | Helix | SIT | 6.13 | Helix | Complete | COMPLETE |  |  |  |  |
| 1305 | 1.4.1.4.5.5.8.2 | **ServiceNow Portal System Configuration** |  | 48d? | 2024-11-27 A | 2025-01-31 A |  | 100% |  |  | 2024-11-27 | 2025-01-07 | 0d |  | Helix | SIT | 6.13 | Helix |  |  | -755.67 |  |  |  |
| 1306 | 1.4.1.4.5.5.8.2.1 | Create Supplier User Accounts |  | 48d | 2024-11-27 A | 2025-01-31 A | 1304 | 100% |  |  | 2024-11-27 | 2024-12-10 | 0d | finish no earlier than 2025-01-31 | Helix | SIT | 6.13 | Helix | Complete | COMPLETE |  |  |  |  |
| 1307 | 1.4.1.4.5.5.8.2.2 | Assign appropriate access based on the supplier’s needs and security requirements (e.g., read-only access, submit requests, etc.). |  | 25d? | 2024-12-30 A | 2025-01-31 A | 1306FF | 100% |  |  | 2024-12-11 | 2024-12-24 | 0d | finish no earlier than 2024-12-24 | Helix | SIT | 6.13 | Helix | Complete | COMPLETE |  |  |  |  |
| 1308 | 1.4.1.4.5.5.8.2.3 | Configure Access Controls |  | 25d? | 2024-12-30 A | 2025-01-31 A | 1307FF | 100% |  |  | 2024-12-25 | 2025-01-07 | 0d | finish no earlier than 2025-01-07 | Helix | SIT | 6.13 | Helix | Complete | COMPLETE |  |  |  |  |
| 1309 | 1.4.1.4.5.5.8.3 | **ServiceNow Portal Training and Documentation** |  | 20d? | 2025-01-06 A | 2025-01-31 A |  | 100% |  |  | 2025-01-06 | 2025-01-10 | 0d |  | Helix | SIT | 6.13 | Helix |  |  | -755.67 |  |  |  |
| 1310 | 1.4.1.4.5.5.8.3.1 | Provide Training to the Supplier |  | 1d | 2025-01-31 A | 2025-01-31 A |  | 100% |  |  | 2025-01-06 | 2025-01-10 | 0d | finish no earlier than 2025-01-31 | Helix | SIT | 6.13 | Helix | Complete | COMPLETE |  |  |  |  |
| 1311 | 1.4.1.4.5.5.8.3.2 | Create Supplier Training Documentation |  | 20d | 2025-01-06 A | 2025-01-31 A |  | 100% |  |  | 2025-01-06 | 2025-01-10 | 0d | finish no earlier than 2025-01-31 | Helix | SIT | 6.13 | Helix | Complete | COMPLETE |  |  |  |  |
| 1312 | 1.4.1.4.5.5.8.4 | **ServiceNow Portal Testing and Validation** |  | 18d | 2025-01-08 | 2025-01-31 A |  | 100% | 2025-01-28 |  | 2025-01-08 | 2025-01-17 | 0d |  | Helix | SIT | 6.13 | Helix |  |  | -755.67 |  |  |  |
| 1313 | 1.4.1.4.5.5.8.4.1 | Conduct User Acceptance Testing (UAT) |  | 1d | 2025-01-31 A | 2025-01-31 A | 1310SS | 100% |  |  | 2025-01-13 | 2025-01-17 | 0d | finish no earlier than 2025-01-17 | Helix | SIT | 6.13 | Helix | Complete | COMPLETE |  |  |  |  |
| 1314 | 1.4.1.4.5.5.8.4.2 | Validate Access and Security Controls |  | 4d | 2025-01-28 A | 2025-01-31 A |  | 100% |  |  | 2025-01-13 | 2025-01-17 | 0d | finish no earlier than 2025-01-31 | Helix | SIT | 6.13 | Helix | Complete | COMPLETE |  |  |  |  |
| 1315 | 1.4.1.4.5.5.8.5 | ServiceNow Support Portal Onboarding (Helix Suppliers& SIT Participants) Completed | milestone | 0d | 2025-01-31 A | 2025-01-31 A | 1304, 1308, 1311, 1314, 1310 | 100% |  |  | 2025-01-17 | 2025-01-17 | 0d | start no earlier than 2025-01-17 | Helix | SIT | 6.13 | Helix | Complete | COMPLETE |  |  |  |  |
| 1316 | 1.4.1.4.5.5.9 | Stage 1 - Helix SIT Operational Readiness Completed | milestone | 0d | 2025-01-31 A | 2025-01-31 A | 1298, 1283, 1251 | 100% |  |  | 2025-01-31 | 2025-01-31 | 0d | start no earlier than 2025-01-31 | Helix | SIT | 6.13 | Helix | Complete | COMPLETE |  | T3-TE-0137 | SITAG | T3 |

| ID | WBS | Task | Type | Duration | Start | Finish | Predecessors | Complete | Baseline start | Baseline finish | Baseline duration | Constraint | Baseline cost | Text9 | Task Status | Update Version | Responsible | Involved | MHHS Resource Name | MHHS Programme Phase | Text29 | Sched Status | RAG | Milestone ID | Tier | Guidance |
| --- | --- | --- | --- | --- | --- | --- | --- | --- | --- | --- | --- | --- | --- | --- | --- | --- | --- | --- | --- | --- | --- | --- | --- | --- | --- | --- |
| 1317 | 1.4.1.4.5.6 | **Theme 3 Test Cases Approved** |  | 246d? | 2024-04-10 A | 2025-03-19 A |  | 100% |  |  |  |  |  | SIT | -827.67 | 6.18 |  |  |  |  |  |  |  |  |  |  |
| 1318 | 1.4.1.4.5.6.1 | **Theme 3 (Batch 2)** |  | 64d | 2024-09-19 A | 2024-12-18 A |  | 100% | 2024-09-19 | 2024-12-11 | 116d |  | -0 | SIT | -448.67 | 6.0 | N/A | N/A | Steve Evans | Systems Integration Testing (SIT) | SITAG |  |  |  |  |  |
| 1319 | 1.4.1.4.5.6.1.1 | Conclude BCDR Scope with SRO, Code Bodies and DIP Manager |  | 22d | 2024-09-19 A | 2024-10-18 A |  | 100% | 2024-09-19 | 2024-10-18 | 0d | start no earlier than 2024-09-19 |  | SIT |  | 6.0 | SI Test |  | Steve Evans |  | SITAG | Complete | COMPLETE |  |  |  |
| 1320 | 1.4.1.4.5.6.1.2 | Develop BDCR Test Scenarios & Test Cases (Batch 2) |  | 10d | 2024-10-14 A | 2024-10-25 A | 1319 | 100% | 2024-10-14 | 2024-10-25 | 0d |  |  | SIT |  | 6.0 | SI Test |  | Steve Evans |  | SITAG | Complete | COMPLETE |  |  |  |
| 1321 | 1.4.1.4.5.6.1.3 | Develop DIP Test Scenarios and Test Cases (Batch 2) |  | 27d | 2024-09-19 A | 2024-10-25 A |  | 100% | 2024-09-19 | 2024-10-25 | 0d | start no earlier than 2024-09-19 |  | SIT |  | 6.0 | SI Test |  | Steve Evans |  | SITAG | Complete | COMPLETE |  |  |  |
| 1322 | 1.4.1.4.5.6.1.4 | SRO Review |  | 5d | 2024-10-28 A | 2024-11-01 A | 1321 | 100% | 2024-10-28 | 2024-11-01 | 0d | start no earlier than 2024-10-28 |  | SIT |  | 6.0 | SI Test |  | Steve Evans |  | SITAG | Complete | COMPLETE |  |  |  |
| 1323 | 1.4.1.4.5.6.1.5 | Industry Consultation (Batch 2) |  | 10d | 2024-11-11 A | 2024-11-22 A | 1322 | 100% | 2024-11-11 | 2024-11-22 | 1d |  |  | SIT |  | 6.0 | SI Test, PP | SI Test, PP | Steve Evans |  | SITAG | Complete | COMPLETE |  |  |  |
| 1324 | 1.4.1.4.5.6.1.6 | Review Feedback and Update |  | 4d | 2024-11-25 A | 2024-11-28 A | 1323 | 100% | 2024-11-25 | 2024-11-29 | 0d |  |  | SIT |  | 6.13 | SI Test |  | Steve Evans |  | SITAG | Complete | COMPLETE |  |  |  |
| 1325 | 1.4.1.4.5.6.1.7 | SITWG paper day | milestone | 0d | 2024-11-28 A | 2024-11-28 A | 1324 | 100% | 2024-11-28 | 2024-11-28 | 0d |  |  | SIT |  | 6.13 | SI Test |  | Steve Evans |  | SITAG | Complete | COMPLETE |  |  |  |
| 1326 | 1.4.1.4.5.6.1.8 | Review with SIT WG (Batch 2) |  | 5d | 2024-11-29 A | 2024-12-05 A | 1325 | 100% | 2024-11-29 | 2024-12-05 | 0d |  |  | SIT |  | 6.13 | SI Test |  | Steve Evans |  | SITAG | Complete | COMPLETE |  |  |  |
| 1327 | 1.4.1.4.5.6.1.9 | SITWG endorse Theme 3 (Batch 2) | milestone | 0d | 2024-12-05 A | 2024-12-05 A | 1326 | 100% | 2024-12-05 | 2024-12-05 | 0d |  |  | SIT |  | 6.13 | SI Test |  | Steve Evans |  | SITAG | Complete | COMPLETE |  |  |  |
| 1328 | 1.4.1.4.5.6.1.10 | SITAG paper day | milestone | 0d | 2024-12-11 A | 2024-12-11 A | 1327FS+4d | 100% | 2024-12-11 | 2024-12-11 | 0d |  |  | SIT |  | 6.13 | SI Test |  | Steve Evans |  | SITAG | Complete | COMPLETE |  |  |  |
| 1329 | 1.4.1.4.5.6.1.11 | SITAG approve Theme 3 (Batch 2) | milestone | 0d | 2024-12-18 A | 2024-12-18 A | 1328FS+5d | 100% | 2024-12-18 | 2024-12-18 | 0d |  |  | SIT |  | 6.13 | SI Test |  | Steve Evans |  | SITAG | Complete | COMPLETE | T3-TE-0138 | T3 |  |
| 1330 | 1.4.1.4.5.6.2 | **Theme 3 (Batch 1)** |  | 181d? | 2024-04-10 A | 2024-12-18 A |  | 100% | 2024-04-10 | 2024-12-11 | 0d |  |  | SIT | -688.67 | 6.0 | SI Test |  | Steve Evans |  | SITAG |  |  |  |  |  |
| 1331 | 1.4.1.4.5.6.2.1 | Develop Test Scenarios & Test Cases (Batch 1) |  | 78d | 2024-04-10 A | 2024-07-26 A | 1198 | 100% | 2024-04-10 | 2024-07-26 | 46d |  |  | SIT |  | 6.0 | SI Test | SI Test, PP | Steve Evans |  | SITAG | Complete | COMPLETE |  |  |  |
| 1332 | 1.4.1.4.5.6.2.2 | Conclude Industry Consultation (Batch 1) |  | 11d | 2024-09-05 A | 2024-09-19 A |  | 100% | 2024-09-05 | 2024-09-19 | 0d | start no earlier than 2024-09-05 |  | SIT |  | 6.0 | SI Test |  | Steve Evans |  | SITAG | Complete | COMPLETE |  |  |  |
| 1333 | 1.4.1.4.5.6.2.3 | Review Feedback and Update |  | 5d | 2024-09-20 A | 2024-09-26 A | 1332 | 100% | 2024-09-20 | 2024-09-26 | 0d |  |  | SIT |  | 6.0 | SI Test |  | Steve Evans |  | SITAG | Complete | COMPLETE |  |  |  |
| 1334 | 1.4.1.4.5.6.2.4 | Draft Test Cases from Feedback and LLSD |  | 15d? | 2024-09-30 A | 2024-10-18 A | 1333FS+1d, 1356 | 100% | 2024-09-30 | 2024-10-18 | 0d |  |  | SIT |  | 6.0 | SI Test |  | Steve Evans |  | SITAG | Complete | COMPLETE |  |  |  |
| 1335 | 1.4.1.4.5.6.2.5 | SRO Review |  | 5d? | 2024-10-21 A | 2024-10-25 A | 1334 | 100% | 2024-10-21 | 2024-10-25 | 0d |  |  | SIT |  | 6.0 | SI Test |  | Steve Evans |  | SITAG | Complete | COMPLETE |  |  |  |
| 1336 | 1.4.1.4.5.6.2.6 | Industry Consultation |  | 10d? | 2024-10-28 A | 2024-11-08 A | 1335 | 100% | 2024-10-28 | 2024-11-08 | 0d |  |  | SIT |  | 6.0 | SI Test |  | Steve Evans |  | SITAG | Complete | COMPLETE |  |  |  |
| 1337 | 1.4.1.4.5.6.2.7 | Review Feedback and Update |  | 10d | 2024-11-11 A | 2024-11-22 A | 1336 | 100% | 2024-11-11 | 2024-11-15 | 0d |  |  | SIT |  | 6.0 | SI Test |  | Steve Evans |  | SITAG | Complete | COMPLETE |  |  |  |
| 1338 | 1.4.1.4.5.6.2.8 | SITWG paper day | milestone | 0d | 2024-11-28 A | 2024-11-28 A | 1337FS+4d | 100% | 2024-11-28 | 2024-11-28 | 0d |  |  | SIT |  | 6.13 | SI Test |  | Steve Evans |  | SITAG | Complete | COMPLETE |  |  |  |
| 1339 | 1.4.1.4.5.6.2.9 | Review with SITWG (Batch 1) |  | 5d | 2024-11-29 A | 2024-12-05 A | 1338 | 100% | 2024-11-29 | 2024-12-05 | 0d |  |  | SIT |  | 6.13 | SI Test |  | Steve Evans |  | SITAG | Complete | COMPLETE |  |  |  |
| 1340 | 1.4.1.4.5.6.2.10 | SITWG endorse Theme 3 (Batch 1) | milestone | 0d | 2024-12-05 A | 2024-12-05 A | 1339 | 100% | 2024-12-05 | 2024-12-05 | 0d |  |  | SIT |  | 6.13 | SI Test |  | Steve Evans |  | SITAG | Complete | COMPLETE |  |  |  |
| 1341 | 1.4.1.4.5.6.2.11 | SITAG paper day | milestone | 0d | 2024-12-11 A | 2024-12-11 A | 1340FS+4d | 100% | 2024-12-11 | 2024-12-11 | 0d |  |  | SIT |  | 6.13 | SI Test |  | Steve Evans |  | SITAG | Complete | COMPLETE |  |  |  |
| 1342 | 1.4.1.4.5.6.2.12 | SITAG approve Theme 3 (Batch 1) | milestone | 0d | 2024-12-18 A | 2024-12-18 A | 1341FS+5d | 100% | 2024-12-18 | 2024-12-18 | 0d |  |  | SIT |  | 6.13 | SI Test |  | Steve Evans |  | SITAG | Complete | COMPLETE | T3-TE-0139 | T3 |  |
| 1343 | 1.4.1.4.5.6.2.13 | SIT Operational Scenarios & Test Cases Approved - Theme 3 (Batch 1 + 2) | milestone | 0d | 2024-12-18 A | 2024-12-18 A | 1356, 1329, 1342 | 100% | 2024-12-18 | 2024-12-18 | 0d |  |  | SIT |  | 6.13 | SI Test | SI Test, PP | Steve Evans | Systems Integration Testing (SIT) | SITAG | Complete | COMPLETE | T3-TE-0119 | T3 | 31/7/24: baseline date change approved at esitag on 26/7/24 |

| ID | WBS | Task | Type | Duration | Start | Finish | Predecessors | Complete | Remaining | Baseline start | Baseline finish | Baseline duration | Total slack | Free slack | Constraint | Responsible | Text9 | Task Status | Update Version | MHHS Resource Name | Text29 | Sched Status | RAG |
| --- | --- | --- | --- | --- | --- | --- | --- | --- | --- | --- | --- | --- | --- | --- | --- | --- | --- | --- | --- | --- | --- | --- | --- |
| 1344 | 1.4.1.4.5.6.3 | **Theme 3 (Batch 2) Supplementary** |  | 33d | 2025-02-03 A | 2025-03-19 A |  | 100% |  | 2025-02-03 | 2025-03-19 | 0d |  |  |  | SI Test | SIT | -827.67 | 6.18 | Steve Evans | SITAG |  |  |
| 1345 | 1.4.1.4.5.6.3.1 | Conclude DIP Onboarding / Offboarding Scope with DIP Manager |  | 5d | 2025-02-03 A | 2025-02-07 A |  | 100% |  | 2025-02-03 | 2025-02-07 | 0d |  |  | start no earlier than 2025-02-03 | SI Test | SIT |  | 6.18 | Steve Evans | SITAG | Complete | COMPLETE |
| 1346 | 1.4.1.4.5.6.3.2 | Develop DIP Onboarding / Offboarding Test Scenarios & Test Cases (Batch 2) Supplementary |  | 2d | 2025-02-10 A | 2025-02-11 A | 1345 | 100% |  | 2025-02-10 | 2025-02-11 | 0d |  |  |  | SI Test | SIT |  | 6.18 | Steve Evans | SITAG | Complete | COMPLETE |
| 1347 | 1.4.1.4.5.6.3.3 | SRO Review |  | 5d | 2025-02-12 A | 2025-02-18 A | 1346 | 100% |  | 2025-02-12 | 2025-02-18 | 0d |  |  |  | SI Test | SIT |  | 6.18 | Steve Evans | SITAG | Complete | COMPLETE |
| 1348 | 1.4.1.4.5.6.3.4 | Industry Consultation (Batch 2) Supplementary |  | 10d | 2025-02-19 A | 2025-03-04 A | 1347 | 100% |  | 2025-02-19 | 2025-03-04 | 0d |  |  |  | SI Test | SIT |  | 6.18 | Steve Evans | SITAG | Complete | COMPLETE |
| 1349 | 1.4.1.4.5.6.3.5 | SITWG Paper Day | milestone | 0d | 2025-02-27 A | 2025-02-27 A | 1348SS+7d, 1347FS+7d | 100% |  | 2025-02-27 | 2025-02-27 | 0d |  |  |  | SI Test | SIT |  | 6.18 | Steve Evans | SITAG | Complete | COMPLETE |
| 1350 | 1.4.1.4.5.6.3.6 | Review Feedback and Update |  | 1d | 2025-03-05 A | 2025-03-05 A | 1348 | 100% |  | 2025-03-05 | 2025-03-05 | 0d |  |  |  | SI Test | SIT |  | 6.18 | Steve Evans | SITAG | Complete | COMPLETE |
| 1351 | 1.4.1.4.5.6.3.7 | SITWG endorse Theme 3 (Batch 2) Supplementary | milestone | 0d | 2025-03-06 A | 2025-03-06 A | 1348, 1349, 1350FS+1d | 100% |  | 2025-03-06 | 2025-03-06 | 0d |  |  |  | SI Test | SIT |  | 6.18 | Steve Evans | SITAG | Complete | COMPLETE |
| 1352 | 1.4.1.4.5.6.3.8 | SITAG paper day | milestone | 0d | 2025-03-12 A | 2025-03-12 A | 1351FS+4d | 100% |  | 2025-03-12 | 2025-03-12 | 0d |  |  |  | SI Test | SIT |  | 6.18 | Steve Evans | SITAG | Complete | COMPLETE |
| 1353 | 1.4.1.4.5.6.3.9 | SITAG approve Theme 3 (Batch 2) Supplementary | milestone | 0d | 2025-03-19 A | 2025-03-19 A | 1352FS+5d | 100% |  | 2025-03-19 | 2025-03-19 | 0d |  |  |  | SI Test | SIT |  | 6.18 | Steve Evans | SITAG | Complete | COMPLETE |
| 1354 | 1.4.1.4.5.7 | **Helix SDD and LLSD Development and Approval** |  | 1d | 2024-09-27 A | 2024-09-30 A |  | 100% |  | 2024-09-27 | 2024-09-30 | 0d |  |  |  | SI Test | SIT | -688.67 | 6.0 | Steve Evans | SITAG |  |  |
| 1355 | 1.4.1.4.5.7.1 | Development | milestone | 0d | 2024-09-27 A | 2024-09-27 A |  | 100% |  | 2024-09-27 | 2024-09-27 | 0d |  |  | start no earlier than 2024-09-27 | SI Test | SIT |  | 6.0 | Steve Evans | SITAG | Complete | COMPLETE |
| 1356 | 1.4.1.4.5.7.2 | Approval | milestone | 0d | 2024-09-30 A | 2024-09-30 A |  | 100% |  | 2024-09-30 | 2024-09-30 | 0d |  |  | start no earlier than 2024-09-30 | SI Test | SIT |  | 6.0 | Steve Evans | SITAG | Complete | COMPLETE |
| 1357 | 1.4.1.4.5.8 | **SIT Operational Programme RTTM (Theme 3 (Batch 1))** |  | 35d | 2024-12-09 A | 2025-01-24 A |  | 100% |  | 2024-12-12 | 2025-01-17 | 0d |  |  |  | SI Test | SIT | -686.67 | 6.12 | Steve Evans | SITAG |  |  |
| 1358 | 1.4.1.4.5.8.1 | Develop SIT Operational Theme 3 (Batch 1) RTTM |  | 25d | 2024-12-09 A | 2025-01-10 A | 1343FF | 100% |  | 2024-12-12 | 2025-01-10 | 0d |  |  |  | SI Test | SIT |  | 6.16 | Steve Evans | SITAG | Complete | COMPLETE |
| 1359 | 1.4.1.4.5.8.2 | SRO review of SIT Operational Theme 3 (Batch 1) RTTM |  | 5d | 2025-01-13 A | 2025-01-17 A | 1358 | 100% |  | 2025-01-13 | 2025-01-17 | 0d |  |  |  | SI Test | SIT |  | 6.16 | Steve Evans | SITAG | Complete | COMPLETE |
| 1360 | 1.4.1.4.5.8.3 | DIP Manager / Code Bodies / Full SRO to review |  | 5d | 2025-01-20 A | 2025-01-24 A | 1359 | 100% |  | 2025-01-20 | 2025-01-24 | 0d |  |  |  | SI Test | SIT |  | 6.16 | Steve Evans | SITAG | Complete | COMPLETE |
| 1361 | 1.4.1.4.5.8.4 | DIP Manager / Code Bodies / Full SRO acceptance of Theme 3 (Batch 1) Operational RTTM | milestone | 0d | 2025-01-24 A | 2025-01-24 A | 1360 | 100% |  | 2025-01-24 | 2025-01-24 | 0d |  |  |  | SI Test | SIT |  | 6.16 | Steve Evans | SITAG | Complete | COMPLETE |
| 1362 | 1.4.1.4.5.8.5 | SIT Operational Theme 3 (Batch 1) RTTM Complete | milestone | 0d | 2025-01-24 A | 2025-01-24 A | 1358, 1361 | 100% |  | 2025-01-10 | 2025-01-10 | 0d |  |  |  | SI Test | SIT |  | 6.12 | Steve Evans | SITAG | Complete | COMPLETE |
| 1363 | 1.4.1.4.5.9 | **SIT Operational Programme RTTM (Theme 1, 2 & 3 (Batch 2))** |  | 80d | 2025-01-06 A | 2025-04-25 |  | 75% | 20.11d | 2025-01-06 | 2025-03-07 | 0d | 694d |  |  | SI Test | SIT | -827.67 | 6.18 | Steve Evans | SITAG |  |  |
| 1364 | 1.4.1.4.5.9.1 | Develop SIT Operational (Theme 1, 2 & 3 (Batch 2)) RTTM |  | 36d | 2025-01-06 A | 2025-02-24 A |  | 100% |  | 2025-01-06 | 2025-02-07 | 0d |  |  | start no earlier than 2025-01-06 | SI Test | SIT |  | 6.18 | Steve Evans | SITAG | Complete | COMPLETE |
| 1365 | 1.4.1.4.5.9.2 | SRO review of SIT Operational (Theme 1, 2 & 3 (Batch 2)) RTTM |  | 9d | 2025-02-25 A | 2025-03-07 A | 1364 | 100% |  | 2025-02-25 | 2025-03-07 | 0d |  |  |  | SI Test | SIT |  | 6.18 | Steve Evans | SITAG | Complete | COMPLETE |
| 1366 | 1.4.1.4.5.9.3 | DIP Manager / Code Bodies / Full SRO to review |  | 34d | 2025-03-10 A | 2025-04-24 | 1365 | 90% | 3.4d | 2025-03-10 | 2025-03-21 | 0d | 694d | 0d |  | SI Test | SIT |  | 6.18 | Steve Evans | SITAG | Overdue | RED |
| 1367 | 1.4.1.4.5.9.4 | Incorporate feedback |  | 34d | 2025-03-10 A | 2025-04-24 | 1366FF | 26% | 25d | 2025-03-10 | 2025-03-21 | 0d | 695d |  |  | SI Test | SIT |  | 6.18 | Steve Evans | SITAG | Overdue | RED |
| 1368 | 1.4.1.4.5.9.5 | DIP Manager / Code Bodies / SRO acceptance of (Theme 1, 2 & 3 (Batch 2)) Operational RTTM | milestone | 0d | 2025-04-25 | 2025-04-25 | 1366FS+1d |  |  | 2025-03-24 | 2025-03-24 | 0d | 694d | 0d |  | SI Test | SIT | -11.29 | 6.18 | Steve Evans | SITAG | Overdue Start | RED |
| 1369 | 1.4.1.4.5.9.6 | SIT Operational (Theme 1, 2 & 3 (Batch 2)) RTTM Complete | milestone | 0d | 2025-04-25 | 2025-04-25 | 1368 |  |  | 2025-03-24 | 2025-03-24 | 0d | 694d |  | start no earlier than 2025-03-28 | SI Test | SIT | -11.29 | 6.18 | Steve Evans | SITAG | Overdue Start | RED |

Notes:
- 1366: 06/05/25 - Programme has shared RTTM with Code Bodies and continues to address feedback on it so it can be accepted by them. Delay has a minimal impact on current activity. Target completion date 09/05/25.
- 1367: 06/05/25 - Programme has shared RTTM with Code Bodies and continues to address feedback on it so it can be accepted by them. Delay has a minimal impact on current activity. Target completion date 09/05/25.
- 1368: 06/05/25 - Programme has shared RTTM with Code Bodies and continues to address feedback on it so it can be accepted by them. Delay has a minimal impact on current activity. Target completion date 09/05/25.
- 1369: 06/05/25 - Programme has shared RTTM with Code Bodies and continues to address feedback on it so it can be accepted by them. Delay has a minimal impact on current activity. Target completion date 09/05/25.

| ID | WBS | Task | Type | Duration | Start | Finish | Predecessors | Complete | Actual start | Actual finish | Baseline start | Baseline finish | Baseline duration | Constraint | Responsible | Text9 | Task Status | Update Version | Sched Status | MHHS Resource Name | Text29 | RAG |
| --- | --- | --- | --- | --- | --- | --- | --- | --- | --- | --- | --- | --- | --- | --- | --- | --- | --- | --- | --- | --- | --- | --- |
| 1370 | 1.4.1.4.5.10 | **SIT Operational Theme 3 (Batch 1) DITL** |  | 17d | 2025-01-06 A | 2025-01-28 A |  | 100% |  |  | 2024-10-08 | 2024-10-17 | 0d |  | SI Test | SIT | 6.33 | 6.15 | No BL | Steve Evans | SITAG |  |
| 1371 | 1.4.1.4.5.10.1 | DITL + Familiarisation session development |  | 8d | 2025-01-06 A | 2025-01-15 A |  | 100% |  |  | 2025-01-06 | 2025-01-17 | 0d | start no earlier than 2025-01-06 | SI Test | SIT |  | 6.15 | Complete | Steve Evans | SITAG | COMPLETE |
| 1372 | 1.4.1.4.5.10.2 | SRO Review |  | 5d | 2025-01-16 A | 2025-01-22 A | 1371 | 100% |  |  | 2025-01-20 | 2025-01-24 | 0d |  | SI Test | SIT |  | 6.15 | Complete | Steve Evans | SITAG | COMPLETE |
| 1373 | 1.4.1.4.5.10.3 | Post-SRO Review Changes |  | 2d | 2025-01-23 A | 2025-01-24 A | 1372 | 100% |  |  | 2025-01-23 | 2025-01-24 | 0d |  | SI Test | SIT |  | 6.16 | Complete | Steve Evans | SITAG | COMPLETE |
| 1374 | 1.4.1.4.5.10.4 | Familiarisation session Service Management test case schedule + mapping | milestone | 0d | 2025-01-24 A | 2025-01-24 A | 1373 | 100% |  |  | 2025-01-24 | 2025-01-24 | 0d |  | SI Test | SIT |  | 6.16 | Complete | Steve Evans | SITAG | COMPLETE |
| 1375 | 1.4.1.4.5.10.5 | Publish Cycle 3 DITL / Cycle 3 DITL Online Sessions for SIT PPs | milestone | 0d | 2025-01-28 A | 2025-01-28 A | 1374FS+2d | 100% |  |  | 2025-01-28 | 2025-01-28 | 0d |  | SI Test | SIT |  | 6.16 | Complete | Steve Evans | SITAG | COMPLETE |
| 1376 | 1.4.1.4.5.11 | **SIT Operational Theme 1, 2 & 3 (Batch 2) DITL** |  | 23d | 2025-02-24 A | 2025-03-26 A |  | 100% |  |  | 2025-02-24 | 2025-03-26 | 0d |  | SI Test | SIT | -828.67 | 6.18 |  | Steve Evans | SITAG |  |
| 1377 | 1.4.1.4.5.11.1 | DITL + Familiarisation session development |  | 15d | 2025-02-24 A | 2025-03-14 A |  | 100% |  |  | 2025-02-24 | 2025-03-14 | 0d | start no earlier than 2025-02-24 | SI Test | SIT |  | 6.18 | Complete | Steve Evans | SITAG | COMPLETE |
| 1378 | 1.4.1.4.5.11.2 | SRO Review |  | 5d | 2025-03-17 A | 2025-03-21 A | 1377 | 100% |  |  | 2025-03-17 | 2025-03-21 | 0d |  | SI Test | SIT |  | 6.18 | Complete | Steve Evans | SITAG | COMPLETE |
| 1379 | 1.4.1.4.5.11.3 | Post-SRO Review Changes |  | 3d | 2025-03-24 A | 2025-03-26 A | 1378 | 100% |  |  | 2025-03-24 | 2025-03-26 | 0d |  | SI Test | SIT |  | 6.18 | Complete | Steve Evans | SITAG | COMPLETE |
| 1380 | 1.4.1.4.5.11.4 | Familiarisation session Service Management test case schedule + mapping | milestone | 0d | 2025-03-26 A | 2025-03-26 A | 1379 | 100% |  |  | 2025-03-26 | 2025-03-26 | 0d |  | SI Test | SIT |  | 6.18 | Complete | Steve Evans | SITAG | COMPLETE |
| 1381 | 1.4.1.4.5.11.5 | Publish Cycle 3 DITL / Cycle 3 DITL Online Sessions for SIT PPs | milestone | 0d | 2025-03-26 A | 2025-03-26 A | 1380 | 100% |  |  | 2025-03-26 | 2025-03-26 | 0d |  | SI Test | SIT |  | 6.18 | Complete | Steve Evans | SITAG | COMPLETE |
| 1382 | 1.4.1.4.5.12 | **SIT Operational Defect Management** |  | 15d? | 2025-01-06 A | 2025-01-24 A |  | 100% |  |  | 2025-01-06 | 2025-01-24 | 0d |  | SI Test | SIT | -807.67 | 6.17 |  | Steve Evans | SITAG |  |
| 1383 | 1.4.1.4.5.12.1 | Develop defect management approach |  | 10d? | 2025-01-06 A | 2025-01-17 A |  | 100% |  |  | 2025-01-06 | 2025-01-17 | 0d | start no earlier than 2025-01-06 | SI Test | SIT |  | 6.17 | Complete | Steve Evans | SITAG | COMPLETE |
| 1384 | 1.4.1.4.5.12.2 | Defect management approach agreed |  | 5d? | 2025-01-20 A | 2025-01-24 A | 1383 | 100% |  |  | 2025-01-20 | 2025-01-24 | 0d |  | SI Test | SIT |  | 6.17 | Complete | Steve Evans | SITAG | COMPLETE |
| 1385 | 1.4.1.4.5.13 | **SIT Operational Execution Model** |  | 43d? | 2024-08-05 | 2024-10-02 |  | 100% | 2024-12-16 | 2025-03-17 | 2024-08-05 | 2024-10-02 | 0d |  | SI Test | SIT | -134.67 | 6.15 |  | Steve Evans | SITAG |  |
| 1386 | 1.4.1.4.5.13.1 | **Theme 3 (Batch 1)** |  | 27d | 2024-08-05 | 2024-09-10 |  | 100% | 2024-12-16 | 2025-01-21 | 2024-08-05 | 2024-09-10 | 0d |  | SI Test | SIT | -134.67 | 6.15 |  | Steve Evans | SITAG |  |
| 1387 | 1.4.1.4.5.13.1.1 | Develop execution model Theme 3 (Batch 1) |  | 3d | 2024-12-16 A | 2024-12-18 A | 1343FF | 100% |  |  | 2024-12-16 | 2024-12-18 | 0d |  | SI Test | SIT |  | 6.15 | Complete | Steve Evans | SITAG | COMPLETE |
| 1388 | 1.4.1.4.5.13.1.2 | SRO provide feedback |  | 14d | 2024-12-19 A | 2025-01-07 A | 1387 | 100% |  |  | 2024-12-19 | 2025-01-07 | 0d |  | SI Test | SIT |  | 6.15 | Complete | Steve Evans | SITAG | COMPLETE |
| 1389 | 1.4.1.4.5.13.1.3 | Address SRO feedback on execution model |  | 2d | 2025-01-08 A | 2025-01-09 A | 1388 | 100% |  |  | 2025-01-08 | 2025-01-09 | 0d |  | SI Test | SIT |  | 6.15 | Complete | Steve Evans | SITAG | COMPLETE |
| 1390 | 1.4.1.4.5.13.1.4 | Finalise execution model |  | 3d | 2025-01-10 A | 2025-01-14 A | 1389 | 100% |  |  | 2025-01-10 | 2025-01-14 | 0d |  | SI Test | SIT |  | 6.15 | Complete | Steve Evans | SITAG | COMPLETE |
| 1391 | 1.4.1.4.5.13.1.5 | SITWG paper day | milestone | 0d | 2025-01-14 A | 2025-01-14 A | 1390 | 100% |  |  | 2025-01-14 | 2025-01-14 | 0d |  | SI Test | SIT |  | 6.15 | Complete | Steve Evans | SITAG | COMPLETE |
| 1392 | 1.4.1.4.5.13.1.6 | SITWG update on execution model | milestone | 0d | 2025-01-21 A | 2025-01-21 A | 1391FS+5d | 100% |  |  | 2025-01-21 | 2025-01-21 | 0d |  | SI Test | SIT |  | 6.15 | Complete | Steve Evans | SITAG | COMPLETE |
| 1393 | 1.4.1.4.5.13.2 | **Theme 1, 2 and 3 (Batch 2)** |  | 23d? | 2024-08-05 | 2024-09-04 |  | 100% | 2025-02-03 | 2025-03-17 | 2024-08-05 | 2024-09-04 | 0d |  | SI Test | SIT | -134.67 | 6.15 |  | Steve Evans | SITAG |  |
| 1394 | 1.4.1.4.5.13.2.1 | Develop execution model Theme 1, 2 and 3 (Batch 2) |  | 10d | 2025-02-03 A | 2025-02-14 A | 1343 | 100% |  |  | 2025-02-03 | 2025-02-14 | 0d | start no earlier than 2025-02-03 | SI Test | SIT |  | 6.15 | Complete | Steve Evans | SITAG | COMPLETE |
| 1395 | 1.4.1.4.5.13.2.2 | SRO provide feedback |  | 5d | 2025-02-25 A | 2025-03-03 A | 1394 | 100% |  |  | 2025-02-17 | 2025-02-21 | 0d | finish no earlier than 2025-01-21 | SI Test | SIT |  | 6.15 | Complete | Steve Evans | SITAG | COMPLETE |
| 1396 | 1.4.1.4.5.13.2.3 | Address SRO feedback on execution model |  | 5d | 2025-03-04 A | 2025-03-10 A | 1395 | 100% |  |  | 2025-02-17 | 2025-02-21 | 0d |  | SI Test | SIT |  | 6.15 | Complete | Steve Evans | SITAG | COMPLETE |
| 1397 | 1.4.1.4.5.13.2.4 | Finalise execution model |  | 5d | 2025-03-11 A | 2025-03-17 A | 1396 | 100% |  |  | 2025-02-24 | 2025-02-27 | 0d |  | SI Test | SIT |  | 6.15 | Complete | Steve Evans | SITAG | COMPLETE |
| 1398 | 1.4.1.4.5.13.2.5 | Execution Model shared with industry | milestone | 0d | 2025-03-17 A | 2025-03-17 A | 1397 | 100% |  |  | 2025-02-27 | 2025-02-27 | 0d |  | SI Test | SIT |  | 6.20 | Complete | Steve Evans | SITAG | COMPLETE |

| ID | WBS | Task | Type | Duration | Start | Finish | Predecessors | Complete | Actual start | Actual finish | Baseline start | Baseline finish | Baseline duration | Baseline 1 start | Baseline 1 finish | Constraint | Baseline cost | Responsible | Text9 | Task Status | Update Version | MHHS Resource Name | Text29 | Sched Status | RAG | Involved | MHHS Programme Phase | Milestone ID | Tier |
| --- | --- | --- | --- | --- | --- | --- | --- | --- | --- | --- | --- | --- | --- | --- | --- | --- | --- | --- | --- | --- | --- | --- | --- | --- | --- | --- | --- | --- | --- |
| 1399 | 1.4.1.4.5.13.3 | **SIT Operational Theme 3 (Batch 1) progress reporting** |  | 29d? | 2024-12-19 A | 2025-01-28 |  | 100% |  | 2025-01-24 | 2024-12-19 | 2025-01-31 | 0d |  |  |  |  | SI Test | SIT | -94.67 | 6.14 | Steve Evans | SITAG |  |  |  |  |  |  |
| 1400 | 1.4.1.4.5.13.3.1 | Determine reporting methodology |  | 2d? | 2024-12-19 A | 2024-12-20 A |  | 100% |  |  | 2024-12-19 | 2025-01-17 | 0d |  |  |  |  | SI Test | SIT |  | 6.14 | Steve Evans | SITAG | Complete | COMPLETE |  |  |  |  |
| 1401 | 1.4.1.4.5.13.3.2 | Implement reporting |  | 25d | 2024-12-23 A | 2025-01-24 A | 1400 | 100% |  |  | 2025-01-20 | 2025-01-31 | 0d |  |  |  |  | SI Test | SIT |  | 6.14 | Steve Evans | SITAG | Complete | COMPLETE |  |  |  |  |
| 1402 | 1.4.1.4.5.14 | **SIT Operational Overarching Test Readiness Reports** |  | 33d? | 2024-08-05 | 2024-09-18 |  | 100% | 2024-12-18 | 2025-03-28 | 2024-08-05 | 2024-09-18 | 151d | 2025-01-07 | 2025-03-03 |  | -0 | N/A | SIT |  | 6.0 | Steve Evans | SITAG |  |  | N/A | Systems Integration Testing (SIT) |  |  |
| 1403 | 1.4.1.4.5.14.1 | **SI SIT Operational Theme 3 (Batch 1) Overarching Test Readiness Report** |  | 31d? | 2024-12-18 A | 2025-01-29 A |  | 100% |  |  | 2024-12-23 | 2025-01-29 | 0d |  |  |  |  | SI Test | SIT | -135.67 | 6.17 | Steve Evans | SITAG |  |  |  |  |  |  |
| 1404 | 1.4.1.4.5.14.1.1 | Develop Overarching SIT Operational Theme 3 (Batch 1) Overarching Test Readiness Report |  | 20d | 2024-12-18 A | 2025-01-14 A | 429FF | 100% |  |  | 2024-12-18 | 2025-01-14 | 0d |  |  | finish no earlier than 2025-01-14 |  | SI Test | SIT |  | 6.17 | Steve Evans | SITAG | Complete | COMPLETE |  |  |  |  |
| 1405 | 1.4.1.4.5.14.1.2 | SRO review |  | 5d | 2025-01-08 A | 2025-01-14 A | 1404FF | 100% |  |  | 2025-01-08 | 2025-01-14 | 0d |  |  | finish no earlier than 2025-01-13 |  | SI Test | SIT |  | 6.17 | Steve Evans | SITAG | Complete | COMPLETE |  |  |  |  |
| 1406 | 1.4.1.4.5.14.1.3 | SITWG Paper day | milestone | 0d | 2025-01-14 A | 2025-01-14 A | 1405 | 100% |  |  | 2025-01-14 | 2025-01-14 | 0d |  |  | finish no earlier than 2025-01-14 |  | SI Test | SIT |  | 6.17 | Steve Evans | SITAG | Complete | COMPLETE |  |  |  |  |
| 1407 | 1.4.1.4.5.14.1.4 | SITWG review the Operational Theme 3 (Batch 1) Overarching Test Readiness Report | milestone | 0d | 2025-01-21 A | 2025-01-21 A | 1406FS+5d | 100% |  |  | 2025-01-21 | 2025-01-21 | 0d |  |  | finish no earlier than 2025-01-21 |  | SI Test | SIT |  | 6.17 | Steve Evans | SITAG | Complete | COMPLETE |  |  |  |  |
| 1408 | 1.4.1.4.5.14.1.5 | Update Operational Theme 3 (Batch 1) Overarching Test Readiness Report following SRO / SITWG feedback |  | 1d | 2025-01-22 A | 2025-01-22 A | 1407 | 100% |  |  | 2025-01-22 | 2025-01-22 | 0d |  |  | start no earlier than 2025-01-22 |  | SI Test | SIT |  | 6.17 | Steve Evans | SITAG | Complete | COMPLETE |  |  |  |  |
| 1409 | 1.4.1.4.5.14.1.6 | SITAG paper day | milestone | 0d | 2025-01-22 A | 2025-01-22 A | 1408 | 100% |  |  | 2025-01-22 | 2025-01-22 | 0d |  |  | finish no earlier than 2025-01-22 |  | SI Test | SIT |  | 6.17 | Steve Evans | SITAG | Complete | COMPLETE |  |  |  |  |
| 1410 | 1.4.1.4.5.14.1.7 | FTIG recommendation | milestone | 0d | 2025-01-24 A | 2025-01-24 A | 1408FS+2d | 100% |  |  | 2025-01-24 | 2025-01-24 | 0d |  |  |  |  | SI Test | SIT |  | 6.17 | Steve Evans | SITAG | Complete | COMPLETE |  |  |  |  |
| 1411 | 1.4.1.4.5.14.1.8 | Republish Operational Theme 3 (Batch 1) Overarching Test Readiness Report with latest data and evidence |  | 1d? | 2025-01-27 A | 2025-01-27 A | 1409FS+2d | 100% |  |  | 2025-01-27 | 2025-01-27 | 0d |  |  |  |  | SI Test | SIT |  | 6.17 | Steve Evans | SITAG | Complete | COMPLETE |  |  |  |  |
| 1412 | 1.4.1.4.5.14.1.9 | SITAG approve Theme 3 (Batch 1) Test Readiness Report | milestone | 0d | 2025-01-29 A | 2025-01-29 A | 1409FS+5d, 1251, 1411 | 100% |  |  | 2025-01-29 | 2025-01-29 | 0d |  |  | finish no earlier than 2025-01-29 |  | SI Test | SIT |  | 6.17 | Steve Evans | SITAG | Complete | COMPLETE |  |  | T3-TE-0192 | T3 |
| 1413 | 1.4.1.4.5.14.2 | **SI SIT Operational Theme 1, 2 and 3 (Batch 2) Overarching Test Readiness Report** |  | 45d | 2025-01-27 A | 2025-03-28 A |  | 100% |  |  | 2025-01-27 | 2025-03-28 | 0d |  |  |  |  | SI Test | SIT | -135.67 | 6.17 | Steve Evans | SITAG |  |  |  |  |  |  |
| 1414 | 1.4.1.4.5.14.2.1 | Develop Overarching SIT Operational Theme 1, 2 and 3 (Batch 2) Overarching Test Readiness Report |  | 20d | 2025-01-27 A | 2025-02-21 A | 412FS+25d | 100% |  |  | 2025-01-27 | 2025-02-21 | 0d |  |  | start no earlier than 2025-01-20 |  | SI Test | SIT |  | 6.17 | Steve Evans | SITAG | Complete | COMPLETE |  |  |  |  |
| 1415 | 1.4.1.4.5.14.2.2 | SRO review |  | 5d | 2025-02-24 A | 2025-02-28 A | 1414 | 100% |  |  | 2025-02-24 | 2025-02-28 | 0d |  |  |  |  | SI Test | SIT |  | 6.17 | Steve Evans | SITAG | Complete | COMPLETE |  |  |  |  |
| 1416 | 1.4.1.4.5.14.2.3 | SITWG Paper day | milestone | 0d | 2025-02-27 A | 2025-02-27 A |  | 100% |  |  | 2025-02-27 | 2025-02-27 | 0d |  |  | finish no earlier than 2025-02-27 |  | SI Test | SIT |  | 6.17 | Steve Evans | SITAG | Complete | COMPLETE |  |  |  |  |
| 1417 | 1.4.1.4.5.14.2.4 | SITWG review the Operational Theme 1, 2 and 3 (Batch 2) Overarching Test Readiness Report | milestone | 0d | 2025-03-06 A | 2025-03-06 A | 1416SS+5d | 100% |  |  | 2025-03-06 | 2025-03-06 | 0d |  |  |  |  | SI Test | SIT |  | 6.17 | Steve Evans | SITAG | Complete | COMPLETE |  |  |  |  |
| 1418 | 1.4.1.4.5.14.2.5 | Update Operational Theme 1, 2 and 3 (Batch 2) Overarching Test Readiness Report following SRO feedback |  | 13d | 2025-03-07 A | 2025-03-25 A | 1417 | 100% |  |  | 2025-03-07 | 2025-03-25 | 0d |  |  | start no earlier than 2025-03-07 |  | SI Test | SIT |  | 6.17 | Steve Evans | SITAG | Complete | COMPLETE |  |  |  |  |
| 1419 | 1.4.1.4.5.14.2.6 | GLIG recommendation | milestone | 0d | 2025-03-21 A | 2025-03-21 A | 1417FS+11d | 100% |  |  | 2025-03-21 | 2025-03-21 | 0d |  |  |  |  | SI Test | SIT |  | 6.17 | Steve Evans | SITAG | Complete | COMPLETE |  |  |  |  |
| 1420 | 1.4.1.4.5.14.2.7 | eSITAG paper day | milestone | 0d | 2025-03-26 A | 2025-03-26 A | 1418 | 100% |  |  | 2025-03-26 | 2025-03-26 | 0d |  |  | finish no earlier than 2025-03-26 |  | SI Test | SIT |  | 6.17 | Steve Evans | SITAG | Complete | COMPLETE |  |  |  |  |
| 1421 | 1.4.1.4.5.14.2.8 | eSITAG approve Operational Theme 1, 2 and 3 (Batch 2) Overarching Test Readiness Report | milestone | 0d | 2025-03-28 A | 2025-03-28 A | 1419, 1429, 1430 | 100% |  |  | 2025-03-28 | 2025-03-28 | 0d |  |  |  |  | SI Test | SIT |  | 6.17 | Steve Evans | SITAG | Complete | COMPLETE |  |  | T3-TE-0193 | T3 |
| 1422 | 1.4.1.4.5.15 | SIT Operational Theme 3 (Batch 1) Testing Preparation Complete | milestone | 0d | 2025-01-31 A | 2025-01-31 A | 1412, 1315 | 100% |  |  | 2025-01-31 | 2025-01-31 | 0d |  |  |  |  | SI Test | SIT |  | 6.15 | Steve Evans | SITAG | Complete | COMPLETE |  |  | T2-TE-0750 | T2 |
| 1423 | 1.4.1.4.5.16 | SIT Operational Theme 1, 2, 3 (Batch 2) Testing Preparation Complete | milestone | 0d | 2025-03-28 A | 2025-03-28 A | 430, 1211, 1217, 1343, 1421, 1401, 1381, 1353 | 100% |  |  | 2025-03-31 | 2025-04-25 | 0d | 2025-03-10 | 2025-03-10 | finish no earlier than 2024-10-04 |  | SI Test | SIT |  | 6.15 | Steve Evans | SITAG | Complete | COMPLETE | PP,IPA | Systems Integration Testing (SIT) | T2-TE-1300 | T2 |

| ID | WBS | Task | Type | Duration | Start | Finish | Predecessors | Complete | Remaining | Actual finish | Baseline start | Baseline finish | Baseline duration | Constraint | Responsible | Text9 | Task Status | Update Version | MHHS Resource Name | Text29 | Sched Status | RAG | Milestone ID | Tier | Programme Governance Forum responsible for decisio |
| --- | --- | --- | --- | --- | --- | --- | --- | --- | --- | --- | --- | --- | --- | --- | --- | --- | --- | --- | --- | --- | --- | --- | --- | --- | --- |
| 1424 | 1.4.1.4.5.17 | **Test Data - Non-Functional and Operational (SIT B)** |  | 25d? | 2025-02-24 A | 2025-03-28 A |  | 100% |  |  | 2025-01-06 | 2025-03-14 | 0d |  | SI Test | SIT | -686.67 | 6.0 | Heath Thomas | SITAG |  |  |  |  |  |
| 1425 | 1.4.1.4.5.17.1 | **Data Load** |  | 25d? | 2025-02-24 A | 2025-03-28 A |  | 100% |  |  | 2025-01-06 | 2025-03-14 | 0d |  | SI Test | SIT | -689.67 | 6.0 | Michael Inije | SITAG |  |  |  |  |  |
| 1426 | 1.4.1.4.5.17.1.1 | Non-Functional Theme 1 (Avenade) Data Load |  | 5d? | 2025-02-24 A | 2025-02-28 A | 1595 | 100% |  |  | 2025-02-24 | 2025-02-28 | 0d |  | SI Test | SIT |  | 6.15 | Michael Inije | SITAG | Complete | COMPLETE | T3-TE-0126 | T3 |  |
| 1427 | 1.4.1.4.5.17.1.2 | Non-Functional Theme 2 & 3 (Helix, Avenade & PPs) Data Load |  | 5d | 2025-03-24 A | 2025-03-28 A | 1722 | 100% |  |  | 2025-03-24 | 2025-03-28 | 0d |  | SI Test | SIT |  | 6.15 | Michael Inije | SITAG | Complete | COMPLETE | T3-TE-0127 | T3 |  |
| 1428 | 1.4.1.4.5.17.1.3 | Non-Functional Themes 2 & 3 (LDSO's) Data Load |  | 15d | 2025-03-03 A | 2025-03-21 A | 1154 | 100% |  |  | 2025-03-03 | 2025-03-21 | 0d |  | SI Test | SIT |  | 6.15 | Michael Inije | SITAG | Complete | COMPLETE | T3-TE-0128 | T3 |  |
| 1429 | 1.4.1.4.5.17.1.4 | Operational Themes 1, 2 & 3 (Batch 2) (LDSO's) Data Load |  | 20d? | 2025-03-03 A | 2025-03-28 A | 1154 | 100% |  |  | 2025-03-03 | 2025-03-28 | 0d | start no earlier than 2025-01-06 | SI Test | SIT |  | 6.15 | Michael Inije | SITAG | Complete | COMPLETE | T3-TE-0129 | T3 |  |
| 1430 | 1.4.1.4.5.17.1.5 | Operational Themes 1, 2 & 3 (Batch 2) (Helix, Avenade & PPs) Data Load |  | 5d | 2025-03-24 A | 2025-03-28 A | 1722 | 100% |  |  | 2025-03-24 | 2025-03-28 | 0d |  | SI Test | SIT |  | 6.15 | Michael Inije | SITAG | Complete | COMPLETE | T3-TE-0130 | T3 |  |
| 1431 | 1.4.1.4.5.17.1.6 | Non-Functional and Operational Test Data Preparation Complete | milestone | 0d | 2025-03-28 A | 2025-03-28 A | 1430 | 100% |  |  | 2025-03-28 | 2025-03-28 | 0d |  | SI Test | SIT |  | 6.15 | Michael Inije | SITAG | Complete | COMPLETE | T3-TE-0131 | T3 |  |
| 1432 | 1.4.1.4.6 | **Regression Test Preparation** |  | 2d? | 2024-11-18 A | 2024-11-19 |  | 95% | 0.09d? |  | 2024-11-18 | 2024-11-19 | 0d |  | SI Test | SIT | -686.67 | 6.17 | Roger Robar | SITAG |  |  |  |  |  |
| 1433 | 1.4.1.4.6.1 | **Regression Test Approach** |  | 10d | 2024-11-18 A | 2024-11-29 |  | 100% |  | 2025-02-28 | 2024-11-18 | 2024-11-29 | 0d |  | SI Test | SIT | -686.67 | 6.17 | Roger Robar | SITAG |  |  |  |  |  |
| 1434 | 1.4.1.4.6.1.1 | Develop approach doc |  | 45d | 2024-11-18 A | 2025-01-17 A |  | 100% |  |  | 2024-11-18 | 2025-01-17 | 0d | start no earlier than 2024-09-16 | SI Test | SIT |  | 6.17 | Roger Robar | SITAG | Complete | COMPLETE |  |  |  |
| 1435 | 1.4.1.4.6.1.2 | SRO / LDP review of approach doc |  | 5d | 2025-01-20 A | 2025-01-24 A | 1434 | 100% |  |  | 2025-01-20 | 2025-01-24 | 0d |  | SI Test | SIT |  | 6.17 | Roger Robar | SITAG | Complete | COMPLETE |  |  |  |
| 1436 | 1.4.1.4.6.1.3 | Incorporate SRO feedback into approach doc |  | 5d | 2025-01-20 A | 2025-01-24 A | 1435FF | 100% |  |  | 2025-01-20 | 2025-01-24 | 0d |  | SI Test | SIT |  | 6.17 | Roger Robar | SITAG | Complete | COMPLETE |  |  |  |
| 1437 | 1.4.1.4.6.1.4 | Industry review of approach |  | 10d | 2025-01-27 A | 2025-02-07 A | 1436 | 100% |  |  | 2025-01-27 | 2025-02-07 | 0d |  | SI Test | SIT |  | 6.17 | Roger Robar | SITAG | Complete | COMPLETE |  |  |  |
| 1438 | 1.4.1.4.6.1.5 | Updates to approach doc on back of industry feedback |  | 2d | 2025-02-10 A | 2025-02-11 A | 1437 | 100% |  |  | 2025-02-10 | 2025-02-11 | 0d |  | SI Test | SIT |  | 6.17 | Roger Robar | SITAG | Complete | COMPLETE |  |  |  |
| 1439 | 1.4.1.4.6.1.6 | eSITWG paper day | milestone | 0d | 2025-02-11 A | 2025-02-11 A | 1438 | 100% |  |  | 2025-02-11 | 2025-02-11 | 0d |  | SI Test | SIT |  | 6.17 | Roger Robar | SITAG | Complete | COMPLETE |  |  |  |
| 1440 | 1.4.1.4.6.1.7 | eSITWG Recommendation | milestone | 0d | 2025-02-18 A | 2025-02-18 A | 1439FS+5d | 100% |  |  | 2025-02-18 | 2025-02-18 | 0d | start no earlier than 2025-01-20 | SI Test | SIT |  | 6.17 | Roger Robar | SITAG | Complete | COMPLETE |  |  |  |
| 1441 | 1.4.1.4.6.1.8 | Incorporate eSITWG feedback into approach doc |  | 2d | 2025-02-19 A | 2025-02-20 A | 1440 | 100% |  |  | 2025-02-19 | 2025-02-20 | 0d |  | SI Test | SIT |  | 6.17 | Roger Robar | SITAG | Complete | COMPLETE |  |  |  |
| 1442 | 1.4.1.4.6.1.9 | eSITAG paper day | milestone | 0d | 2025-02-20 A | 2025-02-20 A | 1441 | 100% |  |  | 2025-02-20 | 2025-02-20 | 0d |  | SI Test | SIT |  | 6.17 | Roger Robar | SITAG | Complete | COMPLETE |  |  |  |
| 1443 | 1.4.1.4.6.1.10 | eSITAG (inc SRO) Approval | milestone | 0d | 2025-02-28 A | 2025-02-28 A | 1442FS+5d | 100% |  |  | 2025-02-28 | 2025-02-28 | 0d | finish no earlier than 2025-02-28 | SI Test | SIT |  | 6.17 | Roger Robar | SITAG | Complete | COMPLETE |  |  |  |
| 1444 | 1.4.1.4.6.1.11 | SIT Regression Testing Approach and Plan Approval | milestone | 0d | 2025-02-28 A | 2025-02-28 A | 1443 | 100% |  |  | 2025-02-28 | 2025-02-28 | 0d |  | SI Test | SIT |  | 6.17 | Roger Robar | SITAG | Complete | COMPLETE | T3-TE-0123 | T3 |  |
| 1445 | 1.4.1.4.6.2 | **Regression Core Test Pack** |  | 52d? | 2025-02-12 A | 2025-04-24 A |  | 100% |  |  | 2025-02-12 | 2025-04-16 | 0d |  | SI Test | SIT | -686.67 | 6.17 | Roger Robar | SITAG |  |  |  |  |  |
| 1446 | 1.4.1.4.6.2.1 | Build Regression Core Pack |  | 17d | 2025-02-12 A | 2025-03-06 A | 1439, 1449FF | 100% |  |  |  |  |  | start no earlier than 2025-02-12 | SI Test | SIT |  | 6.19 | Roger Robar | SITAG | Complete | COMPLETE |  |  |  |
| 1447 | 1.4.1.4.6.2.2 | Build Regression Framework |  | 12d | 2025-02-12 A | 2025-02-27 A | 1439 | 100% |  |  | 2025-02-12 | 2025-02-28 | 0d |  | SI Test | SIT |  | 6.17 | Roger Robar | SITAG | Complete | COMPLETE |  |  |  |
| 1448 | 1.4.1.4.6.2.3 | SITWG paper day | milestone | 0d | 2025-02-27 A | 2025-02-27 A | 1447 | 100% |  |  | 2025-02-27 | 2025-02-27 | 0d | start no earlier than 2025-02-27 | SI Test | SIT |  | 6.17 | Roger Robar | SITAG | Complete | COMPLETE |  |  |  |
| 1449 | 1.4.1.4.6.2.4 | SITWG provides feedback on Regression Framework approach | milestone | 0d | 2025-03-06 A | 2025-03-06 A | 1448FS+5d | 100% |  |  | 2025-03-06 | 2025-03-06 | 0d |  | SI Test | SIT |  | 6.17 | Roger Robar | SITAG | Complete | COMPLETE |  |  |  |
| 1450 | 1.4.1.4.6.2.5 | LDP walkthrough of Regression Core Pack |  | 3d | 2025-02-27 A | 2025-03-03 A | 1446SS | 100% |  |  | 2025-02-28 | 2025-02-28 | 0d | start no earlier than 2025-02-27 | SI Test | SIT |  | 6.17 | Roger Robar | SITAG | Complete | COMPLETE |  |  |  |
| 1451 | 1.4.1.4.6.2.6 | SRO Review of Regression Core Pack |  | 6d | 2025-03-07 A | 2025-03-14 A | 1446SS | 100% |  |  | 2025-03-03 | 2025-03-07 | 0d | start no earlier than 2025-03-07 | SI Test | SIT |  | 6.20 | Roger Robar | SITAG | Complete | COMPLETE |  |  |  |
| 1452 | 1.4.1.4.6.2.7 | Incorporate SRO feedback into Regression Core Pack |  | 6d | 2025-03-07 A | 2025-03-14 A | 1451SS | 100% |  |  | 2025-03-03 | 2025-03-07 | 0d |  | SI Test | SIT |  | 6.20 | Roger Robar | SITAG | Complete | COMPLETE |  |  |  |
| 1453 | 1.4.1.4.6.2.8 | Industry review of Regression Core Pack |  | 10d | 2025-03-17 A | 2025-03-28 A | 1452, 1446 | 100% |  |  | 2025-03-17 | 2025-03-28 | 0d | start no earlier than 2025-03-13 | SI Test | SIT |  | 6.21 | Roger Robar | SITAG | Complete | COMPLETE |  |  |  |
| 1454 | 1.4.1.4.6.2.9 | Regression Test Framework Core Pack - PP Walkthrough |  | 1d? | 2025-03-20 A | 2025-03-20 A | 1453SS | 100% |  |  | 2025-03-20 | 2025-03-20 | 0d | start no earlier than 2025-03-20 | SI Test | SIT |  | 6.20 | Roger Robar | SITAG | Complete | COMPLETE |  |  |  |
| 1455 | 1.4.1.4.6.2.10 | Regression Test Framework Core Pack - Q&A Drop in session |  | 1d? | 2025-03-27 A | 2025-03-27 A | 1453SS | 100% |  |  | 2025-03-27 | 2025-03-27 | 0d | start no earlier than 2025-03-27 | SI Test | SIT |  | 6.21 | Roger Robar | SITAG | Complete | COMPLETE |  |  |  |
| 1456 | 1.4.1.4.6.2.11 | Incorporate Industry feedback into Regression Core Pack |  | 3d | 2025-03-31 A | 2025-04-02 A | 1453, 1454, 1455 | 100% |  |  | 2025-03-31 | 2025-04-02 | 0d |  | SI Test | SIT |  | 6.21 | Roger Robar | SITAG | Complete | COMPLETE |  |  |  |
| 1457 | 1.4.1.4.6.2.12 | Second industry review of Regression Core Pack |  | 5d | 2025-04-03 A | 2025-04-09 A | 1456 | 100% |  |  | 2025-04-03 | 2025-04-09 | 0d |  | SI Test | SIT |  | 6.21 | Roger Robar | SITAG | Complete | COMPLETE |  |  |  |
| 1458 | 1.4.1.4.6.2.13 | Incorporate industry feedback into regression Core Pack |  | 1d | 2025-04-10 A | 2025-04-10 A | 1457 | 100% |  |  | 2025-04-10 | 2025-04-10 | 0d |  | SI Test | SIT |  | 6.21 | Roger Robar | SITAG | Complete | COMPLETE |  |  |  |
| 1459 | 1.4.1.4.6.2.14 | SITWG paper day | milestone | 0d | 2025-04-08 A | 2025-04-08 A |  | 100% |  |  | 2025-04-10 | 2025-04-10 | 0d | finish no earlier than 2025-04-08 | SI Test | SIT |  | 6.21 | Roger Robar | SITAG | Complete | COMPLETE |  |  |  |
| 1460 | 1.4.1.4.6.2.15 | SITWG endorses regression Core Pack | milestone | 0d | 2025-04-15 A | 2025-04-15 A | 1459FS+3d | 100% |  |  | 2025-04-15 | 2025-04-15 | 0d | finish no earlier than 2025-04-15 | SI Test | SIT |  | 6.21 | Roger Robar | SITAG | Complete | COMPLETE |  |  |  |
| 1461 | 1.4.1.4.6.2.16 | Incorporate SITWG feedback into regression Core Pack |  | 2d | 2025-04-16 A | 2025-04-17 A | 1460 | 100% |  |  | 2025-04-16 | 2025-04-17 | 0d | start no earlier than 2025-04-16 | SI Test | SIT |  | 6.21 | Roger Robar | SITAG | Complete | COMPLETE |  |  |  |
| 1462 | 1.4.1.4.6.2.17 | Regression Test Approach and Plan Uplift | milestone | 0d | 2025-04-16 A | 2025-04-16 A | 1460 | 100% |  |  | 2025-04-16 | 2025-04-16 | 0d | start no earlier than 2025-04-16 | SI Test | SIT |  | 6.21 | Roger Robar | SITAG | Complete | COMPLETE |  |  |  |
| 1463 | 1.4.1.4.6.2.18 | Industry Review on the Uplifted Test Approach and Plan |  | 5d | 2025-04-17 A | 2025-04-23 A | 1462 | 100% |  |  | 2025-04-17 | 2025-04-23 | 0d | finish no earlier than 2025-04-23 | SI Test | SIT |  | 6.21 | Roger Robar | SITAG | Complete | COMPLETE |  |  |  |
| 1464 | 1.4.1.4.6.2.19 | SITAG paper day | milestone | 0d | 2025-04-17 A | 2025-04-17 A |  | 100% |  |  | 2025-04-17 | 2025-04-17 | 0d | finish no earlier than 2025-04-17 | SI Test | SIT |  | 6.20 | Roger Robar | SITAG | Complete | COMPLETE |  |  |  |
| 1465 | 1.4.1.4.6.2.20 | SITAG (inc SRO) Approval of regression Core Pack | milestone | 0d | 2025-04-24 A | 2025-04-24 A | 1464FS+5d, 1463 | 100% |  |  | 2025-04-24 | 2025-04-24 | 0d | start no earlier than 2025-04-24 | SI Test | SIT |  | 6.21 | Roger Robar | SITAG | Complete | COMPLETE |  |  |  |
| 1466 | 1.4.1.4.6.2.21 | SIT Regression Approval | milestone | 0d | 2025-04-24 A | 2025-04-24 A | 1465 | 100% |  |  | 2025-04-24 | 2025-04-24 | 0d |  | SI Test | SIT |  | 6.20 | Roger Robar | SITAG | Complete | COMPLETE | T3-TE-0122 | T3 | SITAG |

| ID | WBS | Task | Type | Duration | Start | Finish | Predecessors | Complete | Remaining | Actual start | Baseline start | Baseline finish | Baseline duration | Total slack | Free slack | Constraint | Responsible | Text9 | Task Status | Update Version | MHHS Resource Name | Text29 | Sched Status | RAG | Milestone ID | Tier |
| --- | --- | --- | --- | --- | --- | --- | --- | --- | --- | --- | --- | --- | --- | --- | --- | --- | --- | --- | --- | --- | --- | --- | --- | --- | --- | --- |
| 1467 | 1.4.1.4.6.3 | **Regression Test Data Load Window (SIT Functional and Migration) - SIT A** |  | 1d? | 2025-04-28 | 2025-04-29 |  | 76% | 0.24d? | 2025-03-31 | 2025-03-14 | 2025-03-17 | 0d |  |  |  | SI Test | SIT | -686.67 | 6.15 | Michael Inije | SITAG |  |  |  |  |
| 1468 | 1.4.1.4.6.3.1 | Data Load preparation activities |  | 20d | 2025-03-31 A | 2025-04-25 A | 1427 | 100% |  |  | 2025-03-31 | 2025-04-25 | 0d |  |  | start no earlier than 2025-03-17 | SI Test | SIT |  | 6.15 | Michael Inije | SITAG | Complete | COMPLETE |  |  |
| 1469 | 1.4.1.4.6.3.2 | Regression Test Data Load Start | milestone | 0d | 2025-04-28 A | 2025-04-28 A | 1683, 1563FS+1d, 1687FS+1d, 1468, 1466 | 100% |  |  | 2025-04-28 | 2025-04-28 | 0d |  |  |  | SI Test | SIT |  | 6.15 | Michael Inije | SITAG | Complete | COMPLETE | T2-TE-1000 | T2 |
| 1470 | 1.4.1.4.6.3.3 | Regression Test Data Load Window |  | 14d | 2025-04-29 A | 2025-05-16 | 1469 | 43% | 8d |  | 2025-04-28 | 2025-05-16 | 0d | 5d | 0d | start no earlier than 2025-04-28 | SI Test | SIT |  | 6.15 | Michael Inije | SITAG | Green | GREEN |  |  |
| 1471 | 1.4.1.4.7 | **Single Instance ADO** |  | 32d? | 2024-08-21 A | 2024-10-03 A |  | 100% |  |  | 2024-08-21 | 2024-10-03 | 0d |  |  |  | SI Test | SIT | -701.67 | 6.1 | Heath Thomas | SITAG |  |  |  |  |
| 1472 | 1.4.1.4.7.1 | **Single ADO Project for all Cohorts - Implementation and Test Phase** |  | 30d? | 2024-08-21 A | 2024-10-01 A |  | 100% |  |  | 2024-08-21 | 2024-10-01 | 0d |  |  |  | SI Test | SIT | -701.67 | 6.1 | Heath Thomas | SITAG |  |  |  |  |
| 1473 | 1.4.1.4.7.1.1 | Create test plans and suites in master project |  | 2d? | 2024-08-21 A | 2024-08-22 A |  | 100% |  |  | 2024-08-21 | 2024-08-22 | 0d |  |  | finish no earlier than 2024-08-22 | SI Test | SIT |  | 6.1 | Heath Thomas | SITAG | Complete | COMPLETE |  |  |
| 1474 | 1.4.1.4.7.1.2 | Create area paths / iterations |  | 2d? | 2024-08-21 A | 2024-08-22 A |  | 100% |  |  | 2024-08-21 | 2024-08-22 | 0d |  |  | finish no earlier than 2024-08-22 | SI Test | SIT |  | 6.1 | Heath Thomas | SITAG | Complete | COMPLETE |  |  |
| 1475 | 1.4.1.4.7.1.3 | Create IAM roles |  | 2d? | 2024-08-21 A | 2024-08-22 A |  | 100% |  |  | 2024-08-21 | 2024-08-22 | 0d |  |  | finish no earlier than 2024-08-22 | SI Test | SIT |  | 6.1 | Heath Thomas | SITAG | Complete | COMPLETE |  |  |
| 1476 | 1.4.1.4.7.1.4 | Add users to roles |  | 1d? | 2024-08-23 A | 2024-08-23 A |  | 100% |  |  | 2024-08-23 | 2024-08-23 | 0d |  |  | start no earlier than 2024-08-23 | SI Test | SIT |  | 6.1 | Heath Thomas | SITAG | Complete | COMPLETE |  |  |
| 1477 | 1.4.1.4.7.1.5 | **Testing permissions** |  | 2d? | 2024-08-27 A | 2024-08-28 A |  | 100% |  |  | 2024-08-27 | 2024-08-28 | 0d |  |  |  | SI Test | SIT |  | 6.1 | Heath Thomas | SITAG | Complete | COMPLETE |  |  |
| 1478 | 1.4.1.4.7.1.5.1 | Adding tests |  | 2d? | 2024-08-27 A | 2024-08-28 A |  | 100% |  |  | 2024-08-27 | 2024-08-28 | 0d |  |  | finish no earlier than 2024-08-28 | SI Test | SIT |  | 6.1 | Heath Thomas | SITAG | Complete | COMPLETE |  |  |
| 1479 | 1.4.1.4.7.1.5.2 | Deleting tests |  | 2d? | 2024-08-27 A | 2024-08-28 A |  | 100% |  |  | 2024-08-27 | 2024-08-28 | 0d |  |  | finish no earlier than 2024-08-28 | SI Test | SIT |  | 6.1 | Heath Thomas | SITAG | Complete | COMPLETE |  |  |
| 1480 | 1.4.1.4.7.1.5.3 | Adding tests to incorrect Cohort |  | 2d? | 2024-08-27 A | 2024-08-28 A |  | 100% |  |  | 2024-08-27 | 2024-08-28 | 0d |  |  | finish no earlier than 2024-08-28 | SI Test | SIT |  | 6.1 | Heath Thomas | SITAG | Complete | COMPLETE |  |  |
| 1481 | 1.4.1.4.7.1.5.4 | Add / delete defects |  | 2d? | 2024-08-27 A | 2024-08-28 A |  | 100% |  |  | 2024-08-27 | 2024-08-28 | 0d |  |  | finish no earlier than 2024-08-28 | SI Test | SIT |  | 6.1 | Heath Thomas | SITAG | Complete | COMPLETE |  |  |
| 1482 | 1.4.1.4.7.1.6 | Migrate defects from cohort project to master - Option 2 |  | 3d | 2024-09-23 A | 2024-09-25 A |  | 100% |  |  | 2024-09-23 | 2024-09-25 | 0d |  |  | start no earlier than 2024-09-23 | SI Test | SIT |  | 6.1 | Heath Thomas | SITAG | Complete | COMPLETE |  |  |
| 1483 | 1.4.1.4.7.1.7 | Testing Permissions - Evidence attachment security |  | 10d? | 2024-09-18 A | 2024-10-01 A |  | 100% |  |  | 2024-09-18 | 2024-10-01 | 0d |  |  | finish no earlier than 2024-10-01 | SI Test | SIT |  | 6.1 | Heath Thomas | SITAG | Complete | COMPLETE |  |  |
| 1484 | 1.4.1.4.7.2 | **ADO Dashboard Updates** |  | 20d? | 2024-09-03 A | 2024-09-30 A |  | 100% |  |  | 2024-09-03 | 2024-09-30 | 0d |  |  |  | SI Test | SIT | -701.67 | 6.1 | Heath Thomas | SITAG | Overdue Start |  |  |  |
| 1485 | 1.4.1.4.7.2.1 | Update reporting dashboards in ADO |  | 3d | 2024-09-03 A | 2024-09-05 A |  | 100% |  |  | 2024-09-03 | 2024-09-05 | 0d |  |  | start no earlier than 2024-09-03 | SI Test | SIT |  | 6.1 | Heath Thomas | SITAG | Complete | COMPLETE |  |  |
| 1486 | 1.4.1.4.7.2.2 | Review dashboards with SI LDP leads |  | 16d | 2024-09-06 A | 2024-09-27 A |  | 100% |  |  | 2024-09-06 | 2024-09-27 | 0d |  |  | start no earlier than 2024-09-06 | SI Test | SIT |  | 6.1 | Heath Thomas | SITAG | Complete | COMPLETE |  |  |
| 1487 | 1.4.1.4.7.2.3 | Review dashboards with SRO |  | 16d | 2024-09-09 A | 2024-09-30 A |  | 100% |  |  | 2024-09-09 | 2024-09-30 | 0d |  |  | start no earlier than 2024-09-09 | SI Test | SIT |  | 6.1 | Heath Thomas | SITAG | Complete | COMPLETE |  |  |
| 1488 | 1.4.1.4.7.2.4 | Update dashboards following review |  | 2d | 2024-09-12 A | 2024-09-13 A |  | 100% |  |  | 2024-09-12 | 2024-09-13 | 0d |  |  | start no earlier than 2024-09-12 | SI Test | SIT |  | 6.1 | Heath Thomas | SITAG | Complete | COMPLETE |  |  |
| 1489 | 1.4.1.4.7.2.5 | Document changes to dashboard creation process |  | 4d | 2024-09-16 A | 2024-09-19 A |  | 100% |  |  | 2024-09-16 | 2024-09-19 | 0d |  |  | start no earlier than 2024-09-16 | SI Test | SIT |  | 6.1 | Heath Thomas | SITAG | Complete | COMPLETE |  |  |
| 1490 | 1.4.1.4.7.2.6 | Update SIT Dashboards for Sprints 4.1 & 4.2 across all Cohorts |  | 1d? | 2024-09-03 A | 2024-09-03 A |  | 100% |  |  | 2024-09-03 | 2024-09-03 | 0d |  |  | start no earlier than 2024-09-03 | SI Test | SIT |  | 6.1 | Heath Thomas | SITAG | Complete | COMPLETE |  |  |

| ID | WBS | Task | Duration | Start | Finish | Complete | Baseline start | Baseline finish | Baseline duration | Constraint | Responsible | Text9 | Task Status | Update Version | Sched Status | MHHS Resource Name | Text29 | RAG |
| --- | --- | --- | --- | --- | --- | --- | --- | --- | --- | --- | --- | --- | --- | --- | --- | --- | --- | --- |
| 1491 | 1.4.1.4.7.3 | **Reporting Changes - PowerBI & QIP** | 23d? | 2024-08-23 A | 2024-09-24 A | 100% | 2024-08-23 | 2024-09-24 | 0d |  | SI Test | SIT | -701.67 | 6.1 | Overdue Start | Heath Thomas | SITAG |  |
| 1492 | 1.4.1.4.7.3.1 | Design, Create and ETL ADO Entities into PowerBI Data Model | 1d? | 2024-08-23 A | 2024-08-23 A | 100% | 2024-08-23 | 2024-08-23 | 0d | start no earlier than 2024-08-23 | SI Test | SIT |  | 6.1 | Complete | Heath Thomas | SITAG | COMPLETE |
| 1493 | 1.4.1.4.7.3.2 | Determine Relationships between ADO Entities & Attributes | 1d? | 2024-08-27 A | 2024-08-27 A | 100% | 2024-08-27 | 2024-08-27 | 0d | start no earlier than 2024-08-27 | SI Test | SIT |  | 6.1 | Complete | Heath Thomas | SITAG | COMPLETE |
| 1494 | 1.4.1.4.7.3.3 | Create Relevant Dax Measures | 1d? | 2024-08-28 A | 2024-08-28 A | 100% | 2024-08-28 | 2024-08-28 | 0d | start no earlier than 2024-08-28 | SI Test | SIT |  | 6.1 | Complete | Heath Thomas | SITAG | COMPLETE |
| 1495 | 1.4.1.4.7.3.4 | Design & Build Visualisations (Graphs) | 1d? | 2024-08-29 A | 2024-08-29 A | 100% | 2024-08-29 | 2024-08-29 | 0d | start no earlier than 2024-08-29 | SI Test | SIT |  | 6.1 | Complete | Heath Thomas | SITAG | COMPLETE |
| 1496 | 1.4.1.4.7.3.5 | Implement Filters | 1d? | 2024-09-23 A | 2024-09-23 A | 100% | 2024-09-23 | 2024-09-23 | 0d | start no earlier than 2024-09-23 | SI Test | SIT |  | 6.1 | Complete | Heath Thomas | SITAG | COMPLETE |
| 1497 | 1.4.1.4.7.3.6 | Check Data Quality & Integrity | 1d? | 2024-09-24 A | 2024-09-24 A | 100% | 2024-09-24 | 2024-09-24 | 0d | start no earlier than 2024-09-24 | SI Test | SIT |  | 6.1 | Complete | Heath Thomas | SITAG | COMPLETE |
| 1498 | 1.4.1.4.7.3.7 | Performance Optimisation | 1d? | 2024-09-24 A | 2024-09-24 A | 100% | 2024-09-24 | 2024-09-24 | 0d | start no earlier than 2024-09-24 | SI Test | SIT |  | 6.1 | Complete | Heath Thomas | SITAG | COMPLETE |
| 1499 | 1.4.1.4.7.4 | **Reporting Changes - Daily Excel Extract & PDF** | 2d | 2024-09-05 A | 2024-09-06 A | 100% | 2024-09-05 | 2024-09-06 | 0d |  | SI Test | SIT | -701.67 | 6.1 | Overdue Start | Heath Thomas | SITAG |  |
| 1500 | 1.4.1.4.7.4.1 | Excel Daily Report changes (Refer to above) | 2d | 2024-09-05 A | 2024-09-06 A | 100% | 2024-09-05 | 2024-09-06 | 0d | start no earlier than 2024-09-05 | SI Test | SIT |  | 6.1 | Complete | Heath Thomas | SITAG | COMPLETE |
| 1501 | 1.4.1.4.7.4.2 | PDF Daily Report changes (Refer to Above) | 2d | 2024-09-05 A | 2024-09-06 A | 100% | 2024-09-05 | 2024-09-06 | 0d | start no earlier than 2024-09-05 | SI Test | SIT |  | 6.1 | Complete | Heath Thomas | SITAG | COMPLETE |
| 1502 | 1.4.1.4.7.5 | **Documentation Updates** | 23d? | 2024-09-02 A | 2024-10-02 A | 100% | 2024-09-02 | 2024-10-02 | 0d |  | SI Test | SIT | -701.67 | 6.1 | Overdue Start | Heath Thomas | SITAG |  |
| 1503 | 1.4.1.4.7.5.1 | Changes to onboarding process (security) | 10d | 2024-09-02 A | 2024-09-13 A | 100% | 2024-09-02 | 2024-09-13 | 0d | start no earlier than 2024-09-02 | SI Test | SIT |  | 6.1 | Complete | Heath Thomas | SITAG | COMPLETE |
| 1504 | 1.4.1.4.7.5.2 | Update the documents on loading tests into ADO? | 10d | 2024-09-02 A | 2024-09-13 A | 100% | 2024-09-02 | 2024-09-13 | 0d | start no earlier than 2024-09-02 | SI Test | SIT |  | 6.1 | Complete | Heath Thomas | SITAG | COMPLETE |
| 1505 | 1.4.1.4.7.5.3 | Update ADO Training material | 10d | 2024-09-02 A | 2024-09-13 A | 100% | 2024-09-02 | 2024-09-13 | 0d | start no earlier than 2024-09-02 | SI Test | SIT |  | 6.1 | Complete | Heath Thomas | SITAG | COMPLETE |
| 1506 | 1.4.1.4.7.5.4 | Update ADO User Guide | 10d | 2024-09-02 A | 2024-09-13 A | 100% | 2024-09-02 | 2024-09-13 | 0d | start no earlier than 2024-09-02 | SI Test | SIT |  | 6.1 | Complete | Heath Thomas | SITAG | COMPLETE |
| 1507 | 1.4.1.4.7.5.5 | Update ADO Configuration document | 10d | 2024-09-02 A | 2024-09-13 A | 100% | 2024-09-02 | 2024-09-13 | 0d | start no earlier than 2024-09-02 | SI Test | SIT |  | 6.1 | Complete | Heath Thomas | SITAG | COMPLETE |
| 1508 | 1.4.1.4.7.5.6 | Update ADO Training Material and User Guide following SRO review | 1d? | 2024-10-02 A | 2024-10-02 A | 100% | 2024-10-02 | 2024-10-02 | 0d | start no earlier than 2024-10-02 | SI Test | SIT |  | 6.1 | Complete | Heath Thomas | SITAG | COMPLETE |
| 1509 | 1.4.1.4.7.6 | **ADO Changes - Review Stage** | 19d? | 2024-09-09 A | 2024-10-03 A | 100% | 2024-09-09 | 2024-10-03 | 0d |  | SI Test | SIT | -701.67 | 6.1 | Overdue Start | Heath Thomas | SITAG |  |
| 1510 | 1.4.1.4.7.6.1 | Review implementation with SI LDP leads | 1d? | 2024-09-27 A | 2024-09-27 A | 100% | 2024-09-27 | 2024-09-27 | 0d | start no earlier than 2024-09-27 | SI Test | SIT |  | 6.1 | Complete | Heath Thomas | SITAG | COMPLETE |
| 1511 | 1.4.1.4.7.6.2 | Review implementation with SRO | 1d? | 2024-09-30 A | 2024-09-30 A | 100% | 2024-09-30 | 2024-09-30 | 0d | start no earlier than 2024-09-30 | SI Test | SIT |  | 6.1 | Complete | Heath Thomas | SITAG | COMPLETE |
| 1512 | 1.4.1.4.7.6.3 | LDP Review - ADO User Guide, Training Materials | 5d | 2024-09-09 A | 2024-09-13 A | 100% | 2024-09-09 | 2024-09-13 | 0d | start no earlier than 2024-09-09 | SI Test | SIT |  | 6.1 | Complete | Heath Thomas | SITAG | COMPLETE |
| 1513 | 1.4.1.4.7.6.4 | SRO Review - ADO User Guide, Training Materials | 1d? | 2024-09-30 A | 2024-09-30 A | 100% | 2024-09-30 | 2024-09-30 | 0d | start no earlier than 2024-09-30 | SI Test | SIT |  | 6.1 | Complete | Heath Thomas | SITAG | COMPLETE |
| 1514 | 1.4.1.4.7.6.5 | LDP Review - Config doc | 1d? | 2024-09-30 A | 2024-09-30 A | 100% | 2024-09-30 | 2024-09-30 | 0d | start no earlier than 2024-09-30 | SI Test | SIT |  | 6.1 | Complete | Heath Thomas | SITAG | COMPLETE |
| 1515 | 1.4.1.4.7.6.6 | SRO Review - Config doc | 1d? | 2024-09-30 A | 2024-09-30 A | 100% | 2024-09-30 | 2024-09-30 | 0d | start no earlier than 2024-09-30 | SI Test | SIT |  | 6.1 | Complete | Heath Thomas | SITAG | COMPLETE |
| 1516 | 1.4.1.4.7.6.7 | SRO Sign-off of all changes | 1d? | 2024-10-03 A | 2024-10-03 A | 100% | 2024-10-03 | 2024-10-03 | 0d | start no earlier than 2024-10-03 | SI Test | SIT |  | 6.1 | Complete | Heath Thomas | SITAG | COMPLETE |

| ID | WBS | Task | Type | Duration | Start | Finish | Predecessors | Complete | Remaining | Baseline start | Baseline finish | Baseline duration | Baseline 1 start | Baseline 1 finish | Total slack | Constraint | Baseline cost | Responsible | Text9 | Task Status | Update Version | Sched Status | MHHS Resource Name | Text29 | RAG | Involved | MHHS Programme Phase | Artefact ID | Milestone ID | Tier | Future RAG |
| --- | --- | --- | --- | --- | --- | --- | --- | --- | --- | --- | --- | --- | --- | --- | --- | --- | --- | --- | --- | --- | --- | --- | --- | --- | --- | --- | --- | --- | --- | --- | --- |
| 1517 | 1.4.1.4.7.7 | **Azure DevOps Changes - Final Implementation** |  | 1d? | 2024-10-03 A | 2024-10-03 A |  | 100% |  | 2024-10-03 | 2024-10-03 | 0d |  |  |  |  |  | SI Test | SIT | -701.67 | 6.1 | Overdue Start | Heath Thomas | SITAG |  |  |  |  |  |  |  |
| 1518 | 1.4.1.4.7.7.1 | Final task rollout |  | 1d? | 2024-10-03 A | 2024-10-03 A |  | 100% |  | 2024-10-03 | 2024-10-03 | 0d |  |  |  | start no earlier than 2024-10-03 |  | SI Test | SIT |  | 6.1 | Complete | Heath Thomas | SITAG | COMPLETE |  |  |  |  |  |  |
| 1519 | 1.4.1.4.7.7.2 | ADO Training Drop-in Session ahead of Cycle 3 |  | 1d? | 2024-10-03 A | 2024-10-03 A |  | 100% |  | 2024-10-03 | 2024-10-03 | 0d |  |  |  | start no earlier than 2024-10-03 |  | SI Test | SIT |  | 6.1 | Complete | Heath Thomas | SITAG | COMPLETE |  |  |  |  |  |  |
| 1520 | 1.4.2 | **SIT Execution** |  | 543d? | 2023-10-30 A | 2025-11-26 |  | 49% | 275.84d? | 2022-10-31 | 2025-11-27 | 390d | 2023-10-30 | 2025-04-25 | 541d |  | -0 | N/A | SIT |  | 5.0 |  | N/A | SITAG |  | N/A | Systems Integration Testing (SIT) |  |  |  |  |
| 1521 | 1.4.2.1 | System Integration Testing Start (M9) | milestone | 0d | 2023-10-30 A | 2023-10-30 A | 712FS+5d, 626 | 100% |  | 2023-10-30 | 2023-10-30 | 0d | 2023-10-30 | 2023-10-30 |  | must start on 2023-10-30 |  | CPT | SIT |  | 5.11 | Complete |  | SITAG | COMPLETE | PMO | Systems Integration Testing (SIT) | MHHS-ART071 | T1-TE-1000 | T1 |  |
| 1522 | 1.4.2.2 | **SIT Component Integration Testing** |  | 96d | 2023-10-30 A | 2024-03-11 A |  | 100% |  | 2023-10-30 | 2024-03-11 | 95d | 2023-10-30 | 2024-03-08 |  |  |  | N/A | SIT |  | 5.0 |  | N/A | SITAG |  | N/A | Systems Integration Testing (SIT) |  |  |  | D24A - Industry Integration Test Completion Report |
| 1523 | 1.4.2.2.1 | SIT Component Integration Testing Start | milestone | 0d | 2023-10-30 A | 2023-10-30 A | 1521 | 100% |  | 2023-10-30 | 2023-10-30 | 0d | 2023-10-30 | 2023-10-30 |  |  |  | SI Test | SIT |  | 5.11 | Complete |  | SITAG | COMPLETE | PP | Systems Integration Testing (SIT) |  |  |  |  |
| 1524 | 1.4.2.2.2 | Component Integration Testing Interval 1 Start | milestone | 0d | 2023-10-30 A | 2023-10-30 A | 712SS+1d, 633, 637, 641, 114 | 100% |  | 2023-10-30 | 2023-10-30 | 0d | 2023-10-30 | 2023-10-30 |  |  |  | SI Test | SIT |  | 5.11 | Complete |  | SITAG | COMPLETE | PP | Systems Integration Testing (SIT) | MHHS-ART071 | T3-TE-0060 | T3 |  |
| 1525 | 1.4.2.2.3 | Component Integration Testing Interval 2 Start | milestone | 0d | 2023-11-13 A | 2023-11-13 A | 739SS+5d, 633, 641, 637, 114 | 100% |  | 2023-11-13 | 2023-11-13 | 0d | 2023-11-13 | 2023-11-13 |  |  |  | SI Test | SIT |  | 5.12 | Complete |  | SITAG | COMPLETE | PP | Systems Integration Testing (SIT) |  | T3-TE-0061 | T3 |  |
| 1526 | 1.4.2.2.4 | Component Integration Testing Interval 3 Start | milestone | 0d | 2023-11-27 A | 2023-11-27 A | 771SS+5d, 633, 637, 641, 114 | 100% |  | 2023-11-27 | 2023-11-27 | 0d | 2023-11-27 | 2023-11-27 |  |  |  | SI Test | SIT |  | 5.0 | Complete |  | SITAG | COMPLETE | PP | Systems Integration Testing (SIT) |  | T3-TE-0062 | T3 |  |
| 1527 | 1.4.2.2.5 | Component Integration Testing Interval 4 Start | milestone | 0d | 2023-12-11 A | 2023-12-11 A | 803SS+5d, 633, 637, 641, 114 | 100% |  | 2023-12-11 | 2023-12-11 | 0d | 2023-12-11 | 2023-12-11 |  |  |  | SI Test | SIT |  | 5.0 | Complete |  | SITAG | COMPLETE | PP | Systems Integration Testing (SIT) |  | T3-TE-0063 | T3 |  |
| 1528 | 1.4.2.2.6 | Component Integration Testing Interval 5 Start | milestone | 0d | 2024-01-15 A | 2024-01-15 A | 835SS+5d, 633, 637, 641, 114 | 100% |  | 2024-01-15 | 2024-01-15 | 0d | 2024-01-15 | 2024-01-15 |  |  |  | SI Test | SIT |  | 5.0 | Complete |  | SITAG | COMPLETE | PP | Systems Integration Testing (SIT) |  | T3-TE-0064 | T3 |  |
| 1529 | 1.4.2.2.7 | Component Integration Testing Interval 6 Start | milestone | 0d | 2024-01-29 A | 2024-01-29 A | 633, 637, 641, 867, 114, 679 | 100% |  | 2024-01-29 | 2024-01-29 | 0d | 2024-01-29 | 2024-01-29 |  | must start on 2024-01-29 |  | SI Test | SIT |  | 5.0 | Complete |  | SITAG | COMPLETE | PP | Systems Integration Testing (SIT) |  | T3-TE-0065 | T3 |  |
| 1530 | 1.4.2.2.8 | SIT Component Integration Testing Execution |  | 85d | 2023-10-30 A | 2024-02-23 A | 1524SS | 100% |  | 2023-10-30 | 2024-02-23 | 85d | 2023-10-30 | 2024-02-23 |  | must start on 2023-10-30 |  | SI Test | SIT |  | 5.0 | Complete |  | SITAG | COMPLETE | PP | Systems Integration Testing (SIT) |  |  |  | D24A - Industry Integration Test Completion Report |
| 1531 | 1.4.2.2.9 | SIT Component Integration Testing End (incl. confirmation that PPs have submitted their Test Completion Reports to Programme for assurance) | milestone | 0d | 2024-02-23 A | 2024-02-23 A | 1530FF | 100% |  | 2024-02-23 | 2024-02-23 | 0d | 2024-02-23 | 2024-02-23 |  | finish no earlier than 2024-02-23 |  | SI Test | SIT |  | 5.19 | Complete |  | SITAG | COMPLETE | PP | Systems Integration Testing (SIT) | MHHS-ART074 | T3-TE-0032 | T3 |  |
| 1532 | 1.4.2.2.10 | Assurance of PPs Test Completion Reports |  | 30d | 2024-01-22 A | 2024-03-01 A | 1531FF+5d | 100% |  | 2024-01-22 | 2024-03-01 | 30d | 2024-01-22 | 2024-03-01 |  |  |  | SI Test | SIT |  | 5.19 | Complete |  | SITAG | COMPLETE | PP | Systems Integration Testing (SIT) |  |  |  |  |
| 1533 | 1.4.2.2.11 | **SIT CI Test Completion Report** |  | 18d | 2024-02-07 A | 2024-03-01 A |  | 100% |  | 2024-02-07 | 2024-03-01 | 18d | 2024-02-07 | 2024-03-01 |  |  |  | N/A | SIT |  | 5.0 |  | N/A | SITAG |  | N/A | Systems Integration Testing (SIT) |  |  |  |  |
| 1534 | 1.4.2.2.11.1 | Develop document |  | 13d | 2024-02-07 A | 2024-02-23 A | 1531FF | 100% |  | 2024-02-07 | 2024-02-23 | 13d | 2024-02-07 | 2024-02-23 |  |  |  | SI Test | SIT |  | 5.19 | Complete |  | SITAG | COMPLETE |  | Systems Integration Testing (SIT) |  |  |  |  |
| 1535 | 1.4.2.2.11.2 | Review & agree document |  | 5d | 2024-02-26 A | 2024-03-01 A | 1534, 1532FF | 100% |  | 2024-02-26 | 2024-03-01 | 5d | 2024-02-26 | 2024-03-01 |  |  |  | SI Test | SIT |  | 5.19 | Complete |  | SITAG | COMPLETE | PP,IPA | Systems Integration Testing (SIT) |  |  |  |  |
| 1536 | 1.4.2.2.12 | SIT Component Integration Testing Test Completion Report Approved | milestone | 0d | 2024-03-11 A | 2024-03-11 A | 1535FS+6d | 100% |  | 2024-03-11 | 2024-03-11 | 0d | 2024-03-08 | 2024-03-08 |  |  |  | SI Test | SIT |  | 5.18 | Complete |  | SITAG | COMPLETE | PP | Systems Integration Testing (SIT) | MHHS-ART074 | T2-TE-0600 | T2 |  |
| 1537 | 1.4.2.3 | **SIT** |  | 380d? | 2024-03-11 A | 2025-08-22 |  | 52% | 184.08d? | 2022-10-31 | 2025-08-22 | 240d | 2024-03-11 | 2025-02-07 | 609d |  | -0 | N/A | SIT |  | 6.24 |  | N/A | SITAG |  | N/A | Systems Integration Testing (SIT) |  |  |  |  |
| 1538 | 1.4.2.3.1 | **SIT Functional Testing (MVC)** |  | 375d? | 2024-03-11 A | 2025-08-15 |  | 58% | 156.42d? | 2022-10-31 | 2025-08-15 | 225d | 2024-03-11 | 2025-01-17 | 614d |  |  | N/A | SIT |  | 5.0 |  | N/A | SITAG |  | N/A | Systems Integration Testing (SIT) |  |  |  |  |
| 1539 | 1.4.2.3.1.1 | SIT Functional Testing Start | milestone | 0d | 2024-03-11 A | 2024-03-11 A | 1536, 995FS+5d, 874, 882, 883, 884, 891 | 100% |  | 2024-03-11 | 2024-03-11 | 0d | 2024-03-11 | 2024-03-11 |  |  |  | SI Test | SIT |  | 6.1 | Complete |  | SITAG | COMPLETE | PP | Systems Integration Testing (SIT) | MHHS-ART073 | T3-TE-0034 | T3 |  |
| 1540 | 1.4.2.3.1.2 | **SIT Functional Testing Execution (Minimum Viable Cohort)** |  | 295d? | 2024-03-11 A | 2025-04-28 A |  | 100% |  | 2022-10-31 | 2025-08-15 | 225d | 2024-03-11 | 2025-01-17 |  |  |  | N/A | SIT | M10 | 5.0 |  | N/A | SITAG |  | N/A | Systems Integration Testing (SIT) |  |  |  | D24C - E2E Test Completion Report |
| 1541 | 1.4.2.3.1.2.1 | **Cycle 1 (Full Cycle)** |  | 70d | 2024-03-11 A | 2024-06-14 A |  | 100% |  | 2024-03-11 | 2024-06-14 | 90d | 2024-03-11 | 2024-07-12 |  |  |  | N/A | SIT |  | 5.0 |  | N/A | SITAG |  | N/A | Systems Integration Testing (SIT) |  |  |  |  |
| 1542 | 1.4.2.3.1.2.1.1 | Test Execution |  | 55d | 2024-03-11 A | 2024-05-24 A | 1539SS-1d, 959 | 100% |  | 2024-03-11 | 2024-05-24 | 80d | 2024-03-11 | 2024-06-28 |  |  |  | PP | SIT |  | 5.0 | Complete |  | SITAG | COMPLETE | SI Test | Systems Integration Testing (SIT) |  |  |  |  |
| 1543 | 1.4.2.3.1.2.1.2 | Defect resolution, assurance, review, data & environments maintenance |  | 15d | 2024-05-27 A | 2024-06-14 A | 1542 | 100% |  | 2024-05-27 | 2024-06-14 | 10d | 2024-07-01 | 2024-07-12 |  |  |  | SI Test | SIT |  | 5.0 | Complete |  | SITAG | COMPLETE | PP | Systems Integration Testing (SIT) |  |  |  |  |

Notes:
- 1537: 06/05/25 - Programme is proposing that this be renamed to not include a reference to 'MVC'. Programme is proposing to rename 'SIT MVC' to 'SIT' and 'SIT Non-MVC' to 'SIT Contingency'. Testing evidence to date suggests all SIT PPs are in a position to complete SIT at the end of Regression, meaning the end of Regression is no longer just the target SIT end date for PPs who will be ready for M10, but all PPs. 'SIT non-MVC' will be renamed 'SIT Contingency', to show that SIT will still go on until November, as per the existing plan. This change is going to May SITAG for formal approval.

| ID | WBS | Task | Type | Duration | Start | Finish | Predecessors | Complete | Actual finish | Baseline start | Baseline finish | Baseline duration | Baseline 1 start | Baseline 1 finish | Constraint | Responsible | Involved | Text9 | Update Version | MHHS Resource Name | MHHS Programme Phase | Text29 | Sched Status | RAG | Milestone ID | Tier | Task Status |
| --- | --- | --- | --- | --- | --- | --- | --- | --- | --- | --- | --- | --- | --- | --- | --- | --- | --- | --- | --- | --- | --- | --- | --- | --- | --- | --- | --- |
| 1544 | 1.4.2.3.1.2.2 | **Cycle 2 (Defect retests and targeted regression testing)** |  | 80d | 2024-06-17 A | 2024-10-04 A |  | 100% |  | 2024-06-17 | 2024-10-04 | 50d | 2024-07-15 | 2024-09-20 |  | N/A | N/A | SIT | 5.0 | N/A | Systems Integration Testing (SIT) | SITAG |  |  |  |  |  |
| 1545 | 1.4.2.3.1.2.2.1 | Test Execution |  | 70d | 2024-06-17 A | 2024-09-20 A | 1543, 964 | 100% |  | 2024-06-17 | 2024-09-20 | 40d | 2024-07-15 | 2024-09-06 |  | PP | SI Test | SIT | 5.0 | Roger Robar | Systems Integration Testing (SIT) | SITAG | Complete | COMPLETE |  |  |  |
| 1546 | 1.4.2.3.1.2.2.2 | Defect resolution, assurance, review, data & environments maintenance |  | 10d | 2024-09-23 A | 2024-10-04 A | 1545 | 100% |  | 2024-09-23 | 2024-10-04 | 10d | 2024-09-09 | 2024-09-20 |  | SI Test | PP | SIT | 5.0 | Roger Robar | Systems Integration Testing (SIT) | SITAG | Complete | COMPLETE |  |  |  |
| 1547 | 1.4.2.3.1.2.3 | **SIT Functional Testing back-up progress risk-assessment** |  | 7d? | 2024-10-07 A | 2024-10-15 A |  | 100% |  | 2022-10-31 | 2022-10-31 | 20d | 2024-09-23 | 2024-10-18 |  | N/A | N/A | SIT | 5.31 | N/A | Systems Integration Testing (SIT) | SITAG |  |  |  |  |  |
| 1548 | 1.4.2.3.1.2.3.1 | Back-up risk-assessment of SIT Functional progress to assess whether Qualification Execution can start early |  | 1d? | 2024-10-07 A | 2024-10-07 A | 1546 | 100% |  | 2024-10-07 | 2024-10-07 | 0d |  |  |  | SI Test |  | SIT | 5.31 | Nicola Farley |  | SITAG | Complete | COMPLETE |  |  |  |
| 1549 | 1.4.2.3.1.2.3.2 | Back-up SITAG decision on early Qualification Testing Execution start |  | 1d? | 2024-10-15 A | 2024-10-15 A | 1548FS+5d | 100% |  | 2024-10-15 | 2024-10-15 | 0d |  |  |  | SI Test |  | SIT | 5.31 | Nicola Farley |  | SITAG | Complete | COMPLETE |  |  |  |
| 1550 | 1.4.2.3.1.2.4 | **Cycle 3 (Defect retests and targeted regression testing)** |  | 105d? | 2024-10-21 A | 2025-03-14 |  | 100% | 2025-04-28 | 2024-10-21 | 2025-03-14 | 30d | 2024-09-23 | 2024-11-01 |  | SI Test | N/A | SIT | 5.0 | Dom Mooney | Systems Integration Testing (SIT) | SITAG |  |  |  |  |  |
| 1551 | 1.4.2.3.1.2.4.1 | Sprint 5 |  | 10d? | 2024-10-21 A | 2024-11-01 A | 140SS-1d | 100% |  | 2024-10-21 | 2024-11-01 | 0d |  |  |  | SI Test |  | SIT | 6.0 | Dom Mooney |  | SITAG | Complete | COMPLETE |  |  |  |
| 1552 | 1.4.2.3.1.2.4.2 | Sprint 6 |  | 10d? | 2024-11-04 A | 2024-11-15 A | 1551 | 100% |  | 2024-11-04 | 2024-11-15 | 0d |  |  |  | SI Test |  | SIT | 6.0 | Dom Mooney |  | SITAG | Complete | COMPLETE |  |  |  |
| 1553 | 1.4.2.3.1.2.4.3 | Sprint 7 |  | 10d? | 2024-11-18 A | 2024-11-29 A | 1552 | 100% |  | 2024-11-18 | 2024-11-29 | 0d |  |  |  | SI Test |  | SIT | 6.0 | Dom Mooney |  | SITAG | Complete | COMPLETE |  |  |  |
| 1554 | 1.4.2.3.1.2.4.4 | Sprint 8 |  | 15d? | 2024-12-02 A | 2024-12-20 A | 1553 | 100% |  | 2024-12-02 | 2024-12-20 | 0d |  |  |  | SI Test |  | SIT | 6.0 | Dom Mooney |  | SITAG | Complete | COMPLETE |  |  |  |
| 1555 | 1.4.2.3.1.2.4.5 | Christmas downtime |  | 10d? | 2024-12-23 A | 2025-01-03 A | 1554 | 100% |  | 2024-12-23 | 2025-01-03 | 0d |  |  |  | SI Test |  | SIT | 6.0 | Dom Mooney |  | SITAG | Complete | COMPLETE |  |  |  |
| 1556 | 1.4.2.3.1.2.4.6 | Sprint 9 |  | 10d? | 2025-01-06 A | 2025-01-17 A | 1555 | 100% |  | 2025-01-06 | 2025-01-17 | 0d |  |  |  | SI Test |  | SIT | 6.0 | Dom Mooney |  | SITAG | Complete | COMPLETE |  |  |  |
| 1557 | 1.4.2.3.1.2.4.7 | Sprint 10 |  | 10d? | 2025-01-20 A | 2025-01-31 A | 1556 | 100% |  | 2025-01-20 | 2025-01-31 | 0d |  |  |  | SI Test |  | SIT | 6.0 | Dom Mooney |  | SITAG | Complete | COMPLETE |  |  |  |
| 1558 | 1.4.2.3.1.2.4.8 | Sprint 11 |  | 10d? | 2025-02-03 A | 2025-02-14 A | 1557 | 100% |  | 2025-02-03 | 2025-02-14 | 0d |  |  |  | SI Test |  | SIT | 6.0 | Dom Mooney |  | SITAG | Complete | COMPLETE |  |  |  |
| 1559 | 1.4.2.3.1.2.4.9 | Sprint 12 |  | 10d? | 2025-02-17 A | 2025-02-28 A | 1558 | 100% |  | 2025-02-17 | 2025-02-28 | 0d |  |  |  | SI Test |  | SIT | 6.0 | Dom Mooney |  | SITAG | Complete | COMPLETE |  |  |  |
| 1560 | 1.4.2.3.1.2.4.10 | Sprint 13 (RTTM Gap Analysis + CR056) |  | 10d? | 2025-03-03 A | 2025-03-14 A | 1559 | 100% |  | 2025-03-03 | 2025-03-14 | 0d |  |  |  | SI Test |  | SIT | 6.0 | Dom Mooney |  | SITAG | Complete | COMPLETE |  |  |  |
| 1561 | 1.4.2.3.1.2.4.11 | Sprint 14 (RTTM Gap Analysis + CR056) |  | 10d? | 2025-03-17 A | 2025-03-28 A | 1560 | 100% |  | 2025-03-17 | 2025-03-28 | 0d |  |  |  | SI Test |  | SIT | 6.1 | Dom Mooney |  | SITAG | Complete | COMPLETE |  |  |  |
| 1562 | 1.4.2.3.1.2.4.12 | Sprint 15 (Contingency 1) |  | 10d? | 2025-03-31 A | 2025-04-11 A | 1561 | 100% |  | 2025-03-31 | 2025-04-11 | 0d |  |  |  | SI Test |  | SIT | 6.1 | Dom Mooney |  | SITAG | Complete | COMPLETE |  |  |  |
| 1563 | 1.4.2.3.1.2.4.13 | Sprint 16 (Contingency 2) |  | 10d? | 2025-04-14 A | 2025-04-25 A | 1562 | 100% |  | 2025-04-14 | 2025-04-25 | 0d |  |  |  | SI Test |  | SIT | 6.1 | Dom Mooney |  | SITAG | Complete | COMPLETE |  |  |  |
| 1564 | 1.4.2.3.1.2.4.14 | SIT Functional Cycle 3 Complete | milestone | 0d | 2025-04-28 A | 2025-04-28 A | 1563 | 100% |  | 2025-04-28 | 2025-04-28 | 0d |  |  |  | SI Test |  | SIT | 6.13 | Dom Mooney |  | SITAG | Complete | COMPLETE | T2-TE-1150 | T2 |  |
| 1565 | 1.4.2.3.1.3 | **SIT Scope Traceability** |  | 64d | 2025-01-27 A | 2025-04-24 A |  | 100% |  | 2025-01-27 | 2025-03-19 | 0d |  |  |  | SI Test |  | SIT | 6.17 | Salman Bukhari |  | SITAG |  |  |  |  | -94.67 |
| 1566 | 1.4.2.3.1.3.1 | Draft Scope Tracability document |  | 10d | 2025-01-27 A | 2025-02-07 A |  | 100% |  | 2025-01-27 | 2025-02-07 | 0d |  |  | start no earlier than 2025-01-27 | SI Test |  | SIT | 6.17 | Salman Bukhari |  | SITAG | Complete | COMPLETE |  |  |  |
| 1567 | 1.4.2.3.1.3.2 | LDP review |  | 2d | 2025-02-10 A | 2025-02-11 A | 1566 | 100% |  | 2025-02-10 | 2025-02-11 | 0d |  |  |  | SI Test |  | SIT | 6.17 | Salman Bukhari |  | SITAG | Complete | COMPLETE |  |  |  |
| 1568 | 1.4.2.3.1.3.3 | SRO review |  | 5d | 2025-02-12 A | 2025-02-18 A | 1567 | 100% |  | 2025-02-12 | 2025-02-18 | 0d |  |  |  | SI Test |  | SIT | 6.17 | Salman Bukhari |  | SITAG | Complete | COMPLETE |  |  |  |
| 1569 | 1.4.2.3.1.3.4 | Updates to reflect SRO feedback |  | 5d | 2025-02-12 A | 2025-02-18 A | 1568FF | 100% |  | 2025-02-12 | 2025-02-18 | 0d |  |  |  | SI Test |  | SIT | 6.17 | Salman Bukhari |  | SITAG | Complete | COMPLETE |  |  |  |
| 1570 | 1.4.2.3.1.3.5 | Industry Review |  | 10d | 2025-02-19 A | 2025-03-04 A | 1569 | 100% |  | 2025-02-19 | 2025-03-04 | 0d |  |  |  | SI Test |  | SIT | 6.17 | Salman Bukhari |  | SITAG | Complete | COMPLETE |  |  |  |
| 1571 | 1.4.2.3.1.3.6 | SITWG paper day | milestone | 0d | 2025-04-08 A | 2025-04-08 A | 1569FS+35d | 100% |  | 2025-04-08 | 2025-04-08 | 0d |  |  | start no earlier than 2025-04-08 | SI Test |  | SIT | 6.20 | Salman Bukhari |  | SITAG | Complete | COMPLETE |  |  |  |
| 1572 | 1.4.2.3.1.3.7 | SITWG recommends Scope Tracability document | milestone | 0d | 2025-04-15 A | 2025-04-15 A | 1571FS+5d | 100% |  | 2025-04-15 | 2025-04-15 | 0d |  |  |  | SI Test |  | SIT | 6.20 | Salman Bukhari |  | SITAG | Complete | COMPLETE |  |  |  |
| 1573 | 1.4.2.3.1.3.8 | Update document to reflect industry consultation views |  | 8d | 2025-03-05 A | 2025-03-14 A | 1570 | 100% |  | 2025-03-05 | 2025-03-14 | 0d |  |  |  | SI Test |  | SIT | 6.20 | Salman Bukhari |  | SITAG | Complete | COMPLETE |  |  |  |
| 1574 | 1.4.2.3.1.3.9 | SITAG paper day | milestone | 0d | 2025-04-17 A | 2025-04-17 A | 1572FS+2d, 1573 | 100% |  | 2025-04-17 | 2025-04-17 | 0d |  |  |  | SI Test |  | SIT | 6.20 | Salman Bukhari |  | SITAG | Complete | COMPLETE |  |  |  |
| 1575 | 1.4.2.3.1.3.10 | SITAG approve SIT Scope Traceability document | milestone | 0d | 2025-04-24 A | 2025-04-24 A | 1574FS+5d | 100% |  | 2025-04-24 | 2025-04-24 | 0d |  |  |  | SI Test |  | SIT | 6.20 | Salman Bukhari |  | SITAG | Complete | COMPLETE |  |  |  |
| 1576 | 1.4.2.3.1.3.11 | SIT Scope Traceability Approved | milestone | 0d | 2025-04-24 A | 2025-04-24 A | 1575 | 100% |  | 2025-04-24 | 2025-04-24 | 0d |  |  |  | SI Test |  | SIT | 6.20 | Salman Bukhari |  | SITAG | Complete | COMPLETE |  |  |  |

| ID | WBS | Task | Type | Duration | Start | Finish | Predecessors | Complete | Remaining | Actual start | Baseline start | Baseline finish | Baseline duration | Total slack | Free slack | Constraint | Responsible | Text9 | Task Status | Update Version | MHHS Resource Name | Text29 | Sched Status | RAG | Milestone ID | Tier |
| --- | --- | --- | --- | --- | --- | --- | --- | --- | --- | --- | --- | --- | --- | --- | --- | --- | --- | --- | --- | --- | --- | --- | --- | --- | --- | --- |
| 1577 | 1.4.2.3.1.4 | **SIT Functional Settlement Testing** |  | 230d? | 2024-06-17 | 2025-05-02 |  | 25% | 171.53d? | 2024-10-07 | 2024-06-17 | 2025-05-02 | 0d |  |  |  | SI Test | SIT | -685.67 | 6.12 | Stuart Scott | SITAG |  |  |  |  |
| 1578 | 1.4.2.3.1.4.1 | SIT-B Settlement Testing Cycle 2 |  | 70d | 2025-03-10 A | 2025-06-13 | 1595FS+10d | 5% | 66.5d |  | 2025-03-10 | 2025-06-13 | 0d | 659d |  | start no earlier than 2024-06-17 | SI Test | SIT |  | 6.12 | Stuart Scott | SITAG | Green | GREEN |  |  |
| 1579 | 1.4.2.3.1.4.2 | **SIT-B Settlement Testing Cycle 3** |  | 100d? | 2024-10-07 A | 2025-02-21 A |  | 100% |  |  | 2024-10-07 | 2024-12-20 | 0d |  |  |  | SI Test | SIT | -24.67 | 6.12 | Stuart Scott | SITAG |  | GREEN |  |  |
| 1580 | 1.4.2.3.1.4.2.1 | Sprint 5 |  | 20d? | 2024-10-07 A | 2024-11-01 A | 1222 | 100% |  |  | 2024-10-07 | 2024-11-01 | 0d |  |  |  | SI Test | SIT |  | 6.12 | Stuart Scott | SITAG | Complete | COMPLETE |  |  |
| 1581 | 1.4.2.3.1.4.2.2 | Sprint 5 Review (Flexibility Window Checkpoint) | milestone | 0d | 2024-11-04 A | 2024-11-04 A | 1580SS+21d | 100% |  |  | 2024-11-04 | 2024-11-04 | 0d |  |  |  | SI Test | SIT |  | 6.12 | Stuart Scott | SITAG | Complete | COMPLETE |  |  |
| 1582 | 1.4.2.3.1.4.2.3 | Sprint 6 |  | 10d? | 2024-11-04 A | 2024-11-15 A | 1580 | 100% |  |  | 2024-11-04 | 2024-11-15 | 0d |  |  |  | SI Test | SIT |  | 6.12 | Stuart Scott | SITAG | Complete | COMPLETE |  |  |
| 1583 | 1.4.2.3.1.4.2.4 | Sprint 6 Review (Pre Christmas Contingency Decision Point) | milestone | 0d | 2024-11-18 A | 2024-11-18 A | 1582SS+11d | 100% |  |  | 2024-11-18 | 2024-11-18 | 0d |  |  |  | SI Test | SIT |  | 6.12 | Stuart Scott | SITAG | Complete | COMPLETE |  |  |
| 1584 | 1.4.2.3.1.4.2.5 | Sprint 7 |  | 10d? | 2024-11-18 A | 2024-11-29 A | 1582 | 100% |  |  | 2024-11-18 | 2024-11-29 | 0d |  |  |  | SI Test | SIT |  | 6.12 | Stuart Scott | SITAG | Complete | COMPLETE |  |  |
| 1585 | 1.4.2.3.1.4.2.6 | Sprint 7 Review (Post Christmas Contingency Decision Point) | milestone | 0d | 2024-12-02 A | 2024-12-02 A | 1584SS+11d | 100% |  |  | 2024-12-02 | 2024-12-02 | 0d |  |  |  | SI Test | SIT |  | 6.12 | Stuart Scott | SITAG | Complete | COMPLETE |  |  |
| 1586 | 1.4.2.3.1.4.2.7 | Sprint 8 |  | 15d | 2024-12-02 A | 2024-12-20 A | 1584 | 100% |  |  | 2024-12-02 | 2024-12-20 | 0d |  |  |  | SI Test | SIT |  | 6.15 | Stuart Scott | SITAG | Complete | COMPLETE |  |  |
| 1587 | 1.4.2.3.1.4.2.8 | Post-Christmas Stabilisation |  | 5d | 2025-01-06 A | 2025-01-10 A | 1586FS+10d | 100% |  |  | 2025-01-06 | 2025-01-10 | 0d |  |  |  | SI Test | SIT |  | 6.15 | Stuart Scott | SITAG | Complete | COMPLETE |  |  |
| 1588 | 1.4.2.3.1.4.2.9 | Sprint 9 |  | 10d | 2025-01-06 A | 2025-01-17 A | 1586FS+10d | 100% |  |  | 2025-01-13 | 2025-01-17 | 0d |  |  |  | SI Test | SIT |  | 6.15 | Stuart Scott | SITAG | Complete | COMPLETE |  |  |
| 1589 | 1.4.2.3.1.4.2.10 | Sprint 9 Review | milestone | 0d | 2025-01-20 A | 2025-01-20 A | 1588FS+1d | 100% |  |  | 2025-01-20 | 2025-01-20 | 0d |  |  |  | SI Test | SIT |  | 6.15 | Stuart Scott | SITAG | Complete | COMPLETE |  |  |
| 1590 | 1.4.2.3.1.4.2.11 | Sprint 10 |  | 10d | 2025-01-20 A | 2025-01-31 A | 1588 | 100% |  |  | 2025-01-20 | 2025-01-31 | 0d |  |  |  | SI Test | SIT |  | 6.15 | Stuart Scott | SITAG | Complete | COMPLETE |  |  |
| 1591 | 1.4.2.3.1.4.2.12 | Sprint 10 Review | milestone | 0d | 2025-02-03 A | 2025-02-03 A | 1590FS+1d | 100% |  |  | 2025-02-03 | 2025-02-03 | 0d |  |  |  | SI Test | SIT |  | 6.15 | Stuart Scott | SITAG | Complete | COMPLETE |  |  |
| 1592 | 1.4.2.3.1.4.2.13 | Sprint 11 |  | 10d | 2025-02-03 A | 2025-02-14 A | 1590 | 100% |  |  | 2025-02-03 | 2025-02-14 | 0d |  |  |  | SI Test | SIT |  | 6.15 | Stuart Scott | SITAG | Complete | COMPLETE |  |  |
| 1593 | 1.4.2.3.1.4.2.14 | Sprint 11 Review | milestone | 0d | 2025-02-14 A | 2025-02-14 A | 1592 | 100% |  |  | 2025-02-14 | 2025-02-14 | 0d |  |  |  | SI Test | SIT |  | 6.15 | Stuart Scott | SITAG | Complete | COMPLETE |  |  |
| 1594 | 1.4.2.3.1.4.2.15 | Sprint 12 |  | 5d | 2025-02-17 A | 2025-02-21 A | 1593 | 100% |  |  | 2025-02-17 | 2025-02-21 | 0d |  |  |  | SI Test | SIT |  | 6.15 | Stuart Scott | SITAG | Complete | COMPLETE |  |  |
| 1595 | 1.4.2.3.1.4.2.16 | End of Settlement Testing Cycle 3 | milestone | 0d | 2025-02-21 A | 2025-02-21 A | 1594 | 100% |  |  | 2025-02-21 | 2025-02-21 | 0d |  |  |  | SI Test | SIT |  | 6.15 | Stuart Scott | SITAG | Complete | COMPLETE | T3-TE-0140 | T3 |
| 1596 | 1.4.2.3.1.4.3 | **SIT-A Settlement Testing** |  | 20d | 2025-05-19 | 2025-06-16 |  |  |  |  | 2025-05-19 | 2025-06-13 | 0d | 5d |  |  | SI Test | SIT | -258.67 | 6.19 | Stuart Scott | SITAG | Overdue Start |  |  |  |
| 1597 | 1.4.2.3.1.4.3.1 | SIT-A Settlement Testing Start | milestone | 0d | 2025-05-19 | 2025-05-19 | 1470FS+1d |  |  |  | 2025-05-19 | 2025-05-19 | 0d | 5d | 0d |  | SI Test | SIT | 12.71 | 6.20 | Stuart Scott | SITAG | Green | GREEN |  |  |
| 1598 | 1.4.2.3.1.4.3.2 | SIT-A Settlement Testing |  | 20d | 2025-05-20 | 2025-06-16 | 1597 |  |  |  | 2025-05-20 | 2025-06-16 | 0d | 5d | 0d |  | SI Test | SIT | 13.33 | 6.20 | Stuart Scott | SITAG | Green | GREEN |  |  |
| 1599 | 1.4.2.3.1.4.3.3 | SIT-A Settlement Decision Point Exit Criteria | milestone | 0d | 2025-06-13 | 2025-06-13 | 1598FS-2d |  |  |  | 2025-06-13 | 2025-06-13 | 0d | 5d | 0d |  | SI Test | SIT | 37.33 | 6.20 | Stuart Scott | SITAG | Green | GREEN |  |  |
| 1600 | 1.4.2.3.1.4.3.4 | SIT-A Settlement Testing Completed | milestone | 0d | 2025-06-13 | 2025-06-13 | 1599 |  |  |  | 2025-06-13 | 2025-06-13 | 0d | 5d | 0d |  | SI Test | SIT | 37.33 | 6.20 | Stuart Scott | SITAG | Green | GREEN |  |  |

| ID | WBS | Task | Type | Duration | Start | Finish | Predecessors | Complete | Remaining | Baseline start | Baseline finish | Baseline duration | Baseline 1 start | Baseline 1 finish | Total slack | Free slack | Constraint | Responsible | Involved | Text9 | Task Status | Update Version | MHHS Resource Name | MHHS Programme Phase | Text29 | Sched Status | RAG | Milestone ID | Tier | Artefact ID |
| --- | --- | --- | --- | --- | --- | --- | --- | --- | --- | --- | --- | --- | --- | --- | --- | --- | --- | --- | --- | --- | --- | --- | --- | --- | --- | --- | --- | --- | --- | --- |
| 1601 | 1.4.2.3.1.4.4 | **SIT Functional Regression Testing (code freeze)** |  | 40d? | 2025-06-16 | 2025-08-08 |  |  |  | 2025-06-16 | 2025-08-08 | 45d | 2024-11-04 | 2025-01-03 | 5d |  |  | PP | SI Test | SIT | 84.33 | 6.15 | Roger Robar | Systems Integration Testing (SIT) | SITAG |  |  |  |  |  |
| 1602 | 1.4.2.3.1.4.4.1 | Regression Test Execution Start | milestone | 0d | 2025-06-16 | 2025-06-16 | 1470FS+2d, 1600FS+2d |  |  | 2025-06-16 | 2025-06-16 | 0d |  |  | 5d | 0d |  | SI Test |  | SIT | 40.71 | 6.15 | Roger Robar |  | SITAG | Green | GREEN | T2-TE-1250 | T2 |  |
| 1603 | 1.4.2.3.1.4.4.2 | Regression Execution |  | 5d | 2025-06-16 | 2025-06-20 | 1602FS-1d |  |  | 2025-06-16 | 2025-06-20 | 0d |  |  | 5d | 0d |  | SI Test |  | SIT | 40.33 | 6.20 | Roger Robar |  | SITAG | Green | GREEN |  |  |  |
| 1604 | 1.4.2.3.1.4.4.3 | Regression Sprint 1 |  | 10d? | 2025-06-23 | 2025-07-04 | 1603 |  |  | 2025-06-23 | 2025-07-04 | 0d |  |  | 5d | 0d |  | SI Test |  | SIT | 47.33 | 6.20 | Roger Robar |  | SITAG | Green | GREEN |  |  |  |
| 1605 | 1.4.2.3.1.4.4.4 | Regression Sprint 2 |  | 10d | 2025-07-07 | 2025-07-18 | 1604 |  |  | 2025-07-07 | 2025-07-18 | 0d |  |  | 5d | 0d |  | SI Test |  | SIT | 61.33 | 6.20 | Roger Robar |  | SITAG | Green | GREEN |  |  |  |
| 1606 | 1.4.2.3.1.4.4.5 | Regression Sprint 3 |  | 10d | 2025-07-21 | 2025-08-01 | 1605 |  |  | 2025-07-21 | 2025-08-01 | 0d |  |  | 5d | 0d |  | SI Test |  | SIT | 75.33 | 6.20 | Roger Robar |  | SITAG | Green | GREEN |  |  |  |
| 1607 | 1.4.2.3.1.4.4.6 | Regression Contingency Week |  | 5d | 2025-08-04 | 2025-08-08 | 1606, 1620FF |  |  | 2025-08-04 | 2025-08-08 | 0d |  |  | 5d | 0d |  | SI Test |  | SIT | 89.33 | 6.20 | Roger Robar |  | SITAG | Green | GREEN |  |  |  |
| 1608 | 1.4.2.3.1.4.5 | SIT Functional Testing End (incl. confirmation that PPs have submitted their Test Completion Reports to Programme for assurance) | milestone | 0d | 2025-08-08 | 2025-08-08 | 1607 |  |  | 2025-08-08 | 2025-08-08 | 0d | 2025-01-03 | 2025-01-03 | 5d | 0d | start no earlier than 2025-03-14 | SI Test | PP | SIT | 93.71 | 6.24 | Roger Robar | Systems Integration Testing (SIT) | SITAG | Green | GREEN | T3-TE-0046 | T3 | MHHS-ART072 |
| 1609 | 1.4.2.3.1.4.6 | Assurance of PPs Test Completion Reports |  | 25d | 2025-07-14 | 2025-08-15 | 1608FF+5d |  |  | 2025-07-14 | 2025-08-15 | 30d | 2024-12-02 | 2025-01-10 | 5d | 0d |  | SI Test | PP | SIT | 68.33 | 6.1 | Roger Robar | Systems Integration Testing (SIT) | SITAG | Green | GREEN |  |  |  |
| 1610 | 1.4.2.3.1.4.7 | **SIT Functional & Migration Overarching Completion Report** |  | 38d | 2025-04-28 A | 2025-06-18 |  | 14% | 32.68d | 2025-07-21 | 2025-08-15 | 20d | 2024-12-16 | 2025-01-10 | 656d |  |  | SI Test | N/A | SIT |  | 6.1 | N/A | Systems Integration Testing (SIT) | SITAG |  |  |  |  |  |
| 1611 | 1.4.2.3.1.4.7.1 | Programme drafts Functional & Migration Overarching Report Proformas |  | 15d | 2025-04-28 A | 2025-05-16 | 1564 | 47% | 8d |  |  |  |  |  | 656d | 0d |  | SI Test |  | SIT |  | 6.24 | Roger Robar |  | SITAG | No BL | GREEN |  |  |  |
| 1612 | 1.4.2.3.1.4.7.2 | Functional & Migration Overarching Proformas shared with PPs | milestone | 0d | 2025-05-16 | 2025-05-16 | 1611 |  |  |  |  |  |  |  | 656d | 0d |  | SI Test |  | SIT | 9.71 | 6.24 | Roger Robar |  | SITAG | No BL | GREEN |  |  |  |
| 1613 | 1.4.2.3.1.4.7.3 | PPs complete and return Completion Report Proformas |  | 10d | 2025-05-19 | 2025-05-30 | 1612 |  |  |  |  |  |  |  | 666d | 0d |  | PP |  | SIT | 12.33 | 6.24 | Roger Robar |  | SITAG | No BL | GREEN |  |  |  |
| 1614 | 1.4.2.3.1.4.7.4 | PPs Completion Report Proforma deadline | milestone | 0d | 2025-05-30 | 2025-05-30 | 1613 |  |  |  |  |  |  |  | 666d | 10d |  | PP |  | SIT | 23.71 | 6.24 | Roger Robar |  | SITAG | No BL | GREEN |  |  |  |
| 1615 | 1.4.2.3.1.4.7.5 | Programme drafts Functional & Migration Overarching Completion Report |  | 20d | 2025-05-19 | 2025-06-13 | 1612, 1614FF |  |  |  |  |  |  |  | 656d | 0d |  | SI Test |  | SIT | 12.33 | 6.24 | Roger Robar |  | SITAG | No BL | GREEN |  |  |  |
| 1616 | 1.4.2.3.1.4.7.6 | SITWG Review status of Functional & Migration Overarching Completion Report | milestone | 0d | 2025-06-05 | 2025-06-05 |  |  |  |  |  |  |  |  | 666d | 10d | start no earlier than 2025-06-05 | SI Test |  | SIT | 29.33 | 6.24 | Roger Robar |  | SITAG | No BL | GREEN |  |  |  |
| 1617 | 1.4.2.3.1.4.7.7 | SRO Review Functional & Migration Overarching Completion Report |  | 5d | 2025-06-02 | 2025-06-06 | 1615SS |  |  |  |  |  |  |  | 664d |  | start no earlier than 2025-06-02 | SI Test |  | SIT | 26.33 | 6.24 | Roger Robar |  | SITAG | No BL | GREEN |  |  |  |
| 1618 | 1.4.2.3.1.4.7.8 | SITAG endorses the Functional & Migration Overarching Test Completion Report | milestone | 0d | 2025-06-18 | 2025-06-18 | 1615FS+3d, 1616 |  |  |  |  |  |  |  | 656d |  |  |  |  | SIT | 42.71 | 6.24 |  |  |  | No BL | GREEN |  |  |  |
| 1619 | 1.4.2.3.1.4.8 | **SIT Settlement and Regression Test Completion Report** |  | 35d | 2025-06-30 | 2025-08-15 |  |  |  |  |  |  |  |  | 5d |  |  | SI Test |  | SIT | -317.67 | 6.24 | Roger Robar |  | SITAG | Overdue Start |  |  |  |  |
| 1620 | 1.4.2.3.1.4.8.1 | Programme drafts Settlement and Regression Completion Report Proformas (when Participant completes Regression testing) |  | 30d | 2025-06-30 | 2025-08-08 | 1604SS |  |  |  |  |  |  |  | 5d | 0d | start no earlier than 2025-06-30 | SI Test |  | SIT | 54.33 | 6.24 | Roger Robar |  | SITAG | No BL | GREEN |  |  |  |
| 1621 | 1.4.2.3.1.4.8.2 | Settlement and Regression Completion Proformas shared with PPs | milestone | 0d | 2025-08-08 | 2025-08-08 | 1620 |  |  |  |  |  |  |  | 619d |  |  | SI Test |  | SIT | 93.71 | 6.24 | Roger Robar |  | SITAG | No BL | GREEN |  |  |  |
| 1622 | 1.4.2.3.1.4.8.3 | PPs complete and return Completion Report Proformas |  | 30d | 2025-07-07 | 2025-08-15 | 1620SS, 1707SS |  |  |  |  |  |  |  | 5d | 0d | start no earlier than 2025-07-07 | PP |  | SIT | 61.33 | 6.24 | Roger Robar |  | SITAG | No BL | GREEN |  |  |  |
| 1623 | 1.4.2.3.1.4.8.4 | PPs Completion Report Proforma deadline | milestone | 0d | 2025-08-15 | 2025-08-15 | 1622, 1709 |  |  |  |  |  |  |  | 614d |  |  | PP |  | SIT | 100.71 | 6.24 | Roger Robar |  | SITAG | No BL | GREEN |  |  |  |
| 1624 | 1.4.2.3.1.4.8.5 | Programme drafts Settlement and Regression Overarching Completion Report |  | 30d | 2025-07-07 | 2025-08-15 | 1622SS, 1709SS |  |  |  |  |  |  |  | 5d | 0d |  | SI Test |  | SIT | 61.33 | 6.24 | Roger Robar |  | SITAG | No BL | GREEN |  |  |  |
| 1625 | 1.4.2.3.1.4.8.6 | SITWG Review status of Settlement and Regression Overarching Completion Report | milestone | 0d | 2025-08-07 | 2025-08-07 |  |  |  |  |  |  |  |  | 12d | 7d | start no earlier than 2025-08-07 | SI Test |  | SIT | 92.33 | 6.24 | Roger Robar |  | SITAG | No BL | GREEN |  |  |  |
| 1626 | 1.4.2.3.1.4.8.7 | SRO Review Settlement and Regression Overarching Completion Report |  | 5d | 2025-08-04 | 2025-08-08 | 1624SS |  |  |  |  |  |  |  | 619d |  | start no earlier than 2025-08-04 | SI Test |  | SIT | 89.33 | 6.24 | Roger Robar |  | SITAG | No BL | GREEN |  |  |  |
| 1627 | 1.4.2.3.1.4.8.8 | Develop document |  | 15d | 2025-07-21 | 2025-08-08 | 1608FF |  |  | 2025-07-21 | 2025-08-08 | 15d | 2024-12-16 | 2025-01-03 | 5d | 0d | start no earlier than 2025-07-21 | SI Test |  | SIT | 75.33 | 6.1 | Roger Robar | Systems Integration Testing (SIT) | SITAG | Green | GREEN |  |  |  |
| 1628 | 1.4.2.3.1.4.8.9 | Review & agree document |  | 5d | 2025-08-11 | 2025-08-15 | 1627, 1609FF |  |  | 2025-08-11 | 2025-08-15 | 5d | 2025-01-06 | 2025-01-10 | 5d | 0d |  | SI Test | PP,IPA | SIT | 96.33 | 6.1 | Roger Robar | Systems Integration Testing (SIT) | SITAG | Green | GREEN |  |  |  |
| 1629 | 1.4.2.3.1.4.8.10 | SIT Functional Testing Test Completion Report Approved | milestone | 0d | 2025-08-15 | 2025-08-15 | 1628FF, 1624, 1625, 1607 |  |  | 2025-08-15 | 2025-08-15 | 0d | 2025-01-17 | 2025-01-17 | 5d | 0d |  | SI Test | PP | SIT | 100.71 | 6.24 | Roger Robar | Systems Integration Testing (SIT) | SITAG | Green | GREEN | T2-TE-0850 | T2 | MHHS-ART072 |

Notes:
- 1608: 06/05/25 - Programme is proposing to rename 'SIT MVC' to 'SIT' and 'SIT Non-MVC' to 'SIT Contingency'. Testing evidence to date suggests all SIT PPs are in a position to complete SIT at the end of Regression, meaning the end of Regression is no longer just the target SIT end date for PPs who will be ready for M10, but all PPs. 'SIT non-MVC' will be renamed 'SIT Contingency', to show that SIT will still go on until November, as per the existing plan. This change is going to May SITAG for formal approval.
- 1609: 06/05/25 - This activity will be superseded by the updated SIT Exit Approach the Programme has had endorsed by SITWG on 01/05, provided SITAG approve it in May.
- 1611: 06/05/25 - This activity is part of the proposed SIT Exit approach which was endorsed at May SITWG, which the Programme is taking to May SITAG for formal approval. Functional & Migration will be covered in a combined report.
- 1612: 06/05/25 - This activity is part of the proposed SIT Exit approach which was endorsed at May SITWG, which the Programme is taking to May SITAG for formal approval. Functional & Migration will be covered in a combined report.
- 1613: 06/05/25 - This activity is part of the proposed SIT Exit approach which was endorsed at May SITWG, which the Programme is taking to May SITAG for formal approval. Functional & Migration will be covered in a combined report.
- 1614: 06/05/25 - This activity is part of the proposed SIT Exit approach which was endorsed at May SITWG, which the Programme is taking to May SITAG for formal approval. Functional & Migration will be covered in a combined report.
- 1615: 06/05/25 - This activity is part of the proposed SIT Exit approach which was endorsed at May SITWG, which the Programme is taking to May SITAG for formal approval. Functional & Migration will be covered in a combined report.
- 1616: 06/05/25 - This activity is part of the proposed SIT Exit approach which was endorsed at May SITWG, which the Programme is taking to May SITAG for formal approval. Functional & Migration will be covered in a combined report.
- 1617: 06/05/25 - This activity is part of the proposed SIT Exit approach which was endorsed at May SITWG, which the Programme is taking to May SITAG for formal approval. Functional & Migration will be covered in a combined report.
- 1618: 06/05/25 - This activity is part of the proposed SIT Exit approach which was endorsed at May SITWG, which the Programme is taking to May SITAG for formal approval. Functional & Migration will be covered in a combined report.
- 1620: 06/05/25 - This activity is part of the proposed SIT Exit approach which was endorsed at May SITWG, which the Programme is taking to May SITAG for formal approval.
- 1621: 06/05/25 - This activity is part of the proposed SIT Exit approach which was endorsed at May SITWG, which the Programme is taking to May SITAG for formal approval.
- 1622: 06/05/25 - This activity is part of the proposed SIT Exit approach which was endorsed at May SITWG, which the Programme is taking to May SITAG for formal approval.
- 1623: 06/05/25 - This activity is part of the proposed SIT Exit approach which was endorsed at May SITWG, which the Programme is taking to May SITAG for formal approval.
- 1624: 06/05/25 - This activity is part of the proposed SIT Exit approach which was endorsed at May SITWG, which the Programme is taking to May SITAG for formal approval.
- 1625: 06/05/25 - This activity is part of the proposed SIT Exit approach which was endorsed at May SITWG, which the Programme is taking to May SITAG for formal approval.
- 1626: 06/05/25 - This activity is part of the proposed SIT Exit approach which was endorsed at May SITWG, which the Programme is taking to May SITAG for formal approval.
- 1627: 06/05/25 - Existing SIT Exit activity to be superseded by proposed approach pending May SITAG approval.
- 1628: 06/05/25 - Existing SIT Exit activity to be superseded by proposed approach pending May SITAG approval.
- 1629: 06/05/25 - Programme is proposing that this milestone be renamed to not include a reference to 'MVC'. Programme is proposing to rename 'SIT MVC' to 'SIT' and 'SIT Non-MVC' to 'SIT Contingency'. Testing evidence to date suggests all SIT PPs are in a position to complete SIT at the end of Regression, meaning the end of Regression is no longer just the target SIT end date for PPs who will be ready for M10, but all PPs. 'SIT non-MVC' will be renamed 'SIT Contingency', to show that SIT will still go on until November, as per the existing plan. This change is going to May SITAG for formal approval.

| ID | WBS | Task | Type | Duration | Start | Finish | Predecessors | Complete | Remaining | Baseline start | Baseline finish | Baseline duration | Total slack | Free slack | Constraint | Responsible | Text9 | Task Status | Update Version | Sched Status | MHHS Resource Name | Text29 | RAG |
| --- | --- | --- | --- | --- | --- | --- | --- | --- | --- | --- | --- | --- | --- | --- | --- | --- | --- | --- | --- | --- | --- | --- | --- |
| 1630 | 1.4.2.3.2 | **Helix E2E Settlement Assurance Testing (SAT)** |  | 229d? | 2024-08-19 A | 2025-07-03 |  | 60% | 92.67d? | 2025-01-06 | 2025-04-04 | 0d | 645d |  |  | Helix | SIT | -689.67 | 6.0 | Overdue Start | Helix |  |  |
| 1631 | 1.4.2.3.2.1 | **Test design** |  | 125d | 2024-09-02 A | 2025-02-21 A |  | 100% |  | 2024-09-02 | 2025-02-21 | 0d |  |  |  | Helix | SIT | -827.67 | 6.18 |  | Helix | Helix Programme Board |  |
| 1632 | 1.4.2.3.2.1.1 | SAT tests (Review and finalise) |  | 95d | 2024-09-02 A | 2025-01-10 A |  | 100% |  | 2024-09-02 | 2025-01-10 | 0d |  |  | start no earlier than 2024-09-02 | Helix | SIT |  | 6.18 | Complete | Helix | Helix Programme Board | COMPLETE |
| 1633 | 1.4.2.3.2.1.2 | Test Automation and Supporting Tools |  | 80d | 2024-11-04 A | 2025-02-21 A |  | 100% |  | 2024-11-04 | 2025-02-21 | 0d |  |  | start no earlier than 2024-11-04 | Helix | SIT |  | 6.18 | Complete | Helix | Helix Programme Board | COMPLETE |
| 1634 | 1.4.2.3.2.1.3 | SAT tests batch 3 |  | 50d | 2024-12-16 A | 2025-02-21 A |  | 100% |  | 2024-12-16 | 2025-02-21 | 0d |  |  | start no earlier than 2024-12-16 | Helix | SIT |  | 6.18 | Complete | Helix | Helix Programme Board | COMPLETE |
| 1635 | 1.4.2.3.2.2 | **Data and environment** |  | 120d? | 2024-08-19 A | 2025-01-31 A |  | 100% |  | 2024-08-19 | 2025-01-31 | 0d |  |  |  | Helix | SIT | -827.67 | 6.18 |  | Helix | Helix Programme Board |  |
| 1636 | 1.4.2.3.2.2.1 | Data and environment requirements |  | 55d | 2024-08-19 A | 2024-11-01 A |  | 100% |  | 2024-08-19 | 2024-11-01 | 0d |  |  | start no earlier than 2024-08-19 | Helix | SIT |  | 6.18 | Complete | Helix | Helix Programme Board | COMPLETE |
| 1637 | 1.4.2.3.2.2.2 | Data sourcing |  | 95d | 2024-09-02 A | 2025-01-10 A |  | 100% |  | 2024-09-02 | 2025-01-10 | 0d |  |  | start no earlier than 2024-09-02 | Helix | SIT |  | 6.18 | Complete | Helix | Helix Programme Board | COMPLETE |
| 1638 | 1.4.2.3.2.2.3 | Environment data check |  | 15d? | 2025-01-13 A | 2025-01-31 A | 1637 | 100% |  | 2025-01-13 | 2025-01-31 | 0d |  |  |  | Helix | SIT |  | 6.18 | Complete | Helix | Helix Programme Board | COMPLETE |
| 1639 | 1.4.2.3.2.3 | **Execution** |  | 169d | 2024-11-11 A | 2025-07-03 |  | 46% | 91.13d | 2024-11-11 | 2025-07-03 | 0d | 645d |  |  | Helix | SIT | -827.67 | 6.18 |  | Helix | Helix Programme Board |  |
| 1640 | 1.4.2.3.2.3.1 | Trial test runs |  | 50d | 2024-11-11 A | 2025-01-17 A |  | 100% |  | 2024-11-11 | 2025-01-17 | 0d |  |  | start no earlier than 2024-11-11 | Helix | SIT |  | 6.18 | Complete | Helix | Helix Programme Board | COMPLETE |
| 1641 | 1.4.2.3.2.3.2 | Test planning prioritisation |  | 14d | 2025-01-20 A | 2025-02-06 A | 1640 | 100% |  | 2025-01-20 | 2025-02-06 | 0d |  |  |  | Helix | SIT |  | 6.18 | Complete | Helix | Helix Programme Board | COMPLETE |
| 1642 | 1.4.2.3.2.3.3 | Programme agreement to start SAT testing | milestone | 0d | 2025-02-06 A | 2025-02-06 A | 1641 | 100% |  | 2025-02-06 | 2025-02-06 | 0d |  |  |  | Helix | SIT |  | 6.18 | Complete | Helix | Helix Programme Board | COMPLETE |
| 1643 | 1.4.2.3.2.3.4 | SAT Testing Start | milestone | 0d | 2025-02-06 A | 2025-02-06 A | 1642 | 100% |  | 2025-02-06 | 2025-02-06 | 0d |  |  |  | Helix | SIT |  | 6.18 | Complete | Helix | Helix Programme Board | COMPLETE |
| 1644 | 1.4.2.3.2.3.5 | SAT first run |  | 39d | 2025-02-07 A | 2025-04-02 | 1643 | 77% | 9d | 2025-02-07 | 2025-04-02 | 0d | 645d | 0d |  | Helix | SIT |  | 6.18 | Overdue | Helix | Helix Programme Board | RED |
| 1645 | 1.4.2.3.2.3.6 | First run complete | milestone | 0d | 2025-04-02 | 2025-04-02 | 1644 |  |  | 2025-04-02 | 2025-04-02 | 0d | 645d | 0d |  | Helix | SIT | -34.29 | 6.18 | Overdue Start | Helix | Helix Programme Board | RED |
| 1646 | 1.4.2.3.2.3.7 | SAT test second run |  | 30d | 2025-04-03 | 2025-05-14 | 1645 |  |  | 2025-04-03 | 2025-05-14 | 0d | 645d | 0d |  | Helix | SIT | -33.67 | 6.18 | Overdue Start | Helix | Helix Programme Board | RED |
| 1647 | 1.4.2.3.2.3.8 | Second run complete | milestone | 0d | 2025-05-14 | 2025-05-14 | 1646 |  |  | 2025-05-14 | 2025-05-14 | 0d | 645d | 0d |  | Helix | SIT | 7.71 | 6.18 | Green | Helix | Helix Programme Board | RED |
| 1648 | 1.4.2.3.2.3.9 | **Contingency test time** |  | 48d | 2025-04-07 | 2025-06-11 |  |  |  | 2025-03-06 | 2025-06-11 | 0d | 661d |  |  | Helix | SIT | 102.33 | 6.18 | No BL | Helix | Helix Programme Board |  |
| 1649 | 1.4.2.3.2.3.9.1 | Demand Disconnection Event (DDE) |  | 20d | 2025-05-15 | 2025-06-11 | 1647 |  |  | 2025-05-15 | 2025-06-11 | 0d | 645d | 0d |  | Helix | SIT | 8.33 | 6.18 | Green | Helix | Helix Programme Board | RED |
| 1650 | 1.4.2.3.2.3.9.2 | Trading Disputes |  | 20d | 2025-05-15 | 2025-06-11 | 1647 |  |  | 2025-05-15 | 2025-06-11 | 0d | 645d | 0d |  | Helix | SIT | 8.33 | 6.18 | Green | Helix | Helix Programme Board | RED |
| 1651 | 1.4.2.3.2.3.9.3 | **NESO** |  | 48d | 2025-04-07 | 2025-06-11 |  |  |  | 2025-03-06 | 2025-06-11 | 0d | 661d |  |  | Helix | SIT | -832.67 | 6.18 | Overdue Start | Helix | Helix Programme Board |  |
| 1652 | 1.4.2.3.2.3.9.3.1 | P210 Test files to NESO | milestone | 0d | 2025-04-07 | 2025-04-07 |  |  |  | 2025-04-07 | 2025-04-07 | 0d | 709d |  | start no earlier than 2025-04-07 | Helix | SIT | -29.67 | 6.18 | Overdue Start | Helix | Helix Programme Board | RED |
| 1653 | 1.4.2.3.2.3.9.3.2 | NESO |  | 20d | 2025-05-15 | 2025-06-11 | 1647 |  |  | 2025-05-15 | 2025-06-11 | 0d | 645d | 0d |  | Helix | SIT | 8.33 | 6.18 | Green | Helix | Helix Programme Board | RED |
| 1654 | 1.4.2.3.2.3.10 | Estimated all SAT tests completed | milestone | 0d | 2025-06-11 | 2025-06-11 | 1649, 1650, 1653 |  |  | 2025-06-11 | 2025-06-11 | 0d | 645d | 0d |  | Helix | SIT | 35.71 | 6.18 | Green | Helix | Helix Programme Board | RED |
| 1655 | 1.4.2.3.2.3.11 | Test Completion Report Drafting |  | 11d | 2025-06-12 | 2025-06-26 | 1654 |  |  | 2025-06-12 | 2025-06-26 | 0d | 645d | 0d |  | Helix | SIT | 36.33 | 6.18 | Green | Helix | Helix Programme Board | RED |
| 1656 | 1.4.2.3.2.3.12 | Test Completion Report/Recommendation | milestone | 0d | 2025-06-26 | 2025-06-26 | 1655 |  |  | 2025-06-26 | 2025-06-26 | 0d | 645d | 0d |  | Helix | SIT | 50.71 | 6.18 | Green | Helix | Helix Programme Board | RED |
| 1657 | 1.4.2.3.2.3.13 | SAT is signed off by the SAA Value Stream Lead / Head of Product (SAT complete) | milestone | 0d | 2025-07-03 | 2025-07-03 | 1656FS+5d |  |  | 2025-07-03 | 2025-07-03 | 0d | 645d | 0d |  | Helix | SIT | 57.71 | 6.18 | Green | Helix | Helix Programme Board | RED |

Notes:
- 1644: 06/04/25 - Programme is in discussion with Helix on a revised testing approach as Cycle 1 will be a number of weeks late completing.
- 1645: 06/04/25 - Programme is in discussion with Helix on a revised testing approach as Cycle 1 will be a number of weeks late completing.
- 1646: 06/04/25 - Programme is in discussion with Helix on a revised testing approach as Cycle 1 will be a number of weeks late completing.
- 1647: 06/04/25 - Programme is in discussion with Helix on a revised testing approach as Cycle 1 will be a number of weeks late completing.
- 1648: 06/04/25 - Programme is in discussion with Helix on a revised testing approach as Cycle 1 will be a number of weeks late completing.
- 1649: 06/04/25 - Programme is in discussion with Helix on a revised testing approach as Cycle 1 will be a number of weeks late completing.
- 1650: 06/04/25 - Programme is in discussion with Helix on a revised testing approach as Cycle 1 will be a number of weeks late completing.
- 1651: 06/04/25 - Programme is in discussion with Helix on a revised testing approach as Cycle 1 will be a number of weeks late completing.
- 1652: 06/04/25 - Programme is in discussion with Helix on a revised testing approach as Cycle 1 will be a number of weeks late completing.
- 1653: 06/04/25 - Programme is in discussion with Helix on a revised testing approach as Cycle 1 will be a number of weeks late completing.
- 1654: 06/04/25 - Programme is in discussion with Helix on a revised testing approach as Cycle 1 will be a number of weeks late completing.
- 1655: 06/04/25 - Programme is in discussion with Helix on a revised testing approach as Cycle 1 will be a number of weeks late completing.
- 1656: 06/04/25 - Programme is in discussion with Helix on a revised testing approach as Cycle 1 will be a number of weeks late completing.
- 1657: 06/04/25 - Programme is in discussion with Helix on a revised testing approach as Cycle 1 will be a number of weeks late completing.

| ID | WBS | Task | Type | Duration | Start | Finish | Predecessors | Complete | Remaining | Actual start | Actual finish | Baseline start | Baseline finish | Baseline duration | Baseline 1 start | Baseline 1 finish | Total slack | Free slack | Constraint | Baseline cost | Responsible | Text9 | Task Status | Update Version | Sched Status | RAG | Involved | MHHS Programme Phase | Text29 | MHHS Resource Name | Milestone ID | Tier |
| --- | --- | --- | --- | --- | --- | --- | --- | --- | --- | --- | --- | --- | --- | --- | --- | --- | --- | --- | --- | --- | --- | --- | --- | --- | --- | --- | --- | --- | --- | --- | --- | --- |
| 1658 | 1.4.2.3.2.4 | **MHHS Programme Assurance of Helix E2E SAT** |  | 219d | 2024-09-02 A | 2025-07-03 |  |  | 219d |  |  | 2024-09-02 | 2025-07-03 | 0d |  |  | 645d |  |  |  | SI Test | SIT | -860.67 | 6.20 | Overdue Start |  |  |  |  |  |  |  |
| 1659 | 1.4.2.3.2.4.1 | MHHS Programme Assurance Start | milestone | 0d | 2024-09-02 A | 2024-09-02 A | 1632SS | 100% |  |  |  | 2024-09-02 | 2024-09-02 | 0d |  |  |  |  |  |  | SI Test | SIT |  | 6.20 | Complete | COMPLETE |  |  |  |  |  |  |
| 1660 | 1.4.2.3.2.4.2 | Ongoing MHHS Programme Assurance |  | 219d | 2024-09-02 | 2025-07-03 | 1659 |  |  |  |  | 2024-09-02 | 2025-07-03 | 0d |  |  | 645d | 0d |  |  | SI Test | SIT | -246.67 | 6.20 | Overdue Start | GREEN |  |  |  |  |  |  |
| 1661 | 1.4.2.3.2.4.3 | MHHS Programme Assurance End | milestone | 0d | 2025-07-03 | 2025-07-03 | 1660, 1657 |  |  |  |  | 2025-07-03 | 2025-07-03 | 0d |  |  | 645d |  |  |  | SI Test | SIT | 57.71 | 6.20 | Green | GREEN |  |  |  |  |  |  |
| 1662 | 1.4.2.3.3 | **SIT Migration Testing** |  | 380d? | 2024-03-11 A | 2025-08-22 |  | 57% | 161.94d? |  |  | 2024-03-11 | 2025-08-22 | 155d | 2024-06-10 | 2024-10-18 | 609d |  |  | -0 | SI Test | SIT |  | 6.0 | Overdue | GREEN | N/A | Systems Integration Testing (SIT) | SITAG |  |  |  |
| 1663 | 1.4.2.3.3.1 | SIT Migration Testing Start | milestone | 0d? | 2024-03-11 A | 2024-03-11 A |  | 100% |  |  |  | 2024-03-11 | 2024-03-11 | 0d |  |  |  |  | start no earlier than 2024-03-11 |  | SI Test | SIT |  | 6.0 | Complete | COMPLETE |  |  |  |  |  |  |
| 1664 | 1.4.2.3.3.2 | **SIT Migration Testing Execution** |  | 380d? | 2024-03-11 A | 2025-08-22 |  | 57% | 161.94d? |  |  | 2024-03-11 | 2025-08-22 | 0d |  |  | 609d |  |  |  | SI Test | SIT | -685.67 | 6.0 | Overdue Start |  |  |  | SITAG | Ankur Pande |  |  |
| 1665 | 1.4.2.3.3.2.1 | **Cycle 1 (Full Cycle)** |  | 70d? | 2024-03-11 A | 2024-06-14 A |  | 100% |  |  |  | 2024-03-11 | 2024-06-14 | 0d |  |  |  |  |  |  | SI Test | SIT | -685.67 | 6.0 | Overdue Start |  |  |  |  | Ankur Pande |  |  |
| 1666 | 1.4.2.3.3.2.1.1 | Test Execution |  | 55d? | 2024-03-11 A | 2024-05-24 A |  | 100% |  |  |  | 2024-03-11 | 2024-05-24 | 0d |  |  |  |  | start no earlier than 2024-03-11 |  | SI Test | SIT |  | 6.0 | Complete | COMPLETE |  |  |  | Ankur Pande |  |  |
| 1667 | 1.4.2.3.3.2.1.2 | Defect resolution, assurance, review, data& environments maintenance |  | 15d? | 2024-05-27 A | 2024-06-14 A |  | 100% |  |  |  | 2024-05-27 | 2024-06-14 | 0d |  |  |  |  | finish no earlier than 2024-06-14 |  | SI Test | SIT |  | 6.0 | Complete | COMPLETE |  |  |  | Ankur Pande |  |  |
| 1668 | 1.4.2.3.3.2.2 | **Cycle 2 (Defect retests and targeted regression testing)** |  | 80d? | 2024-03-11 | 2024-06-28 |  | 100% |  | 2024-06-17 | 2024-10-04 | 2024-03-11 | 2024-06-28 | 0d |  |  |  |  |  |  | SI Test | SIT | -685.67 | 6.0 |  |  |  |  |  | Ankur Pande |  |  |
| 1669 | 1.4.2.3.3.2.2.1 | Test Execution |  | 70d? | 2024-06-17 A | 2024-09-20 A | 1667 | 100% |  |  |  | 2024-06-17 | 2024-09-20 | 0d |  |  |  |  | start no earlier than 2024-06-17 |  | SI Test | SIT |  | 6.0 | Complete | COMPLETE |  |  |  | Ankur Pande |  |  |
| 1670 | 1.4.2.3.3.2.2.2 | Defect resolution, assurance, review, data & environments maintenance |  | 10d? | 2024-09-23 A | 2024-10-04 A | 1669 | 100% |  |  |  | 2024-09-23 | 2024-10-04 | 0d |  |  |  |  | finish no earlier than 2024-10-04 |  | SI Test | SIT |  | 6.0 | Complete | COMPLETE |  |  |  | Ankur Pande |  |  |
| 1671 | 1.4.2.3.3.2.3 | **SIT Migration Testing back-up progress risk-assessment** |  | 70d? | 2024-06-17 | 2024-09-20 |  | 100% |  | 2024-10-07 | 2024-11-01 | 2024-06-17 | 2024-09-20 | 0d |  |  |  |  |  |  | SI Test | SIT | -685.67 | 6.0 |  |  |  |  |  | Ankur Pande |  |  |
| 1672 | 1.4.2.3.3.2.3.1 | Back-up risk-assessment of SIT Migration progress to assess whether Qualification Execution can start early |  | 15d? | 2024-10-07 A | 2024-10-25 A | 1670 | 100% |  |  |  | 2024-10-07 | 2024-10-25 | 0d |  |  |  |  | finish no earlier than 2024-10-04 |  | SI Test | SIT |  | 6.0 | Complete | COMPLETE |  |  |  | Ankur Pande |  |  |
| 1673 | 1.4.2.3.3.2.3.2 | Back-up SITAG decision on early Qualification Testing Execution start | milestone | 0d? | 2024-11-01 A | 2024-11-01 A | 1672FS+5d | 100% |  |  |  | 2024-11-01 | 2024-11-01 | 0d |  |  |  |  |  |  | SI Test | SIT |  | 6.0 | Complete | COMPLETE |  |  |  | Ankur Pande |  |  |
| 1674 | 1.4.2.3.3.2.4 | **Cycle 3 (Defect retests and targeted regression testing)** |  | 135d? | 2024-10-21 A | 2025-04-25 A |  | 100% |  |  |  | 2024-10-21 | 2025-04-25 | 0d |  |  |  |  |  |  | SI Test | SIT | -685.67 | 6.0 |  |  |  |  | SITAG | Dom Mooney |  |  |
| 1675 | 1.4.2.3.3.2.4.1 | Sprint 5 |  | 10d | 2024-10-21 A | 2024-11-01 A | 140FS-1d | 100% |  |  |  | 2024-10-21 | 2024-11-01 | 0d |  |  |  |  | start no earlier than 2024-10-21 |  | SI Test | SIT |  | 6.0 | Complete | COMPLETE |  |  |  | Dom Mooney |  |  |
| 1676 | 1.4.2.3.3.2.4.2 | Sprint 6 |  | 10d | 2024-11-04 A | 2024-11-15 A | 1675 | 100% |  |  |  | 2024-11-04 | 2024-11-15 | 0d |  |  |  |  | start no earlier than 2024-11-04 |  | SI Test | SIT |  | 6.0 | Complete | COMPLETE |  |  |  | Dom Mooney |  |  |
| 1677 | 1.4.2.3.3.2.4.3 | Sprint 7 |  | 10d | 2024-11-18 A | 2024-11-29 A | 1676 | 100% |  |  |  | 2024-11-18 | 2024-11-29 | 0d |  |  |  |  |  |  | SI Test | SIT |  | 6.0 | Complete | COMPLETE |  |  |  | Dom Mooney |  |  |
| 1678 | 1.4.2.3.3.2.4.4 | Sprint 8 |  | 15d | 2024-12-02 A | 2024-12-20 A | 1677 | 100% |  |  |  | 2024-12-02 | 2024-12-20 | 0d |  |  |  |  | finish no earlier than 2024-11-15 |  | SI Test | SIT |  | 6.0 | Complete | COMPLETE |  |  |  | Dom Mooney |  |  |
| 1679 | 1.4.2.3.3.2.4.5 | Christmas downtime |  | 10d | 2024-12-23 A | 2025-01-03 A | 1678 | 100% |  |  |  | 2024-12-23 | 2025-01-03 | 0d |  |  |  |  | finish no earlier than 2024-11-29 |  | SI Test | SIT |  | 6.0 | Complete | COMPLETE |  |  |  | Dom Mooney |  |  |
| 1680 | 1.4.2.3.3.2.4.6 | Sprint 9 |  | 10d | 2025-01-06 A | 2025-01-17 A | 1679 | 100% |  |  |  | 2025-01-06 | 2025-01-17 | 0d |  |  |  |  | finish no earlier than 2024-12-20 |  | SI Test | SIT |  | 6.0 | Complete | COMPLETE |  |  |  | Dom Mooney |  |  |
| 1681 | 1.4.2.3.3.2.4.7 | Sprint 10 |  | 10d | 2025-01-20 A | 2025-01-31 A | 1680 | 100% |  |  |  | 2025-01-20 | 2025-01-31 | 0d |  |  |  |  | finish no earlier than 2025-01-03 |  | SI Test | SIT |  | 6.0 | Complete | COMPLETE |  |  |  | Dom Mooney |  |  |
| 1682 | 1.4.2.3.3.2.4.8 | Sprint 11 |  | 10d | 2025-02-03 A | 2025-02-14 A | 1681 | 100% |  |  |  | 2025-02-03 | 2025-02-14 | 0d |  |  |  |  | finish no earlier than 2025-01-17 |  | SI Test | SIT |  | 6.0 | Complete | COMPLETE |  |  |  | Dom Mooney |  |  |
| 1683 | 1.4.2.3.3.2.4.9 | Sprint 12 |  | 10d | 2025-02-17 A | 2025-02-28 A | 1682 | 100% |  |  |  | 2025-02-17 | 2025-02-28 | 0d |  |  |  |  | finish no earlier than 2025-01-31 |  | SI Test | SIT |  | 6.0 | Complete | COMPLETE |  |  |  | Dom Mooney |  |  |
| 1684 | 1.4.2.3.3.2.4.10 | Sprint 13 |  | 10d | 2025-03-03 A | 2025-03-14 A | 1683 | 100% |  |  |  | 2025-03-03 | 2025-03-14 | 0d |  |  |  |  |  |  | SI Test | SIT |  | 6.1 | Complete | COMPLETE |  |  |  | Dom Mooney |  |  |
| 1685 | 1.4.2.3.3.2.4.11 | Sprint 14 (RTTM Gap Analysis + CR056) |  | 10d? | 2025-03-17 A | 2025-03-28 A | 1684 | 100% |  |  |  | 2025-03-17 | 2025-03-28 | 0d |  |  |  |  |  |  | SI Test | SIT |  | 6.1 | Complete | COMPLETE |  |  |  | Dom Mooney |  |  |
| 1686 | 1.4.2.3.3.2.4.12 | Sprint 15 (Contingency 1) |  | 10d? | 2025-03-31 A | 2025-04-11 A | 1685 | 100% |  |  |  | 2025-03-31 | 2025-04-11 | 0d |  |  |  |  |  |  | SI Test | SIT |  | 6.1 | Complete | COMPLETE |  |  | SITAG | Dom Mooney |  |  |
| 1687 | 1.4.2.3.3.2.4.13 | Sprint 16 (Contingency 2) |  | 10d? | 2025-04-14 A | 2025-04-25 A | 1686 | 100% |  |  |  | 2025-04-14 | 2025-04-25 | 0d |  |  |  |  |  |  | SI Test | SIT |  | 6.1 | Complete | COMPLETE |  |  | SITAG | Dom Mooney |  |  |
| 1688 | 1.4.2.3.3.2.4.14 | SIT Migration Cycle 3 Complete | milestone | 0d | 2025-04-25 A | 2025-04-25 A | 1687 | 100% |  |  |  | 2025-04-25 | 2025-04-25 | 0d |  |  |  |  |  |  | SI Test | SIT |  | 6.1 | Complete | COMPLETE |  |  | SITAG | Dom Mooney | T2-TE-1200 | T2 |

| ID | WBS | Task | Type | Duration | Start | Finish | Predecessors | Complete | Remaining | Baseline start | Baseline finish | Baseline duration | Baseline 1 start | Baseline 1 finish | Total slack | Free slack | Constraint | Responsible | Text9 | Task Status | Update Version | MHHS Resource Name | Sched Status | RAG | Involved | Artefact ID | MHHS Programme Phase | Text29 | Tier | Future RAG | Milestone ID |
| --- | --- | --- | --- | --- | --- | --- | --- | --- | --- | --- | --- | --- | --- | --- | --- | --- | --- | --- | --- | --- | --- | --- | --- | --- | --- | --- | --- | --- | --- | --- | --- |
| 1689 | 1.4.2.3.3.2.5 | **SIT Migration Regression Testing (code freeze)** |  | 40d? | 2025-06-16 | 2025-08-08 |  |  |  | 2025-06-16 | 2025-08-01 | 0d |  |  | 40d |  |  | SI Test | SIT | -685.67 | 6.24 | Roger Robar |  |  |  |  |  |  |  |  |  |
| 1690 | 1.4.2.3.3.2.5.1 | Regression Test Execution Start | milestone | 0d | 2025-06-16 | 2025-06-16 | 1600FS+2d |  |  | 2025-06-16 | 2025-06-16 | 0d |  |  | 40d | 0d |  | SI Test | SIT | 40.71 | 6.20 | Roger Robar | Green | GREEN |  |  |  |  |  |  |  |
| 1691 | 1.4.2.3.3.2.5.2 | Regression Execution |  | 5d | 2025-06-16 | 2025-06-20 | 1690FS-1d |  |  | 2025-06-16 | 2025-06-20 | 0d |  |  | 40d | 0d |  | SI Test | SIT | 40.33 | 6.20 | Roger Robar | Green | GREEN |  |  |  |  |  |  |  |
| 1692 | 1.4.2.3.3.2.5.3 | Regression Sprint 1 |  | 10d | 2025-06-23 | 2025-07-04 | 1691 |  |  | 2025-06-23 | 2025-07-04 | 0d |  |  | 40d | 0d |  | SI Test | SIT | 47.33 | 6.20 | Roger Robar | Green | GREEN |  |  |  |  |  |  |  |
| 1693 | 1.4.2.3.3.2.5.4 | Regression Sprint 2 |  | 10d? | 2025-07-07 | 2025-07-18 | 1692 |  |  | 2025-07-07 | 2025-07-18 | 0d |  |  | 614d | 0d |  | SI Test | SIT | 61.33 | 6.20 | Roger Robar | Green | GREEN |  |  |  |  |  |  |  |
| 1694 | 1.4.2.3.3.2.5.5 | Regression Sprint 3 |  | 10d | 2025-07-21 | 2025-08-01 | 1693 |  |  | 2025-07-21 | 2025-08-01 | 0d |  |  | 619d | 0d |  | SI Test | SIT | 75.33 | 6.20 | Roger Robar | Green | GREEN |  |  |  |  |  |  |  |
| 1695 | 1.4.2.3.3.2.5.6 | Regression Contingency Week |  | 5d | 2025-08-04 | 2025-08-08 | 1694, 1707FF |  |  | 2025-08-04 | 2025-08-08 | 0d |  |  | 619d | 0d |  | SI Test | SIT | 89.33 | 6.20 | Roger Robar | Green | GREEN |  |  |  |  |  |  |  |
| 1696 | 1.4.2.3.3.2.5.7 | SIT Migration Testing End (incl. confirmation that PPs have submitted their Test Completion Reports to Programme for assurance) | milestone | 0d | 2025-08-08 | 2025-08-08 | 1695 |  |  | 2025-08-08 | 2025-08-08 | 0d |  |  | 619d |  | start no earlier than 2025-06-20 | SI Test | SIT | 93.71 | 6.0 | Roger Robar | Green | GREEN |  |  |  |  |  |  |  |
| 1697 | 1.4.2.3.3.2.6 | **SIT Functional & Migration Test Completion Report** |  | 38d | 2025-04-28 A | 2025-06-18 | 1099, 1002, 1006, 1013, 1019, 1025 | 14% | 32.68d | 2025-07-14 | 2025-08-15 | 0d | 2024-06-10 | 2024-06-10 | 656d |  |  | SI Test | SIT |  | 6.1 | Roger Robar | Complete |  | PP | MHHS-ART076 | Systems Integration Testing (SIT) | SITAG | T3 |  |  |
| 1698 | 1.4.2.3.3.2.6.1 | Programme drafts Functional & Migration Completion Report Proformas |  | 15d | 2025-04-28 A | 2025-05-16 | 1688 | 47% | 8d |  |  |  |  |  | 656d | 0d | finish no earlier than 2025-05-16 | SI Test | SIT |  | 6.24 | Roger Robar | No BL | GREEN |  |  |  | SITAG |  |  |  |
| 1699 | 1.4.2.3.3.2.6.2 | Functional & Migration Completion Proformas shared with PPs | milestone | 0d | 2025-05-16 | 2025-05-16 | 1698 |  |  |  |  |  |  |  | 656d | 0d | start no earlier than 2025-05-16 | SI Test | SIT | 9.71 | 6.24 | Roger Robar | No BL | GREEN |  |  |  | SITAG |  |  |  |
| 1700 | 1.4.2.3.3.2.6.3 | PPs complete and return Completion Report Proformas |  | 10d | 2025-05-19 | 2025-05-30 | 1699 |  |  |  |  |  |  |  | 666d | 0d | finish no earlier than 2025-05-30 | PP | SIT | 12.33 | 6.24 | Roger Robar | No BL | GREEN |  |  |  | SITAG |  |  |  |
| 1701 | 1.4.2.3.3.2.6.4 | PPs Completion Report Proforma deadline | milestone | 0d | 2025-05-30 | 2025-05-30 | 1700 |  |  |  |  |  |  |  | 669d |  | start no earlier than 2025-05-30 | PP | SIT | 23.71 | 6.24 | Roger Robar | No BL | GREEN |  |  |  | SITAG |  |  |  |
| 1702 | 1.4.2.3.3.2.6.5 | Programme drafts Functional & Migration Overarching Completion Report |  | 20d | 2025-05-19 | 2025-06-13 | 1699, 1700FF |  |  |  |  |  |  |  | 656d | 0d | finish no earlier than 2025-06-13 | SI Test | SIT | 12.33 | 6.24 | Roger Robar | No BL | GREEN |  |  |  | SITAG |  |  |  |
| 1703 | 1.4.2.3.3.2.6.6 | SITWG Review status of Functional & Migration Overarching Completion Report | milestone | 0d | 2025-06-05 | 2025-06-05 | 1702SS |  |  |  |  |  |  |  | 666d | 10d | start no earlier than 2025-06-05 | SI Test | SIT | 29.33 | 6.24 | Roger Robar | No BL | GREEN |  |  |  | SITAG |  |  |  |
| 1704 | 1.4.2.3.3.2.6.7 | SRO Review Functional & Migration Overarching Completion Report |  | 5d | 2025-06-02 | 2025-06-06 | 1702SS |  |  |  |  |  |  |  | 664d |  | finish no earlier than 2025-06-06 | SI Test | SIT | 26.33 | 6.24 | Roger Robar | No BL | GREEN |  |  |  | SITAG |  |  |  |
| 1705 | 1.4.2.3.3.2.6.8 | SITAG endorses the Functional & Migration Overarching Test Completion Report | milestone | 0d | 2025-06-18 | 2025-06-18 | 1702FS+3d, 1703 |  |  |  |  |  |  |  | 656d | 42d |  |  | SIT | 42.71 | 6.24 | Roger Robar | No BL | GREEN |  |  |  |  |  |  |  |
| 1706 | 1.4.2.3.3.2.7 | **SIT Settlement and Regression Test Completion Report** |  | 35d | 2025-06-30 | 2025-08-15 |  |  |  |  |  |  |  |  | 614d |  |  | SI Test | SIT | -330.67 | 6.24 | Roger Robar | Overdue Start |  |  |  |  | SITAG |  |  |  |
| 1707 | 1.4.2.3.3.2.7.1 | Programme drafts Settlement and Regression Completion Report Proformas (when Participant completes Regression testing) |  | 30d | 2025-06-30 | 2025-08-08 | 1692SS |  |  |  |  |  |  |  | 619d | 0d | finish no earlier than 2025-08-08 | SI Test | SIT | 54.33 | 6.24 | Roger Robar | No BL | GREEN |  |  |  | SITAG |  |  |  |
| 1708 | 1.4.2.3.3.2.7.2 | Settlement and Regression Completion Proformas shared with PPs | milestone | 0d | 2025-08-08 | 2025-08-08 | 1707 |  |  |  |  |  |  |  | 619d |  | start no earlier than 2025-08-08 | SI Test | SIT | 93.71 | 6.24 | Roger Robar | No BL | GREEN |  |  |  | SITAG |  |  |  |
| 1709 | 1.4.2.3.3.2.7.3 | PPs complete and return Completion Report Proformas |  | 30d | 2025-07-07 | 2025-08-15 | 1707SS |  |  |  |  |  |  |  | 614d | 0d | finish no earlier than 2025-08-15 | PP | SIT | 61.33 | 6.24 | Roger Robar | No BL | GREEN |  |  |  | SITAG |  |  |  |
| 1710 | 1.4.2.3.3.2.7.4 | PPs Completion Report Proforma deadline | milestone | 0d | 2025-08-15 | 2025-08-15 | 1709 |  |  |  |  |  |  |  | 614d |  | start no earlier than 2025-08-15 | PP | SIT | 100.71 | 6.24 | Roger Robar | No BL | GREEN |  |  |  | SITAG |  |  |  |
| 1711 | 1.4.2.3.3.2.7.5 | Programme drafts Settlement and Regression Overarching Completion Report |  | 30d | 2025-07-07 | 2025-08-15 | 1709SS |  |  |  |  |  |  |  | 609d | 0d | finish no earlier than 2025-08-15 | SI Test | SIT | 61.33 | 6.24 | Roger Robar | No BL | GREEN |  |  |  | SITAG |  |  |  |
| 1712 | 1.4.2.3.3.2.7.6 | SITWG Review status of Settlement and Regression Overarching Completion Report | milestone | 0d | 2025-08-07 | 2025-08-07 |  |  |  |  |  |  |  |  | 621d |  | start no earlier than 2025-08-07 | SI Test | SIT | 92.33 | 6.24 | Roger Robar | No BL | GREEN |  |  |  | SITAG |  |  |  |
| 1713 | 1.4.2.3.3.2.7.7 | SRO Review Settlement and Regression Overarching Completion Report |  | 5d | 2025-08-04 | 2025-08-08 | 1711SS |  |  |  |  |  |  |  | 619d |  | start no earlier than 2025-08-04 | SI Test | SIT | 89.33 | 6.24 | Roger Robar | No BL | GREEN |  |  |  | SITAG |  |  |  |
| 1714 | 1.4.2.3.3.2.7.8 | Develop document |  | 15d | 2025-07-14 | 2025-08-01 | 1693SS |  |  | 2025-07-14 | 2025-08-01 | 85d | 2024-06-10 | 2024-10-04 | 609d | 0d | start no earlier than 2025-07-14 | SI Test | SIT | 68.33 | 6.1 | Roger Robar | Green | GREEN | PP |  | Systems Integration Testing (SIT) | SITAG |  | D24E - Migration Test Completion Report |  |
| 1715 | 1.4.2.3.3.2.7.9 | Review & agree document |  | 5d | 2025-08-04 | 2025-08-08 | 1714 |  |  | 2025-08-04 | 2025-08-08 | 10d | 2024-10-21 | 2024-11-01 | 609d | 0d |  | SI Test | SIT | 89.33 | 6.1 | Roger Robar | Green | GREEN | PP |  | Systems Integration Testing (SIT) | SITAG |  |  |  |
| 1716 | 1.4.2.3.3.2.7.10 | SIT Migration Testing Test Completion Report Approved | milestone | 0d | 2025-08-15 | 2025-08-15 | 1715FS+5d |  |  | 2025-08-15 | 2025-08-15 | 45d |  |  | 609d | 0d |  | SI Test | SIT | 100.71 | 6.1 | Roger Robar | Green | GREEN |  |  |  | SITAG | T2 |  | T2-TE-0800 |
| 1717 | 1.4.2.3.3.2.8 | SIT Migration Testing End (incl. confirmation that PPs have submitted their Test Completion Reports to Programme for assurance) | milestone | 0d | 2025-08-15 | 2025-08-15 | 1714FF, 1716, 1711 |  |  | 2025-08-15 | 2025-08-15 | 0d | 2024-10-04 | 2024-10-04 | 609d | 0d | start no earlier than 2025-03-14 | SI Test | SIT | 100.71 | 6.24 | Roger Robar | Green | GREEN | PP | MHHS-ART076 | Systems Integration Testing (SIT) | SITAG | T3 |  | T3-TE-0043 |
| 1718 | 1.4.2.3.3.2.9 | SITAG Approves Functional & Migration (Post-Regression) Overarching Test Completion Report | milestone | 0d | 2025-08-15 | 2025-08-15 | 1711, 1717, 1695, 1705 |  |  |  |  |  |  |  | 614d |  |  |  | SIT | 100.71 | 6.24 | Roger Robar | No BL | GREEN |  |  |  |  |  |  |  |
| 1719 | 1.4.2.3.3.2.10 | Assurance of PPs Test Completion Reports |  | 30d | 2025-07-14 | 2025-08-22 | 1717FF+5d |  |  | 2025-07-14 | 2025-08-22 | 30d | 2024-09-02 | 2024-10-11 | 609d |  |  | SI Test | SIT | 68.33 | 6.1 | Roger Robar | Green | GREEN | PP |  | Systems Integration Testing (SIT) |  |  |  |  |

Notes:
- 1698: 06/05/25 - This activity is part of the proposed SIT Exit approach which was endorsed at May SITWG, which the Programme is taking to May SITAG for formal approval. Functional & Migration will be covered in a combined report.
- 1699: 06/05/25 - This activity is part of the proposed SIT Exit approach which was endorsed at May SITWG, which the Programme is taking to May SITAG for formal approval. Functional & Migration will be covered in a combined report.
- 1700: 06/05/25 - This activity is part of the proposed SIT Exit approach which was endorsed at May SITWG, which the Programme is taking to May SITAG for formal approval. Functional & Migration will be covered in a combined report.
- 1701: 06/05/25 - This activity is part of the proposed SIT Exit approach which was endorsed at May SITWG, which the Programme is taking to May SITAG for formal approval. Functional & Migration will be covered in a combined report.
- 1702: 06/05/25 - This activity is part of the proposed SIT Exit approach which was endorsed at May SITWG, which the Programme is taking to May SITAG for formal approval. Functional & Migration will be covered in a combined report.
- 1703: 06/05/25 - This activity is part of the proposed SIT Exit approach which was endorsed at May SITWG, which the Programme is taking to May SITAG for formal approval. Functional & Migration will be covered in a combined report.
- 1704: 06/05/25 - This activity is part of the proposed SIT Exit approach which was endorsed at May SITWG, which the Programme is taking to May SITAG for formal approval. Functional & Migration will be covered in a combined report.
- 1705: 06/05/25 - This activity is part of the proposed SIT Exit approach which was endorsed at May SITWG, which the Programme is taking to May SITAG for formal approval. Functional & Migration will be covered in a combined report.
- 1707: 06/05/25 - This activity is part of the proposed SIT Exit approach which was endorsed at May SITWG, which the Programme is taking to May SITAG for formal approval.
- 1708: 06/05/25 - This activity is part of the proposed SIT Exit approach which was endorsed at May SITWG, which the Programme is taking to May SITAG for formal approval.
- 1709: 06/05/25 - This activity is part of the proposed SIT Exit approach which was endorsed at May SITWG, which the Programme is taking to May SITAG for formal approval.
- 1710: 06/05/25 - This activity is part of the proposed SIT Exit approach which was endorsed at May SITWG, which the Programme is taking to May SITAG for formal approval.
- 1711: 06/05/25 - This activity is part of the proposed SIT Exit approach which was endorsed at May SITWG, which the Programme is taking to May SITAG for formal approval.
- 1712: 06/05/25 - This activity is part of the proposed SIT Exit approach which was endorsed at May SITWG, which the Programme is taking to May SITAG for formal approval.
- 1713: 06/05/25 - This activity is part of the proposed SIT Exit approach which was endorsed at May SITWG, which the Programme is taking to May SITAG for formal approval.
- 1714: 06/05/25 - This activity is part of the proposed SIT Exit approach which was endorsed at May SITWG, which the Programme is taking to May SITAG for formal approval.
- 1715: 06/05/25 - Existing SIT Exit activity to be superseded by proposed approach pending May SITAG approval.
- 1716: 06/05/25 - Existing SIT Exit activity to be superseded by proposed approach pending May SITAG approval.
- 1717: 06/05/25 - Programme is proposing that this milestone be renamed to not include a reference to 'MVC'. Programme is proposing to rename 'SIT MVC' to 'SIT' and 'SIT Non-MVC' to 'SIT Contingency'. Testing evidence to date suggests all SIT PPs are in a position to complete SIT at the end of Regression, meaning the end of Regression is no longer just the target SIT end date for PPs who will be ready for M10, but all PPs. 'SIT non-MVC' will be renamed 'SIT Contingency', to show that SIT will still go on until November, as per the existing plan. This change is going to May SITAG for formal approval.
- 1718: 06/05/25 - This activity is part of the proposed SIT Exit approach which was endorsed at May SITWG, which the Programme is taking to May SITAG for formal approval.

| ID | WBS | Task | Type | Duration | Start | Finish | Predecessors | Complete | Remaining | Baseline start | Baseline finish | Baseline duration | Baseline 1 start | Baseline 1 finish | Total slack | Free slack | Constraint | Responsible | Involved | Text9 | Update Version | MHHS Resource Name | MHHS Programme Phase | Text29 | Sched Status | RAG | Milestone ID | Tier | Artefact ID | Guidance | Future RAG | Task Status |
| --- | --- | --- | --- | --- | --- | --- | --- | --- | --- | --- | --- | --- | --- | --- | --- | --- | --- | --- | --- | --- | --- | --- | --- | --- | --- | --- | --- | --- | --- | --- | --- | --- |
| 1720 | 1.4.2.3.4 | **SIT Non-Functional Testing (all SIT PPs)** |  | 93d? | 2025-03-03 A | 2025-07-09 |  | 27% | 67.99d? | 2025-02-28 | 2025-07-10 | 100d | 2024-09-02 | 2025-01-17 | 641d |  |  | N/A | N/A | SIT | 6.1 | N/A | Systems Integration Testing (SIT) | SITAG |  |  |  |  |  |  |  |  |
| 1721 | 1.4.2.3.4.1 | Theme 1 (Helix and DIP Volume Testing) Start | milestone | 0d? | 2025-03-03 A | 2025-03-03 A | 1182FS+1d, 1426 | 100% |  | 2025-03-03 | 2025-03-03 | 0d |  |  |  |  | finish no earlier than 2025-01-13 | SIT Participant |  | SIT | 6.15 | Roger Robar |  | SITAG | Complete | COMPLETE | T3-TE-0124 | T3 |  |  |  |  |
| 1722 | 1.4.2.3.4.2 | Theme 1 (Helix and DIP Volume Testing) Execution |  | 15d? | 2025-03-03 A | 2025-03-21 A | 1721FS-1d | 100% |  | 2025-03-03 | 2025-03-21 | 0d |  |  |  |  | start no earlier than 2025-01-13 | SI Test |  | SIT | 6.15 | Roger Robar |  |  | Complete | COMPLETE |  |  |  |  |  |  |
| 1723 | 1.4.2.3.4.3 | Theme 2 & 3 SIT Non-Functional Testing Start | milestone | 0d | 2025-03-31 A | 2025-03-31 A | 1545, 1106, 1110, 1117, 1123, 1129, 1595, 1191FS+2d, 1428, 1172 | 100% |  | 2025-03-31 | 2025-03-31 | 0d | 2024-09-02 | 2024-09-02 |  |  |  | SI Test | PP | SIT | 6.21 | Roger Robar | Systems Integration Testing (SIT) | SITAG | Complete | COMPLETE | T3-TE-0040 | T3 | MHHS-ART079 | 12/8/24: needs to be 7/10/24 |  |  |
| 1724 | 1.4.2.3.4.4 | Theme 2 & 3 SIT Non-Functional Testing Execution |  | 40d | 2025-03-31 A | 2025-05-23 | 1723SS-1d | 60% | 16d | 2025-03-31 | 2025-05-23 | 90d | 2024-09-02 | 2025-01-03 | 60d | 0d |  | SI Test | PP | SIT | 6.21 | Roger Robar | Systems Integration Testing (SIT) |  | Green | AMBER |  |  |  |  | D24D - NF Test Completion Report |  |
| 1725 | 1.4.2.3.4.5 | SIT Non-Functional Testing End (all SIT PPs) (incl. confirmation that PPs have submitted their Test Completion Reports to Programme for assurance) | milestone | 0d | 2025-05-23 | 2025-05-23 | 1724FF |  |  | 2025-05-23 | 2025-05-23 | 0d | 2025-01-03 | 2025-01-03 | 60d | 0d | start no earlier than 2025-05-23 | SI Test | PP | SIT | 6.15 | Roger Robar | Systems Integration Testing (SIT) | SITAG | Green | AMBER | T3-TE-0047 | T3 | MHHS-ART079 |  |  | 16.71 |
| 1726 | 1.4.2.3.4.6 | Assurance of PPs Test Completion Reports |  | 20d | 2025-05-05 | 2025-05-30 | 1725FF+5d |  |  | 2025-05-05 | 2025-05-30 | 30d | 2024-12-02 | 2025-01-10 | 60d | 0d |  | SI Test | PP | SIT | 6.15 | Roger Robar | Systems Integration Testing (SIT) | SITAG | Overdue Start | GREEN |  |  |  |  |  | -1.67 |
| 1727 | 1.4.2.3.4.7 | **SIT Non-Functional Testing Test Completion Report (all SIT PPs)** |  | 45d | 2025-05-05 | 2025-07-04 |  |  |  | 2025-05-02 | 2025-05-29 | 20d | 2024-12-16 | 2025-01-10 | 60d |  |  | N/A | N/A | SIT | 6.15 | N/A | Systems Integration Testing (SIT) |  |  |  |  |  |  |  |  |  |
| 1728 | 1.4.2.3.4.7.1 | Programme drafts Non-Functional Completion Report Proformas |  | 15d | 2025-05-26 | 2025-06-13 | 1725 |  |  |  |  |  |  |  | 659d | 0d |  | SI Test |  | SIT | 6.24 | Roger Robar |  | SITAG | No BL | GREEN |  |  |  |  |  | 19.33 |
| 1729 | 1.4.2.3.4.7.2 | Non-Functional Completion Proformas shared with PPs | milestone | 0d | 2025-06-13 | 2025-06-13 | 1728 |  |  |  |  |  |  |  | 659d |  | start no earlier than 2025-06-09 | SI Test |  | SIT | 6.24 | Roger Robar |  | SITAG | No BL | GREEN |  |  |  |  |  | 37.71 |
| 1730 | 1.4.2.3.4.7.3 | PPs complete and return Completion Report Proformas |  | 15d | 2025-06-09 | 2025-06-27 | 1728SS |  |  |  |  |  |  |  | 649d | 0d | finish no earlier than 2025-06-27 | SI Test |  | SIT | 6.24 | Roger Robar |  | PP | No BL | GREEN |  |  |  |  |  | 33.33 |
| 1731 | 1.4.2.3.4.7.4 | PPs Completion Report Proforma deadline | milestone | 0d | 2025-06-27 | 2025-06-27 | 1730 |  |  |  |  |  |  |  | 649d |  |  | SI Test |  | SIT | 6.24 | Roger Robar |  | PP | No BL | GREEN |  |  |  |  |  | 51.71 |
| 1732 | 1.4.2.3.4.7.5 | Programme drafts Non-Functional Overarching Completion Report |  | 15d | 2025-06-16 | 2025-07-04 | 1730SS |  |  |  |  |  |  |  | 37d | 0d | start no earlier than 2025-06-16 | SI Test |  | SIT | 6.24 | Roger Robar |  | SITAG | No BL | GREEN |  |  |  |  |  | 40.33 |
| 1733 | 1.4.2.3.4.7.6 | SITWG Review status of Non-Functional Overarching Completion Report | milestone | 0d | 2025-07-03 | 2025-07-03 |  |  |  |  |  |  |  |  | 646d |  | start no earlier than 2025-07-03 | SI Test |  | SIT | 6.24 | Roger Robar |  | SITAG | No BL | GREEN |  |  |  |  |  | 57.33 |
| 1734 | 1.4.2.3.4.7.7 | SRO Review Non-Functional Overarching Completion Report |  | 5d | 2025-06-23 | 2025-06-27 | 1732SS |  |  |  |  |  |  |  | 649d |  | start no earlier than 2025-06-23 | SI Test |  | SIT | 6.24 | Roger Robar |  | SITAG | No BL | GREEN |  |  |  |  |  | 47.33 |
| 1735 | 1.4.2.3.4.7.8 | Develop document |  | 15d | 2025-05-05 | 2025-05-23 | 1725FF |  |  | 2025-05-05 | 2025-05-23 | 15d | 2024-12-16 | 2025-01-03 | 60d | 0d |  | SI Test |  | SIT | 6.15 | Roger Robar | Systems Integration Testing (SIT) | SITAG | Overdue Start | GREEN |  |  |  |  |  | -1.67 |
| 1736 | 1.4.2.3.4.7.9 | Review & agree document |  | 5d | 2025-05-26 | 2025-05-30 | 1735, 1726FF |  |  | 2025-05-26 | 2025-05-30 | 5d | 2025-01-06 | 2025-01-10 | 60d | 23d |  | SI Test | PP,IPA | SIT | 6.15 | Roger Robar | Systems Integration Testing (SIT) | SITAG | Green | GREEN |  |  |  |  |  | 19.33 |
| 1737 | 1.4.2.3.4.8 | SIT Non-Functional Testing Test Completion Report (all SIT PPs) Approved | milestone | 0d | 2025-07-09 | 2025-07-09 | 1736FF+5d, 1732FS+3d |  |  | 2025-06-06 | 2025-06-06 | 0d | 2025-01-17 | 2025-01-17 | 37d | 32d |  | SI Test | PP | SIT | 6.24 | Roger Robar | Systems Integration Testing (SIT) | SITAG | Red | RED | T2-TE-0900 | T2 | MHHS-ART079 |  |  | 63.71 |
| 1738 | 1.4.2.3.5 | **SIT Operational Testing (all SIT PPs)** |  | 133d? | 2025-02-03 A | 2025-08-06 |  | 19% | 107.97d? | 2025-02-03 | 2025-06-06 | 90d | 2024-10-07 | 2025-02-07 | 621d |  |  | N/A | N/A | SIT | 5.0 | N/A | Systems Integration Testing (SIT) | SITAG |  |  |  |  |  |  |  |  |
| 1739 | 1.4.2.3.5.1 | **Non-SIT B Testing** |  | 25d? | 2025-02-03 A | 2025-03-07 A |  | 100% |  | 2025-02-03 | 2025-03-07 | 0d |  |  |  |  |  |  |  | SIT |  |  |  | SITAG | Overdue Start |  |  |  |  |  |  | -686.67 |
| 1740 | 1.4.2.3.5.1.1 | SIT Operational Testing Start (Theme 3 - Batch 1 (Service Management)) | milestone | 0d? | 2025-02-03 A | 2025-02-03 A | 1343, 1283, 1284 | 100% |  | 2025-02-03 | 2025-02-03 | 0d |  |  |  |  | start no earlier than 2025-02-03 | SI Test |  | SIT | 6.0 | Roger Robar |  | SITAG | Complete | COMPLETE | T3-TE-0121 | T3 |  |  |  |  |
| 1741 | 1.4.2.3.5.1.2 | SIT Operational Testing Execution Window (Theme 3 - Batch 1 (Service Management)) |  | 25d? | 2025-02-03 A | 2025-03-07 A | 1740 | 100% |  | 2025-02-03 | 2025-03-07 | 0d |  |  |  |  | start no earlier than 2025-01-06 | SI Test |  | SIT | 6.0 | Roger Robar |  | SITAG | Complete | COMPLETE |  |  |  |  |  |  |
| 1742 | 1.4.2.3.5.2 | **SIT B Testing** |  | 70d | 2025-03-31 A | 2025-07-04 |  | 24% | 53.2d | 2025-02-07 | 2025-05-16 | 0d |  |  | 30d |  |  | SI Test |  | SIT | 6.15 | Roger Robar |  | SITAG | Overdue Start |  |  |  |  |  |  | -686.67 |
| 1743 | 1.4.2.3.5.2.1 | SIT Operational Testing Start (SIT B) | milestone | 0d | 2025-03-31 A | 2025-03-31 A | 1423, 1200, 1204, 1211, 1217, 1343, 1421FS+1d, 1429, 1430 | 100% |  | 2025-03-31 | 2025-03-31 | 0d | 2024-10-07 | 2024-10-07 |  |  |  | SI Test | PP | SIT | 6.15 | Roger Robar | Systems Integration Testing (SIT) | SITAG | Complete | COMPLETE | T3-TE-0042 | T3 | MHHS-ART073 MHHS-ART143 |  |  |  |
| 1744 | 1.4.2.3.5.2.2 | SIT Operational Testing Execution Theme 1 |  | 70d | 2025-03-31 A | 2025-07-04 | 1743FS-1d | 45% | 38.5d | 2025-03-31 | 2025-07-04 | 0d |  |  | 30d | 0d | finish no earlier than 2025-07-04 | SI Test |  | SIT | 6.22 | Roger Robar |  | SITAG | Green | GREEN |  |  |  |  |  |  |
| 1745 | 1.4.2.3.5.2.3 | SIT Operational Testing Execution Theme 2 |  | 45d | 2025-05-05 A | 2025-07-04 | 1743 | 2% | 44.1d | 2025-05-05 | 2025-07-04 | 0d |  |  | 30d | 0d | finish no earlier than 2025-07-04 | SI Test |  | SIT | 6.22 | Roger Robar |  | SITAG | Green | GREEN |  |  |  |  |  |  |
| 1746 | 1.4.2.3.5.2.4 | SIT Operational Testing Execution Theme 3 Batch 2 |  | 20d | 2025-06-09 | 2025-07-04 | 1743 |  |  | 2025-06-09 | 2025-07-04 | 0d |  |  | 30d | 0d | start no earlier than 2025-06-09 | SI Test |  | SIT | 6.22 | Roger Robar |  | SITAG | Green | GREEN |  |  |  |  |  | 33.33 |
| 1747 | 1.4.2.3.5.3 | SIT Operational Testing End (all SIT PPs) (incl. confirmation that PPs have submitted their Test Completion Reports to Programme for assurance) | milestone | 0d | 2025-07-04 | 2025-07-04 | 1741, 1744, 1745, 1746 |  |  | 2025-07-11 | 2025-07-11 | 0d | 2025-01-24 | 2025-01-24 | 30d | 0d |  | SI Test | PP | SIT | 6.24 | Roger Robar | Systems Integration Testing (SIT) | SITAG | Green | GREEN | T3-TE-0050 | T3 | MHHS-ART081 |  |  | 58.71 |
| 1748 | 1.4.2.3.5.4 | Assurance of PPs Test Completion Reports |  | 30d | 2025-06-02 | 2025-07-11 | 1747FF+5d |  |  | 2025-06-09 | 2025-07-18 | 30d | 2024-12-23 | 2025-01-31 | 30d | 0d |  | SI Test | PP | SIT | 6.15 | Roger Robar | Systems Integration Testing (SIT) | SITAG | Green | GREEN |  |  |  |  |  | 26.33 |

Notes:
- 1724: 06/05/25 - Theme 3 complete, Theme 2 NF completion pace constrained by environment testing. Activity ongoing, execution activity completed but issues found in testing require analysis to complete all testing.
- 1725: 06/05/25 - Theme 3 complete, Theme 2 NF completion pace constrained by environment testing. Activity ongoing, execution activity completed but issues found in testing require analysis to complete all testing.
- 1726: 06/05/25 - Existing SIT Exit activity to be superseded by proposed approach pending May SITAG approval.
- 1728: 06/05/25 - This activity is part of the proposed SIT Exit approach which was endorsed at May SITWG, which the Programme is taking to May SITAG for formal approval.
- 1729: 06/05/25 - This activity is part of the proposed SIT Exit approach which was endorsed at May SITWG, which the Programme is taking to May SITAG for formal approval.
- 1730: 06/05/25 - This activity is part of the proposed SIT Exit approach which was endorsed at May SITWG, which the Programme is taking to May SITAG for formal approval.
- 1731: 06/05/25 - This activity is part of the proposed SIT Exit approach which was endorsed at May SITWG, which the Programme is taking to May SITAG for formal approval.
- 1732: 06/05/25 - This activity is part of the proposed SIT Exit approach which was endorsed at May SITWG, which the Programme is taking to May SITAG for formal approval.
- 1733: 06/05/25 - This activity is part of the proposed SIT Exit approach which was endorsed at May SITWG, which the Programme is taking to May SITAG for formal approval.
- 1734: 06/05/25 - This activity is part of the proposed SIT Exit approach which was endorsed at May SITWG, which the Programme is taking to May SITAG for formal approval.
- 1735: 06/05/25 - Existing SIT Exit activity to be superseded by proposed approach pending May SITAG approval.
- 1736: 06/05/25 - Existing SIT Exit activity to be superseded by proposed approach pending May SITAG approval.
- 1737: 06/05/25 - This activity is part of the proposed SIT Exit approach which was endorsed at May SITWG, which the Programme is taking to May SITAG for formal approval. As part of this, proposed that this milestone be moved to 09/07.
- 1747: 06/05/25 - As part of the proposed SIT Exit approach work, this milestone would be renamed to not include references to submission of Test Completion Reports, as this is covered elsewhere in the plan.

| ID | WBS | Task | Type | Duration | Start | Finish | Predecessors | Baseline start | Baseline finish | Baseline duration | Baseline 1 start | Baseline 1 finish | Total slack | Free slack | Constraint | Baseline cost | Responsible | Involved | Text9 | Update Version | MHHS Resource Name | MHHS Programme Phase | Text29 | Task Status | Sched Status | RAG | Artefact ID | Milestone ID | Tier | Future RAG |
| --- | --- | --- | --- | --- | --- | --- | --- | --- | --- | --- | --- | --- | --- | --- | --- | --- | --- | --- | --- | --- | --- | --- | --- | --- | --- | --- | --- | --- | --- | --- |
| 1749 | 1.4.2.3.5.5 | **SIT Operational Testing Test Completion Report (all SIT PPs)** |  | 45d | 2025-06-02 | 2025-08-01 |  | 2025-06-23 | 2025-07-18 | 20d | 2025-01-06 | 2025-01-31 | 32d |  |  |  | N/A | N/A | SIT | 6.15 | N/A | Systems Integration Testing (SIT) | SITAG |  |  |  |  |  |  |  |
| 1750 | 1.4.2.3.5.5.1 | Programme drafts Operational Completion Report Proformas (when Participant completes Operational testing) |  | 30d | 2025-06-02 | 2025-07-11 | 1744SS |  |  |  |  |  | 32d | 0d | start no earlier than 2025-06-02 |  | SI Test |  | SIT | 6.24 | Roger Robar |  | SITAG | 26.33 | No BL | GREEN |  |  |  |  |
| 1751 | 1.4.2.3.5.5.2 | All Operational Completion Proformas have been shared with PPs | milestone | 0d | 2025-07-11 | 2025-07-11 | 1750 |  |  |  |  |  | 639d |  |  |  | SI Test |  | SIT | 6.24 | Roger Robar |  | SITAG | 65.71 | No BL | GREEN |  |  |  |  |
| 1752 | 1.4.2.3.5.5.3 | PPs complete and return Completion Report Proformas |  | 30d | 2025-06-16 | 2025-07-25 | 1750SS |  |  |  |  |  | 22d | 0d | start no earlier than 2025-06-16 |  | SI Test |  | SIT | 6.24 | Roger Robar |  | SITAG | 40.33 | No BL | GREEN |  |  |  |  |
| 1753 | 1.4.2.3.5.5.4 | PPs Completion Report Proforma deadline | milestone | 0d | 2025-07-25 | 2025-07-25 | 1752 |  |  |  |  |  | 629d |  |  |  | SI Test |  | SIT | 6.24 | Roger Robar |  | SITAG | 79.71 | No BL | GREEN |  |  |  |  |
| 1754 | 1.4.2.3.5.5.5 | Programme drafts Operational Overarching Completion Report |  | 30d | 2025-06-23 | 2025-08-01 | 1752SS |  |  |  |  |  | 17d | 0d | start no earlier than 2025-06-23 |  | SI Test |  | SIT | 6.24 | Roger Robar |  | SITAG | 47.33 | No BL | GREEN |  |  |  |  |
| 1755 | 1.4.2.3.5.5.6 | SITWG Review status of Operational Overarching Completion Report | milestone | 0d | 2025-07-03 | 2025-07-03 |  |  |  |  |  |  | 646d |  | start no earlier than 2025-07-03 |  | SI Test |  | SIT | 6.24 | Roger Robar |  | SITAG | 57.33 | No BL | GREEN |  |  |  |  |
| 1756 | 1.4.2.3.5.5.7 | SRO Review Operational Overarching Completion Report |  | 5d | 2025-07-21 | 2025-07-25 | 1754SS |  |  |  |  |  | 629d |  | start no earlier than 2025-07-21 |  |  |  | SIT | 6.24 |  |  |  | 75.33 | No BL | GREEN |  |  |  |  |
| 1757 | 1.4.2.3.5.5.8 | Develop document |  | 15d | 2025-06-16 | 2025-07-04 | 1747FF | 2025-06-23 | 2025-07-11 | 15d | 2025-01-06 | 2025-01-24 | 30d | 0d |  |  | SI Test |  | SIT | 6.15 | Roger Robar | Systems Integration Testing (SIT) | SITAG | 40.33 | Green | GREEN |  |  |  |  |
| 1758 | 1.4.2.3.5.5.9 | Review & agree document |  | 5d | 2025-07-07 | 2025-07-11 | 1757, 1748FF | 2025-07-14 | 2025-07-18 | 5d | 2025-01-27 | 2025-01-31 | 30d | 13d |  |  | SI Test | PP,IPA | SIT | 6.15 | Roger Robar | Systems Integration Testing (SIT) | SITAG | 61.33 | Green | GREEN |  |  |  |  |
| 1759 | 1.4.2.3.5.6 | SIT Operational Testing Test Completion Report (all SIT PPs) Approved | milestone | 0d | 2025-08-06 | 2025-08-06 | 1758FF+5d, 1754FS+3d | 2025-07-25 | 2025-07-25 | 0d | 2025-02-07 | 2025-02-07 | 17d | 12d |  |  | SI Test | PP | SIT | 6.24 | Roger Robar | Systems Integration Testing (SIT) | SITAG | 91.71 | yellow | RED | MHHS-ART081 | T2-TE-0950 | T2 |  |
| 1760 | 1.4.2.3.6 | **SIT Test Exit Report** |  | 20d | 2025-07-21 | 2025-08-15 |  | 2025-07-14 | 2025-08-08 | 20d | 2025-01-06 | 2025-01-31 | 614d |  |  |  | N/A | N/A | SIT | 6.24 | N/A | Systems Integration Testing (SIT) |  |  |  |  |  |  |  |  |
| 1761 | 1.4.2.3.6.1 | Develop document |  | 15d | 2025-07-21 | 2025-08-08 | 1627FF | 2025-07-14 | 2025-08-01 | 15d | 2025-01-06 | 2025-01-24 | 614d | 0d |  |  | SI Test |  | SIT | 6.0 | Roger Robar | Systems Integration Testing (SIT) |  | 75.33 | yellow | RED |  |  |  |  |
| 1762 | 1.4.2.3.6.2 | Review & agree document |  | 5d | 2025-08-11 | 2025-08-15 | 1761 | 2025-08-04 | 2025-08-08 | 5d | 2025-01-27 | 2025-01-31 | 614d |  |  |  | SI Test | PP,IPA | SIT | 6.0 | Roger Robar | Systems Integration Testing (SIT) |  | 96.33 | yellow | RED |  |  |  |  |
| 1763 | 1.4.2.3.7 | SIT Complete (SIT Test Exit Report Approved) | milestone | 0d | 2025-08-22 | 2025-08-22 | 1536, 1629FS+5d, 1737, 1759 | 2025-08-22 | 2025-08-22 | 0d | 2025-02-07 | 2025-02-07 | 5d | 0d |  |  | CPT | PP,IPA | SIT | 6.24 | Roger Robar | Systems Integration Testing (SIT) | PSG | 107.71 | Green | GREEN | MHHS-ART081 | T1-TE-2000 | T1 |  |
| 1764 | 1.4.2.4 | **SIT (Contingency)** |  | 119d? | 2025-06-13 | 2025-11-26 |  | 2025-05-05 | 2025-11-27 | 295d | 2024-03-11 | 2025-04-25 | 505d |  |  | -0 | N/A | N/A | SIT | 6.24 | N/A | Systems Integration Testing (SIT) |  | M10,M11 |  |  |  |  |  | D24D - NF Test Completion Report |
| 1765 | 1.4.2.4.1 | **SIT Functional Testing (Contingency)** |  | 110d? | 2025-06-13 | 2025-11-13 |  | 2025-06-16 | 2025-11-14 | 295d | 2024-03-11 | 2025-04-25 | 505d |  |  |  | N/A | N/A | SIT | 6.24 | N/A | Systems Integration Testing (SIT) |  |  |  |  |  |  |  |  |
| 1766 | 1.4.2.4.1.1 | **SIT Functional Testing Execution (Contingency)** |  | 95d? | 2025-06-13 | 2025-10-23 |  | 2025-06-16 | 2025-10-24 | 280d | 2024-03-11 | 2025-04-04 | 505d |  |  |  | N/A | N/A | SIT | 6.24 | N/A | Systems Integration Testing (SIT) |  | M10 |  |  |  |  |  | D24C - E2E Test Completion Report |
| 1767 | 1.4.2.4.1.1.1 | Test Execution (Cycle 3 Completion and Regression Testing) |  | 95d? | 2025-06-13 | 2025-10-23 | 1600 | 2025-06-16 | 2025-10-24 | 0d |  |  | 505d | 0d |  |  | SI Test |  | SIT | 6.0 |  |  |  | 37.33 | Green | GREEN |  |  |  |  |
| 1768 | 1.4.2.4.1.1.2 | SIT Functional Testing End (Contingency) (incl. confirmation that PPs have submitted their Test Completion Reports to Programme for assurance) | milestone | 0d | 2025-10-23 | 2025-10-23 | 1767FF | 2025-10-24 | 2025-10-24 | 0d | 2025-04-04 | 2025-04-04 | 505d | 0d |  |  | SI Test | PP | SIT | 6.24 | Roger Robar | Systems Integration Testing (SIT) | SITAG | 169.71 | Green | GREEN | MHHS-ART072 | T3-TE-0052 | T3 |  |
| 1769 | 1.4.2.4.1.2 | Assurance of PPs Test Completion Reports |  | 5d | 2025-10-31 | 2025-11-06 | 1768FS+5d | 2025-11-03 | 2025-11-07 | 5d | 2025-04-14 | 2025-04-18 | 505d | 0d |  |  | SI Test | PP | SIT | 6.0 | Roger Robar | Systems Integration Testing (SIT) |  | 177.33 | Green | GREEN |  |  |  |  |
| 1770 | 1.4.2.4.1.3 | **SIT Functional Testing Test Completion Report (Contingency)** |  | 25d | 2025-10-03 | 2025-11-06 |  | 2025-10-06 | 2025-11-07 | 25d | 2025-03-17 | 2025-04-18 | 505d |  |  |  | N/A | N/A | SIT | 6.24 | N/A | Systems Integration Testing (SIT) |  |  |  |  |  |  |  |  |
| 1771 | 1.4.2.4.1.3.1 | Develop document |  | 15d | 2025-10-03 | 2025-10-23 | 1768FF | 2025-10-06 | 2025-10-24 | 15d | 2025-03-17 | 2025-04-04 | 510d | 5d |  |  | SI Test |  | SIT | 6.0 | Roger Robar | Systems Integration Testing (SIT) |  | 149.33 | Green | GREEN |  |  |  |  |
| 1772 | 1.4.2.4.1.3.2 | Review & agree document |  | 5d | 2025-10-31 | 2025-11-06 | 1771, 1769FF | 2025-11-03 | 2025-11-07 | 5d | 2025-04-14 | 2025-04-18 | 505d | 0d |  |  | SI Test | PP,IPA | SIT | 6.0 | Roger Robar | Systems Integration Testing (SIT) |  | 177.33 | Green | GREEN |  |  |  |  |
| 1773 | 1.4.2.4.1.4 | SIT Functional Testing Test Completion Report (Contingency) Approved | milestone | 0d | 2025-11-13 | 2025-11-13 | 1772FF+5d | 2025-11-14 | 2025-11-14 | 0d | 2025-04-25 | 2025-04-25 | 505d | 0d |  |  | SI Test | PP | SIT | 6.24 | Roger Robar | Systems Integration Testing (SIT) | SITAG | 190.71 | Green | GREEN | MHHS-ART072 | T3-TE-0055 | T3 |  |

Notes:
- 1750: 06/05/25 - This activity is part of the proposed SIT Exit approach which was endorsed at May SITWG, which the Programme is taking to May SITAG for formal approval.
- 1751: 06/05/25 - This activity is part of the proposed SIT Exit approach which was endorsed at May SITWG, which the Programme is taking to May SITAG for formal approval.
- 1752: 06/05/25 - This activity is part of the proposed SIT Exit approach which was endorsed at May SITWG, which the Programme is taking to May SITAG for formal approval.
- 1753: 06/05/25 - This activity is part of the proposed SIT Exit approach which was endorsed at May SITWG, which the Programme is taking to May SITAG for formal approval.
- 1754: 06/05/25 - This activity is part of the proposed SIT Exit approach which was endorsed at May SITWG, which the Programme is taking to May SITAG for formal approval.
- 1755: 06/05/25 - This activity is part of the proposed SIT Exit approach which was endorsed at May SITWG, which the Programme is taking to May SITAG for formal approval.
- 1756: 06/05/25 - This activity is part of the proposed SIT Exit approach which was endorsed at May SITWG, which the Programme is taking to May SITAG for formal approval.
- 1757: 06/05/25 - Existing SIT Exit activity to be superseded by proposed approach pending May SITAG approval.
- 1758: 06/05/25 - Existing SIT Exit activity to be superseded by proposed approach pending May SITAG approval.
- 1759: 06/05/25 - This activity is part of the proposed SIT Exit approach which was endorsed at May SITWG, which the Programme is taking to May SITAG for formal approval. As part of this, proposed that this milestone be moved to 06/08.
- 1763: 06/05/25 - Programme is proposing that this milestone be renamed to not include a reference to 'MVC'. Programme is proposing to rename 'SIT MVC' to 'SIT' and 'SIT Non-MVC' to 'SIT Contingency'. Testing evidence to date suggests all SIT PPs are in a position to complete SIT at the end of Regression, meaning the end of Regression is no longer just the target SIT end date for PPs who will be ready for M10, but all PPs. 'SIT non-MVC' will be renamed 'SIT Contingency', to show that SIT will still go on until November, as per the existing plan. This change is going to May SITAG for formal approval.
- 1764: 07/05/25 - Current testing velocity shows all PPs on track to complete SIT by the end of Regression (08/08/25). Proposal that all MVC activity becomes SIT, with Non-MVC becoming contingency activity in the instance of any PPs requiring further testing activity after regression.
- 1765: 07/05/25 - Current testing velocity shows all PPs on track to complete SIT by the end of Regression (08/08/25). Proposal that all MVC activity becomes SIT, with Non-MVC becoming contingency activity in the instance of any PPs requiring further testing activity after regression.
- 1766: 07/05/25 - Current testing velocity shows all PPs on track to complete SIT by the end of Regression (08/08/25). Proposal that all MVC activity becomes SIT, with Non-MVC becoming contingency activity in the instance of any PPs requiring further testing activity after regression.
- 1768: 06/05/25 - Programme is proposing that this milestone be renamed to not include a reference to 'Non-MVC'. Programme is proposing to rename 'SIT MVC' to 'SIT' and 'SIT Non-MVC' to 'SIT Contingency'. Testing evidence to date suggests all SIT PPs are in a position to complete SIT at the end of Regression, meaning the end of Regression is no longer just the target SIT end date for PPs who will be ready for M10, but all PPs. 'SIT non-MVC' will be renamed 'SIT Contingency', to show that SIT will still go on until November, as per the existing plan. This change is going to May SITAG for formal approval.
- 1770: 06/05/25 - Programme is proposing that this milestone be renamed to not include a reference to 'Non-MVC'. Programme is proposing to rename 'SIT MVC' to 'SIT' and 'SIT Non-MVC' to 'SIT Contingency'. Testing evidence to date suggests all SIT PPs are in a position to complete SIT at the end of Regression, meaning the end of Regression is no longer just the target SIT end date for PPs who will be ready for M10, but all PPs. 'SIT non-MVC' will be renamed 'SIT Contingency', to show that SIT will still go on until November, as per the existing plan. This change is going to May SITAG for formal approval.
- 1773: 06/05/25 - Programme is proposing that this milestone be renamed to not include a reference to 'Non-MVC'. Programme is proposing to rename 'SIT MVC' to 'SIT' and 'SIT Non-MVC' to 'SIT Contingency'. Testing evidence to date suggests all SIT PPs are in a position to complete SIT at the end of Regression, meaning the end of Regression is no longer just the target SIT end date for PPs who will be ready for M10, but all PPs. 'SIT non-MVC' will be renamed 'SIT Contingency', to show that SIT will still go on until November, as per the existing plan. This change is going to May SITAG for formal approval.

| ID | WBS | Task | Type | Duration | Start | Finish | Predecessors | Complete | Remaining | Baseline start | Baseline finish | Baseline duration | Baseline 1 start | Baseline 1 finish | Total slack | Free slack | Constraint | Baseline cost | Responsible | Involved | Text9 | Update Version | MHHS Resource Name | MHHS Programme Phase | Future RAG | Task Status | Sched Status | RAG | Artefact ID | Milestone ID | Text29 | Tier |
| --- | --- | --- | --- | --- | --- | --- | --- | --- | --- | --- | --- | --- | --- | --- | --- | --- | --- | --- | --- | --- | --- | --- | --- | --- | --- | --- | --- | --- | --- | --- | --- | --- |
| 1774 | 1.4.2.4.2 | **SIT Migration Testing (Contingency)** |  | 110d | 2025-06-13 | 2025-11-13 |  |  |  | 2025-05-05 | 2025-10-08 | 230d | 2024-06-10 | 2025-04-25 | 505d |  |  |  | N/A | N/A | SIT | 6.24 | N/A | Systems Integration Testing (SIT) |  |  |  |  |  |  |  |  |
| 1775 | 1.4.2.4.2.1 | Test Execution (Cycle 3 Completion and Regression Testing) |  | 95d | 2025-06-13 | 2025-10-23 | 1600 |  |  | 2025-06-16 | 2025-10-24 | 215d | 2024-06-10 | 2025-04-04 | 505d | 0d |  |  | SI Test | PP | SIT | 6.0 | Roger Robar | Systems Integration Testing (SIT) | D24E - Migration Test Completion Report | 37.33 | Green | GREEN |  |  |  |  |
| 1776 | 1.4.2.4.2.2 | SIT Migration Testing End (Contingency) (incl. confirmation that PPs have submitted their Test Completion Reports to Programme for assurance) | milestone | 0d | 2025-10-23 | 2025-10-23 | 1775FF |  |  | 2025-10-24 | 2025-10-24 | 0d | 2025-04-04 | 2025-04-04 | 505d | 0d |  |  | SI Test | PP | SIT | 6.24 | Roger Robar | Systems Integration Testing (SIT) |  | 169.71 | Green | GREEN | MHHS-ART076 | T3-TE-0051 | SITAG | T3 |
| 1777 | 1.4.2.4.2.3 | Assurance of PPs Test Completion Reports |  | 5d | 2025-10-31 | 2025-11-06 | 1776FS+5d |  |  | 2025-11-03 | 2025-11-07 | 5d | 2025-04-14 | 2025-04-18 | 505d | 0d |  |  | SI Test | PP | SIT | 6.0 | Roger Robar | Systems Integration Testing (SIT) |  | 177.33 | Green | GREEN |  |  |  |  |
| 1778 | 1.4.2.4.2.4 | **SIT Migration Testing Test Completion Report (Contingency)** |  | 25d | 2025-10-03 | 2025-11-06 |  |  |  | 2025-10-06 | 2025-11-07 | 25d | 2025-03-17 | 2025-04-18 | 505d |  |  |  | N/A | N/A | SIT | 6.24 | N/A | Systems Integration Testing (SIT) |  |  |  |  |  |  |  |  |
| 1779 | 1.4.2.4.2.4.1 | Develop document |  | 15d | 2025-10-03 | 2025-10-23 | 1776FF |  |  | 2025-10-06 | 2025-10-24 | 15d | 2025-03-17 | 2025-04-04 | 510d | 5d |  |  | SI Test |  | SIT | 6.0 | Roger Robar | Systems Integration Testing (SIT) |  | 149.33 | Green | GREEN |  |  |  |  |
| 1780 | 1.4.2.4.2.4.2 | Review & agree document |  | 5d | 2025-10-31 | 2025-11-06 | 1779, 1777FF |  |  | 2025-11-03 | 2025-11-07 | 5d | 2025-04-14 | 2025-04-18 | 505d | 0d |  |  | SI Test | PP,IPA | SIT | 6.0 | Roger Robar | Systems Integration Testing (SIT) |  | 177.33 | Green | GREEN |  |  |  |  |
| 1781 | 1.4.2.4.2.5 | SIT Migration Testing Test Completion Report (Contingency) Approved | milestone | 0d | 2025-11-13 | 2025-11-13 | 1780FF+5d |  |  | 2025-11-14 | 2025-11-14 | 0d | 2025-04-25 | 2025-04-25 | 505d | 0d |  |  | SI Test | PP | SIT | 6.24 | Roger Robar | Systems Integration Testing (SIT) |  | 190.71 | Green | GREEN | MHHS-ART076 | T3-TE-0056 | SITAG | T3 |
| 1782 | 1.4.2.4.3 | **SIT Contingency Test Exit Report** |  | 20d | 2025-10-24 | 2025-11-20 |  |  |  | 2025-10-27 | 2025-11-21 | 20d | 2025-03-17 | 2025-04-11 | 505d |  |  |  | N/A | N/A | SIT | 6.24 | N/A | Systems Integration Testing (SIT) |  |  |  |  |  |  |  |  |
| 1783 | 1.4.2.4.3.1 | Develop document |  | 15d | 2025-10-24 | 2025-11-13 | 1773FF, 1781FF |  |  | 2025-10-27 | 2025-11-14 | 15d | 2025-03-17 | 2025-04-04 | 505d | 0d |  |  | SI Test |  | SIT | 6.0 | Roger Robar | Systems Integration Testing (SIT) |  | 170.33 | Green | GREEN |  |  |  |  |
| 1784 | 1.4.2.4.3.2 | Review & agree document |  | 5d | 2025-11-14 | 2025-11-20 | 1783 |  |  | 2025-11-17 | 2025-11-21 | 5d | 2025-04-07 | 2025-04-11 | 505d | 0d |  |  | SI Test | PP,IPA | SIT | 6.0 | Roger Robar | Systems Integration Testing (SIT) |  | 191.33 | Green | GREEN |  |  |  |  |
| 1785 | 1.4.2.4.4 | SIT Contingency Complete | milestone | 0d | 2025-11-26 | 2025-11-26 | 1784FS+4d, 1773, 1781 |  |  | 2025-11-27 | 2025-11-27 | 0d | 2025-04-21 | 2025-04-21 | 505d | 0d |  |  | SI Test | PP | SIT | 6.24 | Roger Robar | Systems Integration Testing (SIT) |  | 203.71 | Green | GREEN | MHHS-ART081 | T3-TE-0059 | SITAG | T3 |
| 1786 | 1.4.3 | **UIT Environment Preparation** |  | 680d? | 2022-10-31 A | 2025-06-06 |  | 52% | 323.74d? | 2022-10-31 | 2025-07-04 | 680d | 2022-10-31 | 2025-06-06 | 664d |  |  | -0 | N/A | N/A | SIT | 6.0 | N/A | Systems Integration Testing (SIT) |  |  |  |  |  |  | SITAG |  |
| 1787 | 1.4.3.1 | **Test Artefact Development** |  | 557d? | 2023-03-01 A | 2025-04-17 |  | 74% | 146.21d? | 2023-03-01 | 2024-07-18 | 361d | 2023-03-01 | 2023-08-04 | 700d |  |  | -0 | N/A | N/A | SIT | 6.0 | N/A | Systems Integration Testing (SIT) |  |  |  |  |  |  | QAG |  |
| 1788 | 1.4.3.1.1 | **E2E Sandbox Guidance** |  | 557d? | 2023-03-01 A | 2025-04-17 |  | 96% | 20.13d? | 2023-03-01 | 2024-07-18 | 361d | 2023-03-01 | 2023-08-04 | 700d |  |  | -0 | N/A | N/A | SIT | 6.0 | N/A | Systems Integration Testing (SIT) |  |  |  |  |  |  | QAG |  |
| 1789 | 1.4.3.1.1.1 | Develop document |  | 83d | 2023-03-01 A | 2023-06-23 A |  | 100% |  | 2023-03-01 | 2023-06-23 | 83d | 2023-03-01 | 2023-06-23 |  |  | start no earlier than 2023-03-01 |  | SI Test |  | SIT | 6.0 | Stuart Scott | Systems Integration Testing (SIT) |  |  | Complete | COMPLETE |  |  | QAG |  |
| 1790 | 1.4.3.1.1.2 | Artefact review (via SITAG) and updates |  | 25d | 2023-06-26 A | 2023-07-28 A | 1789 | 100% |  | 2023-06-26 | 2023-07-28 | 25d | 2023-06-26 | 2023-07-28 |  |  |  |  | SI Test | PP,IPA | SIT | 6.0 | Stuart Scott | Systems Integration Testing (SIT) |  |  | Complete | COMPLETE |  |  | QAG |  |
| 1791 | 1.4.3.1.1.3 | E2E Sandbox Guidance approved | milestone | 0d | 2024-07-18 A | 2024-07-18 A | 1790FF+5d | 100% |  | 2024-07-18 | 2024-07-18 | 0d | 2023-08-04 | 2023-08-04 |  |  | start no earlier than 2024-07-18 |  | SI Test | PP | SIT | 6.0 | Stuart Scott | Systems Integration Testing (SIT) |  |  | Complete | COMPLETE | MHHS-ART154 | T3-TE-0067 | QAG | T3 |
| 1792 | 1.4.3.1.1.4 | Update E2E Sandbox guidance to reflect CR055 |  | 45d | 2025-01-13 A | 2025-03-14 A |  | 100% |  | 2025-01-13 | 2025-03-14 | 0d |  |  |  |  | finish no earlier than 2025-03-14 |  | SI Test |  | SIT | 6.20 | Stuart Scott |  |  |  | Complete | COMPLETE |  |  | QAG |  |
| 1793 | 1.4.3.1.1.5 | Internal SI review |  | 5d | 2025-03-17 A | 2025-03-21 A | 1792 | 100% |  | 2025-03-17 | 2025-03-21 | 0d |  |  |  |  | start no earlier than 2025-03-17 |  | SI Test |  | SIT | 6.20 | Stuart Scott |  |  |  | Complete | COMPLETE |  |  | QAG |  |
| 1794 | 1.4.3.1.1.6 | SRO / Code Bodies review |  | 5d | 2025-03-24 A | 2025-03-28 | 1793 | 40% | 3d | 2025-03-24 | 2025-03-28 | 0d |  |  | 713d | 2d | finish no earlier than 2025-03-28 |  | SI Test |  | SIT | 6.20 | Stuart Scott |  |  |  | Overdue | RED |  |  | QAG |  |
| 1795 | 1.4.3.1.1.7 | Submit version to QWG | milestone | 0d | 2025-04-01 | 2025-04-01 | 1794 |  |  | 2025-04-01 | 2025-04-01 | 0d |  |  | 711d | 5d | finish no earlier than 2025-04-01 |  | SI Test |  | SIT | 6.20 | Stuart Scott |  |  | -35.29 | Overdue Start | RED |  |  | QAG |  |
| 1796 | 1.4.3.1.1.8 | Artefact Recommendation for Approval (via QWG) | milestone | 0d | 2025-04-08 | 2025-04-08 | 1795 |  |  | 2025-04-08 | 2025-04-08 | 0d |  |  | 706d | 0d | finish no earlier than 2025-04-08 |  | SI Test |  | SIT | 6.20 | Stuart Scott |  |  | -28.29 | Overdue Start | RED |  |  | QAG |  |
| 1797 | 1.4.3.1.1.9 | Final Document updates post QWG review |  | 1d | 2025-04-09 | 2025-04-09 | 1796 |  |  | 2025-04-09 | 2025-04-09 | 0d |  |  | 706d |  | start no earlier than 2025-04-09 |  | SI Test |  | SIT | 6.20 | Stuart Scott |  |  | -27.67 | Overdue Start | RED |  |  | QAG |  |
| 1798 | 1.4.3.1.1.10 | Submit final version to QAG |  | 1d? | 2025-04-10 | 2025-04-10 |  |  |  | 2025-04-10 | 2025-04-10 | 0d |  |  | 701d | 1d | finish no earlier than 2025-04-10 |  | SI Test |  | SIT | 6.20 | Stuart Scott |  |  | -26.67 | Overdue Start | RED |  |  | QAG |  |
| 1799 | 1.4.3.1.1.11 | E2E Sandbox guidance update approved at QAG |  | 1d? | 2025-04-17 | 2025-04-17 | 1798FS+3d |  |  | 2025-04-17 | 2025-04-17 | 0d |  |  | 700d |  | finish no earlier than 2025-04-17 |  | SI Test |  | SIT | 6.20 | Stuart Scott |  |  | -19.67 | Overdue Start | RED |  |  | QAG |  |

Notes:
- 1774: 07/05/25 - Current testing velocity shows all PPs on track to complete SIT by the end of Regression (08/08/25). Proposal that all MVC activity becomes SIT, with Non-MVC becoming contingency activity in the instance of any PPs requiring further testing activity after regression.
- 1776: 06/05/25 - Programme is proposing that this milestone be renamed to not include a reference to 'Non-MVC'. Programme is proposing to rename 'SIT MVC' to 'SIT' and 'SIT Non-MVC' to 'SIT Contingency'. Testing evidence to date suggests all SIT PPs are in a position to complete SIT at the end of Regression, meaning the end of Regression is no longer just the target SIT end date for PPs who will be ready for M10, but all PPs. 'SIT non-MVC' will be renamed 'SIT Contingency', to show that SIT will still go on until November, as per the existing plan. This change is going to May SITAG for formal approval.
- 1778: 06/05/25 - Programme is proposing that this milestone be renamed to not include a reference to 'Non-MVC'. Programme is proposing to rename 'SIT MVC' to 'SIT' and 'SIT Non-MVC' to 'SIT Contingency'. Testing evidence to date suggests all SIT PPs are in a position to complete SIT at the end of Regression, meaning the end of Regression is no longer just the target SIT end date for PPs who will be ready for M10, but all PPs. 'SIT non-MVC' will be renamed 'SIT Contingency', to show that SIT will still go on until November, as per the existing plan. This change is going to May SITAG for formal approval.
- 1781: 06/05/25 - Programme is proposing that this milestone be renamed to not include a reference to 'Non-MVC'. Programme is proposing to rename 'SIT MVC' to 'SIT' and 'SIT Non-MVC' to 'SIT Contingency'. Testing evidence to date suggests all SIT PPs are in a position to complete SIT at the end of Regression, meaning the end of Regression is no longer just the target SIT end date for PPs who will be ready for M10, but all PPs. 'SIT non-MVC' will be renamed 'SIT Contingency', to show that SIT will still go on until November, as per the existing plan. This change is going to May SITAG for formal approval.
- 1782: 06/05/25 - Programme is proposing that this milestone be renamed to not include a reference to 'Non-MVC'. Programme is proposing to rename 'SIT MVC' to 'SIT' and 'SIT Non-MVC' to 'SIT Contingency'. Testing evidence to date suggests all SIT PPs are in a position to complete SIT at the end of Regression, meaning the end of Regression is no longer just the target SIT end date for PPs who will be ready for M10, but all PPs. 'SIT non-MVC' will be renamed 'SIT Contingency', to show that SIT will still go on until November, as per the existing plan. This change is going to May SITAG for formal approval.
- 1783: 06/05/25 - Existing SIT Exit activity to be superseded by proposed approach pending May SITAG approval.
- 1784: 06/05/25 - Existing SIT Exit activity to be superseded by proposed approach pending May SITAG approval.
- 1785: 06/05/25 - Programme is proposing that this milestone be renamed to not include a reference to 'Non-MVC'. Programme is proposing to rename 'SIT MVC' to 'SIT' and 'SIT Non-MVC' to 'SIT Contingency'. Testing evidence to date suggests all SIT PPs are in a position to complete SIT at the end of Regression, meaning the end of Regression is no longer just the target SIT end date for PPs who will be ready for M10, but all PPs. 'SIT non-MVC' will be renamed 'SIT Contingency', to show that SIT will still go on until November, as per the existing plan. This change is going to May SITAG for formal approval.
- 1794: 06/05/25 - Dates will be updated once E2E Test Apporach and Plan is agreed with QWG/QAG.
- 1795: 06/05/25 - Dates will be updated once E2E Test Apporach and Plan is agreed with QWG/QAG.
- 1796: 06/05/25 - Dates will be updated once E2E Test Apporach and Plan is agreed with QWG/QAG.
- 1797: 06/05/25 - Dates will be updated once E2E Test Apporach and Plan is agreed with QWG/QAG.
- 1798: 06/05/25 - Dates will be updated once E2E Test Apporach and Plan is agreed with QWG/QAG.
- 1799: 06/05/25 - Dates will be updated once E2E Test Apporach and Plan is agreed with QWG/QAG.

| ID | WBS | Task | Type | Duration | Start | Finish | Predecessors | Complete | Remaining | Baseline start | Baseline finish | Baseline duration | Baseline 1 start | Baseline 1 finish | Total slack | Free slack | Constraint | Baseline cost | Responsible | Involved | Text9 | Update Version | MHHS Resource Name | MHHS Programme Phase | Text29 | Sched Status | RAG | Task Status | Milestone ID | Tier | Artefact ID |
| --- | --- | --- | --- | --- | --- | --- | --- | --- | --- | --- | --- | --- | --- | --- | --- | --- | --- | --- | --- | --- | --- | --- | --- | --- | --- | --- | --- | --- | --- | --- | --- |
| 1800 | 1.4.3.1.2 | **E2E Sandbox Test Data Approach & Plan** |  | 68d | 2025-01-13 A | 2025-04-16 |  | 23% | 52.38d | 2023-12-05 | 2024-05-09 | 93d | 2023-03-29 | 2023-08-04 | 701d |  |  |  | SI Test | N/A | SIT | 6.1 | Stuart Scott | Systems Integration Testing (SIT) | QAG |  |  |  |  |  |  |
| 1801 | 1.4.3.1.2.1 | Discussion at QWG to reconfirm value provided from E2E Sandbox (UIT) | milestone | 0d | 2025-03-11 A | 2025-03-11 A |  | 100% |  | 2025-03-11 | 2025-03-11 | 0d |  |  |  |  | finish no earlier than 2025-03-11 |  | SI Test |  | SIT | 6.20 | Stuart Scott |  | QAG | Complete | COMPLETE |  |  |  |  |
| 1802 | 1.4.3.1.2.2 | Create PPIR to request PP responses on subject to gather views |  | 5d | 2025-03-10 A | 2025-03-14 A |  | 100% |  | 2025-03-10 | 2025-03-14 | 0d |  |  |  |  | finish no earlier than 2025-03-14 |  | SI Test |  | SIT | 6.20 | Stuart Scott |  | QAG | Complete | COMPLETE |  |  |  |  |
| 1803 | 1.4.3.1.2.3 | PPIR shared to industry |  | 9d | 2025-03-24 A | 2025-04-03 A | 1802 | 100% |  | 2025-03-24 | 2025-04-03 | 0d |  |  |  |  | start no earlier than 2025-03-24 |  | SI Test |  | SIT | 6.22 | Stuart Scott |  | QAG | Complete | COMPLETE |  |  |  |  |
| 1804 | 1.4.3.1.2.4 | Evaluate PPIR responses |  | 2d | 2025-04-04 A | 2025-04-07 A |  | 100% |  | 2025-04-04 | 2025-04-07 | 0d |  |  |  |  | start no earlier than 2025-04-04 |  | SI Test |  | SIT | 6.22 | Stuart Scott |  | QAG | Complete | COMPLETE |  |  |  |  |
| 1805 | 1.4.3.1.2.5 | Discuss PPIR results at QWG |  | 1d | 2025-04-08 A | 2025-04-08 A | 1804SF-5d | 100% |  | 2025-04-08 | 2025-04-08 | 0d |  |  |  |  | finish no earlier than 2025-04-08 |  | SI Test |  | SIT | 6.20 | Stuart Scott |  | QAG | Complete | COMPLETE |  |  |  |  |
| 1806 | 1.4.3.1.2.6 | Develop document |  | 27d | 2025-01-13 | 2025-02-18 | 1789SS+199d |  |  | 2025-01-13 | 2025-02-18 | 68d | 2023-03-29 | 2023-06-30 | 701d | 0d | start no earlier than 2025-01-13 |  | SI Test |  | SIT | 5.0 | Stuart Scott | Systems Integration Testing (SIT) | QAG | Overdue Start | RED | -113.67 |  |  |  |
| 1807 | 1.4.3.1.2.7 | Internal SI review and updates |  | 5d | 2025-02-19 | 2025-02-25 | 1806 |  |  | 2025-02-19 | 2025-02-25 | 0d |  |  | 701d | 0d |  |  | SI Test |  | SIT | 6.1 | Stuart Scott |  | QAG | Overdue Start | RED | -76.67 |  |  |  |
| 1808 | 1.4.3.1.2.8 | SRO / Code Bodies review |  | 5d | 2025-02-26 | 2025-03-04 | 1807 |  |  | 2025-02-26 | 2025-03-04 | 0d |  |  | 701d | 0d |  |  | SI Test |  | SIT | 6.1 | Stuart Scott |  | QAG | Overdue Start | RED | -69.67 |  |  |  |
| 1809 | 1.4.3.1.2.9 | Submit proposed version to QWG | milestone | 0d | 2025-03-04 | 2025-03-04 | 1808 |  |  | 2025-03-04 | 2025-03-04 | 0d |  |  | 701d | 0d |  |  | SI Test |  | SIT | 6.1 | Stuart Scott |  | QAG | Overdue Start | RED | -63.29 |  |  |  |
| 1810 | 1.4.3.1.2.10 | Discuss document at QWG | milestone | 0d | 2025-03-11 | 2025-03-11 | 1809FS+5d |  |  | 2025-03-11 | 2025-03-11 | 0d |  |  | 701d | 0d |  |  | SI Test |  | SIT | 6.1 | Stuart Scott |  | QAG | Overdue Start | RED | -56.29 |  |  |  |
| 1811 | 1.4.3.1.2.11 | Final updates prior to consultation |  | 4d | 2025-03-12 | 2025-03-17 | 1810 |  |  | 2025-03-12 | 2025-03-17 | 0d |  |  | 701d | 0d |  |  | SI Test |  | SIT | 6.1 | Stuart Scott |  | QAG | Overdue Start | RED | -55.67 |  |  |  |
| 1812 | 1.4.3.1.2.12 | Industry Consultation for E2E Sandbox Test Data Approach and Plan document |  | 10d | 2025-03-18 | 2025-03-31 | 1811 |  |  | 2025-03-18 | 2025-03-31 | 0d |  |  | 701d | 0d |  |  | SI Test |  | SIT | 6.1 | Stuart Scott |  | QAG | Overdue Start | RED | -49.67 |  |  |  |
| 1813 | 1.4.3.1.2.13 | Document updates post Industry Consultation |  | 3d | 2025-04-01 | 2025-04-03 | 1812 |  |  | 2025-04-01 | 2025-04-03 | 0d |  |  | 701d | 0d | finish no earlier than 2024-04-22 |  | SI Test |  | SIT | 6.1 | Stuart Scott |  | QAG | Overdue Start | RED | -35.67 |  |  |  |
| 1814 | 1.4.3.1.2.14 | Submit Proposed Version to QWG |  | 3d | 2025-04-04 | 2025-04-08 | 1813 |  |  | 2025-04-04 | 2025-04-08 | 0d |  |  | 701d | 0d |  |  | SI Test |  | SIT | 6.1 | Stuart Scott |  | QAG | Overdue Start | RED | -32.67 |  |  |  |
| 1815 | 1.4.3.1.2.15 | Artefact Approval (via QWG) | milestone | 0d | 2025-04-08 | 2025-04-08 | 1814 |  |  | 2025-04-08 | 2025-04-08 | 0d |  |  | 701d | 0d |  |  | SI Test |  | SIT | 6.1 | Stuart Scott |  | QAG | Overdue Start | RED | -28.29 |  |  |  |
| 1816 | 1.4.3.1.2.16 | Final Document updates post QWG review | milestone | 0d | 2025-04-09 | 2025-04-09 | 1815FS+1d |  |  | 2025-04-09 | 2025-04-09 | 0d |  |  | 701d | 0d | start no earlier than 2024-05-01 |  | SI Test |  | SIT | 6.1 | Stuart Scott |  | QAG | Overdue Start | RED | -27.29 |  |  |  |
| 1817 | 1.4.3.1.2.17 | Submit final version to QAG | milestone | 0d | 2025-04-10 | 2025-04-10 | 1816FS+1d |  |  | 2025-04-10 | 2025-04-10 | 0d |  |  | 701d | 0d | start no earlier than 2024-05-02 |  | SI Test |  | SIT | 6.1 | Stuart Scott |  | QAG | Overdue Start | RED | -26.29 |  |  |  |
| 1818 | 1.4.3.1.2.18 | E2E Sandbox Test Data Approach and Plan | milestone | 0d | 2025-04-16 | 2025-04-16 | 1817FS+4d |  |  | 2025-04-16 | 2025-04-16 | 0d |  |  | 701d |  | start no earlier than 2024-05-09 |  | SI Test |  | SIT | 6.1 | Stuart Scott |  | QAG | Overdue Start | RED | -20.29 | T3-QU-0124 | T3 |  |
| 1819 | 1.4.3.2 | **UIT Stub Specification and Delivery** |  | 260d | 2023-12-04 A | 2024-11-29 A |  | 100% |  | 2023-12-04 | 2024-10-18 | 190d | 2023-10-27 | 2024-08-23 |  |  |  | -0 | N/A | N/A | SIT | 5.0 | N/A | Systems Integration Testing (SIT) |  |  |  |  |  |  |  |
| 1820 | 1.4.3.2.1 | **Qualification Test Stubs** |  | 260d | 2023-12-04 A | 2024-11-29 A |  | 100% |  | 2023-12-04 | 2024-10-18 | 190d | 2023-10-27 | 2024-08-23 |  |  |  | -0 | N/A | N/A | SIT | 5.16 | N/A | Systems Integration Testing (SIT) |  |  |  |  |  |  |  |
| 1821 | 1.4.3.2.1.1 | Specify |  | 44d | 2023-12-04 A | 2024-02-01 A | 553FS+13d | 100% |  | 2023-12-04 | 2024-02-01 | 44d | 2023-10-27 | 2023-12-29 |  |  |  |  | SI DevOps | Qualification,SRO | SIT | 5.0 | Lewis Hall | Systems Integration Testing (SIT) |  | Complete | COMPLETE |  |  |  |  |
| 1822 | 1.4.3.2.1.2 | Build & Test |  | 141d | 2024-02-02 A | 2024-08-16 A | 1821 | 100% |  | 2024-02-02 | 2024-08-16 | 141d | 2023-12-29 | 2024-05-24 |  |  |  |  | SI DevOps | Qualification,SRO | SIT | 5.23 | Lewis Hall | Systems Integration Testing (SIT) |  | Complete | COMPLETE |  |  |  |  |
| 1823 | 1.4.3.2.1.3 | Prepare for release |  | 75d | 2024-08-19 A | 2024-11-29 A | 1822 | 100% |  | 2024-08-19 | 2024-11-29 | 5d | 2024-07-29 | 2024-08-23 |  |  |  |  | SI DevOps | Qualification,SRO | SIT | 5.0 | Lewis Hall | Systems Integration Testing (SIT) |  | Complete | COMPLETE |  |  |  |  |
| 1824 | 1.4.3.2.1.4 | Non-SIT LDSO Test Harness Released | milestone | 0d | 2024-11-29 A | 2024-11-29 A | 1823 | 100% |  | 2024-11-29 | 2024-11-29 | 0d | 2024-08-23 | 2024-08-23 |  |  |  |  | SI DevOps | Qualification,SRO | SIT | 5.27 | Lewis Hall | Systems Integration Testing (SIT) | QAG | Complete | COMPLETE |  | T3-TE-0035 | T3 | MHHS-ART080 |

Notes:
- 1806: 06/05/25 - Dates will be updated once E2E Test Apporach and Plan is agreed with QWG/QAG.
- 1807: 06/05/25 - Dates will be updated once E2E Test Apporach and Plan is agreed with QWG/QAG.
- 1808: 06/05/25 - Dates will be updated once E2E Test Apporach and Plan is agreed with QWG/QAG.
- 1809: 06/05/25 - Dates will be updated once E2E Test Apporach and Plan is agreed with QWG/QAG.
- 1810: 06/05/25 - Dates will be updated once E2E Test Apporach and Plan is agreed with QWG/QAG.
- 1811: 06/05/25 - Dates will be updated once E2E Test Apporach and Plan is agreed with QWG/QAG.
- 1812: 06/05/25 - Dates will be updated once E2E Test Apporach and Plan is agreed with QWG/QAG.
- 1813: 06/05/25 - Dates will be updated once E2E Test Apporach and Plan is agreed with QWG/QAG.
- 1814: 06/05/25 - Dates will be updated once E2E Test Apporach and Plan is agreed with QWG/QAG.
- 1815: 06/05/25 - Dates will be updated once E2E Test Apporach and Plan is agreed with QWG/QAG.
- 1816: 06/05/25 - Dates will be updated once E2E Test Apporach and Plan is agreed with QWG/QAG.
- 1817: 06/05/25 - Dates will be updated once E2E Test Apporach and Plan is agreed with QWG/QAG.
- 1818: 06/05/25 - Dates will be updated once E2E Test Apporach and Plan is agreed with QWG/QAG.

| ID | WBS | Task | Type | Duration | Start | Finish | Predecessors | Complete | Remaining | Baseline start | Baseline finish | Baseline duration | Baseline 1 start | Baseline 1 finish | Total slack | Free slack | Constraint | Baseline cost | Responsible | Involved | Text9 | Update Version | MHHS Resource Name | MHHS Programme Phase | Sched Status | RAG | Task Status | Milestone ID | Text29 | Tier |
| --- | --- | --- | --- | --- | --- | --- | --- | --- | --- | --- | --- | --- | --- | --- | --- | --- | --- | --- | --- | --- | --- | --- | --- | --- | --- | --- | --- | --- | --- | --- |
| 1825 | 1.4.3.3 | **Environments (UIT)** |  | 680d | 2022-10-31 A | 2025-06-06 |  | 50% | 337.96d | 2022-10-31 | 2025-07-04 | 680d | 2022-10-31 | 2025-06-06 | 664d |  |  | -0 | N/A | N/A | SIT | 5.0 | N/A | Systems Integration Testing (SIT) |  |  |  |  |  |  |
| 1826 | 1.4.3.3.1 | **Central Party (Avanade) Environments (UIT)** |  | 488d | 2022-11-16 A | 2024-09-27 A |  | 100% |  | 2022-11-16 | 2024-09-27 | 493d | 2022-11-16 | 2024-10-04 |  |  |  | -0 | N/A | N/A | SIT | 5.28 | N/A | Systems Integration Testing (SIT) |  |  |  |  |  |  |
| 1827 | 1.4.3.3.1.1 | Central Party (Avandae) environment preparation (incl. security certificates and security compliance) |  | 447d | 2022-11-16 A | 2024-08-01 A | 549 | 100% |  | 2022-11-16 | 2024-08-01 | 463d | 2022-11-16 | 2024-08-23 |  |  |  |  | PP | SI Test | SIT | 5.28 | Heath Thomas | Systems Integration Testing (SIT) | Complete | COMPLETE |  |  |  |  |
| 1828 | 1.4.3.3.1.2 | Submit self-declaration of environment preparation complete (incl. security certificates and security compliance) to Programme for assurance |  | 447d | 2022-11-16 A | 2024-08-01 A | 1827SS | 100% |  | 2022-11-16 | 2024-08-01 | 463d | 2022-11-16 | 2024-08-23 |  |  |  |  | PP | SI Test | SIT | 5.28 | Heath Thomas | Systems Integration Testing (SIT) | Complete | COMPLETE |  |  |  |  |
| 1829 | 1.4.3.3.1.3 | Central Party (Avanade) UIT environment connectivity proving |  | 25d | 2024-08-26 A | 2024-09-27 A | 1841 | 100% |  | 2024-08-26 | 2024-09-27 | 25d | 2024-08-27 | 2024-09-20 |  |  |  |  | PP | SI Test | SIT | 5.28 | Heath Thomas | Systems Integration Testing (SIT) | Complete | COMPLETE |  |  |  |  |
| 1830 | 1.4.3.3.1.4 | Deployment of MHHS solution code to UIT environments |  | 2d | 2024-07-29 A | 2024-07-30 A |  | 100% |  | 2024-07-29 | 2024-07-30 | 10d | 2024-09-09 | 2024-09-20 |  |  | start no earlier than 2024-07-29 |  | PP | SI Test | SIT | 5.28 | Heath Thomas | Systems Integration Testing (SIT) | Complete | COMPLETE |  |  |  |  |
| 1831 | 1.4.3.3.1.5 | Central Party (Avanade) UIT environment Regression Testing |  | 1d | 2024-07-31 A | 2024-07-31 A | 1830 | 100% |  | 2024-07-31 | 2024-07-31 | 10d | 2024-09-23 | 2024-10-04 |  |  |  |  | PP | SI Test | SIT | 5.28 | Heath Thomas | Systems Integration Testing (SIT) | Complete | COMPLETE |  |  |  |  |
| 1832 | 1.4.3.3.2 | **E2E Sandbox Participants (UIT)** |  | 680d | 2022-10-31 | 2025-06-06 |  |  |  | 2022-10-31 | 2025-06-06 | 680d | 2022-10-31 | 2025-06-06 | 0d |  |  |  | N/A | N/A | SIT | 5.0 | Heath Thomas | Systems Integration Testing (SIT) |  |  |  |  |  |  |
| 1833 | 1.4.3.3.2.1 | E2E Sandbox Participants environment preparation (incl. security certificates and security compliance) |  | 660d | 2022-10-31 | 2025-05-09 |  |  |  | 2022-10-31 | 2025-05-09 | 660d | 2022-10-31 | 2025-05-09 | 0d |  | must finish on 2025-05-09 |  | PP | SI Test | SIT | 5.0 | Heath Thomas | Systems Integration Testing (SIT) | Overdue Start | GREEN | -918.67 |  |  |  |
| 1834 | 1.4.3.3.2.2 | Submit self-declaration of environment preparation complete (incl. security certificates and security compliance) to Programme for assurance |  | 660d | 2022-10-31 | 2025-05-09 |  |  |  | 2022-10-31 | 2025-05-09 | 660d | 2022-10-31 | 2025-05-09 | 664d | 0d |  |  | PP | SI Test | SIT | 5.0 | Heath Thomas | Systems Integration Testing (SIT) | Overdue Start | GREEN | -918.67 |  |  |  |
| 1835 | 1.4.3.3.2.3 | E2E Sandbox Participants UIT environment connectivity proving |  | 20d | 2025-05-12 | 2025-06-06 | 1834 |  |  | 2025-05-12 | 2025-06-06 | 20d | 2025-05-12 | 2025-06-06 | 664d | 0d |  |  | PP | SI Test | SIT | 5.0 | Heath Thomas | Systems Integration Testing (SIT) | Green | GREEN | 5.33 |  |  |  |
| 1836 | 1.4.3.3.2.4 | Deployment of MHHS solution code to UIT environments |  | 10d | 2025-05-26 | 2025-06-06 | 1835FF |  |  | 2025-05-26 | 2025-06-06 | 10d | 2025-05-26 | 2025-06-06 | 664d |  |  |  | PP | SI Test | SIT | 5.0 | Heath Thomas | Systems Integration Testing (SIT) | Green | GREEN | 19.33 |  |  |  |
| 1837 | 1.4.3.3.2.5 | Coordinate E2E Sandbox Participants' UIT environment preparation (for E2E Sandbox Testing Start) |  | 463d | 2022-10-31 | 2024-08-07 | 1833SS |  |  | 2022-10-31 | 2024-08-07 | 463d | 2022-10-31 | 2024-08-07 | 881d |  |  |  | SI Test | PP | SIT | 5.0 | Heath Thomas | Systems Integration Testing (SIT) | Overdue Start | RED | -918.67 |  |  |  |
| 1838 | 1.4.3.3.3 | **SI Environments (UIT)** |  | 489d | 2022-11-16 A | 2024-09-30 |  | 99% | 6.77d | 2022-11-16 | 2025-07-04 | 680d | 2022-10-31 | 2025-06-06 | 843d |  |  |  | N/A | N/A | SIT | 5.0 | Heath Thomas | Systems Integration Testing (SIT) |  |  |  |  |  |  |
| 1839 | 1.4.3.3.3.1 | Coordinate Central Parties' UIT environment preparation |  | 447d | 2022-11-16 A | 2024-08-01 A | 1827SS | 100% |  | 2022-11-16 | 2024-08-01 | 463d | 2022-11-16 | 2024-08-23 |  |  |  |  | SI Test | PP | SIT | 5.0 | Heath Thomas | Systems Integration Testing (SIT) | Complete | COMPLETE |  |  |  |  |
| 1840 | 1.4.3.3.3.2 | Assure Central Parties' self-declaration of environment preparation complete (incl. security certificates and security compliance) |  | 463d | 2022-11-16 A | 2024-08-23 | 1828SS | 97% | 12d | 2022-11-16 | 2024-08-23 | 463d | 2022-11-16 | 2024-08-23 | 869d |  |  |  | SI Test | PP | SIT | 5.0 | Heath Thomas | Systems Integration Testing (SIT) | Overdue | RED |  |  |  |  |
| 1841 | 1.4.3.3.3.3 | Central Parties' UIT environments ready to start connectivity proving (incl. certificates and security compliance) | milestone | 0d | 2024-08-23 A | 2024-08-23 A | 1824 | 100% |  | 2024-08-23 | 2024-08-23 | 0d | 2024-08-23 | 2024-08-23 |  |  |  |  | SI Test | PP | SIT | 5.0 | Heath Thomas | Systems Integration Testing (SIT) | Complete | COMPLETE |  | T3-TE-0044 | QAG | T3 |
| 1842 | 1.4.3.3.3.4 | Coordinate Central Parties' UIT environment connectivity proving |  | 26d | 2024-08-26 A | 2024-09-30 A | 1829SS | 100% |  | 2024-08-26 | 2024-09-30 | 19d | 2025-05-12 | 2025-06-05 |  |  |  |  | SI Test | PP | SIT | 5.0 | Heath Thomas | Systems Integration Testing (SIT) | Complete | COMPLETE |  |  |  |  |
| 1843 | 1.4.3.3.3.5 | Coordinate deployment of MHHS solution code to Central Parties' UIT environments |  | 2d | 2024-07-29 A | 2024-07-30 A | 1830SS | 100% |  | 2024-07-29 | 2024-07-30 | 10d | 2025-05-26 | 2025-06-06 |  |  |  |  | SI Test | PP | SIT | 5.0 | Heath Thomas | Systems Integration Testing (SIT) | Complete | COMPLETE |  |  |  |  |
| 1844 | 1.4.3.3.3.6 | Coordinate Central Parties' UIT environment Regression Testing |  | 1d | 2024-07-31 | 2024-07-31 | 1843 |  |  | 2024-07-31 | 2024-07-31 | 10d | 2024-09-23 | 2024-10-04 | 886d |  |  |  | SI Test | PP | SIT | 5.0 | Heath Thomas | Systems Integration Testing (SIT) | Overdue Start | RED | -279.67 |  |  |  |
| 1845 | 1.4.3.4 | **Test Data** |  | 30d | 2024-08-26 | 2024-10-04 |  |  |  | 2024-08-26 | 2024-10-04 | 30d | 2024-08-26 | 2024-10-04 | 819d |  |  | -0 | N/A | N/A | SIT | 5.0 | N/A | Systems Integration Testing (SIT) |  |  |  |  |  |  |
| 1846 | 1.4.3.4.1 | **Central Parties (for E2E Sandbox & Qualification)** |  | 30d | 2024-08-26 | 2024-10-04 |  |  |  | 2024-08-26 | 2024-10-04 | 30d | 2024-08-26 | 2024-10-04 | 819d |  |  |  | N/A | N/A | SIT | 5.0 | N/A | Systems Integration Testing (SIT) |  |  |  |  |  |  |
| 1847 | 1.4.3.4.1.1 | Central Parties' UIT environment test data loading & verification (& data cleansing, if required) |  | 30d | 2024-08-26 | 2024-10-04 |  |  |  | 2024-08-26 | 2024-10-04 | 30d | 2024-08-26 | 2024-10-04 | 819d | 0d | start no earlier than 2024-08-26 |  | PP | SI Test | SIT | 5.0 | Michael Inije | Systems Integration Testing (SIT) | Overdue Start | RED | -253.67 |  |  |  |
| 1848 | 1.4.3.4.1.2 | Submit self-declaration to Programme to confirm loading & verification of test data |  | 30d | 2024-08-26 | 2024-10-04 | 1847SS |  |  | 2024-08-26 | 2024-10-04 | 30d | 2024-08-26 | 2024-10-04 | 819d | 0d |  |  | PP | SI Test | SIT | 5.0 | Michael Inije | Systems Integration Testing (SIT) | Overdue Start | RED | -253.67 |  |  |  |

Notes:
- 1837: 06/05/25 - Dates will be updated once E2E Test Apporach and Plan is agreed with QWG/QAG.
- 1840: 06/05/25 - Dates will be updated once E2E Test Apporach and Plan is agreed with QWG/QAG.
- 1844: 06/05/25 - Dates will be updated once E2E Test Apporach and Plan is agreed with QWG/QAG.
- 1845: 06/05/25 - Dates will be updated once E2E Test Apporach and Plan is agreed with QWG/QAG.
- 1846: 06/05/25 - Dates will be updated once E2E Test Apporach and Plan is agreed with QWG/QAG.
- 1847: 06/05/25 - Dates will be updated once E2E Test Apporach and Plan is agreed with QWG/QAG.
- 1848: 06/05/25 - Dates will be updated once E2E Test Apporach and Plan is agreed with QWG/QAG.

| ID | WBS | Task | Type | Duration | Start | Finish | Predecessors | Complete | Remaining | Baseline start | Baseline finish | Baseline duration | Baseline 1 start | Baseline 1 finish | Total slack | Free slack | Constraint | Baseline cost | Responsible | Involved | Text9 | Update Version | MHHS Resource Name | MHHS Programme Phase | Task Status | Sched Status | RAG | Artefact ID | Milestone ID | Text29 | Tier |
| --- | --- | --- | --- | --- | --- | --- | --- | --- | --- | --- | --- | --- | --- | --- | --- | --- | --- | --- | --- | --- | --- | --- | --- | --- | --- | --- | --- | --- | --- | --- | --- |
| 1849 | 1.4.3.4.2 | **E2E Sandbox Participants** |  | 30d | 2024-08-26 | 2024-10-04 |  |  |  | 2024-08-26 | 2024-10-04 | 30d | 2024-08-26 | 2024-10-04 | 839d |  |  | -0 | N/A | N/A | SIT | 5.0 | Michael Inije | Systems Integration Testing (SIT) |  |  |  |  |  |  |  |
| 1850 | 1.4.3.4.2.1 | UIT environment test data loading and verification (and data cleansing, if required) (for E2E Sandbox Testing Start) |  | 30d | 2024-08-26 | 2024-10-04 | 1847FF |  |  | 2024-08-26 | 2024-10-04 | 30d | 2024-08-26 | 2024-10-04 | 839d | 0d |  |  | PP | SI Test | SIT | 5.0 | Michael Inije | Systems Integration Testing (SIT) | -253.67 | Overdue Start | RED |  |  |  |  |
| 1851 | 1.4.3.4.3 | **SI Test Data** |  | 30d | 2024-08-26 | 2024-10-04 |  |  |  | 2024-08-26 | 2024-10-04 | 30d | 2024-08-26 | 2024-10-04 | 839d |  |  |  | N/A | N/A | SIT | 5.0 | Michael Inije | Systems Integration Testing (SIT) |  |  |  |  |  |  |  |
| 1852 | 1.4.3.4.3.1 | Coordinate Central Parties' UIT environment test data loading and verification (and data cleansing, if required) |  | 30d | 2024-08-26 | 2024-10-04 | 1847SS |  |  | 2024-08-26 | 2024-10-04 | 30d | 2024-08-26 | 2024-10-04 | 839d |  |  |  | SI Test | PP | SIT | 5.0 | Michael Inije | Systems Integration Testing (SIT) | -253.67 | Overdue Start | RED |  |  |  |  |
| 1853 | 1.4.3.4.3.2 | Assure evidence of Central Parties' UIT environment test data load and verification |  | 30d | 2024-08-26 | 2024-10-04 | 1848SS |  |  | 2024-08-26 | 2024-10-04 | 30d | 2024-08-26 | 2024-10-04 | 839d |  |  |  | SI Test | PP | SIT | 5.0 | Michael Inije | Systems Integration Testing (SIT) | -253.67 | Overdue Start | RED |  |  |  |  |
| 1854 | 1.4.3.4.3.3 | Coordinate E2E Sandbox Participants' UIT environment test data loading and verification (and data cleansing, if required) (for E2E Sandbox Testing Start) |  | 30d | 2024-08-26 | 2024-10-04 | 1850SS |  |  | 2024-08-26 | 2024-10-04 | 30d | 2024-08-26 | 2024-10-04 | 839d |  |  |  | SI Test | PP | SIT | 5.0 | Michael Inije | Systems Integration Testing (SIT) | -253.67 | Overdue Start | RED |  |  |  |  |
| 1855 | 1.4.3.5 | **Other Preparation** |  | 496d | 2022-10-31 A | 2024-09-23 |  | 59% | 201.3d | 2022-10-31 | 2024-09-23 | 484d | 2022-11-16 | 2024-09-23 | 848d |  |  |  | N/A | N/A | SIT | 5.0 | N/A | Systems Integration Testing (SIT) |  |  |  |  |  |  |  |
| 1856 | 1.4.3.5.1 | **SI Other Preparation** |  | 66d | 2022-10-31 | 2023-01-30 |  |  |  | 2022-10-31 | 2023-01-30 | 66d | 2024-05-02 | 2024-08-01 | 1278d |  |  |  | N/A | N/A | SIT | 5.0 | N/A | Systems Integration Testing (SIT) |  |  |  |  |  |  |  |
| 1857 | 1.4.3.5.1.1 | Onboarding of UIT E2E Sandbox Participants to Test Management Tool for E2E Sandbox Testing Start (onboarding of participants will be ongoing hereafter) |  | 66d | 2022-10-31 | 2023-01-30 |  |  |  | 2022-10-31 | 2023-01-30 | 66d | 2024-05-02 | 2024-08-01 | 1278d | 393d |  |  | SI Test | PP | SIT | 5.0 | Stuart Scott | Systems Integration Testing (SIT) | -918.67 | Overdue Start | RED |  |  |  |  |
| 1858 | 1.4.3.5.2 | **Other Preparation (for Central Parties & E2E Sandbox Participants)** |  | 484d | 2022-11-16 A | 2024-09-23 |  | 67% | 161.92d | 2022-11-16 | 2024-09-23 | 484d | 2022-11-16 | 2024-09-23 | 848d |  |  |  | N/A | N/A | SIT | 5.0 | N/A | Systems Integration Testing (SIT) |  |  |  |  |  |  |  |
| 1859 | 1.4.3.5.2.1 | Test Management Tool onboarding for E2E Sandbox Testing Start (onboarding will be ongoing hereafter) |  | 66d | 2024-05-02 | 2024-08-01 | 1857SS |  |  | 2024-05-02 | 2024-08-01 | 66d | 2024-05-02 | 2024-08-01 | 885d |  | start no earlier than 2024-05-02 |  | PP | SI Test | SIT | 5.0 | Stuart Scott | Systems Integration Testing (SIT) | -369.67 | Overdue Start | RED |  |  |  |  |
| 1860 | 1.4.3.5.2.2 | Other Preparation (incl. test execution planning) |  | 484d | 2022-11-16 A | 2024-09-23 | 1827SS, 1833SS | 76% | 118d | 2022-11-16 | 2024-09-23 | 484d | 2022-11-16 | 2024-09-23 | 848d |  |  |  | PP | SI Test | SIT | 5.0 | Stuart Scott | Systems Integration Testing (SIT) |  | Overdue | RED |  |  |  |  |
| 1861 | 1.4.3.6 | **UIT E2E Sandbox Test Readiness Report** |  | 114d | 2024-08-26 | 2025-01-31 |  |  |  | 2024-08-26 | 2025-01-31 | 114d | 2024-08-26 | 2024-10-25 | 750d |  |  | -0 | N/A | N/A | SIT | 5.0 | N/A | Systems Integration Testing (SIT) |  |  |  |  |  |  |  |
| 1862 | 1.4.3.6.1 | **Central Parties E2E Sandbox Test Readiness Report** |  | 30d | 2024-08-26 | 2024-10-04 |  |  |  | 2024-08-26 | 2024-10-04 | 30d | 2024-08-26 | 2024-10-04 | 819d |  |  |  | N/A | N/A | SIT | 5.0 | N/A | Systems Integration Testing (SIT) |  |  |  |  |  |  |  |
| 1863 | 1.4.3.6.1.1 | Develop draft Test Readiness Report and submit to Programme for assurance |  | 20d | 2024-08-26 | 2024-09-20 | 1848FF-10d |  |  | 2024-08-26 | 2024-09-20 | 20d | 2024-08-26 | 2024-09-20 | 819d | 0d |  |  | PP | SI Test | SIT | 5.0 | Stuart Scott | Systems Integration Testing (SIT) | -253.67 | Overdue Start | RED |  |  |  |  |
| 1864 | 1.4.3.6.1.2 | Finalise Test Readiness Report and submit to Programme for assurance |  | 10d | 2024-09-23 | 2024-10-04 | 1848FF |  |  | 2024-09-23 | 2024-10-04 | 10d | 2024-09-23 | 2024-10-04 | 819d | 0d |  |  | PP | SI Test | SIT | 5.0 | Stuart Scott | Systems Integration Testing (SIT) | -225.67 | Overdue Start | RED |  |  |  |  |
| 1865 | 1.4.3.6.2 | **SI E2E Sandbox Test Readiness Report** |  | 40d | 2024-08-26 | 2024-10-18 |  |  |  | 2024-08-26 | 2024-10-18 | 40d | 2024-08-26 | 2024-10-18 | 819d |  |  |  | N/A | N/A | SIT | 5.0 | N/A | Systems Integration Testing (SIT) |  |  |  |  |  |  |  |
| 1866 | 1.4.3.6.2.1 | Assure Central Parties' E2E Sandbox Test Readiness Reports |  | 35d | 2024-08-26 | 2024-10-11 | 1863SS, 1864FF+5d |  |  | 2024-08-26 | 2024-10-11 | 35d | 2024-08-26 | 2024-10-11 | 819d | 0d |  |  | SI Test | PP | SIT | 5.0 | Stuart Scott | Systems Integration Testing (SIT) | -253.67 | Overdue Start | RED |  |  |  |  |
| 1867 | 1.4.3.6.2.2 | Develop Overarching E2E Sandbox Test Readiness Report |  | 20d | 2024-09-16 | 2024-10-11 | 1866FF |  |  | 2024-09-16 | 2024-10-11 | 20d | 2024-09-16 | 2024-10-11 | 819d | 0d |  |  | SI Test |  | SIT | 5.0 | Stuart Scott | Systems Integration Testing (SIT) | -232.67 | Overdue Start | RED |  |  |  |  |
| 1868 | 1.4.3.6.2.3 | Artefact review (via SITAG) and updates |  | 5d | 2024-10-14 | 2024-10-18 | 1867 |  |  | 2024-10-14 | 2024-10-18 | 5d | 2024-10-14 | 2024-10-18 | 819d | 69d |  |  | SI Test | PP,IPA | SIT | 5.0 | Stuart Scott | Systems Integration Testing (SIT) | -204.67 | Overdue Start | RED |  |  |  |  |
| 1869 | 1.4.3.6.3 | UIT E2E Sandbox Preparation Complete | milestone | 0d | 2025-01-31 | 2025-01-31 | 1868FS+5d |  |  | 2025-01-31 | 2025-01-31 | 0d | 2024-10-25 | 2024-10-25 | 750d | 116d | start no earlier than 2025-01-31 |  | SI Test | PP | SIT | 6.21 | Stuart Scott | Systems Integration Testing (SIT) | -95.67 | Overdue Start | RED | MHHS-ART154 MHHS-ART147 | T3-QU-0125 | QAG | T3 |
| 1870 | 1.4.4 | **Sandbox Testing Execution (UIT)** |  | 260d | 2025-09-01 | 2026-08-28 |  |  |  | 2025-02-07 | 2026-04-24 | 316d | 2024-11-04 | 2026-01-19 | 344d |  |  | -0 | N/A | N/A | SIT | 6.15 | N/A | Systems Integration Testing (SIT) |  |  |  |  |  | QAG |  |
| 1871 | 1.4.4.1 | Sandbox Testing Start (UIT) | milestone | 0d | 2025-09-01 | 2025-09-01 | 1763, 2445FS+5d, 1869 |  |  | 2025-09-01 | 2025-09-01 | 0d | 2024-11-04 | 2024-11-04 | 603d | 0d | start no earlier than 2025-02-10 |  | SI Test | PP | SIT | 6.21 | Stuart Scott | Systems Integration Testing (SIT) | 117.71 | Green | GREEN | MHHS-ART018 MHHS-ART154 MHHS-ART147 | T3-QU-0126 | QAG | T3 |
| 1872 | 1.4.4.2 | Sandbox Testing Execution (UIT) |  | 260d | 2025-09-01 | 2026-08-28 | 1871SS-1d |  |  | 2025-09-01 | 2026-08-28 | 316d | 2024-11-04 | 2026-01-19 | 344d | 0d | start no earlier than 2024-11-04 |  | PP | SI Test | SIT | 6.15 | Stuart Scott | Systems Integration Testing (SIT) | 117.33 | Green | GREEN |  |  | QAG |  |
| 1873 | 1.4.4.3 | Sandbox Testing End (UIT) | milestone | 0d | 2026-08-28 | 2026-08-28 | 1872 |  |  | 2026-08-28 | 2026-08-28 | 0d |  |  | 344d |  |  |  | SI Test |  | SIT | 6.21 | Stuart Scott / Heath Thomas |  | 478.71 | Green | GREEN |  | T3-QU-0127 | QAG |  |

Notes:
- 1849: 06/05/25 - Dates will be updated once E2E Test Apporach and Plan is agreed with QWG/QAG.
- 1850: 06/05/25 - Dates will be updated once E2E Test Apporach and Plan is agreed with QWG/QAG.
- 1851: 06/05/25 - Dates will be updated once E2E Test Apporach and Plan is agreed with QWG/QAG.
- 1852: 06/05/25 - Dates will be updated once E2E Test Apporach and Plan is agreed with QWG/QAG.
- 1853: 06/05/25 - Dates will be updated once E2E Test Apporach and Plan is agreed with QWG/QAG.
- 1854: 06/05/25 - Dates will be updated once E2E Test Apporach and Plan is agreed with QWG/QAG.
- 1855: 06/05/25 - Dates will be updated once E2E Test Apporach and Plan is agreed with QWG/QAG.
- 1856: 06/05/25 - Dates will be updated once E2E Test Apporach and Plan is agreed with QWG/QAG.
- 1857: 06/05/25 - Dates will be updated once E2E Test Apporach and Plan is agreed with QWG/QAG.
- 1858: 06/05/25 - Dates will be updated once E2E Test Apporach and Plan is agreed with QWG/QAG.
- 1859: 06/05/25 - Dates will be updated once E2E Test Apporach and Plan is agreed with QWG/QAG.
- 1860: 06/05/25 - Dates will be updated once E2E Test Apporach and Plan is agreed with QWG/QAG.
- 1861: 06/05/25 - Dates will be updated once E2E Test Apporach and Plan is agreed with QWG/QAG.
- 1862: 06/05/25 - Dates will be updated once E2E Test Apporach and Plan is agreed with QWG/QAG.
- 1863: 06/05/25 - Dates will be updated once E2E Test Apporach and Plan is agreed with QWG/QAG.
- 1864: 06/05/25 - Dates will be updated once E2E Test Apporach and Plan is agreed with QWG/QAG.
- 1865: 06/05/25 - Dates will be updated once E2E Test Apporach and Plan is agreed with QWG/QAG.
- 1866: 06/05/25 - Dates will be updated once E2E Test Apporach and Plan is agreed with QWG/QAG.
- 1867: 06/05/25 - Dates will be updated once E2E Test Apporach and Plan is agreed with QWG/QAG.
- 1868: 06/05/25 - Dates will be updated once E2E Test Apporach and Plan is agreed with QWG/QAG.
- 1869: 06/05/25 - Dates will be updated once E2E Test Apporach and Plan is agreed with QWG/QAG.

| ID | WBS | Task | Type | Duration | Start | Finish | Predecessors | Complete | Remaining | Baseline start | Baseline finish | Baseline duration | Baseline 1 start | Baseline 1 finish | Total slack | Free slack | Constraint | Baseline cost | Responsible | Involved | Text9 | Update Version | MHHS Resource Name | MHHS Programme Phase | Text29 | Artefact ID | Task Status | Sched Status | RAG | Milestone ID | Tier |
| --- | --- | --- | --- | --- | --- | --- | --- | --- | --- | --- | --- | --- | --- | --- | --- | --- | --- | --- | --- | --- | --- | --- | --- | --- | --- | --- | --- | --- | --- | --- | --- |
| 1874 | 1.4.5 | **SIT PPs Early Sandbox Testing Execution (SIT-A)** |  | 70d | 2025-07-21 | 2025-10-24 |  |  |  | 2025-02-07 | 2026-04-24 | 316d | 2024-11-04 | 2026-01-19 | 564d |  |  | -0 | N/A | N/A | SIT | 6.15 | N/A | Systems Integration Testing (SIT) | QAG |  |  |  |  |  |  |
| 1875 | 1.4.5.1 | SIT PPs E2E Sandbox Testing Start | milestone | 0d | 2025-07-21 | 2025-07-21 | 1869FS+5d, 1605 |  |  | 2025-08-11 | 2025-08-11 | 0d | 2024-11-04 | 2024-11-04 | 634d | 1d | start no earlier than 2025-07-21 |  | SI Test | PP | SIT | 6.23 | Stuart Scott | Systems Integration Testing (SIT) | QAG | MHHS-ART018 MHHS-ART154 MHHS-ART147 | 75.33 | Green | GREEN | T3-QU-0128 | T3 |
| 1876 | 1.4.5.2 | SIT PPs E2E Sandbox Testing Execution |  | 70d | 2025-07-21 | 2025-10-24 | 1875SS-1d |  |  | 2025-08-11 | 2025-10-24 | 316d | 2024-11-04 | 2026-01-19 | 564d | 0d | start no earlier than 2025-07-21 |  | PP | SI Test | SIT | 6.23 | Stuart Scott | Systems Integration Testing (SIT) | QAG |  | 75.33 | Green | GREEN |  |  |
| 1877 | 1.4.5.3 | SIT PPs E2E Sandbox Testing End | milestone | 0d | 2025-10-24 | 2025-10-24 | 1876 |  |  | 2025-10-24 | 2025-10-24 | 0d |  |  | 564d |  |  |  | SI Test |  | SIT | 6.22 | Stuart Scott |  | QAG |  | 170.71 | Green | GREEN | T3-QU-0129 |  |
| 1878 | 1.4.6 | **System Integration Testing - Tier 1 Milestones** |  | 411d? | 2024-05-28 A | 2025-12-24 |  | 99% | 0d? | 2025-02-28 | 2025-12-24 | 0d |  |  | 521d |  |  |  |  |  | SIT | 6.15 |  |  | SITAG |  | -685.67 | Overdue Start |  |  |  |
| 1879 | 1.4.6.1 | **M10 Checkpoint 1** |  | 63d? | 2025-01-06 A | 2025-04-02 A |  | 100% |  | 2025-02-28 | 2025-02-28 | 0d |  |  |  |  |  |  | CPT |  | SIT | 6.1 | Lewis Hall |  | PSG |  | -827.67 | Overdue Start |  |  | T3 |
| 1880 | 1.4.6.1.1 | **M10 Readiness** |  | 50d? | 2025-01-06 A | 2025-03-14 A |  | 100% |  | 2025-01-06 | 2025-03-14 | 0d |  |  |  |  |  |  | CPT |  | SIT | 6.18 | Lewis Hall |  | PSG |  | -833.67 | Overdue Start |  |  |  |
| 1881 | 1.4.6.1.1.1 | Define guiding principles and approach |  | 15d? | 2025-01-06 A | 2025-01-24 A |  | 100% |  | 2025-01-06 | 2025-01-24 | 0d |  |  |  |  | start no earlier than 2025-01-06 |  | CPT |  | PSG | 6.18 | Lewis Hall |  | PSG |  |  | Complete | COMPLETE |  |  |
| 1882 | 1.4.6.1.1.2 | Engage IPA |  | 10d | 2025-01-13 A | 2025-01-24 A |  | 100% |  | 2025-01-13 | 2025-01-24 | 0d |  |  |  |  | start no earlier than 2025-01-13 |  | CPT |  | PSG | 6.18 | Lewis Hall |  | PSG |  |  | Complete | COMPLETE |  |  |
| 1883 | 1.4.6.1.1.3 | Mobilise Get to Go-Live Group |  | 10d | 2025-01-27 A | 2025-02-07 A | 1881, 1882 | 100% |  | 2025-01-27 | 2025-02-07 | 0d |  |  |  |  |  |  | CPT |  | PSG | 6.18 | Lewis Hall |  | PSG |  |  | Complete | COMPLETE |  |  |
| 1884 | 1.4.6.1.1.4 | Progress against the M10 Readiness Criteria |  | 25d? | 2025-02-10 A | 2025-03-14 A | 1883 | 100% |  | 2025-02-10 | 2025-03-14 | 0d |  |  |  |  |  |  | CPT |  | PSG | 6.18 | Lewis Hall |  | PSG |  |  | Complete | COMPLETE |  |  |
| 1885 | 1.4.6.1.2 | **Downstream milestone feasibility assessment** |  | 50d? | 2025-01-06 A | 2025-03-14 A |  | 100% |  | 2025-01-06 | 2025-03-14 | 0d |  |  |  |  |  |  | CPT |  | PSG | 6.18 | Lewis Hall |  | PSG |  | -833.67 |  |  |  |  |
| 1886 | 1.4.6.1.2.1 | Define guiding principles and approach to addressing points 1 - 3 |  | 20d? | 2025-01-06 A | 2025-01-31 A |  | 100% |  | 2025-01-06 | 2025-01-31 | 0d |  |  |  |  | start no earlier than 2025-01-06 |  | CPT |  | PSG | 6.18 | Lewis Hall |  | PSG |  |  | Complete | COMPLETE |  |  |
| 1887 | 1.4.6.1.2.2 | Assess capacity within migration envelopes (Point 1 - Bringing M15 forwards) |  | 20d | 2025-01-20 A | 2025-02-14 A | 1886FF | 100% |  | 2025-01-20 | 2025-02-14 | 0d |  |  |  |  | start no earlier than 2025-01-20 |  | CPT |  | PSG | 6.18 | Lewis Hall |  | PSG |  |  | Complete | COMPLETE |  |  |
| 1888 | 1.4.6.1.2.3 | Review M16 process (Point 3 - Bringing M16 forwards) |  | 25d? | 2025-01-20 A | 2025-02-21 A | 1886FF | 100% |  | 2025-01-20 | 2025-02-21 | 0d |  |  |  |  | start no earlier than 2025-01-20 |  | CPT |  | PSG | 6.18 | Lewis Hall |  | PSG |  |  | Complete | COMPLETE |  |  |
| 1889 | 1.4.6.1.2.4 | Develop M16 process review findings |  | 10d | 2025-02-24 A | 2025-03-07 A | 1888 | 100% |  | 2025-02-24 | 2025-03-07 | 0d |  |  |  |  |  |  | CPT |  | PSG | 6.18 | Lewis Hall |  | PSG |  |  | Complete | COMPLETE |  |  |
| 1890 | 1.4.6.1.2.5 | Agree M16 process review findings with Code Bodies |  | 5d | 2025-03-10 A | 2025-03-14 A | 1889 | 100% |  | 2025-03-10 | 2025-03-14 | 0d |  |  |  |  |  |  | CPT |  | PSG | 6.18 | Lewis Hall |  | PSG |  |  | Complete | COMPLETE |  |  |
| 1891 | 1.4.6.1.2.6 | Agree M16 process review findings with PAB |  | 5d | 2025-03-10 A | 2025-03-14 A | 1889 | 100% |  | 2025-03-10 | 2025-03-14 | 0d |  |  |  |  |  |  | CPT |  | PSG | 6.18 | Lewis Hall |  | PSG |  |  | Complete | COMPLETE |  |  |
| 1892 | 1.4.6.1.2.7 | Run PPIR with impacted parties (Point 2 - Bringing M14 forwards) |  | 10d | 2025-03-03 A | 2025-03-14 A | 1887FS+10d | 100% |  | 2025-03-03 | 2025-03-14 | 0d |  |  |  |  |  |  | CPT |  | PSG | 6.18 | Lewis Hall |  | PSG |  |  | Complete | COMPLETE |  |  |
| 1893 | 1.4.6.1.3 | **Checkpoint governance** |  | 21d | 2025-03-05 A | 2025-04-02 A |  | 100% |  | 2022-10-31 | 2025-04-02 | 0d |  |  |  |  |  |  | CPT |  | PSG | 6.18 | Lewis Hall |  | PSG |  | -833.67 |  |  |  |  |
| 1894 | 1.4.6.1.3.1 | PSG Updated on progress | milestone | 0d | 2025-03-05 A | 2025-03-05 A | 1884SS | 100% |  | 2025-03-05 | 2025-03-05 | 0d |  |  |  |  | start no earlier than 2025-03-05 |  | CPT |  | PSG | 6.18 | Lewis Hall |  | PSG |  |  | Complete | COMPLETE |  |  |
| 1895 | 1.4.6.1.3.2 | Review final M10 Readiness outputs with IPA |  | 5d | 2025-03-17 A | 2025-03-21 A | 1890, 1891, 1892, 1884 | 100% |  | 2025-03-17 | 2025-03-21 | 0d |  |  |  |  |  |  | CPT |  | PSG | 6.18 | Lewis Hall |  | PSG |  |  | Complete | COMPLETE |  |  |
| 1896 | 1.4.6.1.3.3 | Review final M10 Readiness outputs with Ofgem |  | 8d | 2025-03-17 A | 2025-03-26 A | 1890, 1891, 1892, 1884, 1895SS | 100% |  | 2025-03-17 | 2025-03-26 | 0d |  |  |  |  |  |  | CPT |  | PSG | 6.18 | Lewis Hall |  | PSG |  |  | Complete | COMPLETE |  |  |
| 1897 | 1.4.6.1.3.4 | QAG paper day | milestone | 0d | 2025-03-13 A | 2025-03-13 A | 1884SS | 100% |  | 2025-03-13 | 2025-03-13 | 0d |  |  |  |  | start no earlier than 2025-03-13 |  | CPT |  | PSG | 6.18 | Lewis Hall |  | PSG |  |  | Complete | COMPLETE |  |  |
| 1898 | 1.4.6.1.3.5 | QAG recommend M10 Checkpoint | milestone | 0d | 2025-03-20 A | 2025-03-20 A | 1897FS+6d | 100% |  | 2025-03-20 | 2025-03-20 | 0d |  |  |  |  |  |  | CPT |  | PSG | 6.18 | Lewis Hall |  | PSG |  |  | Complete | COMPLETE |  |  |
| 1899 | 1.4.6.1.3.6 | MCAG paper day | milestone | 0d | 2025-03-24 A | 2025-03-24 A | 1884FS+6d | 100% |  | 2025-03-24 | 2025-03-24 | 0d |  |  |  |  |  |  | CPT |  | PSG | 6.18 | Lewis Hall |  | PSG |  |  | Complete | COMPLETE |  |  |
| 1900 | 1.4.6.1.3.7 | MCAG recommend M10 Checkpoint | milestone | 0d | 2025-04-01 A | 2025-04-01 A | 1899FS+6d | 100% |  | 2025-04-01 | 2025-04-01 | 0d |  |  |  |  |  |  | CPT |  | PSG | 6.18 | Lewis Hall |  | PSG |  |  | Complete | COMPLETE |  |  |
| 1901 | 1.4.6.1.3.8 | PSG paper day | milestone | 0d | 2025-03-26 A | 2025-03-26 A | 1896 | 100% |  | 2025-03-26 | 2025-03-26 | 0d |  |  |  |  |  |  | CPT |  | PSG | 6.18 | Lewis Hall |  | PSG |  |  | Complete | COMPLETE |  |  |
| 1902 | 1.4.6.1.3.9 | PSG M10 Checkpoint Meeting | milestone | 0d | 2025-04-02 A | 2025-04-02 A | 1901FS+5d, 1900, 1898, 1895, 1896 | 100% |  | 2025-04-02 | 2025-04-02 | 0d |  |  |  |  |  |  | CPT |  | PSG | 6.18 | Lewis Hall |  | PSG |  |  | Complete | COMPLETE |  |  |
| 1903 | 1.4.6.1.4 | M10 Checkpoint 1 complete | milestone | 0d | 2025-04-02 A | 2025-04-02 A | 1938FS-126d, 1902 | 100% |  | 2025-04-02 | 2025-04-02 | 0d |  |  |  |  |  |  | CPT |  | PSG | 6.18 | Lewis Hall |  | PSG |  |  | Complete | COMPLETE | T3-MI-0040 | T3 |
| 1904 | 1.4.6.2 | M10 Checkpoint 2 Complete | milestone | 0d | 2025-07-02 | 2025-07-02 |  |  |  | 2025-07-02 | 2025-07-02 | 0d |  |  | 646d |  | finish no earlier than 2025-07-02 |  | CPT |  | PSG | 6.22 | Lewis Hall |  | PSG |  | 56.71 | Green | GREEN | T3-MI-0046 |  |

Notes:
- 1875: 06/05/25 - Dates will be updated once E2E Test Apporach and Plan is agreed with QWG/QAG.
- 1876: 06/05/25 - Dates will be updated once E2E Test Apporach and Plan is agreed with QWG/QAG.
- 1904: 07/05/25 - The Programme will include the preparatory activities over the coming weeks.

| ID | WBS | Task | Type | Duration | Start | Finish | Predecessors | Complete | Remaining | Baseline start | Baseline finish | Baseline duration | Baseline 1 start | Baseline 1 finish | Total slack | Free slack | Constraint | Responsible | Text9 | Task Status | Update Version | Sched Status | MHHS Resource Name | Text29 | RAG | Involved | Future RAG | MHHS Programme Phase | Milestone ID | Tier |
| --- | --- | --- | --- | --- | --- | --- | --- | --- | --- | --- | --- | --- | --- | --- | --- | --- | --- | --- | --- | --- | --- | --- | --- | --- | --- | --- | --- | --- | --- | --- |
| 1905 | 1.4.6.3 | **M10 Acceptance Criteria** |  | 358d | 2024-05-28 A | 2025-10-10 |  |  | 358d | 2024-05-28 | 2025-10-10 | 0d |  |  | 574d |  |  | CPT | PSG | -889.67 | 6.22 | Overdue Start | Lewis Hall | PSG |  |  |  |  |  |  |
| 1906 | 1.4.6.3.1 | End of SIT MVC testing | milestone | 0d | 2025-08-22 | 2025-08-22 | 1763 |  |  | 2025-08-22 | 2025-08-22 | 0d |  |  | 609d |  | finish no earlier than 2025-08-22 | CPT | PSG | 107.71 | 6.22 | Green | Lewis Hall | PSG | GREEN |  |  |  |  |  |
| 1907 | 1.4.6.3.2 | IPA M10 Assurance Report developed and agreed | milestone | 0d | 2025-09-19 | 2025-09-19 |  |  |  | 2025-09-19 | 2025-09-19 | 0d |  |  | 589d |  | finish no earlier than 2025-09-19 | CPT | PSG | 135.71 | 6.22 | Green | Lewis Hall | PSG | GREEN |  |  |  |  |  |
| 1908 | 1.4.6.3.3 | Non-SIT LDSO Qualification Testing complete | milestone | 0d | 2025-05-16 | 2025-05-16 | 2057 |  |  | 2025-05-16 | 2025-05-16 | 0d |  |  | 679d |  | finish no earlier than 2025-05-16 | CPT | PSG | 9.71 | 6.22 | Green | Lewis Hall | PSG | GREEN |  |  |  |  |  |
| 1909 | 1.4.6.3.4 | A minimum of 1 supplier & required contracted agents are qualified and ready to operate under new MHHS arrangements | milestone | 0d | 2025-09-12 | 2025-09-12 |  |  |  | 2025-09-12 | 2025-09-12 | 0d |  |  | 594d |  | finish no earlier than 2025-09-12 | CPT | PSG | 128.71 | 6.22 | Green | Lewis Hall | PSG | GREEN |  |  |  |  |  |
| 1910 | 1.4.6.3.5 | All LDSOs qualified | milestone | 0d | 2025-09-10 | 2025-09-10 |  |  |  | 2025-09-10 | 2025-09-10 | 0d |  |  | 596d |  | finish no earlier than 2025-09-10 | CPT | PSG | 126.71 | 6.22 | Green | Lewis Hall | PSG | GREEN |  |  |  |  |  |
| 1911 | 1.4.6.3.6 | All pre-migration data cleanse activities complete | milestone | 0d | 2025-08-13 | 2025-08-13 |  |  |  | 2025-08-13 | 2025-08-13 | 0d |  |  | 616d |  | finish no earlier than 2025-08-13 | CPT | PSG | 98.71 | 6.22 | Green | Lewis Hall | PSG | GREEN |  |  |  |  |  |
| 1912 | 1.4.6.3.7 | All data migration activities set out in the cutover plan complete | milestone | 0d | 2025-09-24 | 2025-09-24 |  |  |  | 2025-09-24 | 2025-09-24 | 0d |  |  | 586d |  | finish no earlier than 2025-09-24 | CPT | PSG | 140.71 | 6.22 | Green | Lewis Hall | PSG | GREEN |  |  |  |  |  |
| 1913 | 1.4.6.3.8 | ISD fully populated by Elexon | milestone | 0d | 2025-09-22 | 2025-09-22 |  |  |  | 2025-09-22 | 2025-09-22 | 0d |  |  | 588d |  | finish no earlier than 2025-09-22 | CPT | PSG | 138.71 | 6.22 | Green | Lewis Hall | PSG | GREEN |  |  |  |  |  |
| 1914 | 1.4.6.3.9 | Significant Code Review Powers (SCR) enacted by Ofgem (M7) and updates to regulatory code ready to be implemented at M8 | milestone | 0d | 2024-12-11 A | 2024-12-11 A | 2695 | 100% |  | 2024-12-11 | 2024-12-11 | 0d |  |  |  |  | finish no earlier than 2024-12-11 | CPT | PSG |  | 6.22 | Complete | Lewis Hall | PSG | COMPLETE |  |  |  |  |  |
| 1915 | 1.4.6.3.10 | Migration Schedule approved | milestone | 0d | 2025-08-19 | 2025-08-19 |  |  |  | 2025-08-19 | 2025-08-19 | 0d |  |  | 612d |  | finish no earlier than 2025-08-19 | CPT | PSG | 104.71 | 6.22 | Green | Lewis Hall | PSG | GREEN |  |  |  |  |  |
| 1916 | 1.4.6.3.11 | Migration Framework approved | milestone | 0d | 2025-04-30 A | 2025-04-30 A |  | 100% |  | 2025-04-30 | 2025-04-30 | 0d |  |  |  |  | finish no earlier than 2025-04-30 | CPT | PSG |  | 6.22 | Complete | Lewis Hall | PSG | COMPLETE |  |  |  |  |  |
| 1917 | 1.4.6.3.12 | Migration Control Centre (MCC) delegation of authority approved | milestone | 0d | 2025-04-30 A | 2025-04-30 A |  | 100% |  | 2025-04-30 | 2025-04-30 | 0d |  |  |  |  | finish no earlier than 2025-04-30 | CPT | PSG |  | 6.22 | Complete | Lewis Hall | PSG | COMPLETE |  |  |  |  |  |
| 1918 | 1.4.6.3.13 | Migration incentives implemented | milestone | 0d | 2025-04-30 A | 2025-04-30 A |  | 100% |  | 2025-04-30 | 2025-04-30 | 0d |  |  |  |  | finish no earlier than 2025-04-30 | CPT | PSG |  | 6.22 | Complete | Lewis Hall | PSG | COMPLETE |  |  |  |  |  |
| 1919 | 1.4.6.3.14 | MCC tested and ready to operate | milestone | 0d | 2025-09-19 | 2025-09-19 |  |  |  | 2025-09-19 | 2025-09-19 | 0d |  |  | 589d |  | finish no earlier than 2025-09-19 | CPT | PSG | 135.71 | 6.22 | Green | Lewis Hall | PSG | GREEN |  |  |  |  |  |
| 1920 | 1.4.6.3.15 | Service Delivery Operating Model in place | milestone | 0d | 2025-09-19 | 2025-09-19 |  |  |  | 2025-09-19 | 2025-09-19 | 0d |  |  | 589d |  | finish no earlier than 2025-09-19 | CPT | PSG | 135.71 | 6.22 | Green | Lewis Hall | PSG | GREEN |  |  |  |  |  |
| 1921 | 1.4.6.3.16 | Service Delivery Operating Model in place (Self-Certification) | milestone | 0d | 2025-07-03 | 2025-07-03 |  |  |  | 2025-07-03 | 2025-07-03 | 0d |  |  | 645d |  | finish no earlier than 2025-07-03 | CPT | PSG | 57.71 | 6.22 | Green | Lewis Hall | PSG | GREEN |  |  |  |  |  |
| 1922 | 1.4.6.3.17 | Early Life Support Model defined | milestone | 0d | 2025-04-29 A | 2025-04-29 A | 3115 | 100% |  | 2025-04-29 | 2025-04-29 | 0d |  |  |  |  | finish no earlier than 2025-03-31 | CPT | PSG |  | 6.22 | Complete | Lewis Hall | PSG | COMPLETE |  |  |  |  |  |
| 1923 | 1.4.6.3.18 | Early Life Support Model arrangements in place and operational | milestone | 0d | 2025-09-12 | 2025-09-12 |  |  |  | 2025-09-12 | 2025-09-12 | 0d |  |  | 594d |  | finish no earlier than 2025-09-12 | CPT | PSG | 128.71 | 6.22 | Green | Lewis Hall | PSG | GREEN |  |  |  |  |  |
| 1924 | 1.4.6.3.19 | Early Life Support Model arrangements in place and operational (Self-Certification) | milestone | 0d | 2025-09-12 | 2025-09-12 |  |  |  | 2025-09-12 | 2025-09-12 | 0d |  |  | 594d |  | finish no earlier than 2025-09-12 | CPT | PSG | 128.71 | 6.22 | Green | Lewis Hall | PSG | GREEN |  |  |  |  |  |
| 1925 | 1.4.6.3.20 | M10/M11 Cutover Plan in place | milestone | 0d | 2024-05-28 A | 2024-05-28 A |  | 100% |  | 2024-05-28 | 2024-05-28 | 0d |  |  |  |  | finish no earlier than 2024-05-28 | CPT | PSG |  | 6.22 | Complete | Lewis Hall | PSG | COMPLETE |  |  |  |  |  |
| 1926 | 1.4.6.3.21 | Central Programme Party Cutover Plans in place | milestone | 0d | 2025-07-15 | 2025-07-15 |  |  |  | 2025-07-15 | 2025-07-15 | 0d |  |  | 637d |  | finish no earlier than 2025-07-15 | CPT | PSG | 69.71 | 6.22 | Green | Lewis Hall | PSG | GREEN |  |  |  |  |  |
| 1927 | 1.4.6.3.22 | Production environment in place for LDSOs and Central Parties | milestone | 0d | 2025-09-22 | 2025-09-22 |  |  |  | 2025-09-22 | 2025-09-22 | 0d |  |  | 588d |  | finish no earlier than 2025-09-22 | CPT | PSG | 138.71 | 6.22 | Green | Lewis Hall | PSG | GREEN |  |  |  |  |  |
| 1928 | 1.4.6.3.23 | Service activation complete to DIP Production environment for Central Parties and LDSOs | milestone | 0d | 2025-10-10 | 2025-10-10 |  |  |  | 2025-10-10 | 2025-10-10 | 0d |  |  | 574d |  | finish no earlier than 2025-10-10 | CPT | PSG | 156.71 | 6.22 | Green | Lewis Hall | PSG | GREEN |  |  |  |  |  |
| 1929 | 1.4.6.3.24 | Cutover Plan executed | milestone | 0d | 2025-09-23 | 2025-09-23 |  |  |  | 2025-09-23 | 2025-09-23 | 0d |  |  | 587d |  | finish no earlier than 2025-09-23 | CPT | PSG | 139.71 | 6.22 | Green | Lewis Hall | PSG | GREEN |  |  |  |  |  |
| 1930 | 1.4.6.3.25 | M10 Risk Assessment undertaken | milestone | 0d | 2025-09-03 | 2025-09-03 |  |  |  | 2025-09-03 | 2025-09-03 | 0d |  |  | 601d |  | finish no earlier than 2025-09-03 | CPT | PSG | 119.71 | 6.22 | Green | Lewis Hall | PSG | GREEN |  |  |  |  |  |
| 1931 | 1.4.6.3.26 | Roles and responsibilities post-M10 agreed and accepted | milestone | 0d | 2025-09-19 | 2025-09-19 |  |  |  | 2025-09-19 | 2025-09-19 | 0d |  |  | 589d |  | finish no earlier than 2025-09-19 | CPT | PSG | 135.71 | 6.22 | Green | Lewis Hall | PSG | GREEN |  |  |  |  |  |
| 1932 | 1.4.6.3.27 | M10 Work off plan agreed (if required) | milestone | 0d | 2025-09-19 | 2025-09-19 |  |  |  | 2025-09-19 | 2025-09-19 | 0d |  |  | 589d |  | finish no earlier than 2025-09-19 | CPT | PSG | 135.71 | 6.22 | Green | Lewis Hall | PSG | GREEN |  |  |  |  |  |
| 1933 | 1.4.6.3.28 | Qualification Operating Model in place and operational for all post-M10 activities | milestone | 0d | 2025-09-19 | 2025-09-19 |  |  |  | 2025-09-19 | 2025-09-19 | 0d |  |  | 589d |  | finish no earlier than 2025-09-19 | CPT | PSG | 135.71 | 6.22 | Green | Lewis Hall | PSG | GREEN |  |  |  |  |  |
| 1934 | 1.4.6.3.29 | Programme Governance updated to reflect required changes to support Programme delivery post-M10. | milestone | 0d | 2025-07-01 | 2025-07-01 |  |  |  | 2025-07-01 | 2025-07-01 | 0d |  |  | 647d |  | finish no earlier than 2025-07-01 | CPT | PSG | 55.71 | 6.22 | Green | Lewis Hall | PSG | GREEN |  |  |  |  |  |
| 1935 | 1.4.6.3.30 | All Suppliers and Agents have made the necessary changes to support losing an MPAN via the Forward Migration Process and gaining an MPAN via the Reverse Migration Process. | milestone | 0d | 2025-09-19 | 2025-09-19 |  |  |  | 2025-09-19 | 2025-09-19 | 0d |  |  | 589d |  | finish no earlier than 2025-09-19 | CPT | PSG | 135.71 | 6.22 | Green | Lewis Hall | PSG | GREEN |  |  |  |  |  |
| 1936 | 1.4.6.3.31 | Performance Assurance measures are understood and in place to maintain BAU performance during the Migration period. | milestone | 0d | 2025-09-12 | 2025-09-12 |  |  |  | 2025-09-12 | 2025-09-12 | 0d |  |  | 594d |  | finish no earlier than 2025-09-12 | CPT | PSG | 128.71 | 6.22 | Green | Lewis Hall | PSG | GREEN |  |  |  |  |  |
| 1937 | 1.4.6.3.32 | Programme monitoring, assurance and escalation process for beyond M10 is in place and operational | milestone | 0d | 2025-09-12 | 2025-09-12 |  |  |  | 2025-09-12 | 2025-09-12 | 0d |  |  | 594d |  | finish no earlier than 2025-09-12 | CPT | PSG | 128.71 | 6.22 | Green | Lewis Hall | PSG | GREEN |  |  |  |  |  |
| 1938 | 1.4.6.4 | Central systems ready for migrating MPANs (M10) | milestone | 0d | 2025-09-24 | 2025-09-24 | 1763FS+20d, 3288, 2970FS+2d, 2967, 2985, 2946, 2953 |  |  | 2025-09-24 | 2025-09-24 | 0d | 2025-03-07 | 2025-03-07 | 5d | 0d |  | CPT | PSG | 140.71 | 6.1 | Green | CPT | PSG | GREEN | CPT | Central systems ready for migrating MPANs | Migration | T1-MI-1000 | T1 |
| 1939 | 1.4.6.5 | Central systems ready for migrating MPANs (M10*) - Late Exit | milestone | 0d | 2025-12-24 | 2025-12-24 | 1938FS+65d |  |  | 2025-12-24 | 2025-12-24 | 0d | 2025-06-06 | 2025-06-06 | 521d |  |  | CPT | PSG | 231.71 | 6.1 | Green | CPT | PSG | GREEN | CPT | Central systems ready for migrating MPANs | Migration | T2-MI-1500 | T1 |

| ID | WBS | Task | Type | Duration | Start | Finish | Predecessors | Complete | Remaining | Baseline start | Baseline finish | Baseline duration | Baseline 1 start | Baseline 1 finish | Total slack | Constraint | Baseline cost | Responsible | Involved | Text9 | Update Version | MHHS Resource Name | MHHS Programme Phase | Sched Status | RAG | Text29 | Task Status | Milestone ID | Tier |
| --- | --- | --- | --- | --- | --- | --- | --- | --- | --- | --- | --- | --- | --- | --- | --- | --- | --- | --- | --- | --- | --- | --- | --- | --- | --- | --- | --- | --- | --- |
| 1940 | 1.4.7 | **External Programme Dependency Management** |  | 174d | 2022-10-31 A | 2023-06-30 A |  | 100% |  | 2022-10-31 | 2023-06-30 | 174d | 2022-10-31 | 2023-06-30 |  |  |  | N/A | N/A | SIT | 5.0 | N/A | Systems Integration Testing (SIT) |  |  |  |  |  |  |
| 1941 | 1.4.7.1 | **BSC CP1558** |  | 173d | 2022-10-31 A | 2023-06-29 A |  | 100% |  | 2022-10-31 | 2023-06-29 | 173d | 2022-10-31 | 2023-06-29 |  |  |  | N/A | N/A | SIT | 5.0 | N/A | Systems Integration Testing (SIT) |  |  |  |  |  |  |
| 1942 | 1.4.7.1.1 | Monitor progress to implementation date |  | 173d | 2022-10-31 A | 2023-06-28 A |  | 100% |  | 2022-10-31 | 2023-06-28 | 173d | 2022-10-31 | 2023-06-28 |  |  |  | CPT | Code Bodies | SIT | 5.0 | Andrew Margan | Systems Integration Testing (SIT) | Complete | COMPLETE |  |  |  |  |
| 1943 | 1.4.7.1.2 | BSC CP1558 Implementation Date | milestone | 0d | 2023-06-29 A | 2023-06-29 A | 1942 | 100% |  | 2023-06-29 | 2023-06-29 | 0d | 2023-06-29 | 2023-06-29 |  | must start on 2023-06-29 |  | Code Bodies |  | SIT | 5.0 | Andrew Margan | Systems Integration Testing (SIT) | Complete | COMPLETE |  |  |  |  |
| 1944 | 1.4.7.2 | **REC CP R0032** |  | 174d | 2022-10-31 A | 2023-06-30 A |  | 100% |  | 2022-10-31 | 2023-06-30 | 174d | 2022-10-31 | 2023-06-30 |  |  |  | N/A | N/A | SIT | 5.0 | N/A | Systems Integration Testing (SIT) |  |  |  |  |  |  |
| 1945 | 1.4.7.2.1 | Monitor progress to implementation date |  | 174d | 2022-10-31 A | 2023-06-29 A |  | 100% |  | 2022-10-31 | 2023-06-29 | 174d | 2022-10-31 | 2023-06-29 |  |  |  | CPT | Code Bodies | SIT | 5.0 | Andrew Margan | Systems Integration Testing (SIT) | Complete | COMPLETE |  |  |  |  |
| 1946 | 1.4.7.2.2 | REC CP R0032 Implementation Date | milestone | 0d | 2023-06-30 A | 2023-06-30 A | 1945 | 100% |  | 2023-06-30 | 2023-06-30 | 0d | 2023-06-30 | 2023-06-30 |  | must start on 2023-06-30 |  | Code Bodies |  | SIT | 5.0 | Andrew Margan | Systems Integration Testing (SIT) | Complete | COMPLETE |  |  |  |  |
| 1947 | 1.4.7.3 | **REC CP R0044** |  | 173d | 2022-10-31 A | 2023-06-29 A |  | 100% |  | 2022-10-31 | 2023-06-29 | 173d | 2022-10-31 | 2023-06-29 |  |  |  | N/A | N/A | SIT | 5.0 | N/A | Systems Integration Testing (SIT) |  |  |  |  |  |  |
| 1948 | 1.4.7.3.1 | Monitor progress to implementation date |  | 173d | 2022-10-31 A | 2023-06-28 A |  | 100% |  | 2022-10-31 | 2023-06-28 | 173d | 2022-10-31 | 2023-06-28 |  |  |  | CPT | Code Bodies | SIT | 5.0 | Andrew Margan | Systems Integration Testing (SIT) | Complete | COMPLETE |  |  |  |  |
| 1949 | 1.4.7.3.2 | REC CP R0044 Implementation Date | milestone | 0d | 2023-06-29 A | 2023-06-29 A | 1948 | 100% |  | 2023-06-29 | 2023-06-29 | 0d | 2023-06-29 | 2023-06-29 |  | must start on 2023-06-29 |  | Code Bodies |  | SIT | 5.0 | Andrew Margan | Systems Integration Testing (SIT) | Complete | COMPLETE |  |  |  |  |
| 1950 | 1.5 | **NON SIT LDSO QUALIFICATION** |  | 469d? | 2023-11-07 A | 2025-08-22 |  | 92% | 37.5d? | 2023-11-07 | 2025-08-22 | 343d | 2024-01-29 | 2024-07-05 | 609d |  | -0 | N/A | N/A | Non-SIT LDSO Qualification |  | N/A | Systems Integration Testing (SIT) |  |  | QAG |  |  |  |
| 1951 | 1.5.1 | **Approach Planning** |  | 208d | 2023-11-07 A | 2024-08-22 A |  | 100% |  | 2023-11-07 | 2024-08-22 | 208d |  |  |  |  | -0 | N/A | N/A | Non-SIT LDSO Qualification | 5.24 | N/A |  |  |  |  | -386.67 |  |  |
| 1952 | 1.5.1.1 | Develop Draft Testing Approach & Plan |  | 61d | 2023-11-07 A | 2024-01-30 A |  | 100% |  | 2023-11-07 | 2024-01-30 | 61d |  |  |  | start no earlier than 2023-11-07 |  | Non-SIT LDSO | Non-SIT LDSO | Non-SIT LDSO Qualification | 5.24 | Ben Wickins |  | Complete | COMPLETE |  |  |  |  |
| 1953 | 1.5.1.2 | Draft Testing Approach & Plan Issued to LDSO for Review |  | 1d | 2024-01-31 A | 2024-01-31 A | 1952 | 100% |  | 2024-01-31 | 2024-01-31 | 1d |  |  |  |  |  | Non-SIT LDSO | Non-SIT LDSO | Non-SIT LDSO Qualification | 5.24 | Ben Wickins |  | Complete | COMPLETE |  |  |  |  |
| 1954 | 1.5.1.3 | LDSO Review Complete |  | 10d | 2024-02-01 A | 2024-02-14 A | 1953 | 100% |  | 2024-02-01 | 2024-02-14 | 10d |  |  |  |  |  | LDSOs | Non-SIT LDSO | Non-SIT LDSO Qualification | 5.24 | Ben Wickins |  | Complete | COMPLETE |  |  |  |  |
| 1955 | 1.5.1.4 | Update Following LDSO Review |  | 14d | 2024-02-15 A | 2024-03-05 A | 1954 | 100% |  | 2024-02-15 | 2024-03-05 | 14d |  |  |  |  |  | Non-SIT LDSO | Non-SIT LDSO, Code Bodies | Non-SIT LDSO Qualification | 5.24 | Ben Wickins |  | Complete | COMPLETE |  |  |  |  |
| 1956 | 1.5.1.5 | QWG Review of Approach & Plan |  | 1d | 2024-03-12 A | 2024-03-12 A | 1955FS+4d | 100% |  | 2024-03-12 | 2024-03-12 | 1d |  |  |  |  |  | Non-SIT LDSO, PP | Non-SIT LDSO, Code Bodies | Non-SIT LDSO Qualification | 5.24 | Ben Wickins |  | Complete | COMPLETE |  |  |  |  |
| 1957 | 1.5.1.6 | QAG Approval for Approach & Plan | milestone | 0d | 2024-03-21 A | 2024-03-21 A | 1956FS+7d | 100% |  | 2024-03-21 | 2024-03-21 | 0d |  |  |  |  |  | Code Bodies | Non-SIT LDSO,Code Bodies | Non-SIT LDSO Qualification | 5.24 | Ben Wickins |  | Complete | COMPLETE |  |  |  |  |
| 1958 | 1.5.1.7 | Confirmation of Participants for Non-SIT LDSO Qualification Testing | milestone | 0d | 2024-03-21 A | 2024-03-21 A | 1957 | 100% |  | 2024-03-21 | 2024-03-21 | 0d | 2024-01-29 | 2024-01-29 |  |  |  | Non-SIT LDSO | SI Test, PP, IPA | Non-SIT LDSO Qualification | 5.24 | Ben Wickins | Systems Integration Testing (SIT) | Complete | COMPLETE | QAG (Non-SIT LDSO) |  | T3-QU-0011 | T3 |
| 1959 | 1.5.1.8 | Update to Annex 1 for internal review (NF, Not Operational) |  | 15d | 2024-03-18 A | 2024-04-05 A | 1103 | 100% |  | 2024-03-18 | 2024-04-05 | 15d |  |  |  |  |  | Non-SIT LDSO | PP, Code Bodies | Non-SIT LDSO Qualification | 5.24 | Ben Wickins |  | Complete | COMPLETE |  |  |  |  |
| 1960 | 1.5.1.9 | Non-Functional, Operational & Migration Approaches Socialised with Code Bodies & LDSO & Feedback Actioned |  | 86d | 2024-04-08 A | 2024-08-05 A | 1959 | 100% |  | 2024-04-08 | 2024-08-05 | 86d |  |  |  |  |  | Non-SIT LDSO | PP, Code Bodies | Non-SIT LDSO Qualification | 5.27 | Ben Wickins |  | Complete | COMPLETE |  |  |  |  |
| 1961 | 1.5.1.10 | QWG Review Operational, Non-Functional & Migration Annexes of Approach & Plan |  | 1d | 2024-08-13 A | 2024-08-13 A | 1960FS+5d | 100% |  | 2024-08-13 | 2024-08-13 | 1d |  |  |  |  |  | Non-SIT LDSO, PP | Non-SIT LDSO, PP, Code Bodies | Non-SIT LDSO Qualification | 5.27 | Ben Wickins |  | Complete | COMPLETE |  |  |  |  |
| 1962 | 1.5.1.11 | Update Following QWG Review |  | 6d | 2024-08-14 A | 2024-08-21 A | 1961 | 100% |  | 2024-08-14 | 2024-08-21 | 6d |  |  |  |  |  | Non-SIT LDSO, PP | Non-SIT LDSO, Code Bodies | Non-SIT LDSO Qualification | 5.27 | Ben Wickins |  | Complete | COMPLETE |  |  |  |  |
| 1963 | 1.5.1.12 | QAG Approval for Operational, Non-Functional & Migration Annexes of Approach & Plan | milestone | 0d | 2024-08-22 A | 2024-08-22 A | 1962FS+1d, 1958, 1106 | 100% |  | 2024-08-22 | 2024-08-22 | 0d |  |  |  |  |  | Code Bodies | Non-SIT LDSO, Code Bodies | Non-SIT LDSO Qualification | 5.29 | Ben Wickins |  | Complete | COMPLETE | QAG (Non-SIT LDSO) |  | T3-QU-0110 | T3 |

Notes:
- 1959: Guidance: 26/3: Linked to the development of SIT non functional plan
- 1963: Guidance: 18/7/24: Date change from 18/7/24 to 22/8/24 approved at QAG on 18/7/24

| ID | WBS | Task | Type | Duration | Start | Finish | Predecessors | Complete | Baseline start | Baseline finish | Baseline duration | Baseline 1 start | Baseline 1 finish | Constraint | Baseline cost | Responsible | Involved | Text9 | Task Status | Update Version | MHHS Resource Name | Sched Status | RAG | Milestone ID | Text29 | Tier | MHHS Programme Phase |
| --- | --- | --- | --- | --- | --- | --- | --- | --- | --- | --- | --- | --- | --- | --- | --- | --- | --- | --- | --- | --- | --- | --- | --- | --- | --- | --- | --- |
| 1964 | 1.5.2 | **Functional Test Cases & Scenarios** |  | 58d | 2024-01-30 A | 2024-04-18 A |  | 100% | 2024-01-30 | 2024-04-18 | 58d |  |  |  | -0 | N/A | N/A | Non-SIT LDSO Qualification | -385.67 | 5.24 | N/A |  |  |  |  |  |  |
| 1965 | 1.5.2.1 | **Functional Test Cases & Scenarios Batch 1** |  | 8d | 2024-01-30 A | 2024-02-08 A |  | 100% | 2024-01-30 | 2024-02-08 | 8d |  |  |  | -0 | N/A | N/A | Non-SIT LDSO Qualification |  | 5.24 | N/A |  |  |  |  |  |  |
| 1966 | 1.5.2.1.1 | Walkthrough Test Cases & Scenarios Batch 1 with Code Bodies |  | 1d | 2024-01-30 A | 2024-01-30 A | 1952SS+60d | 100% | 2024-01-30 | 2024-01-30 | 1d |  |  |  |  | Non-SIT LDSO | Non-SIT LDSO, Code Bodies | Non-SIT LDSO Qualification |  | 5.24 | Ben Wickins | Complete | COMPLETE |  |  |  |  |
| 1967 | 1.5.2.1.2 | Walkthrough Test Cases & Scenarios Batch 1 with LDSO |  | 1d | 2024-02-01 A | 2024-02-01 A | 1966 | 100% | 2024-02-01 | 2024-02-01 | 1d |  |  |  |  | LDSO, Non-SIT LDSO | LDSO, Non-SIT LDSO | Non-SIT LDSO Qualification |  | 5.24 | Ben Wickins | Complete | COMPLETE |  |  |  |  |
| 1968 | 1.5.2.1.3 | Action Feedback on Test Cases & Scenarios Batch 1 |  | 5d | 2024-02-02 A | 2024-02-08 A | 1967 | 100% | 2024-02-02 | 2024-02-08 | 5d |  |  |  |  | Non-SIT LDSO | Non-SIT LDSO, LDSO , Code Bodies | Non-SIT LDSO Qualification |  | 5.24 | Ben Wickins | Complete | COMPLETE |  |  |  |  |
| 1969 | 1.5.2.2 | **Functional Test Cases & Scenarios Batch 2** |  | 14d | 2024-02-20 A | 2024-03-08 A |  | 100% | 2024-02-20 | 2024-03-08 | 14d |  |  |  | -0 | N/A | N/A | Non-SIT LDSO Qualification |  | 5.24 | N/A |  |  |  |  |  |  |
| 1970 | 1.5.2.2.1 | Walkthrough Test Cases & Scenarios Batch 2 with Code Bodies |  | 1d | 2024-02-20 A | 2024-02-20 A | 1952SS+75d | 100% | 2024-02-20 | 2024-02-20 | 1d |  |  |  |  | Non-SIT LDSO | Non-SIT LDSO, Code Bodies | Non-SIT LDSO Qualification |  | 5.24 | Ben Wickins | Complete | COMPLETE |  |  |  |  |
| 1971 | 1.5.2.2.2 | Walkthrough Test Cases & Scenarios Batch 2 with LDSO |  | 1d | 2024-03-01 A | 2024-03-01 A | 1970FS+7d | 100% | 2024-03-01 | 2024-03-01 | 1d |  |  |  |  | LDSO, Non-SIT LDSO | LDSO, Non-SIT LDSO | Non-SIT LDSO Qualification |  | 5.24 | Ben Wickins | Complete | COMPLETE |  |  |  |  |
| 1972 | 1.5.2.2.3 | Action Feedback on Test Cases & Scenarios Batch 2 |  | 5d | 2024-03-04 A | 2024-03-08 A | 1971 | 100% | 2024-03-04 | 2024-03-08 | 5d |  |  |  |  | Non-SIT LDSO | Non-SIT LDSO, LDSO , Code Bodies | Non-SIT LDSO Qualification |  | 5.24 | Ben Wickins | Complete | COMPLETE |  |  |  |  |
| 1973 | 1.5.2.3 | **Functional Test Cases & Scenarios Batch 3** |  | 13d | 2024-03-20 A | 2024-04-05 A |  | 100% | 2024-03-20 | 2024-04-05 | 13d |  |  |  | -0 | N/A | N/A | Non-SIT LDSO Qualification |  | 5.24 | N/A |  |  |  |  |  |  |
| 1974 | 1.5.2.3.1 | Walkthrough Test Cases & Scenarios Batch 3 with Code Bodies |  | 1d | 2024-03-20 A | 2024-03-20 A | 1952SS+96d | 100% | 2024-03-20 | 2024-03-20 | 1d |  |  |  |  | Non-SIT LDSO | Non-SIT LDSO, Code Bodies | Non-SIT LDSO Qualification |  | 5.24 | Ben Wickins | Complete | COMPLETE |  |  |  |  |
| 1975 | 1.5.2.3.2 | Walkthrough Test Cases & Scenarios Batch 3 with LDSO |  | 1d | 2024-03-28 A | 2024-03-28 A | 1974FS+5d | 100% | 2024-03-28 | 2024-03-28 | 1d |  |  |  |  | LDSO, Non-SIT LDSO | LDSO, Non-SIT LDSO | Non-SIT LDSO Qualification |  | 5.24 | Ben Wickins | Complete | COMPLETE |  |  |  |  |
| 1976 | 1.5.2.3.3 | Action Feedback on Test Cases & Scenarios Batch 3 |  | 6d | 2024-03-29 A | 2024-04-05 A | 1975 | 100% | 2024-03-29 | 2024-04-05 | 6d |  |  |  |  | Non-SIT LDSO | Non-SIT LDSO, LDSO , Code Bodies | Non-SIT LDSO Qualification |  | 5.24 | Ben Wickins | Complete | COMPLETE |  |  |  |  |
| 1977 | 1.5.2.4 | Test Cases & Scenarios Batch 1-3 Discussion at QWG |  | 1d | 2024-04-09 A | 2024-04-09 A | 1968, 1972, 1976FS+1d | 100% | 2024-04-09 | 2024-04-09 | 1d |  |  |  |  | Non-SIT LDSO, PP | Non-SIT LDSO, Code Bodies | Non-SIT LDSO Qualification |  | 5.24 | Ben Wickins | Complete | COMPLETE |  |  |  |  |
| 1978 | 1.5.2.5 | Action QWG Feedback on Test Cases & Scenarios Batch 1-3 |  | 2d | 2024-04-10 A | 2024-04-11 A | 1977 | 100% | 2024-04-10 | 2024-04-11 | 2d |  |  |  |  | Non-SIT LDSO | Non-SIT LDSO, Code Bodies | Non-SIT LDSO Qualification |  | 5.24 | Ben Wickins | Complete | COMPLETE |  |  |  |  |
| 1979 | 1.5.2.6 | Batch 1-3 Non-SIT LDSO QT Functional Test Scenarios and Test Cases approved | milestone | 0d | 2024-04-18 A | 2024-04-18 A | 1978FS+5d | 100% | 2024-04-18 | 2024-04-18 | 0d |  |  |  |  | Code Bodies | Non-SIT LDSO, Code Bodies | Non-SIT LDSO Qualification |  | 5.24 | Ben Wickins | Complete | COMPLETE | T3-QU-0069 | QAG (Non-SIT LDSO) | T3 |  |
| 1980 | 1.5.3 | **Test Execution Schedule** |  | 161d | 2024-04-19 A | 2024-11-29 A |  | 100% | 2024-04-19 | 2024-11-29 | 90d | 2024-01-29 | 2024-04-26 |  | -0 | N/A | N/A | Non-SIT LDSO Qualification |  | 5.24 | N/A |  |  |  |  |  | Systems Integration Testing (SIT) |
| 1981 | 1.5.3.1 | Draft Test Delivery Schedule for Functional and Operational Testing |  | 20d | 2024-04-19 A | 2024-05-16 A | 1979 | 100% | 2024-04-19 | 2024-05-16 | 20d | 2024-01-29 | 2024-03-22 |  |  | Non-SIT LDSO | SI Test, PP, Non-SIT LDSO | Non-SIT LDSO Qualification |  | 5.24 | Ben Wickins | Complete | COMPLETE |  |  |  | Systems Integration Testing (SIT) |
| 1982 | 1.5.3.2 | Socialise Test Delivery Schedule with Code Bodies & LDSO for Review & Action Feedback |  | 37d | 2024-05-17 A | 2024-07-08 A | 1981 | 100% | 2024-05-17 | 2024-07-08 | 37d |  |  |  |  | Non-SIT LDSO | LDSO, Code Bodies, Non-SIT LDSO | Non-SIT LDSO Qualification |  | 5.24 | Ben Wickins | Complete | COMPLETE |  |  |  |  |
| 1983 | 1.5.3.3 | Agree Test Execution Timetable Format at QWG, Including Anonymisation Requirements |  | 1d | 2024-07-09 A | 2024-07-09 A | 1982 | 100% | 2024-07-09 | 2024-07-09 | 1d | 2024-03-25 | 2024-04-19 |  |  | Non-SIT LDSO, PP | Non-SIT LDSO, Code Bodies | Non-SIT LDSO Qualification |  | 5.24 | Ben Wickins | Complete | COMPLETE |  |  |  | Systems Integration Testing (SIT) |
| 1984 | 1.5.3.4 | Action QWG Feedback |  | 3d | 2024-07-10 A | 2024-07-12 A | 1983 | 100% | 2024-07-10 | 2024-07-12 | 3d |  |  |  |  | Non-SIT LDSO, PP | Non-SIT LDSO, Code Bodies | Non-SIT LDSO Qualification |  | 5.24 | Ben Wickins | Complete | COMPLETE |  |  |  |  |
| 1985 | 1.5.3.5 | Agree Test Execution Timetable Format at QAG, Including Anonymisation Requirements | milestone | 0d | 2024-07-18 A | 2024-07-18 A | 1984FS+4d | 100% | 2024-07-18 | 2024-07-18 | 0d |  |  |  |  | Code Bodies | Non-SIT LDSO, Code Bodies | Non-SIT LDSO Qualification |  | 5.29 | Ben Wickins | Complete | COMPLETE | T3-QU-0111 | QAG (Non-SIT LDSO) | T3 |  |
| 1986 | 1.5.3.6 | Qualification Testing for Non-SIT LDSOs (Functional, Migration, NFT, Operational) Test Execution Schedule Complete | milestone | 0d | 2024-11-29 A | 2024-11-29 A | 1963 | 100% | 2024-11-29 | 2024-11-29 | 0d | 2024-04-26 | 2024-04-26 | finish no earlier than 2024-11-29 |  | Non-SIT LDSO | Non-SIT LDSO, Code Bodies, PP | Non-SIT LDSO Qualification |  | 5.29 | Ben Wickins | Complete | COMPLETE | T3-QU-0008 | QAG (Non-SIT LDSO) | T3 | Systems Integration Testing (SIT) |
| 1987 | 1.5.4 | **Functional, Non-Functional, Operational & Migration Test Scenarios & Cases** |  | 110d | 2024-03-22 A | 2024-08-22 A |  | 100% | 2024-03-22 | 2024-08-22 | 110d |  |  |  | -0 | N/A | N/A | Non-SIT LDSO Qualification |  | 5.24 | N/A |  |  |  |  |  |  |
| 1988 | 1.5.4.1 | Test Scenarios & Cases - Functional - Drafted, Reviewed |  | 14d | 2024-04-01 A | 2024-04-18 A | 1957 | 100% | 2024-04-01 | 2024-04-18 | 14d |  |  |  |  | Non-SIT LDSO | Non-SIT LDSO, LDSO, Code Bodies | Non-SIT LDSO Qualification |  | 5.24 | Ben Wickins | Complete | COMPLETE |  |  |  |  |
| 1989 | 1.5.4.2 | Test Scenarios & Cases- Functional - Approved at QAG | milestone | 0d | 2024-04-18 A | 2024-04-18 A | 1988 | 100% | 2024-04-18 | 2024-04-18 | 0d |  |  |  |  | Non-SIT LDSO | Non-SIT LDSO, LDSO, Code Bodies | Non-SIT LDSO Qualification |  | 5.24 | Ben Wickins | Complete | COMPLETE | T3-QU-0070 | QAG (Non-SIT LDSO) | T3 |  |
| 1990 | 1.5.4.3 | Test Scenarios & Cases - Non-Functional - Drafted, Reviewed |  | 110d | 2024-03-22 A | 2024-08-22 A | 1957, 1123FF | 100% | 2024-03-22 | 2024-08-22 | 110d |  |  |  |  | Non-SIT LDSO | Non-SIT LDSO, LDSO, Code Bodies | Non-SIT LDSO Qualification |  | 5.24 | Ben Wickins | Complete | COMPLETE |  |  |  |  |
| 1991 | 1.5.4.4 | Test Scenarios & Cases - Non-Functional - Approved at QAG | milestone | 0d | 2024-08-22 A | 2024-08-22 A | 1990 | 100% | 2024-08-22 | 2024-08-22 | 0d |  |  |  |  | Non-SIT LDSO | Non-SIT LDSO, LDSO, Code Bodies | Non-SIT LDSO Qualification |  | 5.29 | Ben Wickins | Complete | COMPLETE | T3-QU-0071 | QAG (Non-SIT LDSO) | T3 |  |
| 1992 | 1.5.4.5 | Test Scenarios & Cases - Migration - Drafted, Reviewed |  | 45d | 2024-03-22 A | 2024-05-23 A | 1957 | 100% | 2024-03-22 | 2024-05-23 | 45d |  |  |  |  | Non-SIT LDSO | Non-SIT LDSO, LDSO, Code Bodies | Non-SIT LDSO Qualification |  | 5.24 | Ben Wickins | Complete | COMPLETE |  |  |  |  |
| 1993 | 1.5.4.6 | Test Scenarios & Cases - Migration - Approved at QAG | milestone | 0d | 2024-05-23 A | 2024-05-23 A | 1992 | 100% | 2024-05-23 | 2024-05-23 | 0d |  |  |  |  | Non-SIT LDSO | Non-SIT LDSO, LDSO, Code Bodies | Non-SIT LDSO Qualification |  | 5.24 | Ben Wickins | Complete | COMPLETE | T3-QU-0072 | QAG (Non-SIT LDSO) | T3 |  |
| 1994 | 1.5.4.7 | Test Scenarios & Cases - Operational - Drafted, Reviewed |  | 59d | 2024-06-03 A | 2024-08-22 A | 1957FS+51d | 100% | 2024-06-03 | 2024-08-22 | 59d |  |  |  |  | Non-SIT LDSO | Non-SIT LDSO, LDSO, Code Bodies | Non-SIT LDSO Qualification |  | 5.24 | Ben Wickins | Complete | COMPLETE |  |  |  |  |
| 1995 | 1.5.4.8 | Test Scenarios & Cases - Operational - Approved at QAG | milestone | 0d | 2024-08-22 A | 2024-08-22 A | 1994, 1123FF | 100% | 2024-08-22 | 2024-08-22 | 0d |  |  |  |  | Non-SIT LDSO | Non-SIT LDSO, LDSO, Code Bodies | Non-SIT LDSO Qualification |  | 5.29 | Ben Wickins | Complete | COMPLETE | T3-QU-0073 | QAG (Non-SIT LDSO) | T3 |  |

Notes:
- 1986: Guidance: 18/7/24: Date change from 15/8/24 to 22/8/24 approved at QAG on 18/7/24
- 1991: Guidance: 18/7/24: Date change from 18/7/24 to 22/8/24 approved at QAG on 18/7/24
- 1995: Guidance: 18/7/24: Date change from 18/7/24 to 22/8/24 approved at QAG on 18/7/24

| ID | WBS | Task | Type | Duration | Start | Finish | Predecessors | Complete | Remaining | Baseline start | Baseline finish | Baseline duration | Total slack | Free slack | Constraint | Deadline | Baseline cost | Responsible | Involved | Text9 | Task Status | Update Version | MHHS Resource Name | Sched Status | RAG | Milestone ID | Text29 | Tier |
| --- | --- | --- | --- | --- | --- | --- | --- | --- | --- | --- | --- | --- | --- | --- | --- | --- | --- | --- | --- | --- | --- | --- | --- | --- | --- | --- | --- | --- |
| 1996 | 1.5.5 | **Test Data** |  | 345d | 2024-01-22 A | 2025-05-16 |  | 84% | 55.39d | 2024-01-22 | 2025-05-16 | 241d | 679d |  |  |  | -0 | N/A | N/A | Non-SIT LDSO Qualification | -385.67 | 5.24 | N/A |  |  |  |  |  |
| 1997 | 1.5.5.1 | Test Data Plan Drafted & Reviewed |  | 89d | 2024-01-22 A | 2024-05-23 A | 1952 | 100% |  | 2024-01-22 | 2024-05-23 | 89d |  |  |  |  |  | Code Bodies | Non-SIT LDSO, Code Bodies | Non-SIT LDSO Qualification |  | 5.24 | Ben Wickins | Complete | COMPLETE |  |  |  |
| 1998 | 1.5.5.2 | Non-SIT LDSO QT Test Data Plan Approved by QAG | milestone | 0d | 2024-05-23 A | 2024-05-23 A | 1997 | 100% |  | 2024-05-23 | 2024-05-23 | 0d |  |  |  |  |  | Code Bodies | Non-SIT LDSO, Code Bodies | Non-SIT LDSO Qualification |  | 5.24 | Ben Wickins | Complete | COMPLETE | T3-QU-0074 | QAG (Non-SIT LDSO) | T3 |
| 1999 | 1.5.5.3 | Develop Test Data Matrices |  | 10d | 2024-05-24 A | 2024-06-06 A | 1998 | 100% |  | 2024-05-24 | 2024-06-06 | 10d |  |  |  |  |  | Non-SIT LDSO | Non-SIT LDSO | Non-SIT LDSO Qualification |  | 5.24 | Ben Wickins | Complete | COMPLETE |  |  |  |
| 2000 | 1.5.5.4 | Test Data Cut |  | 17d | 2024-05-24 A | 2024-06-17 A | 1998 | 100% |  | 2024-05-24 | 2024-06-17 | 17d |  |  |  |  |  | PP, Non-SIT LDSO | PP, Non-SIT LDSO | Non-SIT LDSO Qualification |  | 5.24 | Ben Wickins | Complete | COMPLETE |  |  |  |
| 2001 | 1.5.5.5 | Test Data Cut Complete | milestone | 0d | 2024-06-17 A | 2024-06-17 A | 2000, 1999 | 100% |  | 2024-06-17 | 2024-06-17 | 0d |  |  |  |  |  | PP, Non-SIT LDSO | PP, Non-SIT LDSO | Non-SIT LDSO Qualification |  | 5.27 | Ben Wickins | Complete | COMPLETE | T3-QU-0112 | QAG (Non-SIT LDSO) | T3 |
| 2002 | 1.5.5.6 | Test Data Reviewed by the Programme |  | 39d | 2024-06-18 A | 2024-08-09 A | 2001 | 100% |  | 2024-06-18 | 2024-08-09 | 39d |  |  |  |  |  | Non-SIT LDSO | PP, Non-SIT LDSO | Non-SIT LDSO Qualification |  | 5.24 | Ben Wickins | Complete | COMPLETE |  |  |  |
| 2003 | 1.5.5.7 | Test Data Loaded |  | 85d | 2024-08-12 A | 2024-12-06 A | 2002 | 100% |  | 2024-08-12 | 2024-12-06 | 17d |  |  |  |  |  | Non-SIT LDSO | PP, Non-SIT LDSO | Non-SIT LDSO Qualification |  | 5.24 | Ben Wickins | Complete | COMPLETE |  |  |  |
| 2004 | 1.5.5.8 | Test Data Signed Off | milestone | 0d | 2024-12-06 A | 2024-12-06 A | 2003 | 100% |  | 2024-12-06 | 2024-12-06 | 0d |  |  |  |  |  | Non-SIT LDSO | PP, Non-SIT LDSO | Non-SIT LDSO Qualification |  | 5.25 | Ben Wickins | Complete | COMPLETE | T3-QU-0113 | QAG (Non-SIT LDSO) | T3 |
| 2005 | 1.5.5.9 | Test Execution Data Support |  | 115d | 2024-12-09 A | 2025-05-16 | 2004 | 50% | 57d | 2024-12-09 | 2025-05-16 | 79d | 679d |  |  |  |  | Non-SIT LDSO | Non-SIT LDSO | Non-SIT LDSO Qualification |  | 5.24 | Ben Wickins | Green | GREEN |  |  |  |
| 2006 | 1.5.6 | **Tooling** |  | 148d | 2024-01-31 A | 2024-08-23 A |  | 100% |  | 2024-01-31 | 2024-08-23 | 148d |  |  |  |  | -0 | N/A | N/A | Non-SIT LDSO Qualification | -385.67 | 5.24 | N/A |  |  |  |  |  |
| 2007 | 1.5.6.1 | Design Approach & Set-Up ADO Tool for Test & Defect Management Tool |  | 53d | 2024-01-31 A | 2024-04-12 A | 1952 | 100% |  | 2024-01-31 | 2024-04-12 | 53d |  |  |  |  |  | Non-SIT LDSO | Non-SIT LDSO, SI Test | Non-SIT LDSO Qualification |  | 5.24 | Ben Wickins | Complete | COMPLETE |  |  |  |
| 2008 | 1.5.6.2 | Develop Training Requirements & Materials Inc. Day in the Life |  | 87d | 2024-04-15 A | 2024-08-13 A | 2007 | 100% |  | 2024-04-15 | 2024-08-13 | 87d |  |  |  |  |  | Non-SIT LDSO | Non-SIT LDSO, SI Test | Non-SIT LDSO Qualification |  | 5.24 | Ben Wickins | Complete | COMPLETE |  |  |  |
| 2009 | 1.5.6.3 | ADO Launch complete |  | 1d | 2024-08-23 A | 2024-08-23 A | 2008, 1989, 1993, 1995 | 100% |  | 2024-08-23 | 2024-08-23 | 1d |  |  |  |  |  | Non-SIT LDSO | Non-SIT LDSO | Non-SIT LDSO Qualification |  | 5.24 | Ben Wickins | Complete | COMPLETE |  |  |  |
| 2010 | 1.5.7 | **Pre-Integration Testing** |  | 263d | 2024-01-31 A | 2025-01-31 |  | 97% | 8.11d | 2024-01-31 | 2024-11-29 | 174d | 754d |  |  |  | -0 | N/A | N/A | Non-SIT LDSO Qualification | -385.67 | 5.24 | N/A |  |  |  |  |  |
| 2011 | 1.5.7.1 | PIT Guidance & Templates & Approach & Plans Developed |  | 106d | 2024-02-05 A | 2024-07-01 A | 1952FS+3d | 100% |  | 2024-02-05 | 2024-07-01 | 106d |  |  |  |  |  | Non-SIT LDSO | Non-SIT LDSO, LDSO | Non-SIT LDSO Qualification |  | 5.27 | Ben Wickins | Complete | COMPLETE |  |  |  |
| 2012 | 1.5.7.2 | PIT Test Approach & Plan Deadline for Submission for Non-SIT LDSO​ QT | milestone | 0d | 2024-07-01 A | 2024-07-01 A | 2011 | 100% |  | 2024-07-01 | 2024-07-01 | 0d |  |  |  |  |  | Non-SIT LDSO | Non-SIT LDSO, LDSO | Non-SIT LDSO Qualification |  | 5.28 | Ben Wickins | Complete | COMPLETE | T3-QU-0075 | QAG (Non-SIT LDSO) | T3 |
| 2013 | 1.5.7.3 | Develop and agree PIT Test Scenarios |  | 20d | 2024-07-02 A | 2024-07-29 A | 2012 | 100% |  | 2024-07-02 | 2024-07-29 | 31d |  |  |  |  |  | Non-SIT LDSO | Non-SIT LDSO, Code Bodies, LDSO | Non-SIT LDSO Qualification |  | 5.24 | Ben Wickins | Complete | COMPLETE |  |  |  |
| 2014 | 1.5.7.4 | PIT Execution (Functional and Migration) | manual | 45d | 2024-09-30 A | 2024-11-29 A | 2013 | 100% |  | 2024-09-30 | 2024-11-29 | 45d |  |  | start no earlier than 2024-09-30 |  |  | Non-SIT LDSO | Non-SIT LDSO, LDSO | Non-SIT LDSO Qualification |  | 5.24 | Ben Wickins | Complete | COMPLETE |  |  |  |
| 2015 | 1.5.7.5 | PIT Execution (Non-Functional and Operational) |  | 95d | 2024-09-23 A | 2025-01-31 | 2013 | 85% | 14.25d | 2024-09-23 | 2025-01-31 | 0d | 754d | 0d | finish no earlier than 2025-01-31 |  |  | Non-SIT LDSO |  | Non-SIT LDSO Qualification |  | 5.24 | Ben Wickins | Overdue | RED |  |  |  |
| 2016 | 1.5.7.6 | Non-SIT LDSO Participants have submitted functional PIT Test Completion Report & evidence for QT Entry​ | milestone | 0d | 2024-11-29 A | 2024-11-29 A | 2014 | 100% |  | 2024-11-29 | 2024-11-29 | 0d |  |  |  |  |  | Non-SIT LDSO | Non-SIT LDSO, LDSO | Non-SIT LDSO Qualification |  | 5.24 | Ben Wickins | Complete | COMPLETE | T3-QU-0076 | QAG (Non-SIT LDSO) | T3 |
| 2017 | 1.5.7.7 | Non-SIT LDSO Participants have submitted non-functional PIT Test Completion Report | milestone | 0d | 2025-01-31 | 2025-01-31 | 2015 |  |  | 2025-01-31 | 2025-01-31 | 0d | 754d |  |  |  |  | Non-SIT LDSO |  | Non-SIT LDSO Qualification | -95.29 | 5.24 | Ben Wickins | Overdue Start | RED |  |  |  |
| 2018 | 1.5.7.8 | **Placing Reliance - Code Body & LDSO Functional and Migration** |  | 147d | 2024-01-31 A | 2024-08-22 A |  | 100% |  | 2024-01-31 | 2024-08-22 | 147d |  |  |  |  | -0 | N/A | N/A | Non-SIT LDSO Qualification | -100.67 | 5.24 | N/A |  |  |  |  |  |
| 2019 | 1.5.7.8.1 | Placing Reliance Submitted & Reviewed |  | 21d | 2024-01-31 A | 2024-02-28 A | 1952 | 100% |  | 2024-01-31 | 2024-02-28 | 21d |  |  |  | 2024-01-05 |  | LDSO, Non-SIT LDSO | LDSO, Non-SIT LDSO | Non-SIT LDSO Qualification |  | 5.24 | Ben Wickins | Complete | COMPLETE |  |  |  |
| 2020 | 1.5.7.8.2 | Define & Agree QT Testing for Each LDSO |  | 22d | 2024-02-29 A | 2024-03-29 A | 2019 | 100% |  | 2024-02-29 | 2024-03-29 | 22d |  |  |  |  |  | Non-SIT LDSO | LDSO, Non-SIT LDSO | Non-SIT LDSO Qualification |  | 5.24 | Ben Wickins | Complete | COMPLETE |  |  |  |
| 2021 | 1.5.7.8.3 | Develop Test Scope & Reliance Submissions |  | 20d | 2024-04-01 A | 2024-04-26 A | 2020 | 100% |  | 2024-04-01 | 2024-04-26 | 20d |  |  |  |  |  | Non-SIT LDSO | LDSO, Non-SIT LDSO, Code Bodies | Non-SIT LDSO Qualification |  | 5.24 | Ben Wickins | Complete | COMPLETE |  |  |  |
| 2022 | 1.5.7.8.4 | Review and Consultation |  | 84d | 2024-04-29 A | 2024-08-22 A | 2021, 1963FF | 100% |  | 2024-04-29 | 2024-08-22 | 84d |  |  |  |  |  | Non-SIT LDSO | LDSO, Non-SIT LDSO | Non-SIT LDSO Qualification |  | 5.27 | Ben Wickins | Complete | COMPLETE |  |  |  |

Notes:
- 2015: 07/05/25 - At least one PP has not completed NF and Ops PIT execution by 31/01/25. However, this will not delay QT testing because the issue delaying the PP is expiriencing is internal to them and not systemic, hence why other PPs can proceed with testing
- 2017: 07/05/25 - PIT deliverables now submitted, one outstanding PP with new delivery date agreed which does not impact execution, entry checks still to be completed to confirm QIT entry.

| ID | WBS | Task | Type | Duration | Start | Finish | Predecessors | Complete | Remaining | Baseline start | Baseline finish | Baseline duration | Baseline 1 start | Baseline 1 finish | Total slack | Constraint | Deadline | Baseline cost | Responsible | Involved | Text9 | Task Status | Update Version | MHHS Resource Name | Sched Status | RAG | Milestone ID | Text29 | Tier | MHHS Programme Phase | Action |
| --- | --- | --- | --- | --- | --- | --- | --- | --- | --- | --- | --- | --- | --- | --- | --- | --- | --- | --- | --- | --- | --- | --- | --- | --- | --- | --- | --- | --- | --- | --- | --- |
| 2023 | 1.5.7.9 | **Placing Reliance - Code Body & LDSO Non Functional and Operational** |  | 49d | 2024-06-17 A | 2024-08-22 A |  | 100% |  | 2024-06-17 | 2024-08-22 | 49d |  |  |  |  |  | -0 | N/A | N/A | Non-SIT LDSO Qualification | -100.67 | 5.25 | N/A |  |  |  |  |  |  |  |
| 2024 | 1.5.7.9.1 | Placing Reliance Submitted & Reviewed |  | 32d | 2024-06-17 A | 2024-07-30 A | 1961FF-10d | 100% |  | 2024-06-17 | 2024-07-30 | 32d |  |  |  |  |  |  | LDSO, Non-SIT LDSO | LDSO, Non-SIT LDSO | Non-SIT LDSO Qualification |  | 5.27 | Ben Wickins | Complete | COMPLETE |  |  |  |  |  |
| 2025 | 1.5.7.9.2 | Review and Consultation |  | 17d | 2024-07-31 A | 2024-08-22 A | 2024 | 100% |  | 2024-07-31 | 2024-08-22 | 17d |  |  |  |  |  |  | Non-SIT LDSO | LDSO, Non-SIT LDSO | Non-SIT LDSO Qualification |  | 5.27 | Ben Wickins | Complete | COMPLETE |  |  |  |  |  |
| 2026 | 1.5.7.9.3 | PP Test Scope Presented at QAG | milestone | 0d | 2024-08-22 A | 2024-08-22 A | 2025, 2022 | 100% |  | 2024-08-22 | 2024-08-22 | 0d |  |  |  |  |  |  | Non-SIT LDSO | LDSO, Non-SIT LDSO | Non-SIT LDSO Qualification |  | 5.29 | Ben Wickins | Complete | COMPLETE | T3-QU-0077 | QAG (Non-SIT LDSO) | T3 |  |  |
| 2027 | 1.5.8 | **LDSO Test Readiness Reporting** |  | 71d | 2024-04-19 A | 2024-07-26 A |  | 100% |  | 2024-04-19 | 2024-07-26 | 118d |  |  |  |  |  | -0 | N/A | N/A | Non-SIT LDSO Qualification |  | 5.24 | N/A |  |  |  |  |  |  |  |
| 2028 | 1.5.8.1 | Interim Test Readiness Report & Plan Developed & Reviewed |  | 71d | 2024-04-19 A | 2024-07-26 A | 1979 | 100% |  | 2024-04-19 | 2024-07-26 | 71d |  |  |  |  |  |  | Non-SIT LDSO, LDSO | Non-SIT LDSO, LDSO | Non-SIT LDSO Qualification |  | 5.24 | Ben Wickins | Complete | COMPLETE |  |  |  |  |  |
| 2029 | 1.5.8.2 | Test Plan Submission to MHHS Programme For Review | milestone | 0d | 2024-07-26 A | 2024-07-26 A | 2028 | 100% |  | 2024-07-26 | 2024-07-26 | 0d |  |  |  |  |  |  | LDSO | Non-SIT LDSO, LDSO | Non-SIT LDSO Qualification |  | 5.30 | Ben Wickins | Complete | COMPLETE | T3-QU-0114 | QAG (Non-SIT LDSO) | T3 |  |  |
| 2030 | 1.5.9 | **Test Environment** |  | 163d | 2024-04-17 A | 2024-11-29 A |  | 100% |  | 2024-04-17 | 2024-11-29 | 111d | 2024-01-29 | 2024-07-05 |  |  |  | -0 | N/A | N/A | Non-SIT LDSO Qualification |  | 5.24 | N/A |  |  |  |  |  | Systems Integration Testing (SIT) |  |
| 2031 | 1.5.9.1 | Define Test Harness Requirements and Sign-Off with SRO |  | 13d | 2024-04-17 A | 2024-05-03 A | 554 | 100% |  | 2024-04-17 | 2024-05-03 | 13d |  |  |  |  |  |  | Non-SIT LDSO | Non-SIT LDSO,SRO,Sims and Ems | Non-SIT LDSO Qualification |  | 5.24 | Ben Wickins | Complete | COMPLETE |  |  |  |  |  |
| 2032 | 1.5.9.2 | Central System (DIP Env & Helix Test Harness) Test Environment DBT |  | 163d | 2024-04-17 A | 2024-11-29 A | 554 | 100% |  | 2024-04-17 | 2024-11-29 | 92d |  |  |  | finish no earlier than 2024-11-29 |  |  | LDSO | Non SIT-LDSO, LDSO | Non-SIT LDSO Qualification |  | 5.24 | Ben Wickins | Complete | COMPLETE |  |  |  |  |  |
| 2033 | 1.5.9.3 | Coordinate LDSO Environment Preparation |  | 101d | 2024-07-12 A | 2024-11-29 A | 2032FF | 100% |  | 2024-07-12 | 2024-11-29 | 30d |  |  |  |  |  |  | Non-SIT LDSO | Non-SIT LDSO | Non-SIT LDSO Qualification |  | 5.24 | Ben Wickins | Complete | COMPLETE |  |  |  |  |  |
| 2034 | 1.5.9.4 | DIP available for Onboarding |  | 1d | 2024-08-01 A | 2024-08-01 A |  | 100% |  | 2024-08-01 | 2024-08-01 | 1d |  |  |  | start no earlier than 2024-08-01 |  |  | Test Env | Test Env, Non-SIT LDSO | Non-SIT LDSO Qualification |  | 5.24 | Ben Wickins | Complete | COMPLETE |  |  |  |  | 11/3: Ask Simon B for the link |
| 2035 | 1.5.9.5 | Qualification Testing for Non-SIT LDSOs Participants' environments) Ready to start DIP onboarding (incl. certificates and security compliance) | milestone | 0d | 2024-08-05 A | 2024-08-05 A | 2034FS+2d | 100% |  | 2024-08-05 | 2024-08-05 | 0d | 2024-04-26 | 2024-04-26 |  |  |  |  | Non-SIT LDSO | Code Bodies, PP, IPA | Non-SIT LDSO Qualification |  | 5.30 | Ben Wickins | Complete | COMPLETE | T3-QU-0009 | QAG (Non-SIT LDSO) | T3 | Systems Integration Testing (SIT) |  |
| 2036 | 1.5.9.6 | LDSO Test Environments Connection Confirmed to UIT Environment | milestone | 0d | 2024-11-29 A | 2024-11-29 A | 2035FS+32d, 2033 | 100% |  | 2024-11-29 | 2024-11-29 | 0d |  |  |  |  |  |  | Non-SIT LDSO | Code Bodies, PP, IPA | Non-SIT LDSO Qualification |  | 5.24 | Ben Wickins | Complete | COMPLETE | T3-QU-0078 | QAG (Non-SIT LDSO) | T3 |  |  |
| 2037 | 1.5.10 | **Test Readiness** |  | 124d | 2024-07-02 A | 2024-12-20 A |  | 100% |  | 2024-07-02 | 2024-12-20 | 76d |  |  |  |  |  | -0 | N/A | N/A | Non-SIT LDSO Qualification |  | 5.24 | N/A |  |  |  |  |  |  |  |
| 2038 | 1.5.10.1 | Preparation for Interim Test Readiness Report |  | 19d | 2024-07-02 A | 2024-07-26 A | 2012 | 100% |  | 2024-07-02 | 2024-07-26 | 30d |  |  |  |  |  |  | LDSO | LDSO, Non-SIT LDSO | Non-SIT LDSO Qualification |  | 5.24 | Ben Wickins | Complete | COMPLETE |  |  |  |  |  |
| 2039 | 1.5.10.2 | Interim Test Readiness Report Submission to MHHS Programme for Review | milestone | 0d | 2024-07-26 A | 2024-07-26 A | 2038 | 100% |  | 2024-07-26 | 2024-07-26 | 0d |  |  |  |  |  |  | LDSO | Non-SIT LDSO, LDSO | Non-SIT LDSO Qualification |  | 5.25 | Ben Wickins | Complete | COMPLETE | T3-QU-0116 | QAG (Non-SIT LDSO) | T3 |  |  |
| 2040 | 1.5.10.3 | LDSO Update Readiness Report & Final Assurance by Programme |  | 99d | 2024-07-29 A | 2024-12-12 A | 2039 | 100% |  | 2024-07-29 | 2024-12-12 | 25d |  |  |  |  |  |  | Non-SIT LDSO, LDSO | Non-SIT LDSO, LDSO | Non-SIT LDSO Qualification |  | 5.24 | Ben Wickins | Complete | COMPLETE |  |  |  |  |  |
| 2041 | 1.5.10.4 | Final Test Readiness Report Submitted to MHHS Programme |  | 1d | 2024-12-13 A | 2024-12-13 A | 2040 | 100% |  | 2024-12-13 | 2024-12-13 | 1d |  |  |  |  |  |  | LDSO | Non-SIT LDSO, Code Bodies | Non-SIT LDSO Qualification |  | 5.24 | Ben Wickins | Complete | COMPLETE |  |  |  |  |  |
| 2042 | 1.5.10.5 | Final Programme Assurance of LDSO Test Readiness |  | 6d | 2024-12-13 A | 2024-12-20 A | 2040 | 100% |  | 2024-12-13 | 2024-12-20 | 21d |  |  |  |  |  |  | Non-SIT LDSO | Non-SIT LDSO, LDSO | Non-SIT LDSO Qualification |  | 5.24 | Ben Wickins | Complete | COMPLETE |  |  |  |  |  |
| 2043 | 1.5.10.6 | Qualification Testing for Non-SIT LDSOs (Functional, Migration, NFT, Operational) Programme Test Readiness confirmed | milestone | 0d | 2024-12-20 A | 2024-12-20 A | 2041FS+5d, 2016, 1989, 1991, 1993, 2031 | 100% |  | 2024-12-20 | 2024-12-20 | 0d | 2024-07-05 | 2024-07-05 |  |  |  |  | Non-SIT LDSO | SI Test, PP, Non-SIT LDSO | Non-SIT LDSO Qualification |  | 5.24 | Ben Wickins | Complete | COMPLETE | T3-QU-0007 | QAG (Non-SIT LDSO) | T3 | Systems Integration Testing (SIT) |  |
| 2044 | 1.5.10.7 | Qualification Testing for Non-SIT LDSOs (Functional, Migration, NFT, Operational) Test Readiness Confirmed (Final Test Readiness Review for LDSO) | milestone | 0d | 2024-12-20 A | 2024-12-20 A | 2040, 2042 | 100% |  | 2024-12-20 | 2024-12-20 | 0d | 2024-07-05 | 2024-07-05 |  |  |  |  | LDSO | SI Test, PP, LDSO | Non-SIT LDSO Qualification |  | 5.24 | Ben Wickins | Complete | COMPLETE | T2-QU-0550 | QAG (Non-SIT LDSO) | T2 | Systems Integration Testing (SIT) |  |
| 2045 | 1.5.11 | **Test Window** |  | 165d? | 2025-01-06 A | 2025-08-22 |  | 88% | 19.57d? | 2025-01-06 | 2025-05-16 | 59d |  |  | 609d |  |  | -0 | N/A | N/A | Non-SIT LDSO Qualification | -527.67 | 6.0 | N/A |  |  |  | QAG (Non-SIT LDSO) |  |  |  |
| 2046 | 1.5.11.1 | **All Non-SIT LDSOs Qualification Testing** |  | 94d | 2025-01-06 A | 2025-05-16 | 2044, 2036 | 96% | 3.4d | 2025-01-06 | 2025-05-16 | 59d |  |  | 0d |  |  |  | LDSO | Non-SIT LDSO,Code Bodies, LDSO | Non-SIT LDSO Qualification | 118.33 | 6.0 | Ben Wickins |  |  |  | QAG (Non-SIT LDSO) |  |  |  |
| 2047 | 1.5.11.1.1 | Non-SIT LDSO QT Test Execution Starts | milestone | 0d | 2025-01-06 A | 2025-01-06 A | 2044FS+11d | 100% |  | 2025-01-06 | 2025-01-06 | 0d |  |  |  | start no earlier than 2024-11-01 |  |  | Non-SIT LDSO | Non-SIT LDSO, LDSO, Code Bodies | Non-SIT LDSO Qualification |  | 6.0 | Ben Wickins | Complete | COMPLETE | T3-QU-0115 | QAG (Non-SIT LDSO) | T3 |  |  |
| 2048 | 1.5.11.1.2 | LDSO Alpha |  | 86d | 2025-01-06 A | 2025-05-05 A | 2047FS-1d | 100% |  | 2025-01-06 | 2025-05-05 | 0d |  |  |  |  |  |  | LDSO |  | Non-SIT LDSO Qualification |  | 6.15 | Ben Wickins | Complete | COMPLETE |  | QAG (Non-SIT LDSO) |  |  |  |
| 2049 | 1.5.11.1.3 | LDSO Bravo |  | 86d | 2025-01-06 A | 2025-05-05 A | 2047FS-1d | 100% |  | 2025-01-06 | 2025-05-05 | 0d |  |  |  | finish no earlier than 2025-05-05 |  |  | LDSO |  | Non-SIT LDSO Qualification |  | 6.21 | Ben Wickins | Complete | COMPLETE |  | QAG (Non-SIT LDSO) |  |  |  |
| 2050 | 1.5.11.1.4 | LDSO Charlie |  | 88d | 2025-01-06 A | 2025-05-07 | 2047FS-1d | 96% | 3.52d | 2025-01-06 | 2025-05-07 | 0d |  |  | 6d |  |  |  | LDSO |  | Non-SIT LDSO Qualification |  | 6.15 | Ben Wickins | Green | GREEN |  | QAG (Non-SIT LDSO) |  |  |  |
| 2051 | 1.5.11.1.5 | LDSO Delta |  | 83d | 2025-01-06 A | 2025-04-30 A | 2047FS-1d | 100% |  | 2025-01-06 | 2025-04-30 | 0d |  |  |  |  |  |  | LDSO |  | Non-SIT LDSO Qualification |  | 6.15 | Ben Wickins | Complete | COMPLETE |  | QAG (Non-SIT LDSO) |  |  |  |
| 2052 | 1.5.11.1.6 | LDSO Echo |  | 69d | 2025-01-06 A | 2025-04-10 A | 2047FS-1d | 100% |  | 2025-01-06 | 2025-04-10 | 0d |  |  |  |  |  |  | LDSO |  | Non-SIT LDSO Qualification |  | 6.15 | Ben Wickins | Complete | COMPLETE |  | QAG (Non-SIT LDSO) |  |  |  |
| 2053 | 1.5.11.1.7 | LDSO Foxtrot |  | 84d | 2025-01-20 A | 2025-05-15 | 2047FS+9d | 72% | 23.52d | 2025-01-20 | 2025-05-15 | 0d |  |  | 0d | finish no earlier than 2025-05-15 |  |  | LDSO |  | Non-SIT LDSO Qualification |  | 6.21 | Ben Wickins | Green | GREEN |  | QAG (Non-SIT LDSO) |  |  |  |
| 2054 | 1.5.11.1.8 | LDSO Golf |  | 80d | 2025-01-06 A | 2025-04-25 A | 2047FS-1d | 100% |  | 2025-01-06 | 2025-04-25 | 0d |  |  |  | finish no earlier than 2025-04-25 |  |  | LDSO |  | Non-SIT LDSO Qualification |  | 6.15 | Ben Wickins | Complete | COMPLETE |  | QAG (Non-SIT LDSO) |  |  |  |
| 2055 | 1.5.11.1.9 | LDSO Hotel |  | 86d | 2025-01-06 A | 2025-05-05 A | 2047FS-1d | 100% |  | 2025-01-06 | 2025-05-05 | 0d |  |  |  | finish no earlier than 2025-05-05 |  |  | LDSO |  | Non-SIT LDSO Qualification |  | 6.21 | Ben Wickins | Complete | COMPLETE |  | QAG (Non-SIT LDSO) |  |  |  |
| 2056 | 1.5.11.1.10 | LDSO India |  | 86d | 2025-01-06 A | 2025-05-05 A | 2047FS-1d | 100% |  | 2025-01-06 | 2025-05-05 | 0d |  |  |  |  |  |  | LDSO |  | Non-SIT LDSO Qualification |  | 6.15 | Ben Wickins | Complete | COMPLETE |  | QAG (Non-SIT LDSO) |  |  |  |
| 2057 | 1.5.11.1.11 | Qualification Testing for Non-SIT LDSOs (Functional, Migration, NFT, Operational) 1 End | milestone | 0d | 2025-05-16 | 2025-05-16 | 2048, 2049, 2050, 2051, 2052, 2053, 2054, 2055, 2056 |  |  | 2025-05-16 | 2025-05-16 | 0d |  |  | 0d | start no earlier than 2025-05-16 | 2025-05-16 |  | LDSO |  | Non-SIT LDSO Qualification | 9.33 | 6.0 | Ben Wickins | Green | GREEN | T3-QU-0010 | QAG (Non-SIT LDSO) | T3 |  |  |
| 2058 | 1.5.11.2 | Potential for non-SIT LDSO QT Regression for Qualification |  | 70d? | 2025-05-19 | 2025-08-22 | 2057FS+1d |  |  | 2025-05-19 | 2025-08-22 | 0d |  |  | 609d |  |  |  | Non-SIT LDSO |  | Non-SIT LDSO Qualification | 12.33 | 6.12 | Ben Wickins | Green | GREEN |  | QAG (Non-SIT LDSO) |  |  |  |

Notes:
- 2026: Guidance: 18/7/24: Date change from 18/7/24 to 22/8/24 approved at QAG on 18/7/24
- 2053: 22/04/25 - Testing recovery plan has led to forecast completion ahead of end of QT window (16/05)

| ID | WBS | Task | Type | Duration | Start | Finish | Predecessors | Complete | Remaining | Baseline start | Baseline finish | Baseline duration | Total slack | Free slack | Constraint | Baseline cost | Responsible | Involved | Text9 | Update Version | MHHS Resource Name | Text29 | Sched Status | RAG | Task Status | Milestone ID | Tier | Previous RAG |
| --- | --- | --- | --- | --- | --- | --- | --- | --- | --- | --- | --- | --- | --- | --- | --- | --- | --- | --- | --- | --- | --- | --- | --- | --- | --- | --- | --- | --- |
| 2059 | 1.5.12 | **Test Result Assurance** |  | 30d | 2025-04-04 A | 2025-05-16 |  | 43% | 17d | 2025-04-21 | 2025-05-29 | 60d | 649d |  |  | -0 | N/A | N/A | Non-SIT LDSO Qualification | 6.0 | N/A | QAG (Non-SIT LDSO) |  |  |  |  |  |  |
| 2060 | 1.5.12.1 | Test Reports Reviewed By MHHS & Code Bodies & Finalised |  | 30d | 2025-04-04 A | 2025-05-16 | 2057FF | 43% | 17d | 2025-04-04 | 2025-05-16 | 16d | 649d | 0d |  |  | Non-SIT LDSO | Non-SIT LDSO, Code Bodies | Non-SIT LDSO Qualification | 6.0 | Ben Wickins | QAG (Non-SIT LDSO) | Green | GREEN |  |  |  |  |
| 2061 | 1.5.12.2 | Non-SIT LDSOs submission deadline for their QT Test Completion Report to MHHS Programme | milestone | 0d | 2025-05-16 | 2025-05-16 | 2060, 2046, 2057 |  |  | 2025-05-16 | 2025-05-16 | 0d | 649d | 0d |  |  | Non-SIT LDSO | Non-SIT LDSO | Non-SIT LDSO Qualification | 6.23 | Ben Wickins | QAG (Non-SIT LDSO) | Green | GREEN | 9.33 | T3-QU-0079 | T3 |  |
| 2062 | 1.5.13 | **Non-SIT LDSO Qualification Closure** |  | 31d | 2025-05-16 | 2025-06-27 |  |  |  | 2025-05-30 | 2025-08-22 | 49d | 649d |  |  | -0 | N/A | N/A | Non-SIT LDSO Qualification | 6.0 | N/A | QAG (Non-SIT LDSO) |  |  |  |  |  |  |
| 2063 | 1.5.13.1 | Non-SIT LDSO Qualification Learned Captured |  | 10d | 2025-05-16 | 2025-05-29 | 2061 |  |  | 2025-05-16 | 2025-05-29 | 15d | 670d |  | start no earlier than 2025-04-16 |  | Non-SIT LDSO | Non-SIT LDSO | Non-SIT LDSO Qualification | 6.23 | Ben Wickins | QAG (Non-SIT LDSO) | Green | GREEN | 9.33 |  |  |  |
| 2064 | 1.5.13.2 | Non-SIT LDSO Regression Testing |  | 26d | 2025-05-16 | 2025-06-20 | 2061 |  |  | 2025-05-16 | 2025-06-20 | 0d | 649d | 0d |  |  | Non-SIT LDSO |  | Non-SIT LDSO Qualification | 6.23 | Ben Wickins | QAG (Non-SIT LDSO) | Green | GREEN | 9.33 |  |  |  |
| 2065 | 1.5.13.3 | Non-SIT LDSO Qualification Closure Down |  | 5d | 2025-06-23 | 2025-06-27 | 2064 |  |  | 2025-06-23 | 2025-06-27 | 5d | 649d |  | finish no earlier than 2025-06-26 |  | Non-SIT LDSO | Non-SIT LDSO | Non-SIT LDSO Qualification | 6.23 | Ben Wickins | QAG (Non-SIT LDSO) | Green | GREEN | 47.33 |  |  |  |
| 2066 | 1.6 | **SERVICE MANAGEMENT** |  | 130d | 2025-03-03 A | 2025-09-01 |  | 50% | 65.32d | 2025-03-03 | 2025-09-01 | 0d | 604d |  |  |  | Helix |  | Service Management | 6.24 | Helix | Helix | Overdue Start | RED | -918.67 |  |  |  |
| 2067 | 1.6.1 | **Stage 2 - M10 Readiness** |  | 130d | 2025-03-03 A | 2025-09-01 |  | 50% | 65.32d | 2025-03-03 | 2025-09-01 | 0d | 604d |  |  |  | Helix |  | Service Management | 6.24 | Helix | Helix |  |  |  |  |  |  |
| 2068 | 1.6.1.1 | **Service Model Design (Cross Party Service Desk)** |  | 105d | 2025-03-03 A | 2025-07-25 |  | 59% | 42.89d | 2025-03-03 | 2025-07-15 | 0d | 629d |  |  |  | Helix |  | Service Management | 6.24 | Helix | Helix | No BL | RED | 0.33 |  |  | Service Model Design (Cross Party Service Desk) |
| 2069 | 1.6.1.1.1 | **Cross Party Service Desk** |  | 56d | 2025-03-03 A | 2025-05-20 |  | 85% | 8.17d | 2025-03-03 | 2025-07-01 | 0d | 678d |  |  |  | Helix |  | Service Management | 6.24 | Helix | Helix |  |  |  |  |  | Service Model Design (Cross Party Service Desk) |
| 2070 | 1.6.1.1.1.1 | Cross Party Service Desk Definition and Design |  | 24d | 2025-03-03 A | 2025-04-03 A |  | 100% |  | 2025-03-03 | 2025-04-03 | 0d |  |  |  |  | Helix |  | Service Management | 6.24 | Helix | Helix | Complete | COMPLETE |  |  |  | Service Model Design (Cross Party Service Desk) |
| 2071 | 1.6.1.1.1.2 | Cross Party Service Desk Design Document MHHS Review | milestone | 0d | 2025-04-03 A | 2025-04-03 A | 2070 | 100% |  | 2025-04-03 | 2025-04-03 | 0d |  |  | start no earlier than 2025-04-03 |  | Helix |  | Service Management | 6.24 | Helix | Helix | Complete | COMPLETE |  |  |  | Service Model Design (Cross Party Service Desk) |
| 2072 | 1.6.1.1.1.3 | Cross Party Service Desk Model Issued | milestone | 0d | 2025-04-07 A | 2025-04-07 A | 2071 | 100% |  | 2025-04-07 | 2025-04-07 | 0d |  |  | start no earlier than 2025-04-07 |  | Helix |  | Service Management | 6.24 | Helix | Helix | Complete | COMPLETE |  |  |  | Service Model Design (Cross Party Service Desk) |
| 2073 | 1.6.1.1.1.4 | Cross Party Service Desk Model Reissued | milestone | 0d | 2025-04-15 A | 2025-04-15 A | 2072 | 100% |  | 2025-04-15 | 2025-04-15 | 0d |  |  | start no earlier than 2025-04-15 |  | Helix |  | Service Management | 6.24 | Helix | Helix | Complete | COMPLETE |  |  |  | Service Model Design (Cross Party Service Desk) |
| 2074 | 1.6.1.1.1.5 | **Cross Party Service Desk Consultation** |  | 31d | 2025-04-07 A | 2025-05-20 |  | 71% | 9.04d | 2025-04-07 | 2025-07-01 | 0d | 678d |  |  |  | Helix |  | Service Management | 6.24 | Helix | Helix |  |  |  |  |  | Service Model Design (Cross Party Service Desk) |
| 2075 | 1.6.1.1.1.5.1 | Cross Party Service Desk Consultation |  | 16d | 2025-04-07 A | 2025-04-28 A | 2071, 2073FF | 100% |  | 2025-04-07 | 2025-04-28 | 0d |  |  | finish no earlier than 2025-04-28 |  | Helix |  | Service Management | 6.24 | Helix | Helix | Complete | COMPLETE |  |  |  | Service Model Design (Cross Party Service Desk) |
| 2076 | 1.6.1.1.1.5.2 | Cross Party Service Desk Consultation Completed | milestone | 0d | 2025-04-28 A | 2025-04-28 A | 2075 | 100% |  | 2025-04-28 | 2025-04-28 | 0d |  |  | start no earlier than 2025-03-28 |  | Helix |  | Service Management | 6.24 | Helix | Helix | Complete | COMPLETE |  |  |  | Service Model Design (Cross Party Service Desk) |
| 2077 | 1.6.1.1.1.5.3 | Cross Party Service Desk Model Updates (Feedback Review) |  | 8d | 2025-04-29 A | 2025-05-08 | 2076 | 13% | 7d | 2025-04-29 | 2025-05-08 | 0d | 682d | 0d | start no earlier than 2025-04-23 |  | Helix |  | Service Management | 6.24 | Helix | Helix | Green | GREEN |  |  |  | Service Model Design (Cross Party Service Desk) |
| 2078 | 1.6.1.1.1.5.4 | Cross Party Service Desk Model Spotlight at Elexon Service Management Steering Group | milestone | 0d | 2025-05-07 | 2025-05-07 | 2077FF-1d |  |  | 2025-05-07 | 2025-05-07 | 0d | 686d |  | start no earlier than 2025-05-07 |  | Helix |  | Service Management | 6.24 | Helix | Helix | Green | GREEN | 0.71 |  |  | Service Model Design (Cross Party Service Desk) |
| 2079 | 1.6.1.1.1.5.5 | Updated Consultation Documents Shared with MHHS and Industry | milestone | 0d | 2025-05-08 | 2025-05-08 | 2077 |  |  | 2025-05-08 | 2025-05-08 | 0d | 685d | 3d | start no earlier than 2025-04-14 |  | Helix |  | Service Management | 6.24 | Helix | Helix | Green | GREEN | 1.71 |  |  | Service Model Design (Cross Party Service Desk) |
| 2080 | 1.6.1.1.1.5.6 | TORWG Post-Consultation Update (CPSD) | milestone | 0d | 2025-05-14 | 2025-05-14 | 2079 |  |  | 2025-05-14 | 2025-05-14 | 0d | 682d | 35d | start no earlier than 2025-05-14 |  | Helix |  | Service Management | 6.24 | Helix | Helix | Green | GREEN | 7.33 |  |  | Service Model Design (Cross Party Service Desk) |
| 2081 | 1.6.1.1.1.5.7 | Updated Consultation Documents Released to Industry for eTORWG | milestone | 0d | 2025-05-16 | 2025-05-16 | 2080FS+3d, 2124 |  |  | 2025-07-01 | 2025-07-01 | 0d | 679d | 1d |  |  | Helix |  | Service Management | 6.24 | Helix | Helix | Green | GREEN | 9.71 |  |  | Service Model Design (Cross Party Service Desk) |
| 2082 | 1.6.1.1.1.5.8 | CPSD, Operating Hours & Triage Updates Endorsement (eTORWG) | milestone | 0d | 2025-05-20 | 2025-05-20 | 2081 |  |  | 2025-07-01 | 2025-07-01 | 0d | 678d | 0d | start no earlier than 2025-05-20 |  | Helix |  | Service Management | 6.24 | Helix | Helix | Green | GREEN | 13.33 |  |  | Service Model Design (Cross Party Service Desk) |
| 2083 | 1.6.1.1.1.6 | Cross Party Service Desk Model Completed | milestone | 0d | 2025-05-20 | 2025-05-20 | 2082 |  |  | 2025-07-01 | 2025-07-01 | 0d | 678d |  | start no earlier than 2025-03-28 |  | Helix |  | Service Management | 6.24 | Helix | Helix | Green | GREEN | 13.33 |  |  | Service Model Design (Cross Party Service Desk) |

Notes:
- 2061: 16/04/25 - Milestone updated in-line with test end activity, Test Completion report activity currently ongoing.
- 2063: 22/04/25 - Dates updated to reflect end of QT window.
- 2064: 22/04/25 - New activity added to reflect emergent testing contingency requirements post QT window.
- 2065: 22/04/25 - Dates updated to reflect end of QT window.

| ID | WBS | Task | Type | Duration | Start | Finish | Predecessors | Complete | Remaining | Baseline start | Baseline finish | Baseline duration | Total slack | Free slack | Constraint | Responsible | Text9 | Task Status | Update Version | Sched Status | MHHS Resource Name | Previous RAG | RAG | Text29 |
| --- | --- | --- | --- | --- | --- | --- | --- | --- | --- | --- | --- | --- | --- | --- | --- | --- | --- | --- | --- | --- | --- | --- | --- | --- |
| 2084 | 1.6.1.1.2 | **Service Documentation** |  | 64d | 2025-04-29 A | 2025-07-25 |  | 4% | 61.22d | 2025-04-29 | 2025-07-15 | 0d | 629d |  |  | Helix | Service Management | 0.33 | 6.24 | No BL | Helix | Service Model Design (Cross Party Service Desk) | RED | Helix |
| 2085 | 1.6.1.1.2.1 | Operations Manual and LLSD Updates Post-Consultation |  | 13d | 2025-04-29 A | 2025-05-15 | 2076 | 8% | 12d | 2025-04-29 | 2025-05-15 | 0d | 670d | 0d | start no earlier than 2025-04-23 | Helix | Service Management |  | 6.24 | Green | Helix | Service Model Design (Cross Party Service Desk) | GREEN | Helix |
| 2086 | 1.6.1.1.2.2 | Service User LLSD Version 1.2 | milestone | 0d | 2025-05-15 | 2025-05-15 | 2085 |  |  | 2025-05-15 | 2025-05-15 | 0d | 670d | 31d |  | Helix | Service Management | 8.71 | 6.24 | Green | Helix | Service Model Design (Cross Party Service Desk) | GREEN | Helix |
| 2087 | 1.6.1.1.2.3 | Operations Manual Version 1.2 | milestone | 0d | 2025-05-15 | 2025-05-15 | 2085 |  |  | 2025-05-15 | 2025-05-15 | 0d | 670d | 31d |  | Helix | Service Management | 8.71 | 6.24 | Green | Helix | Service Model Design (Cross Party Service Desk) | GREEN | Helix |
| 2088 | 1.6.1.1.2.4 | Post-ORT Operations Manual and LLSD Updates |  | 10d | 2025-07-14 | 2025-07-25 | 2086, 2087 |  |  | 2025-07-14 | 2025-07-25 | 0d | 629d | 0d | start no earlier than 2025-07-14 | Helix | Service Management | 68.33 | 6.24 | Green | Helix | Service Model Design (Cross Party Service Desk) | GREEN | Helix |
| 2089 | 1.6.1.1.2.5 | M10 Operations Manual Version 2.0 & LLSD ORT Learning | milestone | 0d | 2025-07-25 | 2025-07-25 | 2088 |  |  | 2025-07-25 | 2025-07-25 | 0d | 629d |  | start no earlier than 2025-04-01 | Helix | Service Management | 79.71 | 6.24 | Green | Helix | Service Model Design (Cross Party Service Desk) | GREEN | Helix |
| 2090 | 1.6.1.2 | **Operational Readiness Testing** |  | 109d | 2025-03-03 A | 2025-07-31 |  | 45% | 60.19d | 2025-03-03 | 2025-07-21 | 0d | 625d |  |  | Helix | Service Management | 0.33 | 6.24 | No BL | Helix | Operational Readiness Testing |  | Helix |
| 2091 | 1.6.1.2.1 | **ORT Design** |  | 72d | 2025-03-03 A | 2025-06-10 |  | 69% | 22.22d | 2025-03-03 | 2025-06-10 | 0d | 662d | 36d |  | Helix | Service Management |  | 6.24 |  | Helix | Operational Readiness Testing |  | Helix |
| 2092 | 1.6.1.2.1.1 | ORT Test Scope and Approach |  | 25d | 2025-03-03 A | 2025-04-04 A | 2070FF | 100% |  | 2025-03-03 | 2025-04-04 | 0d |  |  | start no earlier than 2025-03-03 | Helix | Service Management |  | 6.24 | Complete | Helix | Operational Readiness Testing | COMPLETE | Helix |
| 2093 | 1.6.1.2.1.2 | ORT Test Approach Shared with MHHS (Initial Review) | milestone | 0d | 2025-04-02 A | 2025-04-02 A | 2092FS-3d | 100% |  | 2025-04-02 | 2025-04-02 | 0d |  |  | start no earlier than 2025-04-02 | Helix | Service Management |  | 6.24 | Complete | Helix | Operational Readiness Testing | COMPLETE | Helix |
| 2094 | 1.6.1.2.1.3 | ORT Test Scenarios Shared with MHHS (Initial Review) | milestone | 0d | 2025-04-02 A | 2025-04-02 A | 2092FS-3d | 100% |  | 2025-04-02 | 2025-04-02 | 0d |  |  | start no earlier than 2025-04-02 | Helix | Service Management |  | 6.24 | Complete | Helix | Operational Readiness Testing | COMPLETE | Helix |
| 2095 | 1.6.1.2.1.4 | ORT Test Scope and Approach Documents Shared with Industry | milestone | 0d | 2025-04-07 A | 2025-04-07 A | 2094 | 100% |  | 2025-04-07 | 2025-04-07 | 0d |  |  | start no earlier than 2025-04-07 | Helix | Service Management |  | 6.24 | Complete | Helix | Operational Readiness Testing | COMPLETE | Helix |
| 2096 | 1.6.1.2.1.5 | **ORT Test Scope and Approach Consultation (Test Scope and Approach & Test Scripts)** |  | 30d | 2025-04-08 A | 2025-05-20 |  | 70% | 9.13d | 2025-04-08 | 2025-05-20 | 0d | 644d |  |  | Helix | Service Management |  | 6.24 |  | Helix | Operational Readiness Testing |  | Helix |
| 2097 | 1.6.1.2.1.5.1 | ORT Test Scope and Approach Consultation |  | 15d | 2025-04-08 A | 2025-04-28 A | 2095 | 100% |  | 2025-04-08 | 2025-04-28 | 0d |  |  | finish no earlier than 2025-04-28 | Helix | Service Management |  | 6.24 | Complete | Helix | Operational Readiness Testing | COMPLETE | Helix |
| 2098 | 1.6.1.2.1.5.2 | ORT Test Scope and Approach Consultation Completed | milestone | 0d | 2025-04-28 A | 2025-04-28 A | 2097 | 100% |  | 2025-04-28 | 2025-04-28 | 0d |  |  | start no earlier than 2025-03-28 | Helix | Service Management |  | 6.24 | Complete | Helix | Operational Readiness Testing | COMPLETE | Helix |
| 2099 | 1.6.1.2.1.5.3 | ORT Test Scope and Approach Updates (Feedback Review) |  | 8d | 2025-04-29 A | 2025-05-08 | 2098 | 13% | 7d | 2025-04-29 | 2025-05-08 | 0d | 633d | 0d | start no earlier than 2025-04-14 | Helix | Service Management |  | 6.24 | Green | Helix | Operational Readiness Testing | GREEN | Helix |
| 2100 | 1.6.1.2.1.5.4 | Updated ORT Test Scope and Approach Documents Shared with MHHS and Industry | milestone | 0d | 2025-05-08 | 2025-05-08 | 2099 |  |  | 2025-05-08 | 2025-05-08 | 0d | 651d | 3d | start no earlier than 2025-04-14 | Helix | Service Management | 1.71 | 6.24 | Green | Helix | Operational Readiness Testing | GREEN | Helix |
| 2101 | 1.6.1.2.1.5.5 | TORWG Post-Consultation Update (ORT Approach) | milestone | 0d | 2025-05-14 | 2025-05-14 | 2100 |  |  | 2025-05-14 | 2025-05-14 | 0d | 648d | 2d | start no earlier than 2025-05-14 | Helix | Service Management | 7.33 | 6.24 | Green | Helix | Operational Readiness Testing | GREEN | Helix |
| 2102 | 1.6.1.2.1.5.6 | Updated ORT Test Scope and Approach Documents Released to Industry for eSITWG | milestone | 0d | 2025-05-16 | 2025-05-16 | 2100, 2101 |  |  | 2025-05-16 | 2025-05-16 | 0d | 646d | 2d | start no earlier than 2025-05-16 | Helix | Service Management | 9.33 | 6.24 | Green | Helix | Operational Readiness Testing | GREEN | Helix |
| 2103 | 1.6.1.2.1.5.7 | ORT Test Scope and Approach Endorsement (eSITWG) | milestone | 0d | 2025-05-20 | 2025-05-20 | 2102 |  |  | 2025-05-20 | 2025-05-20 | 0d | 644d | 11d | start no earlier than 2025-05-20 | Helix | Service Management | 13.33 | 6.24 | Green | Helix | Operational Readiness Testing | GREEN | Helix |
| 2104 | 1.6.1.2.1.6 | ORT Test Script Production and Updates |  | 23d | 2025-04-08 A | 2025-05-08 | 2098FF, 2099FF, 2075FF | 65% | 8d | 2025-04-08 | 2025-05-08 | 0d | 633d | 0d | start no earlier than 2025-04-07 | Helix | Service Management |  | 6.24 | Green | Helix | Operational Readiness Testing | GREEN | Helix |
| 2105 | 1.6.1.2.1.7 | ORT Test Scripts Shared | milestone | 0d | 2025-05-08 | 2025-05-08 | 2104 |  |  | 2025-05-08 | 2025-05-08 | 0d | 633d | 0d | start no earlier than 2025-05-07 | Helix | Service Management | 1.71 | 6.24 | Green | Helix | Operational Readiness Testing | GREEN | Helix |
| 2106 | 1.6.1.2.1.8 | **ORT Test Scripts Consultation** |  | 25d | 2025-05-07 | 2025-06-10 |  |  |  | 2025-05-07 | 2025-06-10 | 0d | 635d |  |  | Helix | Service Management |  | 6.24 |  | Helix | Operational Readiness Testing |  | Helix |
| 2107 | 1.6.1.2.1.8.1 | ORT Spotlight (Test Approach) at Elexon Service Management Helix Steering Group | milestone | 0d | 2025-05-07 | 2025-05-07 |  |  |  | 2025-05-07 | 2025-05-07 | 0d | 645d | 12d | start no earlier than 2025-05-07 | Helix | Service Management | 0.33 | 6.24 | Green | Helix | Operational Readiness Testing | GREEN | Helix |
| 2108 | 1.6.1.2.1.8.2 | ORT Test Scripts Consultation |  | 5d | 2025-05-09 | 2025-05-15 | 2104, 2105 |  |  | 2025-05-09 | 2025-05-15 | 0d | 633d | 0d | start no earlier than 2025-05-01 | Helix | Service Management | 2.33 | 6.24 | Green | Helix | Operational Readiness Testing | GREEN | Helix |
| 2109 | 1.6.1.2.1.8.3 | ORT Test Scripts Consultation Completed | milestone | 0d | 2025-05-15 | 2025-05-15 | 2108 |  |  | 2025-05-15 | 2025-05-15 | 0d | 633d | 0d | start no earlier than 2025-03-28 | Helix | Service Management | 8.71 | 6.24 | Green | Helix | Operational Readiness Testing | GREEN | Helix |
| 2110 | 1.6.1.2.1.8.4 | ORT Test Scripts Updates (Feedback Review) |  | 5d | 2025-05-16 | 2025-05-22 | 2109 |  |  | 2025-05-16 | 2025-05-22 | 0d | 633d | 0d | start no earlier than 2025-04-02 | Helix | Service Management | 9.33 | 6.24 | Green | Helix | Operational Readiness Testing | GREEN | Helix |
| 2111 | 1.6.1.2.1.8.5 | ORT Test Scipts Updates Shared with MHHS and Industry | milestone | 0d | 2025-05-22 | 2025-05-22 | 2110 |  |  | 2025-05-22 | 2025-05-22 | 0d | 633d | 0d | start no earlier than 2025-04-14 | Helix | Service Management | 15.71 | 6.24 | Green | Helix | Operational Readiness Testing | GREEN | Helix |
| 2112 | 1.6.1.2.1.8.6 | Industry Assurance Review Session Post-Consultation Update (ORT Test Scripts) | milestone | 0d | 2025-05-30 | 2025-05-30 | 2111FS+6d |  |  | 2025-05-30 | 2025-05-30 | 0d | 653d | 0d | start no earlier than 2025-04-14 | Helix | Service Management | 23.71 | 6.24 | Green | Helix | Operational Readiness Testing | GREEN | Helix |
| 2113 | 1.6.1.2.1.8.7 | Updated ORT Test Script Consultation Documents Released to industry for eSITWG | milestone | 0d | 2025-06-03 | 2025-06-03 | 2112FS+2d |  |  | 2025-06-03 | 2025-06-03 | 0d | 653d | 0d | start no earlier than 2025-04-04 | Helix | Service Management | 27.71 | 6.24 | Green | Helix | Operational Readiness Testing | GREEN | Helix |
| 2114 | 1.6.1.2.1.8.8 | ORT Test Scripts and Readiness Spotlight at Elexon Service Management Steering Group | milestone | 0d | 2025-06-04 | 2025-06-04 | 2113FS+1d |  |  | 2025-06-04 | 2025-06-04 | 0d | 666d |  | start no earlier than 2025-04-22 | Helix | Service Management | 28.71 | 6.24 | Green | Helix | Operational Readiness Testing | GREEN | Helix |
| 2115 | 1.6.1.2.1.8.9 | ORT Test Scipt Updates Endorsement (eSITWG) | milestone | 0d | 2025-06-10 | 2025-06-10 | 2113FS+5d |  |  | 2025-06-10 | 2025-06-10 | 0d | 662d |  | start no earlier than 2025-04-14 | SITWG | Service Management | 34.71 | 6.24 | Green | Helix | Operational Readiness Testing | GREEN | Helix |

| ID | WBS | Task | Type | Duration | Start | Finish | Predecessors | Complete | Remaining | Baseline start | Baseline finish | Baseline duration | Baseline 1 start | Baseline 1 finish | Total slack | Free slack | Constraint | Baseline cost | Responsible | Text9 | Update Version | MHHS Resource Name | Previous RAG | Text29 | Sched Status | RAG | Task Status | Involved | MHHS Programme Phase | Milestone ID | Tier |
| --- | --- | --- | --- | --- | --- | --- | --- | --- | --- | --- | --- | --- | --- | --- | --- | --- | --- | --- | --- | --- | --- | --- | --- | --- | --- | --- | --- | --- | --- | --- | --- |
| 2116 | 1.6.1.2.2 | **ORT Preparation** |  | 32d | 2025-05-01 A | 2025-06-13 |  | 22% | 24.89d | 2025-05-01 | 2025-06-03 | 0d |  |  | 659d |  |  |  | Helix | Service Management | 6.24 | Helix | Operational Readiness Testing | Helix |  |  |  |  |  |  |  |
| 2117 | 1.6.1.2.2.1 | ORT Participant/User Scheduling |  | 12d | 2025-05-01 A | 2025-05-16 |  | 33% | 8d | 2025-05-01 | 2025-05-16 | 0d |  |  | 665d | 0d | start no earlier than 2025-05-01 |  | Helix | Service Management | 6.24 | Helix | Operational Readiness Testing | Helix | Green | GREEN |  |  |  |  |  |
| 2118 | 1.6.1.2.2.2 | ORT Participant/User Scheduling Completed | milestone | 0d | 2025-05-16 | 2025-05-16 | 2117 |  |  | 2025-05-16 | 2025-05-16 | 0d |  |  | 679d |  | start no earlier than 2025-03-28 |  | Helix | Service Management | 6.24 | Helix | Operational Readiness Testing | Helix | Green | GREEN | 9.71 |  |  |  |  |
| 2119 | 1.6.1.2.2.3 | ORT Training and Preparation |  | 6d | 2025-06-04 | 2025-06-11 | 2097, 2104, 2107, 2111 |  |  | 2025-06-04 | 2025-06-11 | 0d |  |  | 625d | 0d | start no earlier than 2025-06-04 |  | Helix | Service Management | 6.24 | Helix | Operational Readiness Testing | Helix | Green | GREEN | 28.33 |  |  |  |  |
| 2120 | 1.6.1.2.2.4 | ORT DITL Session | milestone | 0d | 2025-06-12 | 2025-06-12 | 2109FS+2d, 2112 |  |  | 2025-06-12 | 2025-06-12 | 0d |  |  | 661d | 35d | start no earlier than 2025-06-12 |  | Helix | Service Management | 6.24 | Helix | Operational Readiness Testing | Helix | Green | GREEN | 36.33 |  |  |  |  |
| 2121 | 1.6.1.2.2.5 | ORT Orientation (JiT) | milestone | 0d | 2025-06-13 | 2025-06-13 | 2119FS+2d |  |  | 2025-06-13 | 2025-06-13 | 0d |  |  | 625d | 0d | start no earlier than 2025-05-30 |  | Helix | Service Management | 6.24 | Helix | Operational Readiness Testing | Helix | Green | GREEN | 37.71 |  |  |  |  |
| 2122 | 1.6.1.2.3 | **ORT Execution** |  | 20d | 2025-06-16 | 2025-07-11 |  |  |  | 2025-06-16 | 2025-07-11 | 0d |  |  | 625d |  |  |  | Helix | Service Management | 6.24 | Helix | Operational Readiness Testing | Helix |  |  |  |  |  |  |  |
| 2123 | 1.6.1.2.3.1 | ORT Execution |  | 20d | 2025-06-16 | 2025-07-11 | 2119, 2121, 2103 |  |  | 2025-06-16 | 2025-07-11 | 0d |  |  | 625d | 0d | start no earlier than 2025-06-02 |  | Helix | Service Management | 6.24 | Helix | Operational Readiness Testing | Helix | Green | GREEN | 40.33 |  |  |  |  |
| 2124 | 1.6.1.2.3.2 | ORT Execution Completed | milestone | 0d | 2025-07-11 | 2025-07-11 | 2123 |  |  | 2025-07-11 | 2025-07-11 | 0d |  |  | 625d | 0d | start no earlier than 2025-03-28 |  | Helix | Service Management | 6.24 | Helix | Operational Readiness Testing | Helix | Green | GREEN | 65.71 |  |  |  |  |
| 2125 | 1.6.1.2.4 | **ORT Exit** |  | 14d | 2025-07-14 | 2025-07-31 | 2103, 2110, 2113, 2117 |  |  | 2025-07-14 | 2025-07-31 | 0d |  |  | 625d |  |  |  | Helix | Service Management | 6.24 | Helix | Operational Readiness Testing | Helix |  |  |  |  |  |  |  |
| 2126 | 1.6.1.2.4.1 | ORT Wrap Up |  | 5d | 2025-07-14 | 2025-07-18 | 2124 |  |  | 2025-07-14 | 2025-07-18 | 0d |  |  | 634d | 8d | start no earlier than 2025-04-22 |  | Helix | Service Management | 6.24 | Helix | Operational Readiness Testing | Helix | Green | GREEN | 68.33 |  |  |  |  |
| 2127 | 1.6.1.2.4.2 | ORT Exit Report |  | 10d | 2025-07-14 | 2025-07-25 | 2124 |  |  | 2025-07-14 | 2025-07-25 | 0d |  |  | 625d | 0d | start no earlier than 2025-04-02 |  | Helix | Service Management | 6.24 | Helix | Operational Readiness Testing | Helix | Green | GREEN | 68.33 |  |  |  |  |
| 2128 | 1.6.1.2.4.3 | ORT Exit Report Shared with Participants | milestone | 0d | 2025-07-25 | 2025-07-25 | 2127 |  |  | 2025-07-25 | 2025-07-25 | 0d |  |  | 625d | 0d | start no earlier than 2025-04-22 |  | Helix | Service Management | 6.24 | Helix | Operational Readiness Testing | Helix | Green | GREEN | 79.71 |  |  |  |  |
| 2129 | 1.6.1.2.4.4 | ORT eSITAG Exit Report Endorsement | milestone | 0d | 2025-07-31 | 2025-07-31 | 2128FS+4d |  |  | 2025-07-31 | 2025-07-31 | 0d |  |  | 625d |  | start no earlier than 2025-04-02 |  | Helix | Service Management | 6.24 | Helix | Operational Readiness Testing | Helix | Green | GREEN | 85.71 |  |  |  |  |
| 2130 | 1.6.1.3 | **Service Go-Live Governance** |  | 22d | 2025-07-31 | 2025-09-01 |  |  |  | 2025-07-02 | 2025-09-01 | 0d |  |  | 604d |  |  |  | Helix | Service Management | 6.24 | Helix | Governance Approach and Feedback Cycle | Helix | No BL |  | 0.33 |  |  |  |  |
| 2131 | 1.6.1.3.1 | Service Management Go/No Go Decision | milestone | 0d | 2025-07-31 | 2025-07-31 | 2091, 2097, 2120, 2126 |  |  | 2025-07-31 | 2025-07-31 | 0d |  |  | 626d | 22d | start no earlier than 2025-07-31 |  | Helix | Service Management | 6.24 | Helix | Governance Approach and Feedback Cycle | Helix | Green | GREEN | 85.33 |  |  |  |  |
| 2132 | 1.6.1.3.2 | Helix Service Management Live | milestone | 0d | 2025-09-01 | 2025-09-01 | 2131 |  |  | 2025-09-01 | 2025-09-01 | 0d |  |  | 604d |  | start no earlier than 2025-09-01 |  | Helix | Service Management | 6.24 | Helix | Governance Approach and Feedback Cycle | Helix | Green | GREEN | 117.33 |  |  |  |  |
| 2133 | 1.7 | **S & A QUALIFICATION** |  | 843d? | 2023-11-07 A | 2027-01-28 |  | 61% | 327.65d? | 2023-11-07 | 2027-01-28 | 603d | 2024-01-29 | 2024-07-05 | 235d |  |  | -0 | N/A | S&A Qualification |  | N/A |  |  |  |  | -461.67 | N/A | Systems Integration Testing (SIT) |  |  |
| 2134 | 1.7.1 | **MHHS Qualification - Qualification Deliverables** |  | 509d | 2023-11-07 A | 2025-10-17 |  | 96% | 19.73d | 2023-11-07 | 2025-08-14 | 349d |  |  | 305d |  |  | -0 | N/A | S&A Qualification | 5.24 | N/A |  |  |  |  | -131.67 | N/A |  |  |  |
| 2135 | 1.7.1.1 | **BSC & REC Assessment Criteria** |  | 463d | 2023-11-07 A | 2025-08-14 A |  | 100% |  | 2023-11-07 | 2025-08-14 | 212d |  |  |  |  |  | -0 | N/A | S&A Qualification | 5.24 | N/A |  |  |  |  | -131.67 | N/A |  |  |  |
| 2136 | 1.7.1.1.1 | Draft BSC Assessment Criteria (Functional) |  | 21d | 2023-11-07 A | 2023-12-05 A |  | 100% |  | 2023-11-07 | 2023-12-05 | 21d |  |  |  |  | finish no earlier than 2023-12-05 |  | Code Bodies | S&A Qualification | 5.24 | Laura Kennedy |  |  | Complete | COMPLETE |  | Code Bodies |  |  |  |
| 2137 | 1.7.1.1.2 | BSC PAB Review |  | 1d | 2023-12-14 A | 2023-12-14 A |  | 100% |  | 2023-12-14 | 2023-12-14 | 1d |  |  |  |  | start no earlier than 2023-12-14 |  | Code Bodies | S&A Qualification | 5.24 | Laura Kennedy |  |  | Complete | COMPLETE |  | Code Bodies |  |  |  |
| 2138 | 1.7.1.1.3 | Update BSC Assessment Criteria (Functional, Non-Functional, Migration) |  | 30d | 2024-02-07 A | 2024-03-19 A |  | 100% |  | 2024-02-07 | 2024-03-19 | 30d |  |  |  |  | finish no earlier than 2024-03-19 |  | Code Bodies | S&A Qualification | 5.24 | Laura Kennedy |  |  | Complete | COMPLETE |  | Code Bodies |  |  |  |
| 2139 | 1.7.1.1.4 | REC & BSC PAB Approval |  | 3d | 2024-03-26 A | 2024-03-28 A |  | 100% |  | 2024-03-26 | 2024-03-28 | 3d |  |  |  |  | start no earlier than 2024-03-28 |  | Code Bodies | S&A Qualification | 5.24 | Laura Kennedy |  |  | Complete | COMPLETE |  | Code Bodies |  |  |  |
| 2140 | 1.7.1.1.5 | Update BSC Assessment Criteria (Functional, Non-Functional, Migration, Operational) |  | 20d | 2024-07-24 A | 2024-08-20 A |  | 100% |  | 2024-07-24 | 2024-08-20 | 20d |  |  |  |  |  |  | Code Bodies | S&A Qualification | 5.24 | Laura Kennedy |  |  | Complete | COMPLETE |  | Code Bodies |  |  |  |
| 2141 | 1.7.1.1.6 | Assessment Criteria (Functional, Non-Functional, Migration, Operational) Approved by REC PAB and BSC PAB |  | 250d | 2024-08-29 A | 2025-08-14 A | 2140FS+7d | 100% |  | 2024-08-29 | 2025-08-14 | 0d |  |  |  |  | start no earlier than 2023-09-15 |  | Code Bodies | S&A Qualification | 5.25 | Laura Kennedy |  | QAG | Complete | COMPLETE |  | Code Bodies |  | T3-QU-0080 | T3 |

| ID | WBS | Task | Type | Duration | Start | Finish | Predecessors | Complete | Remaining | Baseline start | Baseline finish | Baseline duration | Total slack | Constraint | Baseline cost | Responsible | Involved | Text9 | Task Status | Update Version | MHHS Resource Name | Sched Status | RAG | Milestone ID | Text29 | Tier |
| --- | --- | --- | --- | --- | --- | --- | --- | --- | --- | --- | --- | --- | --- | --- | --- | --- | --- | --- | --- | --- | --- | --- | --- | --- | --- | --- |
| 2142 | 1.7.1.2 | **Qualification Approach and Plan** |  | 194d | 2023-12-04 A | 2024-08-29 A |  | 100% |  | 2023-12-04 | 2024-08-29 | 194d |  |  | -0 | N/A | N/A | S&A Qualification | -131.67 | 5.24 | N/A |  |  |  |  |  |
| 2143 | 1.7.1.2.1 | **Qualification Approach and Plan v2** |  | 84d | 2023-12-04 A | 2024-03-28 A |  | 100% |  | 2023-12-04 | 2024-03-28 | 84d |  |  | -0 | N/A | N/A | S&A Qualification | -131.67 | 5.24 | N/A |  |  |  |  |  |
| 2144 | 1.7.1.2.1.1 | Draft Qualification Approach and Plan v2 |  | 30d | 2023-12-04 A | 2024-01-12 A |  | 100% |  | 2023-12-04 | 2024-01-12 | 30d |  | finish no earlier than 2024-01-12 |  | Code Bodies | Code Bodies | S&A Qualification |  | 5.24 | Laura Kennedy | Complete | COMPLETE |  |  |  |
| 2145 | 1.7.1.2.1.2 | Internal Review (Code Bodies and MHHSP) for Qualification Approach and Plan V2 |  | 10d | 2024-01-15 A | 2024-01-26 A | 2144 | 100% |  | 2024-01-15 | 2024-01-26 | 10d |  | finish no earlier than 2024-01-26 |  | Code Bodies, SI Team, SRO | Code Bodies, SI Team, SRO | S&A Qualification |  | 5.24 | Laura Kennedy | Complete | COMPLETE |  |  |  |
| 2146 | 1.7.1.2.1.3 | Industry consultation for Qualification Approach and Plan v2 |  | 11d | 2024-01-31 A | 2024-02-14 A | 2145 | 100% |  | 2024-01-31 | 2024-02-14 | 11d |  | start no earlier than 2024-01-31 |  | Participants | Participants | S&A Qualification |  | 5.24 | Laura Kennedy | Complete | COMPLETE |  |  |  |
| 2147 | 1.7.1.2.1.4 | Update Qualification Approach and Plan v2 post industry consultation |  | 10d | 2024-02-15 A | 2024-02-28 A | 2146 | 100% |  | 2024-02-15 | 2024-02-28 | 10d |  |  |  | Code Bodies | Code Bodies | S&A Qualification |  | 5.24 | Laura Kennedy | Complete | COMPLETE |  |  |  |
| 2148 | 1.7.1.2.1.5 | QWG Endorsement of Qualification Approach and Plan v2 |  | 1d | 2024-03-12 A | 2024-03-12 A |  | 100% |  | 2024-03-12 | 2024-03-12 | 1d |  | start no earlier than 2024-03-12 |  | Code Bodies | Code Bodies | S&A Qualification |  | 5.24 | Laura Kennedy | Complete | COMPLETE |  |  |  |
| 2149 | 1.7.1.2.1.6 | QAG Approval of Qualification Approach and Plan v2 |  | 1d | 2024-03-21 A | 2024-03-21 A |  | 100% |  | 2024-03-21 | 2024-03-21 | 1d |  | start no earlier than 2024-03-21 |  | Code Bodies | Code Bodies | S&A Qualification |  | 5.24 | Laura Kennedy | Complete | COMPLETE |  |  |  |
| 2150 | 1.7.1.2.1.7 | BSC and REC PAB Approval of Qualification Approach and Plan v2 |  | 3d | 2024-03-26 A | 2024-03-28 A |  | 100% |  | 2024-03-26 | 2024-03-28 | 3d |  | finish no earlier than 2024-03-28 |  | Code Bodies | Code Bodies | S&A Qualification |  | 5.24 | Laura Kennedy | Complete | COMPLETE |  |  |  |
| 2151 | 1.7.1.2.1.8 | Functional Testing elements of Qualification Approach & Plan v2 approvement by REC PAB and BSC PAB | milestone | 0d | 2024-03-28 A | 2024-03-28 A | 2150 | 100% |  | 2024-03-28 | 2024-03-28 | 0d |  |  |  | Code Bodies | Code Bodies | S&A Qualification |  | 5.24 | Laura Kennedy | Complete | COMPLETE | T3-QU-0063 | QAG | T3 |
| 2152 | 1.7.1.2.1.9 | Migration Testing elements of Qualification Approach & Plan v2 appoved by REC PAB and BSC PAB | milestone | 0d | 2024-03-28 A | 2024-03-28 A | 2150 | 100% |  | 2024-03-28 | 2024-03-28 | 0d |  |  |  | Code Bodies | Code Bodies | S&A Qualification |  | 5.24 | Laura Kennedy | Complete | COMPLETE | T3-QU-0064 | QAG | T3 |
| 2153 | 1.7.1.2.2 | **Qualification Approach and Plan v3** |  | 84d | 2024-05-06 A | 2024-08-29 A |  | 100% |  | 2024-05-06 | 2024-08-29 | 84d |  |  | -0 | N/A | N/A | S&A Qualification | -133.67 | 5.24 | N/A |  |  |  |  |  |
| 2154 | 1.7.1.2.2.1 | Draft Qualification Approach and Plan v3 |  | 35d | 2024-05-06 A | 2024-06-21 A | 1106 | 100% |  | 2024-05-06 | 2024-06-21 | 35d |  | finish no earlier than 2024-05-17 |  | Code Bodies | Code Bodies | S&A Qualification |  | 5.27 | Laura Kennedy | Complete | COMPLETE |  |  |  |
| 2155 | 1.7.1.2.2.2 | Internal Review (Code Bodies and MHHSP) of Qualification Approach and Plan v3 |  | 10d | 2024-06-24 A | 2024-07-05 A | 2154 | 100% |  | 2024-06-24 | 2024-07-05 | 10d |  |  |  | Code Bodies, SI Team, SRO | Code Bodies, SI Team, SRO | S&A Qualification |  | 5.27 | Laura Kennedy | Complete | COMPLETE |  |  |  |
| 2156 | 1.7.1.2.2.3 | Industry consultation for Qualification Approach and Plan v3 |  | 10d | 2024-07-08 A | 2024-07-19 A | 2155 | 100% |  | 2024-07-08 | 2024-07-19 | 10d |  |  |  | Participants | Participants | S&A Qualification |  | 5.27 | Laura Kennedy | Complete | COMPLETE |  |  |  |
| 2157 | 1.7.1.2.2.4 | Update Qualification Approach and Plan v3 Post-Consultation |  | 10d | 2024-07-22 A | 2024-08-02 A | 2156 | 100% |  | 2024-07-22 | 2024-08-02 | 10d |  |  |  | Code Bodies | Code Bodies | S&A Qualification |  | 5.27 | Laura Kennedy | Complete | COMPLETE |  |  |  |
| 2158 | 1.7.1.2.2.5 | QWG Endorsement of Qualification Approach and Plan v3 |  | 1d | 2024-08-13 A | 2024-08-13 A | 2157FS+6d | 100% |  | 2024-08-13 | 2024-08-13 | 1d |  |  |  | Code Bodies | Code Bodies | S&A Qualification |  | 5.27 | Laura Kennedy | Complete | COMPLETE |  |  |  |
| 2159 | 1.7.1.2.2.6 | QAG Approval of Qualification Approach and Plan v3 | milestone | 0d | 2024-08-22 A | 2024-08-22 A | 2158FS+7d | 100% |  | 2024-08-22 | 2024-08-22 | 0d |  |  |  | Code Bodies | Code Bodies | S&A Qualification |  | 5.27 | Laura Kennedy | Complete | COMPLETE | T3-QU-0081 | QAG | T3 |
| 2160 | 1.7.1.2.2.7 | BSC and REC PAB Approval of Qualification Approach and Plan v3 |  | 3d | 2024-08-27 A | 2024-08-29 A | 2159FS+2d | 100% |  | 2024-08-27 | 2024-08-29 | 3d |  |  |  | Code Bodies | Code Bodies | S&A Qualification |  | 5.27 | Laura Kennedy | Complete | COMPLETE |  |  |  |
| 2161 | 1.7.1.2.2.8 | Non-Functional Testing elements of Qualification Approach and Plan v3 approved by REC PAB and BSC PAB | milestone | 0d | 2024-08-29 A | 2024-08-29 A | 2160 | 100% |  | 2024-08-29 | 2024-08-29 | 0d |  |  |  | Code Bodies | Code Bodies | S&A Qualification |  | 5.27 | Laura Kennedy | Complete | COMPLETE | T3-QU-0065 | QAG | T3 |
| 2162 | 1.7.1.3 | **Qualification Assessment Document** |  | 476d | 2023-12-22 A | 2025-10-17 |  | 90% | 45.48d | 2023-12-22 | 2025-03-07 | 316d | 305d |  | -0 | N/A | N/A | S&A Qualification | -131.67 | 5.24 | N/A |  |  |  |  |  |
| 2163 | 1.7.1.3.1 | **Qualification Assessment Document v1** |  | 70d | 2023-12-22 A | 2024-03-28 A |  | 100% |  | 2023-12-22 | 2024-03-28 | 70d |  |  | -0 | N/A | N/A | S&A Qualification | -131.67 | 5.24 | N/A |  |  |  |  |  |
| 2164 | 1.7.1.3.1.1 | Draft Qualification Assessment Document v1 |  | 30d | 2023-12-22 A | 2024-02-01 A |  | 100% |  | 2023-12-22 | 2024-02-01 | 30d |  | finish no earlier than 2024-02-01 |  | Code Bodies | Code Bodies | S&A Qualification |  | 5.24 | Laura Kennedy | Complete | COMPLETE |  |  |  |
| 2165 | 1.7.1.3.1.2 | Internal Review (Code Bodies and MHHSP) of Qualification Assessment Document v1 |  | 10d | 2024-02-01 A | 2024-02-14 A |  | 100% |  | 2024-02-01 | 2024-02-14 | 10d |  | finish no earlier than 2024-02-14 |  | Code Bodies, SI Team, SRO | Code Bodies, SI Team, SRO | S&A Qualification |  | 5.24 | Laura Kennedy | Complete | COMPLETE |  |  |  |
| 2166 | 1.7.1.3.1.3 | Industry consultation for Qualification Assessment Document v1 |  | 11d | 2024-02-16 A | 2024-03-01 A |  | 100% |  | 2024-02-16 | 2024-03-01 | 11d |  | start no earlier than 2024-02-16 |  | Participants | Participants | S&A Qualification |  | 5.24 | Laura Kennedy | Complete | COMPLETE |  |  |  |
| 2167 | 1.7.1.3.1.4 | Update Post-Consultation for Qualification Assessment Document v1 |  | 10d | 2024-03-04 A | 2024-03-15 A | 2166 | 100% |  | 2024-03-04 | 2024-03-15 | 10d |  |  |  | Code Bodies | Code Bodies | S&A Qualification |  | 5.24 | Laura Kennedy | Complete | COMPLETE |  |  |  |
| 2168 | 1.7.1.3.1.5 | BSC and REC PAB Approval of Qualification Assessment Document v1 |  | 3d | 2024-03-26 A | 2024-03-28 A |  | 100% |  | 2024-03-26 | 2024-03-28 | 3d |  | start no earlier than 2024-03-26 |  | Code Bodies | Code Bodies | S&A Qualification |  | 5.24 | Laura Kennedy | Complete | COMPLETE |  |  |  |
| 2169 | 1.7.1.3.1.6 | Qualification Assessment Document v1 approved by REC PAB and BSC PAB | milestone | 0d | 2024-03-28 A | 2024-03-28 A | 2168 | 100% |  | 2024-03-28 | 2024-03-28 | 0d |  |  |  | Code Bodies | Code Bodies | S&A Qualification |  | 5.24 | Laura Kennedy | Complete | COMPLETE | T3-QU-0066 | QAG | T3 |

| ID | WBS | Task | Type | Duration | Start | Finish | Predecessors | Complete | Remaining | Baseline start | Baseline finish | Baseline duration | Total slack | Free slack | Constraint | Baseline cost | Responsible | Involved | Text9 | Task Status | Update Version | MHHS Resource Name | Sched Status | RAG | Milestone ID | Text29 | Tier |
| --- | --- | --- | --- | --- | --- | --- | --- | --- | --- | --- | --- | --- | --- | --- | --- | --- | --- | --- | --- | --- | --- | --- | --- | --- | --- | --- | --- |
| 2170 | 1.7.1.3.2 | **Qualification Assessment Document v3** |  | 110d | 2024-03-29 A | 2024-08-29 A |  | 100% |  | 2024-03-29 | 2024-08-29 | 110d |  |  |  | -0 | N/A | N/A | S&A Qualification | -131.67 | 5.24 | N/A |  |  |  |  |  |
| 2171 | 1.7.1.3.2.1 | Draft Qualification Assessment Document V1.1 |  | 26d | 2024-03-29 A | 2024-05-03 A | 2169 | 100% |  | 2024-03-29 | 2024-05-03 | 26d |  |  |  |  | Code Bodies |  | S&A Qualification |  | 5.24 | Laura Kennedy | Complete | COMPLETE |  |  |  |
| 2172 | 1.7.1.3.2.2 | Industry Consultation for Qualification Assessment Document V1.1 |  | 12d | 2024-05-06 A | 2024-05-21 A | 2171 | 100% |  | 2024-05-06 | 2024-05-21 | 12d |  |  |  |  | Participants |  | S&A Qualification |  | 5.24 | Laura Kennedy | Complete | COMPLETE |  |  |  |
| 2173 | 1.7.1.3.2.3 | Draft Qualification Assessment Document v3 |  | 6d | 2024-06-14 A | 2024-06-21 A | 1214, 2172 | 100% |  | 2024-06-14 | 2024-06-21 | 6d |  |  |  |  | Code Bodies | Code Bodies | S&A Qualification |  | 5.24 | Laura Kennedy | Complete | COMPLETE |  |  |  |
| 2174 | 1.7.1.3.2.4 | Internal Review (Code Bodies and MHHSP) of Qualification Assessment Document v3 |  | 10d | 2024-06-24 A | 2024-07-05 A | 2173 | 100% |  | 2024-06-24 | 2024-07-05 | 10d |  |  |  |  | Code Bodies, SI Team, SRO | Code Bodies, SI Team, SRO | S&A Qualification |  | 5.24 | Laura Kennedy | Complete | COMPLETE |  |  |  |
| 2175 | 1.7.1.3.2.5 | Industry consultation for Qualification Assessment Document v3 |  | 10d | 2024-07-08 A | 2024-07-19 A | 2174 | 100% |  | 2024-07-08 | 2024-07-19 | 10d |  |  |  |  | Participants | Participants | S&A Qualification |  | 5.24 | Laura Kennedy | Complete | COMPLETE |  |  |  |
| 2176 | 1.7.1.3.2.6 | Update Post-Consultation for Qualification Assessment Document v3 |  | 10d | 2024-07-22 A | 2024-08-02 A | 2175 | 100% |  | 2024-07-22 | 2024-08-02 | 10d |  |  |  |  | Code Bodies | Code Bodies | S&A Qualification |  | 5.24 | Laura Kennedy | Complete | COMPLETE |  |  |  |
| 2177 | 1.7.1.3.2.7 | QWG Endorsement of Qualification Assessment Document v3 |  | 1d | 2024-08-13 A | 2024-08-13 A | 2176FS+6d | 100% |  | 2024-08-13 | 2024-08-13 | 1d |  |  |  |  | Code Bodies | Code Bodies | S&A Qualification |  | 5.24 | Laura Kennedy | Complete | COMPLETE |  |  |  |
| 2178 | 1.7.1.3.2.8 | QAG Endorsement of Qualification Assessment Document v3 |  | 1d | 2024-08-22 A | 2024-08-22 A | 2177FS+6d | 100% |  | 2024-08-22 | 2024-08-22 | 1d |  |  |  |  | Code Bodies | Code Bodies | S&A Qualification |  | 5.25 | Laura Kennedy | Complete | COMPLETE | T3-QU-0083 | QAG | T3 |
| 2179 | 1.7.1.3.2.9 | BSC and REC PAB Approval of Qualification Assessment Document v3 |  | 3d | 2024-08-27 A | 2024-08-29 A | 2178FS+2d | 100% |  | 2024-08-27 | 2024-08-29 | 3d |  |  |  |  | Code Bodies | Code Bodies | S&A Qualification |  | 5.24 | Laura Kennedy | Complete | COMPLETE |  |  |  |
| 2180 | 1.7.1.3.2.10 | Qualification Assessment Document v3 approved by REC PAB and BSC PAB | milestone | 0d | 2024-08-29 A | 2024-08-29 A | 2179 | 100% |  | 2024-08-29 | 2024-08-29 | 0d |  |  |  |  | Code Bodies | Code Bodies | S&A Qualification |  | 5.24 | Laura Kennedy | Complete | COMPLETE | T3-QU-0067 | QAG | T3 |
| 2181 | 1.7.1.3.3 | **Qualification Assessment Document Portal** |  | 445d | 2024-02-05 A | 2025-10-17 |  | 82% | 78.07d | 2024-02-05 | 2025-03-07 | 285d | 305d |  |  | -0 | N/A | N/A | S&A Qualification | -131.67 | 5.24 | N/A |  |  |  |  |  |
| 2182 | 1.7.1.3.3.1 | Design Completion |  | 30d | 2024-02-05 A | 2024-03-15 A |  | 100% |  | 2024-02-05 | 2024-03-15 | 30d |  |  | finish no earlier than 2024-03-15 |  | QAD Portal Dev Team | QAD Portal Dev Team | S&A Qualification |  | 5.24 | Laura Kennedy | Complete | COMPLETE |  |  |  |
| 2183 | 1.7.1.3.3.2 | Qualification Assessment Document Portal Build |  | 30d | 2024-03-18 A | 2024-04-26 A | 2182 | 100% |  | 2024-03-18 | 2024-04-26 | 30d |  |  |  |  | QAD Portal Dev Team | QAD Portal Dev Team | S&A Qualification |  | 5.24 | Laura Kennedy | Complete | COMPLETE |  |  |  |
| 2184 | 1.7.1.3.3.3 | Qualification Assessment Document Internal Testing |  | 20d | 2024-04-29 A | 2024-05-24 A | 2183 | 100% |  | 2024-04-29 | 2024-05-24 | 20d |  |  |  |  | QAD Portal Dev Team. Code Bodies | QAD Portal Dev Team. Code Bodies | S&A Qualification |  | 5.24 | Laura Kennedy | Complete | COMPLETE |  |  |  |
| 2185 | 1.7.1.3.3.4 | Qualification Assessment Document Portal Training and Onboarding Material Creation |  | 20d | 2024-05-27 A | 2024-06-21 A | 2184 | 100% |  | 2024-05-27 | 2024-06-21 | 20d |  |  |  |  | QAD Portal Dev Team | QAD Portal Dev Team | S&A Qualification |  | 5.24 | Laura Kennedy | Complete | COMPLETE |  |  |  |
| 2186 | 1.7.1.3.3.5 | Qualification Assessment Document Portal Webinar (Date TBC) |  | 1d | 2024-06-18 A | 2024-06-18 A |  | 100% |  | 2024-06-18 | 2024-06-18 | 1d |  |  | start no earlier than 2024-06-18 |  | QAD Portal Dev Team | QAD Portal Dev Team | S&A Qualification |  | 5.24 | Laura Kennedy | Complete | COMPLETE |  |  |  |
| 2187 | 1.7.1.3.3.6 | SIT Participant QAD Application Creation in Portal |  | 10d | 2024-12-09 A | 2024-12-20 A | 2185FS+120d | 100% |  | 2024-12-09 | 2024-12-20 | 10d |  |  |  |  | Code Bodies | Code Bodies | S&A Qualification |  | 5.24 | Laura Kennedy | Complete | COMPLETE |  |  |  |
| 2188 | 1.7.1.3.3.7 | Non-SIT LDSO Participant QAD Application Creation in Portal |  | 10d | 2024-12-09 A | 2024-12-20 A | 2185FS+120d | 100% |  | 2024-12-09 | 2024-12-20 | 10d |  |  |  |  | Code Bodies | Code Bodies | S&A Qualification |  | 5.24 | Laura Kennedy | Complete | COMPLETE |  |  |  |
| 2189 | 1.7.1.3.3.8 | QT Wave 1 Participant QAD Application Creation in Portal |  | 10d | 2025-04-21 A | 2025-05-02 A | 2185FS+215d | 100% |  | 2025-04-21 | 2025-05-02 | 10d |  |  |  |  | Code Bodies | Code Bodies | S&A Qualification |  | 6.1 | Laura Kennedy | Complete | COMPLETE |  |  |  |
| 2190 | 1.7.1.3.3.9 | QT Wave 2 Participant QAD Application Creation in Portal |  | 10d | 2025-05-26 | 2025-06-06 | 2185FS+240d |  |  | 2025-05-26 | 2025-06-06 | 10d | 386d | 0d |  |  | Code Bodies | Code Bodies | S&A Qualification | 19.33 | 6.1 | Laura Kennedy | Green | GREEN |  |  |  |
| 2191 | 1.7.1.3.3.10 | QT Wave 3 Participant QAD Application Creation in Portal |  | 10d | 2025-07-28 | 2025-08-08 | 2185FS+285d |  |  | 2025-07-28 | 2025-08-08 | 10d | 355d | 0d |  |  | Code Bodies | Code Bodies | S&A Qualification | 82.33 | 6.1 | Laura Kennedy | Green | GREEN |  |  |  |
| 2192 | 1.7.1.3.3.11 | QT Wave 4 Participant QAD Application Creation in Portal |  | 10d | 2025-10-06 | 2025-10-17 | 2185FS+335d |  |  | 2025-10-06 | 2025-10-17 | 10d | 235d | 0d |  |  | Code Bodies | Code Bodies | S&A Qualification | 152.33 | 6.1 | Laura Kennedy | Green | GREEN |  |  |  |
| 2193 | 1.7.1.3.3.12 | Update to Qualification Assessment Document Portal post QAD V3 |  | 10d | 2024-08-30 A | 2024-09-12 A | 2180 | 100% |  | 2024-08-30 | 2024-09-12 | 10d |  |  |  |  | QAD Portal Dev Team | QAD Portal Dev Team | S&A Qualification |  | 6.1 | Laura Kennedy | Complete | COMPLETE |  |  |  |
| 2194 | 1.7.1.3.3.13 | Update to Qualification Assessment Document Portal post QAD V3 Complete | milestone | 0d | 2024-09-12 A | 2024-09-12 A | 2193 | 100% |  | 2024-09-12 | 2024-09-12 | 0d |  |  |  |  | QAD Portal Dev Team | QAD Portal Dev Team | S&A Qualification |  | 6.1 | Laura Kennedy | Complete | COMPLETE | T3-QU-0084 | QAG | T3 |

| ID | WBS | Task | Type | Duration | Start | Finish | Predecessors | Complete | Remaining | Baseline start | Baseline finish | Baseline duration | Baseline 1 start | Baseline 1 finish | Total slack | Free slack | Constraint | Baseline cost | Responsible | Involved | Text9 | Task Status | Update Version | MHHS Resource Name | MHHS Programme Phase | Sched Status | RAG | Text29 | Tier | Milestone ID |
| --- | --- | --- | --- | --- | --- | --- | --- | --- | --- | --- | --- | --- | --- | --- | --- | --- | --- | --- | --- | --- | --- | --- | --- | --- | --- | --- | --- | --- | --- | --- |
| 2195 | 1.7.2 | **MHHS Qualification - SIT Participants** |  | 248d? | 2025-01-06 A | 2025-12-17 |  | 25% | 186.85d? | 2025-01-06 | 2025-12-22 | 194d | 2024-01-29 | 2024-07-05 | 526d |  |  | -0 | N/A | N/A | S&A Qualification | -133.67 | 6.11 | N/A | Systems Integration Testing (SIT) |  |  |  |  |  |
| 2196 | 1.7.2.1 | Initial QAD Submission Window opens | milestone | 0d | 2025-01-06 A | 2025-01-06 A | 2187FS+10d | 100% |  | 2025-01-06 | 2025-01-06 | 0d |  |  |  |  | start no earlier than 2025-01-06 |  | Participants | Participants | S&A Qualification |  | 6.11 | Laura Kennedy |  | Complete | COMPLETE |  |  |  |
| 2197 | 1.7.2.2 | SIT Participants submit Initial QAD |  | 30d | 2025-01-06 A | 2025-02-14 A |  | 100% |  | 2025-01-06 | 2025-02-14 | 29d |  |  |  |  | start no earlier than 2025-01-06 |  | Participants | Participants | S&A Qualification |  | 6.11 | Laura Kennedy |  | Complete | COMPLETE |  |  |  |
| 2198 | 1.7.2.3 | Code Bodies review Initial QAD |  | 36d | 2025-02-14 A | 2025-04-04 A | 2197FS-1d | 100% |  | 2025-02-14 | 2025-04-04 | 36d |  |  |  |  |  |  | Code Bodies | Code Bodies | S&A Qualification |  | 6.11 | Laura Kennedy |  | Complete | COMPLETE |  |  |  |
| 2199 | 1.7.2.4 | Completion of Code Bodies review of Initial QAD | milestone | 0d | 2025-04-04 A | 2025-04-04 A | 2198 | 100% |  | 2025-04-04 | 2025-04-04 | 0d |  |  |  |  |  |  | Code Bodies | Code Bodies | S&A Qualification |  | 6.11 | Laura Kennedy |  | Complete | COMPLETE |  |  |  |
| 2200 | 1.7.2.5 | **MHHS Qualification - M10-Ready** |  | 113d | 2025-04-07 A | 2025-09-10 |  | 13% | 97.97d | 2025-04-07 | 2025-09-11 | 64d |  |  | 596d |  |  |  | N/A | N/A | S&A Qualification | -154.67 | 6.24 | N/A |  |  |  |  |  |  |
| 2201 | 1.7.2.5.1 | Final QAD Submission Window opens | milestone | 0d | 2025-04-07 A | 2025-04-07 A | 2198, 2194, 2199FS+1d | 100% |  | 2025-04-07 | 2025-04-07 | 0d |  |  |  |  |  |  | Participants | Participants | S&A Qualification |  | 6.24 | Laura Kennedy |  | Complete | COMPLETE |  |  |  |
| 2202 | 1.7.2.5.2 | SIT MVC Participants submit Final QAD (exc Test Reports) |  | 25d | 2025-04-07 A | 2025-05-09 | 2201FS-1d | 25% | 18.75d | 2025-04-07 | 2025-05-09 | 26d |  |  | 60d | 0d |  |  | Participants | Participants | S&A Qualification |  | 6.24 | Laura Kennedy |  | Green | GREEN |  |  |  |
| 2203 | 1.7.2.5.3 | Completion of Code Bodies review of Final QAD (M10-Ready) |  | 20d | 2025-05-12 | 2025-06-06 | 2202 |  |  | 2025-05-12 | 2025-06-06 | 19d |  |  | 60d | 32d |  |  | Code Bodies | Code Bodies | S&A Qualification | 5.33 | 6.24 | Laura Kennedy |  | Green | GREEN |  |  |  |
| 2204 | 1.7.2.5.4 | **SIT / LDSO Pathway 1** |  | 16d | 2025-07-23 | 2025-08-13 |  |  |  |  |  |  |  |  | 616d |  |  |  |  |  | S&A Qualification | -918.67 | 6.24 | Laura Kennedy |  | Overdue Start |  |  |  |  |
| 2205 | 1.7.2.5.4.1 | QAD Sign Off Deadline + Test Reports | milestone | 0d | 2025-07-23 | 2025-07-23 | 2203, 1692FF |  |  |  |  |  |  |  | 616d | 0d | start no earlier than 2025-07-23 |  | Participants | Participants | S&A Qualification | 77.33 | 6.24 | Laura Kennedy |  | No BL | GREEN |  |  |  |
| 2206 | 1.7.2.5.4.2 | REC Code Manager / BSC PAB Approval of Qualification | milestone | 0d | 2025-08-13 | 2025-08-13 | 2205FS+16d |  |  |  |  |  |  |  | 616d |  |  |  | Code Bodies | Code Bodies | S&A Qualification | 98.71 | 6.24 | Laura Kennedy |  | No BL | GREEN | QAG | T3 |  |
| 2207 | 1.7.2.5.5 | **SIT / LDSO Pathway 2** |  | 16d | 2025-08-07 | 2025-08-28 |  |  |  |  |  |  |  |  | 605d |  |  |  |  |  | S&A Qualification | -918.67 | 6.24 | Laura Kennedy |  | Overdue Start |  |  |  |  |
| 2208 | 1.7.2.5.5.1 | QAD Sign Off Deadline + Test Reports | milestone | 0d | 2025-08-07 | 2025-08-07 | 2203, 1692FF |  |  |  |  |  |  |  | 605d | 0d | start no earlier than 2025-08-07 |  | Participants |  | S&A Qualification | 92.33 | 6.24 | Laura Kennedy |  | No BL | GREEN |  |  |  |
| 2209 | 1.7.2.5.5.2 | REC Code Manager / BSC PAB Approval of Qualification (M10-Ready) | milestone | 0d | 2025-08-28 | 2025-08-28 | 2208FS+16d |  |  |  |  |  |  |  | 605d |  |  |  | Code Bodies |  | S&A Qualification | 113.71 | 6.24 | Laura Kennedy |  | No BL | GREEN |  |  |  |
| 2210 | 1.7.2.5.6 | **SIT / LDSO Pathway 3** |  | 13d | 2025-08-22 | 2025-09-10 |  |  |  |  |  |  |  |  | 5d |  |  |  |  |  | S&A Qualification | -918.67 | 6.24 | Laura Kennedy |  | Overdue Start |  |  |  |  |
| 2211 | 1.7.2.5.6.1 | QAD Sign Off Deadline + Test Reports | milestone | 0d | 2025-08-22 | 2025-08-22 | 2203, 1763, 1692FF |  |  |  |  |  |  |  | 5d | 0d |  |  | Participants |  | S&A Qualification | 107.71 | 6.24 | Laura Kennedy |  | No BL | GREEN |  |  |  |
| 2212 | 1.7.2.5.6.2 | REC Code Manager / BSC PAB Approval of Qualification (M10-Ready) |  | 2d | 2025-09-09 | 2025-09-10 | 2211FS+11d |  |  |  |  |  |  |  | 5d | 0d |  |  | Code Bodies |  | S&A Qualification | 125.33 | 6.24 | Laura Kennedy |  | No BL | GREEN |  |  |  |
| 2213 | 1.7.2.5.6.3 | 'M10-Ready SIT Participants are qualified' | milestone | 0d | 2025-09-10 | 2025-09-10 | 2212 |  |  |  |  |  |  |  | 596d |  |  |  | Code Bodies |  | S&A Qualification | 126.71 | 6.24 | Laura Kennedy |  | No BL | GREEN |  |  | T3-QU-0085 |
| 2214 | 1.7.2.6 | **MHHS Qualification - M11-Ready** |  | 137d? | 2025-04-07 A | 2025-10-15 |  |  | 137d? |  |  |  |  |  | 571d |  |  |  |  |  | S&A Qualification | -918.67 | 6.24 | Laura Kennedy |  | Overdue Start |  |  |  |  |
| 2215 | 1.7.2.6.1 | Final QAD Submission Window opens | milestone | 0d | 2025-04-07 A | 2025-04-07 A | 2198, 2194, 2199FS+1d | 100% |  |  |  |  |  |  |  |  |  |  | Participants |  | S&A Qualification |  | 6.24 | Laura Kennedy |  | Complete | COMPLETE |  |  |  |
| 2216 | 1.7.2.6.2 | SIT MVC Participants submit Final QAD (exc Test Reports) |  | 44d | 2025-04-08 | 2025-06-06 | 2215 |  |  |  |  |  |  |  | 628d | 0d |  |  | Participants |  | S&A Qualification | -28.67 | 6.24 | Laura Kennedy |  | Overdue Start | GREEN |  |  |  |
| 2217 | 1.7.2.6.3 | Completion of Code Bodies review of Final QAD (M11-Ready) |  | 20d? | 2025-06-09 | 2025-07-04 | 2216 |  |  |  |  |  |  |  | 628d | 43d |  |  | Code Bodies |  | S&A Qualification | 33.33 | 6.24 | Laura Kennedy |  | No BL | GREEN |  |  |  |
| 2218 | 1.7.2.6.4 | **SIT Pathway 4** |  | 16d | 2025-09-04 | 2025-09-25 |  |  |  |  |  |  |  |  | 585d |  |  |  |  |  | S&A Qualification | -918.67 | 6.24 | Laura Kennedy |  | Overdue Start |  |  |  |  |
| 2219 | 1.7.2.6.4.1 | QAD Sign Off Deadline + Test Reports | milestone | 0d | 2025-09-04 | 2025-09-04 | 2217, 1692FF |  |  |  |  |  |  |  | 585d | 0d | start no earlier than 2025-09-04 |  | Participants |  | S&A Qualification | 120.33 | 6.24 | Laura Kennedy |  | No BL | GREEN |  |  |  |
| 2220 | 1.7.2.6.4.2 | REC Code Manager / BSC PAB Approval of Qualification (M11-Ready) | milestone | 0d | 2025-09-25 | 2025-09-25 | 2219FS+16d |  |  |  |  |  |  |  | 585d |  |  |  | Code Bodies |  | S&A Qualification | 141.71 | 6.24 | Laura Kennedy |  | No BL | GREEN |  |  |  |

Notes:
- 2200: 07/05/25 - As per presentations given to GLIG, QAG & SITAG, Code Bodies and the Programme have developed a proposal to replace MVC/Non-MVC with 'M10-Ready', 'M11-Ready' and 'Not M11-Ready'. Therefore, the MHHS Qualification section has been updated to reflect the pathways that 'M10-Ready', 'M11-Ready' and 'Not M11-Ready' Participants will take to Qualification. This is due for final approval from QAG/SITAG in May, but has been included to support 'M10-Ready', 'M11-Ready' and 'Not M11-Ready' Participants planning.
- 2201: 07/05/25 - As per presentations given to GLIG, QAG & SITAG, Code Bodies and the Programme have developed a proposal to replace MVC/Non-MVC with 'M10-Ready', 'M11-Ready' and 'Not M11-Ready'. Therefore, the MHHS Qualification section has been updated to reflect the pathways that 'M10-Ready', 'M11-Ready' and 'Not M11-Ready' Participants will take to Qualification. This is due for final approval from QAG/SITAG in May, but has been included to support 'M10-Ready', 'M11-Ready' and 'Not M11-Ready' Participants planning.
- 2202: 07/05/25 - As per presentations given to GLIG, QAG & SITAG, Code Bodies and the Programme have developed a proposal to replace MVC/Non-MVC with 'M10-Ready', 'M11-Ready' and 'Not M11-Ready'. Therefore, the MHHS Qualification section has been updated to reflect the pathways that 'M10-Ready', 'M11-Ready' and 'Not M11-Ready' Participants will take to Qualification. This is due for final approval from QAG/SITAG in May, but has been included to support 'M10-Ready', 'M11-Ready' and 'Not M11-Ready' Participants planning.
- 2203: 07/05/25 - As per presentations given to GLIG, QAG & SITAG, Code Bodies and the Programme have developed a proposal to replace MVC/Non-MVC with 'M10-Ready', 'M11-Ready' and 'Not M11-Ready'. Therefore, the MHHS Qualification section has been updated to reflect the pathways that 'M10-Ready', 'M11-Ready' and 'Not M11-Ready' Participants will take to Qualification. This is due for final approval from QAG/SITAG in May, but has been included to support 'M10-Ready', 'M11-Ready' and 'Not M11-Ready' Participants planning.
- 2204: 07/05/25 - As per presentations given to GLIG, QAG & SITAG, Code Bodies and the Programme have developed a proposal to replace MVC/Non-MVC with 'M10-Ready', 'M11-Ready' and 'Not M11-Ready'. Therefore, the MHHS Qualification section has been updated to reflect the pathways that 'M10-Ready', 'M11-Ready' and 'Not M11-Ready' Participants will take to Qualification. This is due for final approval from QAG/SITAG in May, but has been included to support 'M10-Ready', 'M11-Ready' and 'Not M11-Ready' Participants planning.
- 2205: 07/05/25 - As per presentations given to GLIG, QAG & SITAG, Code Bodies and the Programme have developed a proposal to replace MVC/Non-MVC with 'M10-Ready', 'M11-Ready' and 'Not M11-Ready'. Therefore, the MHHS Qualification section has been updated to reflect the pathways that 'M10-Ready', 'M11-Ready' and 'Not M11-Ready' Participants will take to Qualification. This is due for final approval from QAG/SITAG in May, but has been included to support 'M10-Ready', 'M11-Ready' and 'Not M11-Ready' Participants planning.
- 2206: 07/05/25 - As per presentations given to GLIG, QAG & SITAG, Code Bodies and the Programme have developed a proposal to replace MVC/Non-MVC with 'M10-Ready', 'M11-Ready' and 'Not M11-Ready'. Therefore, the MHHS Qualification section has been updated to reflect the pathways that 'M10-Ready', 'M11-Ready' and 'Not M11-Ready' Participants will take to Qualification. This is due for final approval from QAG/SITAG in May, but has been included to support 'M10-Ready', 'M11-Ready' and 'Not M11-Ready' Participants planning.
- 2207: 07/05/25 - As per presentations given to GLIG, QAG & SITAG, Code Bodies and the Programme have developed a proposal to replace MVC/Non-MVC with 'M10-Ready', 'M11-Ready' and 'Not M11-Ready'. Therefore, the MHHS Qualification section has been updated to reflect the pathways that 'M10-Ready', 'M11-Ready' and 'Not M11-Ready' Participants will take to Qualification. This is due for final approval from QAG/SITAG in May, but has been included to support 'M10-Ready', 'M11-Ready' and 'Not M11-Ready' Participants planning.
- 2208: 07/05/25 - As per presentations given to GLIG, QAG & SITAG, Code Bodies and the Programme have developed a proposal to replace MVC/Non-MVC with 'M10-Ready', 'M11-Ready' and 'Not M11-Ready'. Therefore, the MHHS Qualification section has been updated to reflect the pathways that 'M10-Ready', 'M11-Ready' and 'Not M11-Ready' Participants will take to Qualification. This is due for final approval from QAG/SITAG in May, but has been included to support 'M10-Ready', 'M11-Ready' and 'Not M11-Ready' Participants planning.
- 2209: 07/05/25 - As per presentations given to GLIG, QAG & SITAG, Code Bodies and the Programme have developed a proposal to replace MVC/Non-MVC with 'M10-Ready', 'M11-Ready' and 'Not M11-Ready'. Therefore, the MHHS Qualification section has been updated to reflect the pathways that 'M10-Ready', 'M11-Ready' and 'Not M11-Ready' Participants will take to Qualification. This is due for final approval from QAG/SITAG in May, but has been included to support 'M10-Ready', 'M11-Ready' and 'Not M11-Ready' Participants planning.
- 2210: 07/05/25 - As per presentations given to GLIG, QAG & SITAG, Code Bodies and the Programme have developed a proposal to replace MVC/Non-MVC with 'M10-Ready', 'M11-Ready' and 'Not M11-Ready'. Therefore, the MHHS Qualification section has been updated to reflect the pathways that 'M10-Ready', 'M11-Ready' and 'Not M11-Ready' Participants will take to Qualification. This is due for final approval from QAG/SITAG in May, but has been included to support 'M10-Ready', 'M11-Ready' and 'Not M11-Ready' Participants planning.
- 2211: 07/05/25 - As per presentations given to GLIG, QAG & SITAG, Code Bodies and the Programme have developed a proposal to replace MVC/Non-MVC with 'M10-Ready', 'M11-Ready' and 'Not M11-Ready'. Therefore, the MHHS Qualification section has been updated to reflect the pathways that 'M10-Ready', 'M11-Ready' and 'Not M11-Ready' Participants will take to Qualification. This is due for final approval from QAG/SITAG in May, but has been included to support 'M10-Ready', 'M11-Ready' and 'Not M11-Ready' Participants planning.
- 2212: 07/05/25 - As per presentations given to GLIG, QAG & SITAG, Code Bodies and the Programme have developed a proposal to replace MVC/Non-MVC with 'M10-Ready', 'M11-Ready' and 'Not M11-Ready'. Therefore, the MHHS Qualification section has been updated to reflect the pathways that 'M10-Ready', 'M11-Ready' and 'Not M11-Ready' Participants will take to Qualification. This is due for final approval from QAG/SITAG in May, but has been included to support 'M10-Ready', 'M11-Ready' and 'Not M11-Ready' Participants planning.
- 2213: 07/05/25 - Programme and Code Bodies will be asking QAG to approve this milestone being renamed, as part of efforts to replace MVC / Non-MVC with 'M10-Ready', 'M11-Ready' and 'Not M11-Ready'.
- 2214: 07/05/25 - As per presentations given to GLIG, QAG & SITAG, Code Bodies and the Programme have developed a proposal to replace MVC/Non-MVC with 'M10-Ready', 'M11-Ready' and 'Not M11-Ready'. Therefore, the MHHS Qualification section has been updated to reflect the pathways that 'M10-Ready', 'M11-Ready' and 'Not M11-Ready' Participants will take to Qualification. This is due for final approval from QAG/SITAG in May, but has been included to support 'M10-Ready', 'M11-Ready' and 'Not M11-Ready' Participants planning.
- 2215: 07/05/25 - As per presentations given to GLIG, QAG & SITAG, Code Bodies and the Programme have developed a proposal to replace MVC/Non-MVC with 'M10-Ready', 'M11-Ready' and 'Not M11-Ready'. Therefore, the MHHS Qualification section has been updated to reflect the pathways that 'M10-Ready', 'M11-Ready' and 'Not M11-Ready' Participants will take to Qualification. This is due for final approval from QAG/SITAG in May, but has been included to support 'M10-Ready', 'M11-Ready' and 'Not M11-Ready' Participants planning.
- 2216: 07/05/25 - As per presentations given to GLIG, QAG & SITAG, Code Bodies and the Programme have developed a proposal to replace MVC/Non-MVC with 'M10-Ready', 'M11-Ready' and 'Not M11-Ready'. Therefore, the MHHS Qualification section has been updated to reflect the pathways that 'M10-Ready', 'M11-Ready' and 'Not M11-Ready' Participants will take to Qualification. This is due for final approval from QAG/SITAG in May, but has been included to support 'M10-Ready', 'M11-Ready' and 'Not M11-Ready' Participants planning.
- 2217: 07/05/25 - As per presentations given to GLIG, QAG & SITAG, Code Bodies and the Programme have developed a proposal to replace MVC/Non-MVC with 'M10-Ready', 'M11-Ready' and 'Not M11-Ready'. Therefore, the MHHS Qualification section has been updated to reflect the pathways that 'M10-Ready', 'M11-Ready' and 'Not M11-Ready' Participants will take to Qualification. This is due for final approval from QAG/SITAG in May, but has been included to support 'M10-Ready', 'M11-Ready' and 'Not M11-Ready' Participants planning.
- 2218: 07/05/25 - As per presentations given to GLIG, QAG & SITAG, Code Bodies and the Programme have developed a proposal to replace MVC/Non-MVC with 'M10-Ready', 'M11-Ready' and 'Not M11-Ready'. Therefore, the MHHS Qualification section has been updated to reflect the pathways that 'M10-Ready', 'M11-Ready' and 'Not M11-Ready' Participants will take to Qualification. This is due for final approval from QAG/SITAG in May, but has been included to support 'M10-Ready', 'M11-Ready' and 'Not M11-Ready' Participants planning.
- 2219: 07/05/25 - As per presentations given to GLIG, QAG & SITAG, Code Bodies and the Programme have developed a proposal to replace MVC/Non-MVC with 'M10-Ready', 'M11-Ready' and 'Not M11-Ready'. Therefore, the MHHS Qualification section has been updated to reflect the pathways that 'M10-Ready', 'M11-Ready' and 'Not M11-Ready' Participants will take to Qualification. This is due for final approval from QAG/SITAG in May, but has been included to support 'M10-Ready', 'M11-Ready' and 'Not M11-Ready' Participants planning.
- 2220: 07/05/25 - As per presentations given to GLIG, QAG & SITAG, Code Bodies and the Programme have developed a proposal to replace MVC/Non-MVC with 'M10-Ready', 'M11-Ready' and 'Not M11-Ready'. Therefore, the MHHS Qualification section has been updated to reflect the pathways that 'M10-Ready', 'M11-Ready' and 'Not M11-Ready' Participants will take to Qualification. This is due for final approval from QAG/SITAG in May, but has been included to support 'M10-Ready', 'M11-Ready' and 'Not M11-Ready' Participants planning.

| ID | WBS | Task | Type | Duration | Start | Finish | Predecessors | Complete | Remaining | Baseline start | Baseline finish | Baseline duration | Total slack | Free slack | Constraint | Baseline cost | Text9 | Task Status | Update Version | Sched Status | MHHS Resource Name | Responsible | RAG | Milestone ID | Involved | Text29 | Tier |
| --- | --- | --- | --- | --- | --- | --- | --- | --- | --- | --- | --- | --- | --- | --- | --- | --- | --- | --- | --- | --- | --- | --- | --- | --- | --- | --- | --- |
| 2221 | 1.7.2.6.5 | **SIT Pathway 5** |  | 16d | 2025-09-24 | 2025-10-15 |  |  |  |  |  |  | 571d |  |  |  | S&A Qualification | -918.67 | 6.24 | Overdue Start | Laura Kennedy |  |  |  |  |  |  |
| 2222 | 1.7.2.6.5.1 | QAD Sign Off Deadline + Test Reports | milestone | 0d | 2025-09-24 | 2025-09-24 | 2217, 1692FF |  |  |  |  |  | 571d | 0d | start no earlier than 2025-09-24 |  | S&A Qualification | 140.33 | 6.24 | No BL | Laura Kennedy | Participants | GREEN |  |  |  |  |
| 2223 | 1.7.2.6.5.2 | REC Code Manager / BSC PAB Approval of Qualification | milestone | 0d | 2025-10-15 | 2025-10-15 | 2222FS+16d |  |  |  |  |  | 571d | 0d |  |  | S&A Qualification | 161.71 | 6.24 | No BL | Laura Kennedy | Code Bodies | GREEN |  |  |  |  |
| 2224 | 1.7.2.6.5.3 | 'M11-Ready SIT Participants are qualified' | milestone | 0d | 2025-10-15 | 2025-10-15 | 2223 |  |  |  |  |  | 571d |  |  |  | Migration | 161.71 | 6.24 | No BL | Laura Kennedy | Migration | GREEN | T3-MI-XXXX |  |  |  |
| 2225 | 1.7.2.7 | **MHHS Qualification - Not M11-Ready** |  | 153d | 2025-05-19 | 2025-12-17 |  |  |  | 2025-05-19 | 2025-12-22 | 129d | 505d |  |  |  | S&A Qualification | -154.67 | 6.24 |  | Warren Fulton | N/A |  |  | N/A |  |  |
| 2226 | 1.7.2.7.1 | Final QAD Submission Window opens | milestone | 0d | 2025-05-19 | 2025-05-19 | 2199FS+31d |  |  | 2025-05-19 | 2025-05-19 | 0d | 613d | 0d | start no earlier than 2025-04-07 |  | S&A Qualification | 12.71 | 6.24 | Green | Laura Kennedy | Participants | GREEN |  | Participants |  |  |
| 2227 | 1.7.2.7.2 | SIT Not M11-Ready Participants submit Final QAD |  | 90d | 2025-05-19 | 2025-09-19 | 2226SS-1d |  |  | 2025-05-19 | 2025-09-19 | 86d | 524d | 0d |  |  | S&A Qualification | 12.33 | 6.24 | Green | Laura Kennedy | Participants | GREEN |  | Participants |  |  |
| 2228 | 1.7.2.7.3 | Completion of Code Bodies review of Final QAD (Not M11-Ready) |  | 25d | 2025-09-22 | 2025-10-24 | 2227 |  |  | 2025-09-22 | 2025-10-24 | 19d | 524d | 19d |  |  | S&A Qualification | 138.33 | 6.24 | Green | Laura Kennedy | Code Bodies | GREEN |  | Code Bodies |  |  |
| 2229 | 1.7.2.7.4 | **SIT Pathway 6** |  | 15d | 2025-11-27 | 2025-12-17 |  |  |  |  |  |  | 505d |  |  |  | S&A Qualification | -918.67 | 6.24 | Overdue Start | Laura Kennedy |  | RED |  |  |  |  |
| 2230 | 1.7.2.7.4.1 | QAD Sign Off Deadline (Not M11-Ready) |  | 1d | 2025-11-27 | 2025-11-27 | 2228FS+4d, 1785 |  |  | 2025-11-28 | 2025-11-28 | 1d | 505d | 0d |  |  | S&A Qualification | 204.33 | 6.24 | Green | Laura Kennedy | Participants | GREEN |  | Participants |  |  |
| 2231 | 1.7.2.7.4.2 | REC Code Manager / BSC PAB Approval of Qualification (Not M11-Ready) | milestone | 0d | 2025-12-17 | 2025-12-17 | 2230FS+14d |  |  | 2025-12-17 | 2025-12-17 | 0d | 505d | 0d |  |  | S&A Qualification | 224.71 | 6.24 | Green | Laura Kennedy | Code Bodies | GREEN | T3-QU-0086 | Code Bodies | QAG | T3 |
| 2232 | 1.7.3 | **MHHS Qualification - Non-SIT LDSO (M10-Ready)** |  | 178d | 2025-01-06 A | 2025-09-10 |  | 60% | 71.2d | 2025-01-06 | 2025-09-11 | 115d | 9d |  |  | -0 | S&A Qualification | -133.67 | 6.11 |  | Laura Kennedy | N/A |  |  | N/A |  |  |
| 2233 | 1.7.3.1 | Initial QAD Submission window opens | milestone | 0d | 2025-01-06 A | 2025-01-06 A | 2188FS+11d | 100% |  | 2025-01-06 | 2025-01-06 | 0d |  |  |  |  | S&A Qualification |  | 6.11 | Complete | Laura Kennedy | Participants | COMPLETE |  | Participants |  |  |
| 2234 | 1.7.3.2 | Non-SIT LDSO Participants submit initial QAD |  | 30d | 2025-01-06 A | 2025-02-14 A |  | 100% |  | 2025-01-06 | 2025-02-14 | 29d |  |  | start no earlier than 2025-01-06 |  | S&A Qualification |  | 6.11 | Complete | Laura Kennedy | Participants | COMPLETE |  | Participants |  |  |
| 2235 | 1.7.3.3 | Non-SIT LDSO QT Participants have submitted their initial QAD | milestone | 0d | 2025-02-14 A | 2025-02-14 A | 2234 | 100% |  | 2025-02-14 | 2025-02-14 | 0d |  |  |  |  | S&A Qualification |  | 6.11 | Complete | Laura Kennedy | Participants | COMPLETE | T3-QU-0087 | Participants | QAG | T3 |
| 2236 | 1.7.3.4 | Code Bodies review of Non-SIT LDSO participants Initial QAD |  | 35d | 2025-02-17 A | 2025-04-04 A | 2235 | 100% |  | 2025-02-17 | 2025-04-04 | 36d |  |  |  |  | S&A Qualification |  | 6.11 | Complete | Laura Kennedy | Code Bodies | COMPLETE |  | Code Bodies |  |  |
| 2237 | 1.7.3.5 | Completion of Code Bodies review of Initial QAD | milestone | 0d | 2025-04-04 A | 2025-04-04 A | 2236 | 100% |  | 2025-04-04 | 2025-04-04 | 0d |  |  |  |  | S&A Qualification |  | 6.11 | Complete | Laura Kennedy | Code Bodies | COMPLETE |  | Code Bodies |  |  |
| 2238 | 1.7.3.6 | Final QAD Submission window opens | milestone | 0d | 2025-04-07 A | 2025-04-07 A | 2237FS+1d | 100% |  | 2025-04-07 | 2025-04-07 | 0d |  |  |  |  | S&A Qualification |  | 6.11 | Complete | Laura Kennedy | Participants | COMPLETE |  | Participants |  |  |
| 2239 | 1.7.3.7 | Non-SIT LDSO Participants submit Final QAD |  | 35d | 2025-04-07 A | 2025-05-23 | 2238SS-1d, 2057 | 20% | 28d | 2025-04-21 | 2025-05-23 | 26d | 49d | 0d | finish no earlier than 2025-05-23 |  | S&A Qualification |  | 6.19 | Green | Laura Kennedy | Participants | GREEN |  | Participants |  |  |
| 2240 | 1.7.3.8 | Non-SIT LDSO QT Participants have submitted their final QAD | milestone | 0d | 2025-05-23 | 2025-05-23 | 2239 |  |  | 2025-05-23 | 2025-05-23 | 0d | 49d | 0d |  |  | S&A Qualification | 16.71 | 6.11 | Green | Laura Kennedy | Participants | GREEN | T3-QU-0088 | Participants | QAG | T3 |
| 2241 | 1.7.3.9 | Completion of Code Bodies review of the Final QAD |  | 20d | 2025-05-26 | 2025-06-20 | 2240 |  |  | 2025-05-26 | 2025-06-20 | 19d | 49d | 40d |  |  | S&A Qualification | 19.33 | 6.11 | Green | Laura Kennedy | Code Bodies | GREEN |  | Code Bodies |  |  |
| 2242 | 1.7.3.10 | QAD Sign Off Deadline (Non-SIT LDSOs) | milestone | 0d | 2025-08-22 | 2025-08-22 | 2241FS+5d, 1763, 2057 |  |  | 2025-08-22 | 2025-08-22 | 1d | 9d | 0d |  |  | S&A Qualification | 107.71 | 6.11 | Green | Laura Kennedy | Participants | GREEN |  | Participants |  |  |
| 2243 | 1.7.3.11 | BSC PAB & REC Manager approval of Qualification for Non-SIT LDSOs | milestone | 0d | 2025-09-10 | 2025-09-10 | 2242FS+13d |  |  | 2025-09-11 | 2025-09-11 | 0d | 9d | 0d |  |  | S&A Qualification | 126.71 | 6.12 | Green | Nicola Farley | Non-SIT LDSO | GREEN | T2-QU-0500 | Non-SIT LDSO | QAG (Non-SIT LDSO) | T2 |
| 2244 | 1.7.4 | **MHHS Qualification - Qualification Waves** |  | 814d? | 2023-12-18 A | 2027-01-28 |  | 57% | 347.04d? | 2023-12-18 | 2027-01-28 | 574d | 235d |  |  | -0 | S&A Qualification | -131.67 | 5.24 |  | N/A | N/A |  |  | N/A |  |  |
| 2245 | 1.7.4.1 | **Qualification Wave Prep** |  | 560d? | 2023-12-18 A | 2026-02-06 |  | 94% | 34.02d? | 2023-12-18 | 2025-12-26 | 424d | 489d |  |  | -0 | S&A Qualification | -131.67 | 5.24 |  | N/A | N/A |  |  | N/A |  |  |
| 2246 | 1.7.4.1.1 | **Non-SIT Supplier and Agent Test Approach and Plan** |  | 119d | 2023-12-18 A | 2024-05-30 A |  | 100% |  | 2023-12-18 | 2024-05-30 | 118d |  |  |  | -0 | S&A Qualification | -133.67 | 5.24 |  | N/A | N/A |  |  | N/A |  |  |
| 2247 | 1.7.4.1.1.1 | Draft Non-SIT S&A Test Approach and Plan |  | 50d | 2023-12-18 A | 2024-02-23 A |  | 100% |  | 2023-12-18 | 2024-02-23 | 50d |  |  | finish no earlier than 2024-02-23 |  | S&A Qualification |  | 5.24 | Complete | Laura Kennedy | Non-SIT S&A QT Test Team | COMPLETE |  | Non-SIT S&A QT Test Team |  |  |
| 2248 | 1.7.4.1.1.2 | Internal Review of Non-SIT S&A Test Approach and Plan (Code Bodies and MHHSP) |  | 10d | 2024-02-26 A | 2024-03-08 A | 2247 | 100% |  | 2024-02-26 | 2024-03-08 | 10d |  |  |  |  | S&A Qualification |  | 5.24 | Complete | Laura Kennedy | Code Bodies, SI Team, SRO | COMPLETE |  | Code Bodies, SI Team, SRO |  |  |
| 2249 | 1.7.4.1.1.3 | Issue Non-SIT S&A Test Approach and Plan for Consultation |  | 15d | 2024-03-18 A | 2024-04-05 A | 2248 | 100% |  | 2024-03-18 | 2024-04-05 | 15d |  |  | start no earlier than 2024-03-18 |  | S&A Qualification |  | 5.24 | Complete | Laura Kennedy | Participants | COMPLETE |  | Participants |  |  |
| 2250 | 1.7.4.1.1.4 | Update Non-SIT S&A Test Approach and Plan Post-Consultation |  | 10d | 2024-04-08 A | 2024-04-19 A | 2249 | 100% |  | 2024-04-08 | 2024-04-19 | 10d |  |  |  |  | S&A Qualification |  | 5.24 | Complete | Laura Kennedy | Non-SIT S&A QT Test Team | COMPLETE |  | Non-SIT S&A QT Test Team |  |  |
| 2251 | 1.7.4.1.1.5 | QWG Endorsement of Non-SIT S&A Test Approach and Plan |  | 1d | 2024-05-14 A | 2024-05-14 A |  | 100% |  | 2024-05-14 | 2024-05-14 | 1d |  |  | finish no earlier than 2024-05-14 |  | S&A Qualification |  | 5.24 | Complete | Laura Kennedy | Non-SIT S&A QT Test Team | COMPLETE |  | Non-SIT S&A QT Test Team |  |  |
| 2252 | 1.7.4.1.1.6 | QAG Approval of Non-SIT S&A Test Approach and Plan | milestone | 0d | 2024-05-23 A | 2024-05-23 A | 2251FS+7d | 100% |  | 2024-05-23 | 2024-05-23 | 0d |  |  |  |  | S&A Qualification |  | 5.25 | Complete | Laura Kennedy | Non-SIT S&A QT Test Team | COMPLETE | T3-QU-0089 | Non-SIT S&A QT Test Team | QAG | T3 |
| 2253 | 1.7.4.1.1.7 | BSC & REC PAB Approval of Non-SIT S&A Test Approach and Plan | milestone | 0d | 2024-05-30 A | 2024-05-30 A | 2252FS+5d | 100% |  | 2024-05-30 | 2024-05-30 | 0d |  |  |  |  | S&A Qualification |  | 5.25 | Complete | Laura Kennedy | Code Bodies | COMPLETE | T3-QU-0090 | Code Bodies | QAG | T3 |

Notes:
- 2221: 07/05/25 - As per presentations given to GLIG, QAG & SITAG, Code Bodies and the Programme have developed a proposal to replace MVC/Non-MVC with 'M10-Ready', 'M11-Ready' and 'Not M11-Ready'. Therefore, the MHHS Qualification section has been updated to reflect the pathways that 'M10-Ready', 'M11-Ready' and 'Not M11-Ready' Participants will take to Qualification. This is due for final approval from QAG/SITAG in May, but has been included to support 'M10-Ready', 'M11-Ready' and 'Not M11-Ready' Participants planning.
- 2222: 07/05/25 - As per presentations given to GLIG, QAG & SITAG, Code Bodies and the Programme have developed a proposal to replace MVC/Non-MVC with 'M10-Ready', 'M11-Ready' and 'Not M11-Ready'. Therefore, the MHHS Qualification section has been updated to reflect the pathways that 'M10-Ready', 'M11-Ready' and 'Not M11-Ready' Participants will take to Qualification. This is due for final approval from QAG/SITAG in May, but has been included to support 'M10-Ready', 'M11-Ready' and 'Not M11-Ready' Participants planning.
- 2223: 07/05/25 - As per presentations given to GLIG, QAG & SITAG, Code Bodies and the Programme have developed a proposal to replace MVC/Non-MVC with 'M10-Ready', 'M11-Ready' and 'Not M11-Ready'. Therefore, the MHHS Qualification section has been updated to reflect the pathways that 'M10-Ready', 'M11-Ready' and 'Not M11-Ready' Participants will take to Qualification. This is due for final approval from QAG/SITAG in May, but has been included to support 'M10-Ready', 'M11-Ready' and 'Not M11-Ready' Participants planning.
- 2224: 07/05/25 - Programme will be asking MCAG to approve creation of this milestone, as part of efforts to replace MVC / Non-MVC with 'M10-Ready', 'M11-Ready' and 'Not M11-Ready'.
- 2225: 07/05/25 - As per presentations given to GLIG, QAG & SITAG, Code Bodies and the Programme have developed a proposal to replace MVC/Non-MVC with 'M10-Ready', 'M11-Ready' and 'Not M11-Ready'. Therefore, the MHHS Qualification section has been updated to reflect the pathways that 'M10-Ready', 'M11-Ready' and 'Not M11-Ready' Participants will take to Qualification. This is due for final approval from QAG/SITAG in May, but has been included to support 'M10-Ready', 'M11-Ready' and 'Not M11-Ready' Participants planning.
- 2226: 07/05/25 - As per presentations given to GLIG, QAG & SITAG, Code Bodies and the Programme have developed a proposal to replace MVC/Non-MVC with 'M10-Ready', 'M11-Ready' and 'Not M11-Ready'. Therefore, the MHHS Qualification section has been updated to reflect the pathways that 'M10-Ready', 'M11-Ready' and 'Not M11-Ready' Participants will take to Qualification. This is due for final approval from QAG/SITAG in May, but has been included to support 'M10-Ready', 'M11-Ready' and 'Not M11-Ready' Participants planning.
- 2227: 07/05/25 - As per presentations given to GLIG, QAG & SITAG, Code Bodies and the Programme have developed a proposal to replace MVC/Non-MVC with 'M10-Ready', 'M11-Ready' and 'Not M11-Ready'. Therefore, the MHHS Qualification section has been updated to reflect the pathways that 'M10-Ready', 'M11-Ready' and 'Not M11-Ready' Participants will take to Qualification. This is due for final approval from QAG/SITAG in May, but has been included to support 'M10-Ready', 'M11-Ready' and 'Not M11-Ready' Participants planning.
- 2228: 07/05/25 - As per presentations given to GLIG, QAG & SITAG, Code Bodies and the Programme have developed a proposal to replace MVC/Non-MVC with 'M10-Ready', 'M11-Ready' and 'Not M11-Ready'. Therefore, the MHHS Qualification section has been updated to reflect the pathways that 'M10-Ready', 'M11-Ready' and 'Not M11-Ready' Participants will take to Qualification. This is due for final approval from QAG/SITAG in May, but has been included to support 'M10-Ready', 'M11-Ready' and 'Not M11-Ready' Participants planning.
- 2229: 07/05/25 - As per presentations given to GLIG, QAG & SITAG, Code Bodies and the Programme have developed a proposal to replace MVC/Non-MVC with 'M10-Ready', 'M11-Ready' and 'Not M11-Ready'. Therefore, the MHHS Qualification section has been updated to reflect the pathways that 'M10-Ready', 'M11-Ready' and 'Not M11-Ready' Participants will take to Qualification. This is due for final approval from QAG/SITAG in May, but has been included to support 'M10-Ready', 'M11-Ready' and 'Not M11-Ready' Participants planning.
- 2230: 07/05/25 - As per presentations given to GLIG, QAG & SITAG, Code Bodies and the Programme have developed a proposal to replace MVC/Non-MVC with 'M10-Ready', 'M11-Ready' and 'Not M11-Ready'. Therefore, the MHHS Qualification section has been updated to reflect the pathways that 'M10-Ready', 'M11-Ready' and 'Not M11-Ready' Participants will take to Qualification. This is due for final approval from QAG/SITAG in May, but has been included to support 'M10-Ready', 'M11-Ready' and 'Not M11-Ready' Participants planning. / Note that Pathway 6 only represents the BSC PAB straight after the 'SIT Contingency' ends. A 'Not M11-Ready' PP can attend any BSC PAB from 30/10 onwards. v6.25 of the plan will develop this view.
- 2231: 07/05/25 - As per presentations given to GLIG, QAG & SITAG, Code Bodies and the Programme have developed a proposal to replace MVC/Non-MVC with 'M10-Ready', 'M11-Ready' and 'Not M11-Ready'. Therefore, the MHHS Qualification section has been updated to reflect the pathways that 'M10-Ready', 'M11-Ready' and 'Not M11-Ready' Participants will take to Qualification. This is due for final approval from QAG/SITAG in May, but has been included to support 'M10-Ready', 'M11-Ready' and 'Not M11-Ready' Participants planning. / Note that Pathway 6 only represents the BSC PAB straight after the 'SIT Contingency' ends. A 'Not M11-Ready' PP can attend any BSC PAB from 30/10 onwards. v6.25 of the plan will develop this view.

| ID | WBS | Task | Type | Duration | Start | Finish | Predecessors | Complete | Baseline start | Baseline finish | Baseline duration | Constraint | Baseline cost | Responsible | Involved | Text9 | Task Status | Update Version | MHHS Resource Name | Sched Status | RAG | Milestone ID | Text29 | Tier |
| --- | --- | --- | --- | --- | --- | --- | --- | --- | --- | --- | --- | --- | --- | --- | --- | --- | --- | --- | --- | --- | --- | --- | --- | --- |
| 2254 | 1.7.4.1.2 | **QT Test Data Approach and Plan** |  | 64d | 2024-04-19 A | 2024-07-18 A |  | 100% | 2024-04-19 | 2024-07-18 | 64d |  | -0 | N/A | N/A | S&A Qualification | -133.67 | 5.24 | N/A |  |  |  |  |  |
| 2255 | 1.7.4.1.2.1 | QT Test Data Approach agreed as part of the Non-SIT Supplier and Agent Test Approach and Plan | milestone | 0d | 2024-04-19 A | 2024-04-19 A | 2250 | 100% | 2024-04-19 | 2024-04-19 | 0d |  |  | Non-SIT S&A QT Test Team, Participants | Non-SIT S&A QT Test Team, Participants | S&A Qualification |  | 5.24 | Laura Kennedy | Complete | COMPLETE |  |  |  |
| 2256 | 1.7.4.1.2.2 | Draft Test Data Approach and Plan for QT |  | 10d | 2024-05-06 A | 2024-05-17 A | 2255 | 100% | 2024-05-06 | 2024-05-17 | 10d |  |  | Non-SIT S&A QT Test Team | Non-SIT S&A QT Test Team | S&A Qualification |  | 5.24 | Laura Kennedy | Complete | COMPLETE |  |  |  |
| 2257 | 1.7.4.1.2.3 | Internal Review (Code Bodies and MHHSP) of QT Test Data Approach and Plan |  | 15d | 2024-05-20 A | 2024-06-07 A | 2256 | 100% | 2024-05-20 | 2024-06-07 | 10d |  |  | Code Bodies, SI Team, SRO | Code Bodies, SI Team, SRO | S&A Qualification |  | 5.24 | Laura Kennedy | Complete | COMPLETE |  |  |  |
| 2258 | 1.7.4.1.2.4 | Issue QT Test Data Approach and Plan for Industry Consultation |  | 10d | 2024-06-10 A | 2024-06-21 A | 2257 | 100% | 2024-06-10 | 2024-06-21 | 10d |  |  | Participants | Participants | S&A Qualification |  | 5.24 | Laura Kennedy | Complete | COMPLETE |  |  |  |
| 2259 | 1.7.4.1.2.5 | Update QT Test Approach and Plan Post Industry Consultation |  | 5d | 2024-06-24 A | 2024-06-28 A | 2258 | 100% | 2024-06-24 | 2024-06-28 | 10d |  |  | Non-SIT S&A QT Team | Non-SIT S&A QT Team | S&A Qualification |  | 5.24 | Laura Kennedy | Complete | COMPLETE |  |  |  |
| 2260 | 1.7.4.1.2.6 | QWG Endorsement of Test Data Approach and Plan |  | 1d | 2024-07-09 A | 2024-07-09 A | 2259FS+6d | 100% | 2024-07-09 | 2024-07-09 | 1d |  |  | Non-SIT S&A QT Test Team | Non-SIT S&A QT Test Team | S&A Qualification |  | 5.24 | Laura Kennedy | Complete | COMPLETE |  |  |  |
| 2261 | 1.7.4.1.2.7 | QAG Approval of QT Test Data Approach and Plan | milestone | 0d | 2024-07-18 A | 2024-07-18 A | 2260FS+7d | 100% | 2024-07-18 | 2024-07-18 | 0d |  |  | Non-SIT S&A QT Test Team | Non-SIT S&A QT Test Team | S&A Qualification |  | 5.29 | Laura Kennedy | Complete | COMPLETE | T3-QU-0091 | QAG | T3 |
| 2262 | 1.7.4.1.3 | **QT Functional Test Scenarios and Test Cases** |  | 59d | 2024-03-04 A | 2024-05-23 A |  | 100% | 2024-03-04 | 2024-05-23 | 59d |  | -0 | N/A | N/A | S&A Qualification | -133.67 | 5.24 | N/A |  |  |  |  |  |
| 2263 | 1.7.4.1.3.1 | Draft Test Scenarios and Test Case list - Batch 1 |  | 10d | 2024-03-04 A | 2024-03-15 A |  | 100% | 2024-03-04 | 2024-03-15 | 10d | finish no earlier than 2024-03-15 |  | Non-SIT S&A QT Test Team, Code Bodies | Non-SIT S&A QT Test Team, Code Bodies | S&A Qualification |  | 5.24 | Laura Kennedy | Complete | COMPLETE |  |  |  |
| 2264 | 1.7.4.1.3.2 | Issue Batch 1 for Consultation |  | 15d | 2024-03-18 A | 2024-04-05 A | 2263 | 100% | 2024-03-18 | 2024-04-05 | 15d | start no earlier than 2024-03-18 |  | Participants | Participants | S&A Qualification |  | 5.24 | Laura Kennedy | Complete | COMPLETE |  |  |  |
| 2265 | 1.7.4.1.3.3 | Gap analysis against QT Requirements |  | 8d | 2024-03-18 A | 2024-03-27 A | 2263 | 100% | 2024-03-18 | 2024-03-27 | 8d |  |  | Non-SIT S&A QT Test Team | Non-SIT S&A QT Test Team | S&A Qualification |  | 5.24 | Laura Kennedy | Complete | COMPLETE |  |  |  |
| 2266 | 1.7.4.1.3.4 | Update Test Scenarios and Test Case list - Batch 2 |  | 6d | 2024-03-28 A | 2024-04-04 A | 2265 | 100% | 2024-03-28 | 2024-04-04 | 6d |  |  | Non-SIT S&A QT Test Team, Code Bodies | Non-SIT S&A QT Test Team, Code Bodies | S&A Qualification |  | 5.24 | Laura Kennedy | Complete | COMPLETE |  |  |  |
| 2267 | 1.7.4.1.3.5 | Issue Batch 2 for consultation |  | 10d | 2024-04-05 A | 2024-04-18 A | 2266 | 100% | 2024-04-05 | 2024-04-18 | 10d |  |  | Participants | Participants | S&A Qualification |  | 5.24 | Laura Kennedy | Complete | COMPLETE |  |  |  |
| 2268 | 1.7.4.1.3.6 | Update Batch 2 post consultation |  | 10d | 2024-04-19 A | 2024-05-02 A | 2267 | 100% | 2024-04-19 | 2024-05-02 | 10d |  |  | Non-SIT S&A QT Test Team, Code Bodies | Non-SIT S&A QT Test Team, Code Bodies | S&A Qualification |  | 5.24 | Laura Kennedy | Complete | COMPLETE |  |  |  |
| 2269 | 1.7.4.1.3.7 | QWG Endorsement of Batch 1 and 2 |  | 1d | 2024-05-14 A | 2024-05-14 A |  | 100% | 2024-05-14 | 2024-05-14 | 1d | finish no earlier than 2024-05-14 |  | Non-SIT S&A QT Test Team | Non-SIT S&A QT Test Team, Code Bodies, Participants | S&A Qualification |  | 5.24 | Laura Kennedy | Complete | COMPLETE |  |  |  |
| 2270 | 1.7.4.1.3.8 | QAG Approval of QT Functional Test Scenarios and Test Cases Batches 1 and 2 | milestone | 0d | 2024-05-23 A | 2024-05-23 A | 2269FS+7d | 100% | 2024-05-23 | 2024-05-23 | 0d |  |  | Non-SIT S&A QT Test Team | Non-SIT S&A QT Test Team, Code Bodies, Participants | S&A Qualification |  | 5.25 | Laura Kennedy | Complete | COMPLETE | T3-QU-0092 | QAG | T3 |
| 2271 | 1.7.4.1.4 | **QT Migration Test Scenarios and Test Cases** |  | 54d | 2024-05-06 A | 2024-07-18 A |  | 100% | 2024-05-06 | 2024-07-18 | 54d |  |  | N/A | N/A | S&A Qualification |  | 5.25 | N/A |  |  |  |  |  |
| 2272 | 1.7.4.1.4.1 | Draft Test Scenarios and Test Case list - Batch 1 |  | 20d | 2024-05-06 A | 2024-05-31 A | 1025FS+12d | 100% | 2024-05-06 | 2024-05-31 | 20d |  |  | Non-SIT S&A QT Test Team, Code Bodies | Non-SIT S&A QT Test Team, Code Bodies | S&A Qualification |  | 5.25 | Laura Kennedy | Complete | COMPLETE |  |  |  |
| 2273 | 1.7.4.1.4.2 | Issue Batch 1 for Consultation |  | 10d | 2024-06-03 A | 2024-06-14 A | 2272 | 100% | 2024-06-03 | 2024-06-14 | 10d |  |  | Participants | Participants | S&A Qualification |  | 5.25 | Laura Kennedy | Complete | COMPLETE |  |  |  |
| 2274 | 1.7.4.1.4.3 | Update Batch 1 Post Consultation |  | 10d | 2024-06-17 A | 2024-06-28 A | 2273 | 100% | 2024-06-17 | 2024-06-28 | 10d |  |  | Non-SIT S&A QT Test Team | Non-SIT S&A QT Test Team | S&A Qualification |  | 5.25 | Laura Kennedy | Complete | COMPLETE |  |  |  |
| 2275 | 1.7.4.1.4.4 | QWG Endorsement of Batch 1 | milestone | 0d | 2024-07-09 A | 2024-07-09 A | 2274FS+7d | 100% | 2024-07-09 | 2024-07-09 | 0d |  |  | Non-SIT S&A QT Test Team | Non-SIT S&A QT Test Team, Code Bodies, Participants | S&A Qualification |  | 5.25 | Laura Kennedy | Complete | COMPLETE |  |  |  |
| 2276 | 1.7.4.1.4.5 | QAG Approval of QT Migration Test Scenarios and Test Cases Batches 1 | milestone | 0d | 2024-07-18 A | 2024-07-18 A | 2275FS+7d | 100% | 2024-07-18 | 2024-07-18 | 0d |  |  | Non-SIT S&A QT Test Team | Non-SIT S&A QT Test Team, Code Bodies, Participants | S&A Qualification |  | 5.29 | Laura Kennedy | Complete | COMPLETE | T3-QU-0119 | QAG | T3 |
| 2277 | 1.7.4.1.5 | **QT Functional (inc NF and Operational) Test Scenarios and Test Cases** |  | 77d | 2024-11-05 A | 2025-02-20 A |  | 100% | 2024-11-04 | 2024-12-27 | 0d |  |  | Non-SIT S&A QT Test Team |  | S&A Qualification | -721.67 |  | Laura Kennedy |  |  |  |  |  |
| 2278 | 1.7.4.1.5.1 | Draft Test Scenarios and Test Case list - Batch 3 |  | 20d | 2024-11-05 A | 2024-12-02 A | 912FS-1d | 100% | 2024-11-05 | 2024-12-02 | 0d |  |  | Non-SIT S&A QT Test Team |  | S&A Qualification |  | 6.11 | Laura Kennedy | Complete | COMPLETE |  |  |  |
| 2279 | 1.7.4.1.5.2 | Issue Batch 3 for Consultation |  | 10d | 2024-12-03 A | 2024-12-16 A | 2278 | 100% | 2024-12-03 | 2024-12-16 | 0d |  |  | Non-SIT S&A QT Test Team |  | S&A Qualification |  | 6.11 | Laura Kennedy | Complete | COMPLETE |  |  |  |
| 2280 | 1.7.4.1.5.3 | Update Batch 3 Post Consultation |  | 20d | 2024-12-17 A | 2025-01-13 A | 2279 | 100% | 2024-12-17 | 2025-01-13 | 0d |  |  | Non-SIT S&A QT Test Team |  | S&A Qualification |  | 6.11 | Laura Kennedy | Complete | COMPLETE |  |  |  |
| 2281 | 1.7.4.1.5.4 | QWG Endorsement of Batch 3 | milestone | 0d | 2025-02-11 A | 2025-02-11 A | 2280FS+21d | 100% | 2025-02-11 | 2025-02-11 | 0d |  |  | Non-SIT S&A QT Test Team |  | S&A Qualification |  | 6.11 | Laura Kennedy | Complete | COMPLETE |  |  |  |
| 2282 | 1.7.4.1.5.5 | QAG Approval of QT Functional Test Scenarios and Test Cases Batches 3 | milestone | 0d | 2025-02-20 A | 2025-02-20 A | 2281FS+6d | 100% | 2025-02-20 | 2025-02-20 | 0d | start no earlier than 2025-02-20 |  | Non-SIT S&A QT Test Team |  | S&A Qualification |  | 6.11 | Laura Kennedy | Complete | COMPLETE | T3-QU-0123 | QAG | T3 |

| ID | WBS | Task | Duration | Start | Finish | Predecessors | Complete | Remaining | Actual finish | Baseline start | Baseline finish | Baseline duration | Total slack | Constraint | Responsible | Text9 | Task Status | Update Version | MHHS Resource Name | Sched Status | RAG |
| --- | --- | --- | --- | --- | --- | --- | --- | --- | --- | --- | --- | --- | --- | --- | --- | --- | --- | --- | --- | --- | --- |
| 2283 | 1.7.4.1.6 | **Qualification Testing Framework (Test Stubs and Supporting UI)** | 530d? | 2024-01-29 A | 2026-02-06 |  | 93% | 37.93d? |  | 2024-01-29 | 2026-01-08 | 0d | 489d |  | Non-SIT S&A QT Test Team | S&A Qualification | -742.67 | 6.12 | Laura Kennedy |  |  |
| 2284 | 1.7.4.1.6.1 | Proof of Concept for QTF Completion | 45d | 2024-01-29 A | 2024-03-29 A |  | 100% |  |  | 2024-01-29 | 2024-03-29 | 0d |  | finish no earlier than 2024-03-29 | Non-SIT S&A QT Test Team | S&A Qualification |  | 6.12 | Laura Kennedy | Complete | COMPLETE |
| 2285 | 1.7.4.1.6.2 | Discovery and Mobilisation | 25d | 2024-04-01 A | 2024-05-03 A | 2284 | 100% |  |  | 2024-04-01 | 2024-05-03 | 0d |  | finish no earlier than 2024-05-03 | Non-SIT S&A QT Test Team | S&A Qualification |  | 6.12 | Laura Kennedy | Complete | COMPLETE |
| 2286 | 1.7.4.1.6.3 | **Agile DBT of Qualification Testing Framework** | 83d | 2024-04-24 A | 2024-08-16 A |  | 100% |  |  | 2024-04-24 | 2024-08-16 | 0d |  |  | Non-SIT S&A QT Test Team | S&A Qualification | -742.67 | 6.12 | Laura Kennedy |  |  |
| 2287 | 1.7.4.1.6.3.1 | **User Interface (UI)** | 48d | 2024-04-24 A | 2024-06-28 A |  | 100% |  |  | 2024-04-24 | 2024-06-28 | 0d |  |  | Non-SIT S&A QT Test Team | S&A Qualification | -742.67 | 6.12 | Laura Kennedy |  |  |
| 2288 | 1.7.4.1.6.3.1.1 | UI Wireframe | 48d | 2024-04-24 A | 2024-06-28 A |  | 100% |  |  | 2024-04-24 | 2024-06-28 | 0d |  | finish no earlier than 2024-06-28 | Non-SIT S&A QT Test Team | S&A Qualification |  | 6.12 | Laura Kennedy | Complete | COMPLETE |
| 2289 | 1.7.4.1.6.3.1.2 | UI Standards | 35d | 2024-05-13 A | 2024-06-28 A | 2288FS+13d | 100% |  |  | 2024-05-13 | 2024-06-28 | 0d |  | finish no earlier than 2024-06-28 | Non-SIT S&A QT Test Team | S&A Qualification |  | 6.12 | Laura Kennedy | Complete | COMPLETE |
| 2290 | 1.7.4.1.6.3.1.3 | Elexon Branding Sylesheet | 2d | 2024-05-17 A | 2024-05-20 A | 2289FS+10d | 100% |  |  | 2024-05-17 | 2024-05-20 | 0d |  | finish no earlier than 2024-05-20 | Non-SIT S&A QT Test Team | S&A Qualification |  | 6.12 | Laura Kennedy | Complete | COMPLETE |
| 2291 | 1.7.4.1.6.3.1.4 | Elexon Branding QTF Logo | 2d | 2024-05-31 A | 2024-06-03 A | 2290FS+20d | 100% |  |  | 2024-05-31 | 2024-06-03 | 0d |  | finish no earlier than 2024-06-03 | Non-SIT S&A QT Test Team | S&A Qualification |  | 6.12 | Laura Kennedy | Complete | COMPLETE |
| 2292 | 1.7.4.1.6.3.2 | **Design, Build, Test** | 70d | 2024-05-13 A | 2024-08-16 A |  | 100% |  |  | 2024-05-13 | 2024-08-16 | 0d |  |  | Non-SIT S&A QT Test Team | S&A Qualification | -742.67 | 6.12 | Laura Kennedy |  |  |
| 2293 | 1.7.4.1.6.3.2.1 | Core UI Screens | 60d | 2024-05-13 A | 2024-08-02 A | 2289SS | 100% |  |  | 2024-05-13 | 2024-08-02 | 0d |  | finish no earlier than 2024-08-02 | Non-SIT S&A QT Test Team | S&A Qualification |  | 6.12 | Laura Kennedy | Complete | COMPLETE |
| 2294 | 1.7.4.1.6.3.2.2 | Tooling (Trigger Files / Template Generators) | 70d | 2024-05-13 A | 2024-08-16 A | 2288SS+13d | 100% |  |  | 2024-05-13 | 2024-08-16 | 0d |  | finish no earlier than 2024-08-16 | Non-SIT S&A QT Test Team | S&A Qualification |  | 6.12 | Laura Kennedy | Complete | COMPLETE |
| 2295 | 1.7.4.1.6.3.2.3 | Database Schema | 50d | 2024-05-13 A | 2024-07-19 A | 2288SS+13d | 100% |  |  | 2024-05-13 | 2024-07-19 | 0d |  | finish no earlier than 2024-07-19 | Non-SIT S&A QT Test Team | S&A Qualification |  | 6.12 | Laura Kennedy | Complete | COMPLETE |
| 2296 | 1.7.4.1.6.3.2.4 | Core API's | 60d | 2024-05-13 A | 2024-08-02 A | 2288SS+13d | 100% |  |  | 2024-05-13 | 2024-08-02 | 0d |  | finish no earlier than 2024-08-02 | Non-SIT S&A QT Test Team | S&A Qualification |  | 6.12 | Laura Kennedy | Complete | COMPLETE |
| 2297 | 1.7.4.1.6.4 | QTF Test Cases DBT Refinement, Execution and Results Validation, Defect Management, Error Handling | 77d | 2024-11-05 A | 2025-02-20 A | 2282FF, 2276FF, 2278SS | 100% |  |  | 2024-11-05 | 2025-02-20 | 0d |  |  | Non-SIT S&A QT Test Team | S&A Qualification |  | 6.12 | Laura Kennedy | Complete | COMPLETE |
| 2298 | 1.7.4.1.6.5 | **Environments** | 339d | 2024-04-15 A | 2025-07-31 |  | 100% |  | 2025-03-18 | 2024-04-15 | 2025-07-31 | 0d |  |  | Non-SIT S&A QT Test Team | S&A Qualification | -742.67 | 6.12 | Laura Kennedy |  |  |
| 2299 | 1.7.4.1.6.5.1 | **Azure Devops** | 173d | 2024-04-15 A | 2024-12-11 A |  | 100% |  |  | 2024-04-15 | 2024-12-11 | 0d |  |  | Non-SIT S&A QT Test Team | S&A Qualification | -742.67 | 6.12 | Laura Kennedy |  |  |
| 2300 | 1.7.4.1.6.5.1.1 | **QFT ADO Development Instance** | 15d | 2024-04-15 A | 2024-05-03 A |  | 100% |  |  | 2024-04-15 | 2024-05-03 | 0d |  |  | Non-SIT S&A QT Test Team | S&A Qualification | -742.67 | 6.12 | Laura Kennedy |  |  |
| 2301 | 1.7.4.1.6.5.1.1.1 | Elexon Instance Setup for QTF Build | 5d | 2024-04-15 A | 2024-04-19 A | 2285SS+10d | 100% |  |  | 2024-04-15 | 2024-04-19 | 0d |  | finish no earlier than 2024-04-19 | Non-SIT S&A QT Test Team | S&A Qualification |  | 6.12 | Laura Kennedy | Complete | COMPLETE |
| 2302 | 1.7.4.1.6.5.1.1.2 | Configuration and User Access | 10d | 2024-04-22 A | 2024-05-03 A | 2301 | 100% |  |  | 2024-04-22 | 2024-05-03 | 0d |  | finish no earlier than 2024-05-03 | Non-SIT S&A QT Test Team | S&A Qualification |  | 6.12 | Laura Kennedy | Complete | COMPLETE |
| 2303 | 1.7.4.1.6.5.1.2 | **MHHSP ADO Instance** | 102d | 2024-07-23 A | 2024-12-11 A |  | 100% |  |  | 2024-07-23 | 2024-12-11 | 0d |  |  | Non-SIT S&A QT Test Team | S&A Qualification | -742.67 | 6.12 | Laura Kennedy |  |  |
| 2304 | 1.7.4.1.6.5.1.2.1 | MHHSP Instance Setup for QTF Production | 29d | 2024-07-23 A | 2024-08-30 A | 2310SS+41d | 100% |  |  | 2024-07-23 | 2024-08-30 | 0d |  | finish no earlier than 2024-08-30 | Non-SIT S&A QT Test Team | S&A Qualification |  | 6.12 | Laura Kennedy | Complete | COMPLETE |
| 2305 | 1.7.4.1.6.5.1.2.2 | Configuration and User Access | 73d | 2024-09-02 A | 2024-12-11 A | 2304 | 100% |  |  | 2024-09-02 | 2024-12-11 | 0d |  | finish no earlier than 2024-09-27 | Non-SIT S&A QT Test Team | S&A Qualification |  | 6.12 | Laura Kennedy | Complete | COMPLETE |
| 2306 | 1.7.4.1.6.5.2 | **Temporary Development Environment** | 35d | 2024-04-15 A | 2024-05-31 A |  | 100% |  |  | 2024-04-15 | 2024-05-31 | 0d |  |  | Non-SIT S&A QT Test Team | S&A Qualification | -742.67 | 6.12 | Laura Kennedy |  |  |
| 2307 | 1.7.4.1.6.5.2.1 | Design | 15d | 2024-04-15 A | 2024-05-03 A | 2285SS+10d | 100% |  |  | 2024-04-15 | 2024-05-03 | 0d |  | finish no earlier than 2024-05-03 | Non-SIT S&A QT Test Team | S&A Qualification |  | 6.12 | Laura Kennedy | Complete | COMPLETE |
| 2308 | 1.7.4.1.6.5.2.2 | Build and Deployment | 20d | 2024-05-06 A | 2024-05-31 A | 2302, 2307 | 100% |  |  | 2024-05-06 | 2024-05-31 | 0d |  | finish no earlier than 2024-05-31 | Non-SIT S&A QT Test Team | S&A Qualification |  | 6.12 | Laura Kennedy | Complete | COMPLETE |

| ID | WBS | Task | Duration | Start | Finish | Predecessors | Complete | Baseline start | Baseline finish | Baseline duration | Constraint | Responsible | Text9 | Task Status | Update Version | MHHS Resource Name | Sched Status | RAG |
| --- | --- | --- | --- | --- | --- | --- | --- | --- | --- | --- | --- | --- | --- | --- | --- | --- | --- | --- |
| 2309 | 1.7.4.1.6.5.3 | **Dev, Test & Prod Environment Requirements + Design** | 135d | 2024-05-27 A | 2024-11-29 A |  | 100% | 2024-05-27 | 2024-11-29 | 0d |  | Non-SIT S&A QT Test Team | S&A Qualification | -742.67 | 6.12 | Laura Kennedy |  |  |
| 2310 | 1.7.4.1.6.5.3.1 | Design (including Security Review) | 135d | 2024-05-27 A | 2024-11-29 A | 2285FS+15d | 100% | 2024-05-27 | 2024-11-29 | 0d | finish no earlier than 2024-08-30 | Non-SIT S&A QT Test Team | S&A Qualification |  | 6.12 | Laura Kennedy | Complete | COMPLETE |
| 2311 | 1.7.4.1.6.5.3.2 | Hub Development Dev/Test | 20d | 2024-06-10 A | 2024-07-05 A | 2310SS+10d | 100% | 2024-06-10 | 2024-07-05 | 0d |  | Non-SIT S&A QT Test Team | S&A Qualification |  | 6.12 | Laura Kennedy | Complete | COMPLETE |
| 2312 | 1.7.4.1.6.5.3.3 | Hub Deployment | 20d | 2024-06-10 A | 2024-07-05 A | 2310FS+10d, 2311 | 100% | 2024-06-10 | 2024-07-05 | 0d | finish no earlier than 2024-07-05 | Non-SIT S&A QT Test Team | S&A Qualification |  | 6.12 | Laura Kennedy | Complete | COMPLETE |
| 2313 | 1.7.4.1.6.5.3.4 | Development Envn. Deployment | 53.8d | 2024-07-08 A | 2024-09-19 A | 2312 | 100% | 2024-07-08 | 2024-09-19 | 0d | finish no earlier than 2024-08-30 | Non-SIT S&A QT Test Team | S&A Qualification |  | 6.12 | Laura Kennedy | Complete | COMPLETE |
| 2314 | 1.7.4.1.6.5.3.5 | Test Envn. Deployment | 10d | 2024-09-19 A | 2024-10-03 A | 2313 | 100% | 2024-09-19 | 2024-10-03 | 0d | finish no earlier than 2024-09-13 | Non-SIT S&A QT Test Team | S&A Qualification |  | 6.12 | Laura Kennedy | Complete | COMPLETE |
| 2315 | 1.7.4.1.6.5.3.6 | Production Envn. Deployment | 25d | 2024-10-03 A | 2024-11-07 A | 2314 | 100% | 2024-10-03 | 2024-11-07 | 0d | finish no earlier than 2024-10-18 | Non-SIT S&A QT Test Team | S&A Qualification |  | 6.12 | Laura Kennedy | Complete | COMPLETE |
| 2316 | 1.7.4.1.6.5.4 | **QTF Deployment into Production** | 19d | 2025-02-20 A | 2025-03-18 A |  | 100% | 2025-02-03 | 2025-04-25 | 0d |  | Non-SIT S&A QT Test Team | S&A Qualification | -742.67 | 6.15 | Laura Kennedy |  |  |
| 2317 | 1.7.4.1.6.5.4.1 | App Deployment | 5d | 2025-02-20 A | 2025-02-26 A | 2297, 2315 | 100% | 2025-02-20 | 2025-02-26 | 0d | start no earlier than 2025-02-03 | Non-SIT S&A QT Test Team | S&A Qualification |  | 6.15 | Laura Kennedy | Complete | COMPLETE |
| 2318 | 1.7.4.1.6.5.4.2 | Smoke Test | 2d | 2025-02-27 A | 2025-02-28 A | 2317 | 100% | 2025-02-27 | 2025-02-28 | 0d | finish no earlier than 2025-02-04 | Non-SIT S&A QT Test Team | S&A Qualification |  | 6.15 | Laura Kennedy | Complete | COMPLETE |
| 2319 | 1.7.4.1.6.5.4.3 | PEN Test | 2d | 2025-03-03 A | 2025-03-04 A | 2318 | 100% | 2025-03-03 | 2025-03-04 | 0d | finish no earlier than 2025-02-06 | Non-SIT S&A QT Test Team | S&A Qualification |  | 6.15 | Laura Kennedy | Complete | COMPLETE |
| 2320 | 1.7.4.1.6.5.4.4 | Regression Test | 10d | 2025-03-05 A | 2025-03-18 A | 2319 | 100% | 2025-03-05 | 2025-03-18 | 0d | finish no earlier than 2025-02-20 | Non-SIT S&A QT Test Team | S&A Qualification |  | 6.15 | Laura Kennedy | Complete | COMPLETE |
| 2321 | 1.7.4.1.6.5.5 | **DIP Onboarding (UIT)** | 101d | 2024-07-26 A | 2024-12-13 A |  | 100% | 2024-07-26 | 2024-11-29 | 0d |  | Non-SIT S&A QT Test Team | S&A Qualification | -742.67 | 6.15 | Laura Kennedy |  |  |
| 2322 | 1.7.4.1.6.5.5.1 | DIP Simulator | 15d | 2024-07-26 A | 2024-08-15 A |  | 100% | 2024-07-26 | 2024-08-15 | 0d | finish no earlier than 2024-08-15 | Non-SIT S&A QT Test Team | S&A Qualification |  | 6.15 | Laura Kennedy | Complete | COMPLETE |
| 2323 | 1.7.4.1.6.5.5.2 | DIP (UIT) Instance available for Onboarding | 1d | 2024-08-05 A | 2024-08-05 A |  | 100% | 2024-08-05 | 2024-08-05 | 0d | start no earlier than 2024-08-05 | Non-SIT S&A QT Test Team | S&A Qualification |  | 6.15 | Laura Kennedy | Complete | COMPLETE |
| 2324 | 1.7.4.1.6.5.5.3 | DIP (UIT) Portal | 1d | 2024-09-03 A | 2024-09-03 A | 2323 | 100% | 2024-09-03 | 2024-09-03 | 0d | start no earlier than 2024-09-03 | Non-SIT S&A QT Test Team | S&A Qualification |  | 6.15 | Laura Kennedy | Complete | COMPLETE |
| 2325 | 1.7.4.1.6.5.5.4 | DIP (UIT) Onboarding for Development (incl. certificates and security compliance) | 39d | 2024-08-06 A | 2024-09-27 A | 2323 | 100% | 2024-08-06 | 2024-09-27 | 0d | finish no earlier than 2024-09-27 | Non-SIT S&A QT Test Team | S&A Qualification |  | 6.15 | Laura Kennedy | Complete | COMPLETE |
| 2326 | 1.7.4.1.6.5.5.5 | DIP (UIT) Onboarding for Development Connection Confirmed | 1d | 2024-09-30 A | 2024-09-30 A | 2325 | 100% | 2024-09-30 | 2024-09-30 | 0d | start no earlier than 2024-09-30 | Non-SIT S&A QT Test Team | S&A Qualification |  | 6.15 | Laura Kennedy | Complete | COMPLETE |
| 2327 | 1.7.4.1.6.5.5.6 | DIP (UIT) Onboarding for Test (incl. certificates and security compliance) | 5d | 2024-10-01 A | 2024-10-07 A | 2326 | 100% | 2024-10-01 | 2024-10-07 | 0d | finish no earlier than 2024-10-07 | Non-SIT S&A QT Test Team | S&A Qualification |  | 6.15 | Laura Kennedy | Complete | COMPLETE |
| 2328 | 1.7.4.1.6.5.5.7 | DIP (UIT) Onboarding for Test Connection Confirmed | 1d | 2024-10-08 A | 2024-10-08 A | 2327 | 100% | 2024-10-08 | 2024-10-08 | 0d | start no earlier than 2024-10-08 | Non-SIT S&A QT Test Team | S&A Qualification |  | 6.15 | Laura Kennedy | Complete | COMPLETE |
| 2329 | 1.7.4.1.6.5.5.8 | DIP (UIT) Onboarding for Prod (incl. certificates and security compliance) | 5d | 2024-10-09 A | 2024-10-15 A | 2328 | 100% | 2024-10-09 | 2024-10-15 | 0d | finish no earlier than 2024-10-15 | Non-SIT S&A QT Test Team | S&A Qualification |  | 6.15 | Laura Kennedy | Complete | COMPLETE |
| 2330 | 1.7.4.1.6.5.5.9 | DIP (UIT) Onboarding for Prod Connection Confirmed | 1d | 2024-10-16 A | 2024-10-16 A | 2329 | 100% | 2024-10-16 | 2024-10-16 | 0d | start no earlier than 2024-10-16 | Non-SIT S&A QT Test Team | S&A Qualification |  | 6.15 | Laura Kennedy | Complete | COMPLETE |
| 2331 | 1.7.4.1.6.5.5.10 | DIP UIT Test Stubs | 32d | 2024-10-31 A | 2024-12-13 A | 2326, 2328, 2330 | 100% | 2024-10-17 | 2024-11-29 | 0d | start no earlier than 2024-10-31 | Non-SIT S&A QT Test Team | S&A Qualification |  | 6.15 | Laura Kennedy | Complete | COMPLETE |
| 2332 | 1.7.4.1.6.5.6 | **DTN Onboarding** | 115d | 2024-05-20 A | 2024-10-25 A |  | 100% | 2024-05-20 | 2024-10-25 | 0d |  | Non-SIT S&A QT Test Team | S&A Qualification | -742.67 | 6.15 | Laura Kennedy |  |  |
| 2333 | 1.7.4.1.6.5.6.1 | DTN Request Raised for Onboarding | 25d | 2024-05-20 A | 2024-06-21 A |  | 100% | 2024-05-20 | 2024-06-21 | 0d | start no earlier than 2024-05-20 | Non-SIT S&A QT Test Team | S&A Qualification |  | 6.15 | Laura Kennedy | Complete | COMPLETE |
| 2334 | 1.7.4.1.6.5.6.2 | Setup, configuration of New Host and Test Flags | 5d | 2024-06-24 A | 2024-06-28 A | 2333 | 100% | 2024-06-24 | 2024-06-28 | 0d | start no earlier than 2024-06-24 | Non-SIT S&A QT Test Team | S&A Qualification |  | 6.15 | Laura Kennedy | Complete | COMPLETE |
| 2335 | 1.7.4.1.6.5.6.3 | New VPN Connection (Test) | 30d | 2024-08-05 A | 2024-09-13 A | 2334 | 100% | 2024-08-05 | 2024-09-13 | 0d | start no earlier than 2024-08-05 | Non-SIT S&A QT Test Team | S&A Qualification |  | 6.15 | Laura Kennedy | Complete | COMPLETE |
| 2336 | 1.7.4.1.6.5.6.4 | New VPN Connection (Prod) | 30d | 2024-09-16 A | 2024-10-25 A | 2335 | 100% | 2024-09-16 | 2024-10-25 | 0d | finish no earlier than 2024-10-25 | Non-SIT S&A QT Test Team | S&A Qualification |  | 6.15 | Laura Kennedy | Complete | COMPLETE |
| 2337 | 1.7.4.1.6.5.6.5 | DTN Test Stubs | 10d | 2024-09-16 A | 2024-09-27 A | 2335 | 100% | 2024-09-16 | 2024-09-27 | 0d | start no earlier than 2024-09-16 | Non-SIT S&A QT Test Team | S&A Qualification |  | 6.15 | Laura Kennedy | Complete | COMPLETE |

| ID | WBS | Task | Duration | Start | Finish | Predecessors | Complete | Remaining | Actual finish | Baseline start | Baseline finish | Baseline duration | Constraint | Responsible | Text9 | Task Status | Update Version | MHHS Resource Name | Sched Status | RAG |
| --- | --- | --- | --- | --- | --- | --- | --- | --- | --- | --- | --- | --- | --- | --- | --- | --- | --- | --- | --- | --- |
| 2338 | 1.7.4.1.6.5.7 | **Generate Tooling** | 334d | 2024-04-22 A | 2025-07-31 |  | 100% |  | 2024-09-24 | 2024-04-22 | 2025-07-31 | 0d |  | Non-SIT S&A QT Test Team | S&A Qualification | -742.67 | 6.15 | Laura Kennedy |  |  |
| 2339 | 1.7.4.1.6.5.7.1 | MPAN Core Generator | 25d | 2024-04-22 A | 2024-05-24 A |  | 100% |  |  | 2024-04-22 | 2024-05-24 | 0d | finish no earlier than 2024-05-24 | Non-SIT S&A QT Test Team | S&A Qualification |  | 6.15 | Laura Kennedy | Complete | COMPLETE |
| 2340 | 1.7.4.1.6.5.7.2 | MPAN File Generator | 55d | 2024-05-27 A | 2024-08-09 A | 2339 | 100% |  |  | 2024-05-27 | 2024-08-09 | 0d | finish no earlier than 2024-08-09 | Non-SIT S&A QT Test Team | S&A Qualification |  | 6.15 | Laura Kennedy | Complete | COMPLETE |
| 2341 | 1.7.4.1.6.5.7.3 | MPAN Template Loader | 32d | 2024-08-12 A | 2024-09-24 A | 2340 | 100% |  |  | 2024-08-12 | 2024-09-24 | 0d | finish no earlier than 2024-09-24 | Non-SIT S&A QT Test Team | S&A Qualification |  | 6.15 | Laura Kennedy | Complete | COMPLETE |
| 2342 | 1.7.4.1.6.5.7.4 | ADO Extract (QTC) From SIT | 30d | 2024-05-06 A | 2024-06-14 A |  | 100% |  |  | 2024-05-06 | 2024-06-14 | 0d | finish no earlier than 2024-06-14 | Non-SIT S&A QT Test Team | S&A Qualification |  | 6.15 | Laura Kennedy | Complete | COMPLETE |
| 2343 | 1.7.4.1.6.5.7.5 | Populate QT ADO | 40d | 2024-06-17 A | 2024-08-09 A | 2342 | 100% |  |  | 2024-06-17 | 2024-08-09 | 0d | finish no earlier than 2024-08-09 | Non-SIT S&A QT Test Team | S&A Qualification |  | 6.15 | Laura Kennedy | Complete | COMPLETE |
| 2344 | 1.7.4.1.6.5.7.6 | Create QTC Spreadsheets | 20d | 2024-06-03 A | 2024-06-28 A | 2342 | 100% |  |  | 2024-06-03 | 2024-06-28 | 0d | finish no earlier than 2024-06-28 | Non-SIT S&A QT Test Team | S&A Qualification |  | 6.15 | Laura Kennedy | Complete | COMPLETE |
| 2345 | 1.7.4.1.6.5.7.7 | Upload QTC Spreadsheets to QTF | 20d | 2024-07-01 A | 2024-07-26 A | 2344 | 100% |  |  | 2024-07-01 | 2024-07-26 | 0d | finish no earlier than 2024-07-26 | Non-SIT S&A QT Test Team | S&A Qualification |  | 6.15 | Laura Kennedy | Complete | COMPLETE |
| 2346 | 1.7.4.1.6.5.7.8 | Create QTC Set / Master QTC Loader | 40d | 2024-07-22 A | 2024-09-13 A | 2345 | 100% |  |  | 2024-07-22 | 2024-09-13 | 0d | finish no earlier than 2024-09-13 | Non-SIT S&A QT Test Team | S&A Qualification |  | 6.15 | Laura Kennedy | Complete | COMPLETE |
| 2347 | 1.7.4.1.6.5.8 | **Test Data** | 15d | 2024-06-10 A | 2024-06-28 A |  | 100% |  |  | 2024-06-10 | 2024-06-28 | 0d |  | Non-SIT S&A QT Test Team | S&A Qualification | -742.67 | 6.12 | Laura Kennedy |  |  |
| 2348 | 1.7.4.1.6.5.8.1 | Sample MPAN Data + Attributes from Suppliers | 15d | 2024-06-10 A | 2024-06-28 A |  | 100% |  |  | 2024-06-10 | 2024-06-28 | 0d | finish no earlier than 2024-06-28 | Non-SIT S&A QT Test Team | S&A Qualification |  | 6.12 | Laura Kennedy | Complete | COMPLETE |
| 2349 | 1.7.4.1.6.6 | **MPANs, DIP Messages, Settlement, Consumption, Reference** | 423d? | 2024-05-27 A | 2026-01-07 |  | 81% | 79.72d? |  | 2024-05-27 | 2026-01-07 | 0d |  | Non-SIT S&A QT Test Team | S&A Qualification | -742.67 | 6.12 | Laura Kennedy |  |  |
| 2350 | 1.7.4.1.6.6.1 | Create MPAN Data | 55d | 2024-05-27 A | 2024-08-09 A | 2339 | 100% |  |  | 2024-05-27 | 2024-08-09 | 0d | finish no earlier than 2024-08-09 | Non-SIT S&A QT Test Team | S&A Qualification |  | 6.12 | Laura Kennedy | Complete | COMPLETE |
| 2351 | 1.7.4.1.6.6.2 | Create message templates (DIP, CSS, DTN) | 40d | 2024-06-03 A | 2024-07-26 A |  | 100% |  |  | 2024-06-03 | 2024-07-26 | 0d | finish no earlier than 2024-07-26 | Non-SIT S&A QT Test Team | S&A Qualification |  | 6.12 | Laura Kennedy | Complete | COMPLETE |
| 2352 | 1.7.4.1.6.6.3 | Create Consumption Data Templates | 20d | 2024-09-16 A | 2024-10-11 A |  | 100% |  |  | 2024-09-16 | 2024-10-11 | 0d | finish no earlier than 2024-10-11 | Non-SIT S&A QT Test Team | S&A Qualification |  | 6.12 | Laura Kennedy | Complete | COMPLETE |
| 2353 | 1.7.4.1.6.6.4 | Load Consumption Data | 25d | 2024-11-11 A | 2024-12-13 A | 2352FS+20d | 100% |  |  | 2024-11-11 | 2024-12-06 | 0d |  | Non-SIT S&A QT Test Team | S&A Qualification |  | 6.12 | Laura Kennedy | Complete | COMPLETE |
| 2354 | 1.7.4.1.6.6.5 | Create Load Shape and Load Shape Total Templates | 20d | 2024-09-16 A | 2024-10-11 A |  | 100% |  |  | 2024-09-16 | 2024-10-11 | 0d | finish no earlier than 2024-10-11 | Non-SIT S&A QT Test Team | S&A Qualification |  | 6.12 | Laura Kennedy | Complete | COMPLETE |
| 2355 | 1.7.4.1.6.6.6 | Load Shape and Load Shape Total Data | 25d | 2024-11-11 A | 2024-12-13 A | 2354FS+20d | 100% |  |  | 2024-11-11 | 2024-12-06 | 0d |  | Non-SIT S&A QT Test Team | S&A Qualification |  | 6.12 | Laura Kennedy | Complete | COMPLETE |
| 2356 | 1.7.4.1.6.6.7 | Create Settlement Report Templates | 20d | 2024-09-16 A | 2024-10-11 A |  | 100% |  |  | 2024-09-16 | 2024-10-11 | 0d | finish no earlier than 2024-10-11 | Non-SIT S&A QT Test Team | S&A Qualification |  | 6.12 | Laura Kennedy | Complete | COMPLETE |
| 2357 | 1.7.4.1.6.6.8 | Load Settlement Report Data | 25d | 2024-11-11 A | 2024-12-13 A | 2356FS+20d | 100% |  |  | 2024-11-11 | 2024-12-06 | 0d |  | Non-SIT S&A QT Test Team | S&A Qualification |  | 6.12 | Laura Kennedy | Complete | COMPLETE |
| 2358 | 1.7.4.1.6.6.9 | Market Domain Data (MDD) For Legacy Systems | 25d | 2024-07-29 A | 2024-08-30 A |  | 100% |  |  | 2024-07-29 | 2024-08-30 | 0d | finish no earlier than 2024-08-30 | Non-SIT S&A QT Test Team | S&A Qualification |  | 6.12 | Laura Kennedy | Complete | COMPLETE |
| 2359 | 1.7.4.1.6.6.10 | **Industry Standing Data (ISD)** | 71d? | 2024-07-26 A | 2024-11-01 A |  | 100% |  |  | 2024-07-26 | 2024-11-01 | 0d |  | Non-SIT S&A QT Test Team | S&A Qualification | -742.67 | 6.12 | Laura Kennedy |  |  |
| 2360 | 1.7.4.1.6.6.10.1 | Dependant on Receiving ISD Agreed Source Data from Helix | 1d | 2024-07-26 A | 2024-07-26 A |  | 100% |  |  | 2024-07-26 | 2024-07-26 | 0d | start no earlier than 2024-07-26 | Non-SIT S&A QT Test Team | S&A Qualification |  | 6.12 | Laura Kennedy | Complete | COMPLETE |
| 2361 | 1.7.4.1.6.6.10.2 | Helix Dev Environment migration | 6d | 2024-07-29 A | 2024-08-05 A | 2360 | 100% |  |  | 2024-07-29 | 2024-08-05 | 0d | finish no earlier than 2024-08-05 | Non-SIT S&A QT Test Team | S&A Qualification |  | 6.12 | Laura Kennedy | Complete | COMPLETE |
| 2362 | 1.7.4.1.6.6.10.3 | STGi (UK) migration | 5d | 2024-09-09 A | 2024-09-13 A | 2360 | 100% |  |  | 2024-09-09 | 2024-09-13 | 0d | finish no earlier than 2024-09-13 | Non-SIT S&A QT Test Team | S&A Qualification |  | 6.12 | Laura Kennedy | Complete | COMPLETE |
| 2363 | 1.7.4.1.6.6.10.4 | Maintenance window between cycle 2 and 3 | 1d | 2024-09-20 A | 2024-09-20 A | 2360 | 100% |  |  | 2024-09-20 | 2024-09-20 | 0d | finish no earlier than 2024-09-20 | Non-SIT S&A QT Test Team | S&A Qualification |  | 6.12 | Laura Kennedy | Complete | COMPLETE |
| 2364 | 1.7.4.1.6.6.10.5 | First View of Migrated ISD Data | 5d | 2024-09-23 A | 2024-09-27 A | 2363 | 100% |  |  | 2024-09-23 | 2024-09-27 | 0d | finish no earlier than 2024-09-27 | Non-SIT S&A QT Test Team | S&A Qualification |  | 6.12 | Laura Kennedy | Complete | COMPLETE |
| 2365 | 1.7.4.1.6.6.10.6 | Second View of Migrated ISD Data (HXT1 (SIT B) migration) | 5d | 2024-09-23 A | 2024-09-27 A | 2363 | 100% |  |  | 2024-09-23 | 2024-09-27 | 0d | finish no earlier than 2024-09-27 | Non-SIT S&A QT Test Team | S&A Qualification |  | 6.12 | Laura Kennedy | Complete | COMPLETE |
| 2366 | 1.7.4.1.6.6.10.7 | Final Cycle 3 Migrated ISD Data | 5d | 2024-10-07 A | 2024-10-11 A | 2364 | 100% |  |  | 2024-10-07 | 2024-10-11 | 0d | finish no earlier than 2024-10-11 | Non-SIT S&A QT Test Team | S&A Qualification |  | 6.12 | Laura Kennedy | Complete | COMPLETE |
| 2367 | 1.7.4.1.6.6.10.8 | Create ISD Template inc. DIP ID | 35d? | 2024-09-16 A | 2024-11-01 A | 2363 | 100% |  |  | 2024-09-16 | 2024-11-01 | 0d | finish no earlier than 2024-11-01 | Non-SIT S&A QT Test Team | S&A Qualification |  | 6.12 | Laura Kennedy | Complete | COMPLETE |
| 2368 | 1.7.4.1.6.6.10.9 | Publish Qualification ISD | 10d? | 2024-10-14 A | 2024-10-25 A | 2366, 2363 | 100% |  |  | 2024-10-14 | 2024-10-25 | 0d | finish no earlier than 2024-10-25 | Non-SIT S&A QT Test Team | S&A Qualification |  | 6.12 | Laura Kennedy | Complete | COMPLETE |

| ID | WBS | Task | Duration | Start | Finish | Predecessors | Complete | Actual finish | Baseline start | Baseline finish | Baseline duration | Total slack | Free slack | Constraint | Responsible | Text9 | Task Status | Update Version | MHHS Resource Name | Sched Status | RAG |
| --- | --- | --- | --- | --- | --- | --- | --- | --- | --- | --- | --- | --- | --- | --- | --- | --- | --- | --- | --- | --- | --- |
| 2369 | 1.7.4.1.6.6.11 | **BETA Testing 1 - Test Data** | 27d | 2024-11-01 A | 2024-12-09 |  | 100% | 2025-01-22 | 2024-11-01 | 2024-11-15 | 0d |  |  |  | Non-SIT S&A QT Test Team | S&A Qualification | -169.67 | 6.12 | Laura Kennedy |  |  |
| 2370 | 1.7.4.1.6.6.11.1 | Provide Example MPAN File | 3d | 2024-11-01 A | 2024-11-05 A | 2413SS | 100% |  | 2024-11-01 | 2024-11-05 | 0d |  |  | finish no earlier than 2024-11-05 | Non-SIT S&A QT Test Team | S&A Qualification |  | 6.12 | Laura Kennedy | Complete | COMPLETE |
| 2371 | 1.7.4.1.6.6.11.2 | Load Example MPAN File | 6d | 2024-11-06 A | 2024-11-13 A | 2370 | 100% |  | 2024-11-06 | 2024-11-13 | 0d |  |  | finish no earlier than 2024-11-13 | Non-SIT S&A QT Test Team | S&A Qualification |  | 6.12 | Laura Kennedy | Complete | COMPLETE |
| 2372 | 1.7.4.1.6.6.11.3 | Industry Standing Data (ISD) | 6d | 2024-11-06 A | 2024-11-13 A | 2413SS+3d | 100% |  | 2024-11-06 | 2024-11-13 | 0d |  |  | finish no earlier than 2024-11-13 | Non-SIT S&A QT Test Team | S&A Qualification |  | 6.12 | Laura Kennedy | Complete | COMPLETE |
| 2373 | 1.7.4.1.6.6.11.4 | Market Domain Data (MDD) | 6d | 2024-11-06 A | 2024-11-13 A | 2413SS+3d | 100% |  | 2024-11-06 | 2024-11-13 | 0d |  |  | finish no earlier than 2024-11-13 | Non-SIT S&A QT Test Team | S&A Qualification |  | 6.12 | Laura Kennedy | Complete | COMPLETE |
| 2374 | 1.7.4.1.6.6.11.5 | Load ISD / MDD Data | 1d | 2024-12-06 A | 2024-12-06 A | 2372FS+16d, 2373FS+11d | 100% |  | 2024-11-14 | 2024-11-14 | 0d |  |  | start no earlier than 2024-11-14 | Non-SIT S&A QT Test Team | S&A Qualification |  | 6.12 | Laura Kennedy | Complete | COMPLETE |
| 2375 | 1.7.4.1.6.6.11.6 | Create QTC sets and Test MPANs via QTF | 1d | 2024-12-06 A | 2024-12-06 A | 2371FS+16d | 100% |  | 2024-11-14 | 2024-11-14 | 0d |  |  | start no earlier than 2024-11-14 | Non-SIT S&A QT Test Team | S&A Qualification |  | 6.12 | Laura Kennedy | Complete | COMPLETE |
| 2376 | 1.7.4.1.6.6.11.7 | Create QTC sets in ADO via QTF | 1d | 2024-12-06 A | 2024-12-06 A | 2375SS | 100% |  | 2024-11-14 | 2024-11-14 | 0d |  |  | start no earlier than 2024-11-14 | Non-SIT S&A QT Test Team | S&A Qualification |  | 6.12 | Laura Kennedy | Complete | COMPLETE |
| 2377 | 1.7.4.1.6.6.11.8 | Provide Test MPANs (Suppliers only) allocated to specfic QTC's | 1d | 2024-12-06 A | 2024-12-06 A | 2374SS | 100% |  | 2024-11-14 | 2024-11-14 | 0d |  |  | start no earlier than 2024-11-14 | Non-SIT S&A QT Test Team | S&A Qualification |  | 6.12 | Laura Kennedy | Complete | COMPLETE |
| 2378 | 1.7.4.1.6.6.11.9 | Load Test MPANs | 1d | 2024-12-09 A | 2024-12-09 A | 2377 | 100% |  | 2024-11-15 | 2024-11-15 | 0d |  |  | start no earlier than 2024-11-15 | Non-SIT S&A QT Test Team | S&A Qualification |  | 6.12 | Laura Kennedy | Complete | COMPLETE |
| 2379 | 1.7.4.1.6.6.11.10 | **BETA Testing 2 - Test Data** | 11d | 2025-01-08 A | 2025-01-22 A |  | 100% |  | 2025-01-08 | 2025-01-22 | 0d |  |  |  | Non-SIT S&A QT Test Team | S&A Qualification | -169.67 | 6.15 | Laura Kennedy | green |  |
| 2380 | 1.7.4.1.6.6.11.10.1 | Provide Example MPAN File | 3d | 2025-01-08 A | 2025-01-10 A | 2414SS | 100% |  | 2025-01-08 | 2025-01-10 | 0d |  |  | start no earlier than 2025-01-08 | Non-SIT S&A QT Test Team | S&A Qualification |  | 6.15 | Laura Kennedy | Complete | COMPLETE |
| 2381 | 1.7.4.1.6.6.11.10.2 | Load Example MPAN File | 6d | 2025-01-13 A | 2025-01-20 A | 2380 | 100% |  | 2025-01-13 | 2025-01-20 | 0d |  |  | start no earlier than 2025-01-13 | Non-SIT S&A QT Test Team | S&A Qualification |  | 6.15 | Laura Kennedy | Complete | COMPLETE |
| 2382 | 1.7.4.1.6.6.11.10.3 | Industry Standing Data (ISD) | 6d | 2025-01-08 A | 2025-01-15 A | 2368, 2414SS | 100% |  | 2025-01-08 | 2025-01-15 | 0d |  |  | start no earlier than 2025-01-08 | Non-SIT S&A QT Test Team | S&A Qualification |  | 6.15 | Laura Kennedy | Complete | COMPLETE |
| 2383 | 1.7.4.1.6.6.11.10.4 | Market Domain Data (MDD) | 6d | 2025-01-08 A | 2025-01-15 A | 2352, 2414SS | 100% |  | 2025-01-08 | 2025-01-15 | 0d |  |  | start no earlier than 2025-01-08 | Non-SIT S&A QT Test Team | S&A Qualification |  | 6.15 | Laura Kennedy | Complete | COMPLETE |
| 2384 | 1.7.4.1.6.6.11.10.5 | Load ISD / MDD Data | 1d | 2025-01-16 A | 2025-01-16 A | 2382, 2383, 2414SS | 100% |  | 2025-01-16 | 2025-01-16 | 0d |  |  | start no earlier than 2025-01-16 | Non-SIT S&A QT Test Team | S&A Qualification |  | 6.15 | Laura Kennedy | Complete | COMPLETE |
| 2385 | 1.7.4.1.6.6.11.10.6 | Create QTC sets and Test MPANs via QTF | 1d | 2025-01-21 A | 2025-01-21 A | 2381 | 100% |  | 2025-01-21 | 2025-01-21 | 0d |  |  | start no earlier than 2025-01-21 | Non-SIT S&A QT Test Team | S&A Qualification |  | 6.15 | Laura Kennedy | Complete | COMPLETE |
| 2386 | 1.7.4.1.6.6.11.10.7 | Create QTC sets in ADO via QTF | 1d | 2025-01-21 A | 2025-01-21 A | 2385SS | 100% |  | 2025-01-21 | 2025-01-21 | 0d |  |  | start no earlier than 2025-01-21 | Non-SIT S&A QT Test Team | S&A Qualification |  | 6.15 | Laura Kennedy | Complete | COMPLETE |
| 2387 | 1.7.4.1.6.6.11.10.8 | Provide Test MPANs (Suppliers only) allocated to specfic QTC's | 1d | 2025-01-21 A | 2025-01-21 A | 2385SS | 100% |  | 2025-01-21 | 2025-01-21 | 0d |  |  | start no earlier than 2025-01-21 | Non-SIT S&A QT Test Team | S&A Qualification |  | 6.15 | Laura Kennedy | Complete | COMPLETE |
| 2388 | 1.7.4.1.6.6.11.10.9 | Load Test MPANs | 1d | 2025-01-22 A | 2025-01-22 A | 2387 | 100% |  | 2025-01-22 | 2025-01-22 | 0d |  |  | start no earlier than 2025-01-22 | Non-SIT S&A QT Test Team | S&A Qualification |  | 6.15 | Laura Kennedy | Complete | COMPLETE |
| 2389 | 1.7.4.1.6.6.12 | **Wave 1 Test Data** | 46d | 2025-05-12 | 2025-07-15 | 2375SS |  |  | 2025-05-12 | 2025-07-15 | 0d |  |  |  | Non-SIT S&A QT Test Team | S&A Qualification | -168.67 | 6.18 | Laura Kennedy |  |  |
| 2390 | 1.7.4.1.6.6.12.1 | Test Data Request + Templates Completed | 5d | 2025-06-02 | 2025-06-06 | 2374SS |  |  | 2025-06-02 | 2025-06-06 | 0d | 440d | 0d | start no earlier than 2025-06-02 | Non-SIT S&A QT Test Team | S&A Qualification | 26.33 | 6.18 | Laura Kennedy | Green | GREEN |
| 2391 | 1.7.4.1.6.6.12.2 | Test Data Generated | 5d | 2025-06-09 | 2025-06-13 | 2377, 2390 |  |  | 2025-06-09 | 2025-06-13 | 0d | 440d | 0d | finish no earlier than 2025-06-03 | Non-SIT S&A QT Test Team | S&A Qualification | 33.33 | 6.18 | Laura Kennedy | Green | GREEN |
| 2392 | 1.7.4.1.6.6.12.3 | Test Data Loaded into QP Systems | 15d | 2025-06-16 | 2025-07-04 | 2391 |  |  | 2025-06-16 | 2025-07-04 | 0d | 440d | 0d | finish no earlier than 2025-06-17 | Non-SIT S&A QT Test Team | S&A Qualification | 40.33 | 6.18 | Laura Kennedy | Green | GREEN |
| 2393 | 1.7.4.1.6.6.12.4 | Test Data Loaded into QTF + ADO | 15d | 2025-07-07 | 2025-07-25 | 2391, 2392 |  |  | 2025-07-07 | 2025-07-25 | 0d | 440d | 21d | finish no earlier than 2025-06-17 | Non-SIT S&A QT Test Team | S&A Qualification | 61.33 | 6.18 | Laura Kennedy | Green | GREEN |

| ID | WBS | Task | Type | Duration | Start | Finish | Predecessors | Complete | Baseline start | Baseline finish | Baseline duration | Total slack | Free slack | Constraint | Baseline cost | Responsible | Text9 | Task Status | Update Version | MHHS Resource Name | Sched Status | RAG | Milestone ID | Text29 | Tier | Involved |
| --- | --- | --- | --- | --- | --- | --- | --- | --- | --- | --- | --- | --- | --- | --- | --- | --- | --- | --- | --- | --- | --- | --- | --- | --- | --- | --- |
| 2394 | 1.7.4.1.6.6.13 | **Wave 2 Test Data** |  | 42d | 2025-07-07 | 2025-09-03 |  |  | 2025-07-07 | 2025-09-03 | 0d |  |  |  |  | Non-SIT S&A QT Test Team | S&A Qualification | -168.67 | 6.18 | Laura Kennedy |  |  |  |  |  |  |
| 2395 | 1.7.4.1.6.6.13.1 | Test Data Request + Templates Completed |  | 5d | 2025-07-28 | 2025-08-01 |  |  | 2025-07-28 | 2025-08-01 | 0d | 407d | 0d | start no earlier than 2025-07-28 |  | Non-SIT S&A QT Test Team | S&A Qualification | 82.33 | 6.18 | Laura Kennedy | Green | GREEN |  |  |  |  |
| 2396 | 1.7.4.1.6.6.13.2 | Test Data Generated |  | 5d | 2025-08-04 | 2025-08-08 | 2395 |  | 2025-08-04 | 2025-08-08 | 0d | 407d | 0d | finish no earlier than 2025-07-29 |  | Non-SIT S&A QT Test Team | S&A Qualification | 89.33 | 6.18 | Laura Kennedy | Green | GREEN |  |  |  |  |
| 2397 | 1.7.4.1.6.6.13.3 | Test Data Loaded into QP Systems |  | 15d | 2025-08-11 | 2025-08-29 | 2396 |  | 2025-08-11 | 2025-08-29 | 0d | 407d | 0d | finish no earlier than 2025-08-12 |  | Non-SIT S&A QT Test Team | S&A Qualification | 96.33 | 6.18 | Laura Kennedy | Green | GREEN |  |  |  |  |
| 2398 | 1.7.4.1.6.6.13.4 | Test Data Loaded into QTF + ADO |  | 15d | 2025-09-01 | 2025-09-19 | 2396, 2397 |  | 2025-09-01 | 2025-09-19 | 0d | 407d | 21d | finish no earlier than 2025-08-12 |  | Non-SIT S&A QT Test Team | S&A Qualification | 117.33 | 6.18 | Laura Kennedy | Green | GREEN |  |  |  |  |
| 2399 | 1.7.4.1.6.6.14 | **Wave 3 Test Data** |  | 45d | 2025-09-08 | 2025-11-10 |  |  | 2025-09-08 | 2025-11-10 | 0d |  |  |  |  | Non-SIT S&A QT Test Team | S&A Qualification | -168.67 | 6.18 | Laura Kennedy |  |  |  |  |  |  |
| 2400 | 1.7.4.1.6.6.14.1 | Test Data Request + Templates Completed |  | 5d | 2025-10-20 | 2025-10-24 |  |  | 2025-10-20 | 2025-10-24 | 0d | 376d | 0d | start no earlier than 2025-10-20 |  | Non-SIT S&A QT Test Team | S&A Qualification | 166.33 | 6.18 | Laura Kennedy | Green | GREEN |  |  |  |  |
| 2401 | 1.7.4.1.6.6.14.2 | Test Data Generated |  | 5d | 2025-10-27 | 2025-10-31 | 2400 |  | 2025-10-27 | 2025-10-31 | 0d | 376d | 0d | finish no earlier than 2025-09-29 |  | Non-SIT S&A QT Test Team | S&A Qualification | 173.33 | 6.18 | Laura Kennedy | Green | GREEN |  |  |  |  |
| 2402 | 1.7.4.1.6.6.14.3 | Test Data Loaded into QP Systems |  | 15d | 2025-11-03 | 2025-11-21 | 2401 |  | 2025-11-03 | 2025-11-21 | 0d | 376d | 0d | finish no earlier than 2025-10-13 |  | Non-SIT S&A QT Test Team | S&A Qualification | 180.33 | 6.18 | Laura Kennedy | Green | GREEN |  |  |  |  |
| 2403 | 1.7.4.1.6.6.14.4 | Test Data Loaded into QTF + ADO |  | 15d | 2025-11-24 | 2025-12-12 | 2401, 2402 |  | 2025-11-24 | 2025-12-12 | 0d | 376d | 21d | finish no earlier than 2025-10-13 |  | Non-SIT S&A QT Test Team | S&A Qualification | 201.33 | 6.18 | Laura Kennedy | Green | GREEN |  |  |  |  |
| 2404 | 1.7.4.1.6.6.15 | **Wave 4 Test Data** |  | 45d | 2025-11-06 | 2026-01-08 |  |  | 2025-11-06 | 2026-01-08 | 0d |  |  |  |  | Non-SIT S&A QT Test Team | S&A Qualification | -168.67 | 6.18 | Laura Kennedy |  |  |  |  |  |  |
| 2405 | 1.7.4.1.6.6.15.1 | Test Data Request + Templates Completed |  | 5d | 2025-12-15 | 2025-12-19 |  |  | 2025-12-15 | 2025-12-19 | 0d | 256d | 0d | start no earlier than 2025-12-15 |  | Non-SIT S&A QT Test Team | S&A Qualification | 222.33 | 6.18 | Laura Kennedy | Green | GREEN |  |  |  |  |
| 2406 | 1.7.4.1.6.6.15.2 | Test Data Generated |  | 5d | 2025-12-22 | 2025-12-26 | 2405 |  | 2025-12-22 | 2025-12-26 | 0d | 256d | 0d | finish no earlier than 2025-11-27 |  | Non-SIT S&A QT Test Team | S&A Qualification | 229.33 | 6.18 | Laura Kennedy | Green | GREEN |  |  |  |  |
| 2407 | 1.7.4.1.6.6.15.3 | Test Data Loaded into QP Systems |  | 15d | 2025-12-29 | 2026-01-16 | 2406 |  | 2025-12-29 | 2026-01-16 | 0d | 256d | 0d | finish no earlier than 2025-12-11 |  | Non-SIT S&A QT Test Team | S&A Qualification | 236.33 | 6.18 | Laura Kennedy | Green | GREEN |  |  |  |  |
| 2408 | 1.7.4.1.6.6.15.4 | Test Data Loaded into QTF + ADO |  | 15d | 2026-01-19 | 2026-02-06 | 2406, 2407 |  | 2026-01-19 | 2026-02-06 | 0d | 256d | 21d | finish no earlier than 2025-12-11 |  | Non-SIT S&A QT Test Team | S&A Qualification | 257.33 | 6.18 | Laura Kennedy | Green | GREEN |  |  |  |  |
| 2409 | 1.7.4.1.6.6.16 | **Governance** |  | 195d | 2024-07-01 A | 2025-03-28 A |  | 100% | 2024-07-01 | 2024-12-20 | 0d |  |  |  |  | Non-SIT S&A QT Test Team | S&A Qualification | -168.67 | 6.12 | Laura Kennedy |  |  |  |  |  |  |
| 2410 | 1.7.4.1.6.6.16.1 | Onboarding Strategy and Develop Training Requirements & Materials Inc. Day in the Life |  | 120d | 2024-07-01 A | 2024-12-13 A | 2288 | 100% | 2024-07-01 | 2024-11-29 | 0d |  |  | finish no earlier than 2024-12-13 |  | Non-SIT S&A QT Test Team | S&A Qualification |  | 6.12 | Laura Kennedy | Complete | COMPLETE |  |  |  |  |
| 2411 | 1.7.4.1.6.6.16.2 | Design Approach & Set-Up ADO Tool for Test & Defect Management Tool |  | 20d | 2024-07-01 A | 2024-07-26 A | 2410SS | 100% | 2024-07-01 | 2024-07-26 | 0d |  |  |  |  | Non-SIT S&A QT Test Team | S&A Qualification |  | 6.12 | Laura Kennedy | Complete | COMPLETE |  |  |  |  |
| 2412 | 1.7.4.1.6.6.16.3 | Knowledge Transfer, Training, Demonstrations, Documentation, Governance |  | 78d | 2024-08-30 A | 2024-12-17 A | 2410SS+44d | 100% | 2024-08-30 | 2024-12-17 | 0d |  |  |  |  | Non-SIT S&A QT Test Team | S&A Qualification |  | 6.12 | Laura Kennedy | Complete | COMPLETE |  |  |  |  |
| 2413 | 1.7.4.1.6.6.16.4 | BETA Testing |  | 33d | 2024-11-01 A | 2024-12-17 A |  | 100% | 2024-11-01 | 2024-12-20 | 0d |  |  | finish no earlier than 2024-12-17 |  | Non-SIT S&A QT Test Team | S&A Qualification |  | 6.12 | Laura Kennedy | Complete | COMPLETE |  |  |  |  |
| 2414 | 1.7.4.1.6.6.16.5 | BETA Testing 2 |  | 58d | 2025-01-08 A | 2025-03-28 A | 2413 | 100% | 2025-01-08 | 2025-03-28 | 0d |  |  | start no earlier than 2025-01-08 |  | Non-SIT S&A QT Test Team | S&A Qualification |  | 6.13 | Laura Kennedy | Complete | COMPLETE |  |  |  |  |
| 2415 | 1.7.4.1.6.6.17 | Qualification Testing Framework Readiness Confirmed | milestone | 0d | 2025-03-28 A | 2025-03-28 A | 2414 | 100% | 2025-03-28 | 2025-03-28 | 0d |  |  | start no earlier than 2025-03-28 |  | Non-SIT S&A QT Test Team | S&A Qualification |  | 6.12 | Laura Kennedy | Complete | COMPLETE |  |  |  |  |
| 2416 | 1.7.4.1.6.6.18 | Qualification Testing Wave Readiness Confirmed | milestone | 0d | 2025-08-21 | 2025-08-21 | 2444FS-2d |  | 2025-08-21 | 2025-08-21 | 0d | 611d |  | finish no earlier than 2025-05-30 |  | Non-SIT S&A QT Test Team | S&A Qualification | 106.33 | 6.13 | Laura Kennedy | Green | GREEN | T2-QU-1100 | QAG | T2 |  |
| 2417 | 1.7.4.1.7 | **Wave Allocation** |  | 129d | 2024-01-02 A | 2024-06-28 A |  | 100% | 2024-01-02 | 2024-06-28 | 128d |  |  |  | -0 | N/A | S&A Qualification | -133.67 | 5.24 | N/A |  |  |  |  |  | N/A |
| 2418 | 1.7.4.1.7.1 | Draft Pre-Qualification Submission (PQS) document |  | 20d | 2024-01-02 A | 2024-01-29 A |  | 100% | 2024-01-02 | 2024-01-29 | 20d |  |  | finish no earlier than 2024-01-26 |  | Code Bodies | S&A Qualification |  | 5.24 | Laura Kennedy | Complete | COMPLETE |  |  |  | Code Bodies |
| 2419 | 1.7.4.1.7.2 | Publish PQS document |  | 1d | 2024-01-31 A | 2024-01-31 A |  | 100% | 2024-01-31 | 2024-01-31 | 1d |  |  | start no earlier than 2024-01-31 |  | Code Bodies | S&A Qualification |  | 5.24 | Laura Kennedy | Complete | COMPLETE |  |  |  | Code Bodies |
| 2420 | 1.7.4.1.7.3 | PQS Submission window |  | 60d | 2024-02-05 A | 2024-04-26 A |  | 100% | 2024-02-05 | 2024-04-26 | 60d |  |  | start no earlier than 2024-02-05 |  | Participants | S&A Qualification |  | 5.24 | Laura Kennedy | Complete | COMPLETE |  |  |  | Participants |
| 2421 | 1.7.4.1.7.4 | Pre-Qualification Submission and PIT Test Plan Deadline for Submission​ | milestone | 0d | 2024-04-26 A | 2024-04-26 A | 2420 | 100% | 2024-04-26 | 2024-04-26 | 0d |  |  |  |  | Participants | S&A Qualification |  | 5.25 | Laura Kennedy | Complete | COMPLETE | T3-QU-0118 | QAG | T3 | Participants |
| 2422 | 1.7.4.1.7.5 | PQS Review by Code Bodies |  | 25d | 2024-04-29 A | 2024-05-31 A | 2420, 2421 | 100% | 2024-04-29 | 2024-05-31 | 25d |  |  |  |  | Code Bodies | S&A Qualification |  | 5.24 | Laura Kennedy | Complete | COMPLETE |  |  |  | Code Bodies |
| 2423 | 1.7.4.1.7.6 | Draft Wave Allocations |  | 15d | 2024-06-03 A | 2024-06-21 A | 2422 | 100% | 2024-06-03 | 2024-06-21 | 15d |  |  |  |  | Code Bodies | S&A Qualification |  | 5.24 | Laura Kennedy | Complete | COMPLETE |  |  |  | Code Bodies |
| 2424 | 1.7.4.1.7.7 | Confirmation of participant Qualification Wave allocation | milestone | 0d | 2024-06-28 A | 2024-06-28 A | 2423FS+5d | 100% | 2024-06-28 | 2024-06-28 | 0d |  |  |  |  | Code Bodies | S&A Qualification |  | 5.28 | Laura Kennedy | Complete | COMPLETE | T3-QU-0012 | QAG | T3 | Code Bodies |

| ID | WBS | Task | Type | Duration | Start | Finish | Predecessors | Baseline start | Baseline finish | Baseline duration | Total slack | Free slack | Constraint | Baseline cost | Responsible | Involved | Text9 | Task Status | Update Version | MHHS Resource Name | Sched Status | RAG | Milestone ID | Text29 | Tier |
| --- | --- | --- | --- | --- | --- | --- | --- | --- | --- | --- | --- | --- | --- | --- | --- | --- | --- | --- | --- | --- | --- | --- | --- | --- | --- |
| 2425 | 1.7.4.2 | **Qualification Wave 1** |  | 248d | 2025-05-05 | 2026-04-15 |  | 2025-03-24 | 2026-04-10 | 229d | 419d |  |  | -0 | N/A | N/A | S&A Qualification | -133.67 | 6.13 | N/A |  |  |  |  |  |
| 2426 | 1.7.4.2.1 | **Qualification Wave 1 QAD Prep** |  | 80d | 2025-05-05 | 2025-08-22 |  | 2025-03-24 | 2025-07-11 | 80d | 420d |  |  | -0 | N/A | N/A | S&A Qualification | -152.67 | 6.13 | N/A |  |  |  |  |  |
| 2427 | 1.7.4.2.1.1 | Initial QAD Submission window opens | milestone | 0d | 2025-05-05 | 2025-05-05 | 2424, 2189FS+1d | 2025-05-05 | 2025-05-05 | 0d | 420d | 0d | start no earlier than 2025-03-24 |  | Participants | Participants | S&A Qualification | -1.29 | 6.13 | Laura Kennedy | Overdue Start | RED |  |  |  |
| 2428 | 1.7.4.2.1.2 | Qualification Wave 1 Participants Submit Initial QAD |  | 50d | 2025-05-05 | 2025-07-11 | 2427FS-1d | 2025-05-05 | 2025-07-11 | 50d | 420d | 0d |  |  | Participants | Participants | S&A Qualification | -1.67 | 6.13 | Laura Kennedy | Overdue Start | GREEN |  |  |  |
| 2429 | 1.7.4.2.1.3 | Qualification Wave 1 Participants have submitted their initial QAD | milestone | 0d | 2025-07-14 | 2025-07-14 | 2428FS+1d | 2025-07-14 | 2025-07-14 | 0d | 420d | 0d |  |  | Participants | Participants | S&A Qualification | 68.71 | 6.13 | Laura Kennedy | Green | GREEN | T3-QU-0094 | QAG | T3 |
| 2430 | 1.7.4.2.1.4 | Code Bodies review of Wave 1 Participants Initial QAD |  | 30d | 2025-07-14 | 2025-08-22 | 2428FS-1d, 2429FS-1d | 2025-07-14 | 2025-08-22 | 30d | 420d | 0d |  |  | Code Bodies | Code Bodies | S&A Qualification | 68.33 | 6.13 | Laura Kennedy | Green | GREEN |  |  |  |
| 2431 | 1.7.4.2.1.5 | Completion of Code Bodies review of Initial QAD | milestone | 0d | 2025-08-22 | 2025-08-22 | 2430 | 2025-08-22 | 2025-08-22 | 0d | 420d | 0d |  |  | Code Bodies | Code Bodies | S&A Qualification | 107.71 | 6.13 | Laura Kennedy | Green | GREEN |  |  |  |
| 2432 | 1.7.4.2.2 | **Qualification Wave 1 Test Prep** |  | 60d | 2025-05-26 | 2025-08-15 |  | 2025-04-14 | 2025-07-04 | 60d | 425d |  |  | -0 | N/A | N/A | S&A Qualification | -555.67 | 6.13 | N/A |  |  |  |  |  |
| 2433 | 1.7.4.2.2.1 | Confirmation from Qualification Wave 1 Participants that DIP onboarding has commenced | milestone | 0d | 2025-05-26 | 2025-05-26 |  | 2025-05-26 | 2025-05-26 | 0d | 445d | 0d | start no earlier than 2025-05-26 |  | Participants | Participants | S&A Qualification | 19.33 | 6.13 | Laura Kennedy | Green | GREEN | T3-QU-0017 | QAG | T3 |
| 2434 | 1.7.4.2.2.2 | Qualification Wave 1 Participants DIP Onboarding Window |  | 35d | 2025-05-26 | 2025-07-11 | 2433 | 2025-05-26 | 2025-07-11 | 35d | 445d | 0d |  |  | Participants | Participants | S&A Qualification | 19.33 | 6.13 | Laura Kennedy | Green | GREEN |  |  |  |
| 2435 | 1.7.4.2.2.3 | Confirmation from Qualification Wave 1 Participants that DIP onboarding has completed | milestone | 0d | 2025-07-11 | 2025-07-11 | 2434 | 2025-07-11 | 2025-07-11 | 0d | 445d | 25d |  |  | Participants | Participants | S&A Qualification | 65.71 | 6.13 | Laura Kennedy | Green | GREEN | T3-TE-0017 | QAG | T3 |
| 2436 | 1.7.4.2.2.4 | Qualification Wave 1 Participants' to provide status of PIT completion and submit QT Test Plan | milestone | 0d | 2025-06-13 | 2025-06-13 |  | 2025-06-16 | 2025-06-16 | 0d | 451d | 0d | start no earlier than 2025-06-13 |  | Participants | Participants | S&A Qualification | 37.33 | 6.13 | Laura Kennedy | Green | GREEN | T3-QU-0095 | QAG | T3 |
| 2437 | 1.7.4.2.2.5 | Review of Participants' PIT Status and QT Test Plan |  | 15d | 2025-06-13 | 2025-07-03 | 2436 | 2025-06-16 | 2025-07-04 | 15d | 451d | 0d |  |  | Code Bodies, Non-SIT S&A QT Test Team | Code Bodies, Non-SIT S&A QT Test Team | S&A Qualification | 37.33 | 6.13 | Laura Kennedy | Green | GREEN |  |  |  |
| 2438 | 1.7.4.2.2.6 | Qualification Test Plans for Wave 1 Participants approved | milestone | 0d | 2025-07-03 | 2025-07-03 | 2437 | 2025-07-04 | 2025-07-04 | 0d | 451d | 31d |  |  | Non-SIT S&A QT Test Team | Non-SIT S&A QT Test Team | S&A Qualification | 57.71 | 6.13 | Laura Kennedy | Green | GREEN | T3-QU-0016 | QAG | T3 |
| 2439 | 1.7.4.2.2.7 | Qualification Wave 1 Participants have submitted PIT Test Completion Report and evidence for QT Entry | milestone | 0d | 2025-07-14 | 2025-07-14 |  | 2025-07-14 | 2025-07-14 | 0d | 420d | 0d | start no earlier than 2025-07-14 |  | Participants | Participants | S&A Qualification | 68.33 | 6.13 | Laura Kennedy | Green | GREEN | T3-QU-0096 | QAG | T3 |
| 2440 | 1.7.4.2.2.8 | Review of Participants PIT Test Completion Report |  | 25d | 2025-07-14 | 2025-08-15 | 2439 | 2025-07-14 | 2025-08-15 | 25d | 420d | 0d |  |  | Code Bodies, Non-SIT S&A QT Test Team | Code Bodies, Non-SIT S&A QT Test Team | S&A Qualification | 68.33 | 6.13 | Laura Kennedy | Green | GREEN |  |  |  |
| 2441 | 1.7.4.2.2.9 | Onboarding to QTF & ADO |  | 25d | 2025-07-14 | 2025-08-15 | 2440SS | 2025-07-14 | 2025-08-15 | 25d | 425d | 6d |  |  | Code Bodies, Non-SIT S&A QT Test Team | Code Bodies, Non-SIT S&A QT Test Team | S&A Qualification | 68.33 | 6.13 | Laura Kennedy | Green | GREEN |  |  |  |
| 2442 | 1.7.4.2.3 | **Qualification Wave 1 QT Execution** |  | 105d | 2025-08-18 | 2026-01-09 |  | 2025-08-18 | 2026-01-09 | 100d | 420d |  |  | -0 | N/A | N/A | S&A Qualification | -152.67 | 6.13 | N/A |  |  |  |  |  |
| 2443 | 1.7.4.2.3.1 | Review Entry Criteria Evidence for each Wave 1 Participant |  | 5d | 2025-08-18 | 2025-08-22 | 2431FF, 2435, 2438, 2440 | 2025-08-18 | 2025-08-22 | 5d | 420d | 0d |  |  | Non-SIT S&A QT Test Team | Non-SIT S&A QT Test Team | S&A Qualification | 103.33 | 6.13 | Laura Kennedy | Green | GREEN |  |  |  |
| 2444 | 1.7.4.2.3.2 | Qualification Wave 1 Participant Test Readiness Confirmed | milestone | 0d | 2025-08-22 | 2025-08-22 | 2430, 2431, 2443FF | 2025-08-22 | 2025-08-22 | 0d | 420d | 0d |  |  | Non-SIT S&A QT Test Team | Non-SIT S&A QT Test Team | S&A Qualification | 107.71 | 6.13 | Laura Kennedy | Green | GREEN | T3-QU-0027 | QAG | T3 |
| 2445 | 1.7.4.2.3.3 | Qualification Wave 1 QT Execution Start | milestone | 0d | 2025-08-25 | 2025-08-25 | 2444, 2441, 1629FS+6d, 2393 | 2025-08-25 | 2025-08-25 | 0d | 419d | 0d | start no earlier than 2025-07-14 |  | Participants | Participants | S&A Qualification | 110.71 | 6.13 | Laura Kennedy | Green | GREEN | T3-QU-0028 | QAG | T3 |
| 2446 | 1.7.4.2.3.4 | Qualification Wave 1 QT Execution Window |  | 100d | 2025-08-25 | 2026-01-09 | 2445FS-1d | 2025-08-25 | 2026-01-09 | 95d | 424d | 0d |  |  | Participants | Participants | S&A Qualification | 110.33 | 6.13 | Laura Kennedy | Green | GREEN |  |  |  |
| 2447 | 1.7.4.2.3.5 | Qualification Wave 1 QT Projected Execution End | milestone | 0d | 2026-01-09 | 2026-01-09 | 2446 | 2026-01-09 | 2026-01-09 | 0d | 424d | 5d |  |  | Participants | Participants | S&A Qualification | 247.71 | 6.13 | Laura Kennedy | Green | GREEN | T3-QU-0054 | QAG | T3 |
| 2448 | 1.7.4.2.4 | **Qualification Wave 1 Exit** |  | 168d | 2025-08-25 | 2026-04-15 |  | 2025-08-25 | 2026-04-15 | 149d? | 419d |  |  | -0 | N/A | N/A | S&A Qualification | -152.67 | 6.13 | N/A |  |  |  |  |  |
| 2449 | 1.7.4.2.4.1 | Final QAD Submission window opens | milestone | 0d | 2025-08-25 | 2025-08-25 | 2445 | 2025-08-25 | 2025-08-25 | 0d | 419d | 0d |  |  | Participants | Participants | S&A Qualification | 110.71 | 6.13 | Laura Kennedy | Green | GREEN |  |  |  |
| 2450 | 1.7.4.2.4.2 | Qualification Wave 1 Participants submit their Final QAD |  | 105d | 2025-08-25 | 2026-01-16 | 2449FS-1d | 2025-08-25 | 2026-01-16 | 100d | 419d | 0d |  |  | Participants | Participants | S&A Qualification | 110.33 | 6.13 | Laura Kennedy | Green | GREEN |  |  |  |
| 2451 | 1.7.4.2.4.3 | Qualification Wave 1 Participants have submitted their final QAD | milestone | 0d | 2026-01-16 | 2026-01-16 | 2450, 2447 | 2026-01-16 | 2026-01-16 | 0d | 419d | 0d |  |  | Participants | Participants | S&A Qualification | 254.71 | 6.13 | Laura Kennedy | Green | GREEN | T3-QU-0097 | QAG | T3 |
| 2452 | 1.7.4.2.4.4 | Completion of Code Bodies review of Final QAD |  | 35d | 2026-01-19 | 2026-03-06 | 2450, 2451 | 2026-01-19 | 2026-03-06 | 20d | 419d | 0d |  |  | Code Bodies | Code Bodies | S&A Qualification | 257.33 | 6.13 | Laura Kennedy | Green | GREEN |  |  |  |
| 2453 | 1.7.4.2.4.5 | QAD Sign Off deadline |  | 1d | 2026-03-20 | 2026-03-20 | 2452FS+9d | 2026-03-20 | 2026-03-20 | 1d | 419d | 0d |  |  | Participants | Participants | S&A Qualification | 317.33 | 6.13 | Laura Kennedy | Green | GREEN |  |  |  |
| 2454 | 1.7.4.2.4.6 | Qualification Wave 1 Participants Qualification approved by BSC PAB and REC Manager | milestone | 0d | 2026-04-15 | 2026-04-15 | 2453FS+18d | 2026-04-15 | 2026-04-15 | 0d | 419d | 0d |  |  | Code Bodies | Code Bodies | S&A Qualification | 343.71 | 6.13 | Laura Kennedy | Green | GREEN | T2-QU-0150 | QAG | T2 |

| ID | WBS | Task | Type | Duration | Start | Finish | Predecessors | Baseline start | Baseline finish | Baseline duration | Total slack | Free slack | Constraint | Baseline cost | Responsible | Involved | Text9 | Task Status | Update Version | MHHS Resource Name | Sched Status | RAG | Milestone ID | Text29 | Tier |
| --- | --- | --- | --- | --- | --- | --- | --- | --- | --- | --- | --- | --- | --- | --- | --- | --- | --- | --- | --- | --- | --- | --- | --- | --- | --- |
| 2455 | 1.7.4.3 | **Qualification Wave 2** |  | 254d | 2025-06-09 | 2026-05-28 |  | 2025-06-09 | 2026-05-28 | 249d | 386d |  |  | -0 | N/A | N/A | S&A Qualification | -133.67 | 6.13 | N/A |  |  |  |  |  |
| 2456 | 1.7.4.3.1 | **Qualification Wave 2 QAD Prep** |  | 95d | 2025-06-09 | 2025-10-17 |  | 2025-06-09 | 2025-10-17 | 96d | 386d |  |  | -0 | N/A | N/A | S&A Qualification | -154.67 | 6.13 | N/A |  |  |  |  |  |
| 2457 | 1.7.4.3.1.1 | Initial QAD Submission window opens | milestone | 0d | 2025-06-09 | 2025-06-09 | 2190FS+1d | 2025-06-09 | 2025-06-09 | 0d | 386d | 0d |  |  | Participants | Participants | S&A Qualification | 33.71 | 6.13 | Laura Kennedy | Green | GREEN |  |  |  |
| 2458 | 1.7.4.3.1.2 | Qualification Wave 2 Participants Submit Initial QAD |  | 70d | 2025-06-09 | 2025-09-12 | 2457FS-1d | 2025-06-09 | 2025-09-12 | 70d | 386d | 0d |  |  | Participants | Participants | S&A Qualification | 33.33 | 6.13 | Laura Kennedy | Green | GREEN |  |  |  |
| 2459 | 1.7.4.3.1.3 | Qualification Wave 2 Participants have submitted their initial QAD | milestone | 0d | 2025-09-12 | 2025-09-12 | 2458 | 2025-09-12 | 2025-09-12 | 0d | 386d | 0d |  |  | Participants | Participants | S&A Qualification | 128.71 | 6.13 | Laura Kennedy | Green | GREEN | T3-QU-0098 | QAG | T3 |
| 2460 | 1.7.4.3.1.4 | Code Bodies review of Wave 2 Participants' Initial QAD |  | 25d | 2025-09-15 | 2025-10-17 | 2459 | 2025-09-15 | 2025-10-17 | 26d | 386d | 0d |  |  | Code Bodies | Code Bodies | S&A Qualification | 131.33 | 6.13 | Laura Kennedy | Green | GREEN |  |  |  |
| 2461 | 1.7.4.3.1.5 | Completion of Code Bodies review of Initial QAD | milestone | 0d | 2025-10-17 | 2025-10-17 | 2460 | 2025-10-17 | 2025-10-17 | 0d | 386d | 0d |  |  | Code Bodies | Code Bodies | S&A Qualification | 163.71 | 6.13 | Laura Kennedy | Green | GREEN |  |  |  |
| 2462 | 1.7.4.3.2 | **Qualification Wave 2 Test Prep** |  | 60d | 2025-07-21 | 2025-10-10 |  | 2025-07-21 | 2025-10-10 | 60d | 392d |  |  | -0 | N/A | N/A | S&A Qualification | -555.67 | 6.13 | N/A |  |  |  |  |  |
| 2463 | 1.7.4.3.2.1 | Confirmation from Qualification Wave 2 Participants that DIP Onboarding has commenced | milestone | 0d | 2025-07-21 | 2025-07-21 |  | 2025-07-21 | 2025-07-21 | 0d | 411d | 0d | start no earlier than 2025-07-21 |  | Participants | Participants | S&A Qualification | 75.33 | 6.13 | Laura Kennedy | Green | GREEN | T3-QU-0021 | QAG | T3 |
| 2464 | 1.7.4.3.2.2 | Qualification Wave 2 Participants DIP Onboarding Window |  | 35d | 2025-07-21 | 2025-09-05 | 2463 | 2025-07-21 | 2025-09-05 | 40d | 411d | 0d |  |  | Participants | Participants | S&A Qualification | 75.33 | 6.13 | Laura Kennedy | Green | GREEN |  |  |  |
| 2465 | 1.7.4.3.2.3 | Confirmation from Qualificiation Wave 2 Participants that DIP onboarding has completed | milestone | 0d | 2025-09-05 | 2025-09-05 | 2464 | 2025-09-05 | 2025-09-05 | 0d | 411d | 25d |  |  | Participants | Participants | S&A Qualification | 121.71 | 6.13 | Laura Kennedy | Green | GREEN |  |  |  |
| 2466 | 1.7.4.3.2.4 | Qualification Wave 2 Participants' to provide status of PIT completion and submit QT Test Plan | milestone | 0d | 2025-08-18 | 2025-08-18 |  | 2025-08-18 | 2025-08-18 | 0d | 411d | 0d | start no earlier than 2025-08-18 |  | Participants | Participants | S&A Qualification | 103.33 | 6.13 | Laura Kennedy | Green | GREEN | T3-QU-0099 | QAG | T3 |
| 2467 | 1.7.4.3.2.5 | Review of Participants' PIT Status and QT Test Plan |  | 15d | 2025-08-18 | 2025-09-05 | 2466 | 2025-08-18 | 2025-09-05 | 15d | 411d | 0d | start no earlier than 2025-07-07 |  | Code Bodies, Non-SIT S&A QT Test Team | Code Bodies, Non-SIT S&A QT Test Team | S&A Qualification | 103.33 | 6.13 | Laura Kennedy | Green | GREEN |  |  |  |
| 2468 | 1.7.4.3.2.6 | Qualification Test Plans for Wave 2 Participants approved | milestone | 0d | 2025-09-05 | 2025-09-05 | 2467 | 2025-09-05 | 2025-09-05 | 0d | 411d | 25d | start no earlier than 2025-07-25 |  | Non-SIT S&A QT Test Team | Non-SIT S&A QT Test Team | S&A Qualification | 121.71 | 6.13 | Laura Kennedy | Green | GREEN | T3-QU-0020 | QAG | T3 |
| 2469 | 1.7.4.3.2.7 | Qualification Wave 2 Participants have submitted PIT Test Completion Report and evidence for QT entry | milestone | 0d | 2025-09-08 | 2025-09-08 |  | 2025-09-08 | 2025-09-08 | 0d | 386d | 0d | start no earlier than 2025-09-08 |  | Participants | Participants | S&A Qualification | 124.33 | 6.13 | Laura Kennedy | Green | GREEN | T3-QU-0100 | QAG | T3 |
| 2470 | 1.7.4.3.2.8 | Review of Participants' PIT Test Completion Report |  | 25d | 2025-09-08 | 2025-10-10 | 2469 | 2025-09-08 | 2025-10-10 | 25d | 386d | 0d |  |  | Code Bodies, Non-SIT S&A QT Test Team | Code Bodies, Non-SIT S&A QT Test Team | S&A Qualification | 124.33 | 6.13 | Laura Kennedy | Green | GREEN |  |  |  |
| 2471 | 1.7.4.3.2.9 | Onboarding to QTF & ADO |  | 25d | 2025-09-08 | 2025-10-10 | 2470SS | 2025-09-08 | 2025-10-10 | 25d | 392d | 6d |  |  | Code Bodies, Non-SIT S&A QT Test Team | Code Bodies, Non-SIT S&A QT Test Team | S&A Qualification | 124.33 | 6.13 | Laura Kennedy | Green | GREEN |  |  |  |
| 2472 | 1.7.4.3.3 | **Qualification Wave 2 QT Execution** |  | 100d | 2025-10-13 | 2026-02-27 |  | 2025-10-13 | 2026-02-27 | 99d | 386d |  |  | -0 | N/A | N/A | S&A Qualification | -154.67 | 6.13 | N/A |  |  |  |  |  |
| 2473 | 1.7.4.3.3.1 | Review Entry Criteria Evidence for each Wave 2 Participant |  | 5d | 2025-10-13 | 2025-10-17 | 2461FF, 2465, 2468, 2470 | 2025-10-13 | 2025-10-17 | 5d | 386d | 0d |  |  | Non-SIT S&A QT Test Team | Non-SIT S&A QT Test Team | S&A Qualification | 159.33 | 6.13 | Laura Kennedy | Green | GREEN |  |  |  |
| 2474 | 1.7.4.3.3.2 | Qualification Wave 2 Participant Test Readiness Confirmed | milestone | 0d | 2025-10-17 | 2025-10-17 | 2473, 2461 | 2025-10-17 | 2025-10-17 | 0d | 386d | 0d |  |  | Non-SIT S&A QT Test Team | Non-SIT S&A QT Test Team | S&A Qualification | 163.71 | 6.13 | Laura Kennedy | Green | GREEN | T3-QU-0033 | QAG | T3 |
| 2475 | 1.7.4.3.3.3 | Qualification Wave 2 Execution Start | milestone | 0d | 2025-10-20 | 2025-10-20 | 2474FS+1d, 2471, 2398 | 2025-10-20 | 2025-10-20 | 0d | 386d | 0d |  |  | Participants | Participants | S&A Qualification | 166.71 | 6.13 | Laura Kennedy | Green | GREEN | T3-QU-0034 | QAG | T3 |
| 2476 | 1.7.4.3.3.4 | Qualification Wave 2 QT Execution Window |  | 95d | 2025-10-20 | 2026-02-27 | 2475SS-1d | 2025-10-20 | 2026-02-27 | 94d | 391d | 0d |  |  | Participants | Participants | S&A Qualification | 166.33 | 6.13 | Laura Kennedy | Green | GREEN |  |  |  |
| 2477 | 1.7.4.3.3.5 | Qualfication Wave 2 QT Execution End | milestone | 0d | 2026-02-27 | 2026-02-27 | 2476 | 2026-02-27 | 2026-02-27 | 0d | 391d | 5d |  |  | Participants | Participants | S&A Qualification | 296.71 | 6.13 | Laura Kennedy | Green | GREEN | T3-QU-0055 | QAG | T3 |
| 2478 | 1.7.4.3.4 | **Qualification Wave 2 Exit** |  | 159d | 2025-10-20 | 2026-05-28 |  | 2025-10-20 | 2026-05-28 | 153d | 386d |  |  | -0 | N/A | N/A | S&A Qualification | -154.67 | 6.13 | N/A |  |  |  |  |  |
| 2479 | 1.7.4.3.4.1 | Final QAD Submission window opens | milestone | 0d | 2025-10-20 | 2025-10-20 | 2475 | 2025-10-20 | 2025-10-20 | 0d | 386d | 0d |  |  | Participants | Participants | S&A Qualification | 166.71 | 6.13 | Laura Kennedy | Green | GREEN |  |  |  |
| 2480 | 1.7.4.3.4.2 | Qualification Wave 2 Participants submit their Final QAD |  | 100d | 2025-10-20 | 2026-03-06 | 2479FS-1d | 2025-10-20 | 2026-03-06 | 99d | 386d | 0d |  |  | Participants | Participants | S&A Qualification | 166.33 | 6.13 | Laura Kennedy | Green | GREEN |  |  |  |
| 2481 | 1.7.4.3.4.3 | Qualification Wave 2 Participants have submitted their final QAD | milestone | 0d | 2026-03-06 | 2026-03-06 | 2480, 2477 | 2026-03-06 | 2026-03-06 | 0d | 386d | 0d |  |  | Participants | Participants | S&A Qualification | 303.71 | 6.13 | Laura Kennedy | Green | GREEN | T3-QU-0101 | QAG | T3 |
| 2482 | 1.7.4.3.4.4 | Completion of Code Bodies review of Final QAD |  | 26d | 2026-03-09 | 2026-04-13 | 2481 | 2026-03-09 | 2026-04-13 | 27d | 386d | 0d |  |  | Code Bodies | Code Bodies | S&A Qualification | 306.33 | 6.13 | Laura Kennedy | Green | GREEN |  |  |  |
| 2483 | 1.7.4.3.4.5 | QAD Sign Off deadline |  | 1d | 2026-04-20 | 2026-04-20 | 2482FS+4d | 2026-04-20 | 2026-04-20 | 1d | 386d | 0d |  |  | Participants | Participants | S&A Qualification | 348.33 | 6.13 | Laura Kennedy | Green | GREEN |  |  |  |
| 2484 | 1.7.4.3.4.6 | Qualification Wave 2 Participants Qualification approved by BSC PAB and REC Manager | milestone | 0d | 2026-05-28 | 2026-05-28 | 2483FS+28d | 2026-05-28 | 2026-05-28 | 0d | 386d | 0d |  |  | Code Bodies | Code Bodies | S&A Qualification | 386.71 | 6.13 | Laura Kennedy | Green | GREEN | T2-QU-0200 | QAG | T2 |

| ID | WBS | Task | Type | Duration | Start | Finish | Predecessors | Baseline start | Baseline finish | Baseline duration | Total slack | Free slack | Constraint | Baseline cost | Responsible | Involved | Text9 | Task Status | Update Version | MHHS Resource Name | Sched Status | RAG | Milestone ID | Text29 | Tier |
| --- | --- | --- | --- | --- | --- | --- | --- | --- | --- | --- | --- | --- | --- | --- | --- | --- | --- | --- | --- | --- | --- | --- | --- | --- | --- |
| 2485 | 1.7.4.4 | **Qualification Wave 3** |  | 254d | 2025-08-11 | 2026-07-30 |  | 2025-08-11 | 2026-07-30 | 239d | 60d |  |  | -0 | N/A | N/A | S&A Qualification | -133.67 | 6.13 | N/A |  |  |  |  |  |
| 2486 | 1.7.4.4.1 | **Qualification Wave 3 QAD Prep** |  | 95d | 2025-08-11 | 2025-12-19 |  | 2025-08-11 | 2025-12-19 | 95d | 355d |  |  | -0 | N/A | N/A | S&A Qualification | -154.67 | 6.13 | N/A |  |  |  |  |  |
| 2487 | 1.7.4.4.1.1 | Initial QAD Submission window opens | milestone | 0d | 2025-08-11 | 2025-08-11 | 2191FS+1d | 2025-08-11 | 2025-08-11 | 0d | 355d | 0d |  |  | Participants | Participants | S&A Qualification | 96.71 | 6.13 | Laura Kennedy | Green | GREEN |  |  |  |
| 2488 | 1.7.4.4.1.2 | Qualification Wave 3 Participants Submit Initial QAD |  | 65d | 2025-08-11 | 2025-11-07 | 2487FS-1d | 2025-08-11 | 2025-11-07 | 65d | 355d | 0d |  |  | Participants | Participants | S&A Qualification | 96.33 | 6.13 | Laura Kennedy | Green | GREEN |  |  |  |
| 2489 | 1.7.4.4.1.3 | Qualification Wave 3 Participants have submitted their initial QAD | milestone | 0d | 2025-11-07 | 2025-11-07 | 2488 | 2025-11-07 | 2025-11-07 | 0d | 355d | 0d |  |  | Participants | Participants | S&A Qualification | 184.71 | 6.13 | Laura Kennedy | Green | GREEN | T3-QU-0102 | QAG | T3 |
| 2490 | 1.7.4.4.1.4 | Code Bodies review of Wave 3 Participants' Initial QAD |  | 30d | 2025-11-10 | 2025-12-19 | 2489 | 2025-11-10 | 2025-12-19 | 30d | 355d | 0d |  |  | Code Bodies | Code Bodies | S&A Qualification | 187.33 | 6.13 | Laura Kennedy | Green | GREEN |  |  |  |
| 2491 | 1.7.4.4.1.5 | Completion of Code Bodies review of Initial QAD | milestone | 0d | 2025-12-19 | 2025-12-19 | 2490 | 2025-12-19 | 2025-12-19 | 0d | 355d | 0d |  |  | Code Bodies | Code Bodies | S&A Qualification | 226.71 | 6.13 | Laura Kennedy | Green | GREEN |  |  |  |
| 2492 | 1.7.4.4.2 | **Qualification Wave 3 Test Prep** |  | 65d | 2025-09-15 | 2025-12-12 |  | 2025-09-15 | 2025-12-12 | 65d | 385d |  |  | -0 | N/A | N/A | S&A Qualification | -555.67 | 6.13 | N/A |  |  |  |  |  |
| 2493 | 1.7.4.4.2.1 | Confirmation from Qualification Wave 3 Participants that DIP Onboarding has commenced | milestone | 0d | 2025-09-15 | 2025-09-15 |  | 2025-09-15 | 2025-09-15 | 0d | 385d | 0d | start no earlier than 2025-09-15 |  | Participants | Participants | S&A Qualification | 131.33 | 6.13 | Laura Kennedy | Green | GREEN | T3-QU-0025 | QAG | T3 |
| 2494 | 1.7.4.4.2.2 | Qualification Wave 3 Participants DIP Onboarding window |  | 35d | 2025-09-15 | 2025-10-31 | 2493 | 2025-09-15 | 2025-10-31 | 40d | 385d | 0d | start no earlier than 2025-08-04 |  | Participants | Participants | S&A Qualification | 131.33 | 6.13 | Laura Kennedy | Green | GREEN |  |  |  |
| 2495 | 1.7.4.4.2.3 | Confirmation from Qualification Wave 3 Participants that DIP onboarding has completed | milestone | 0d | 2025-10-31 | 2025-10-31 | 2494 | 2025-10-31 | 2025-10-31 | 0d | 385d | 30d | start no earlier than 2025-09-22 |  | Participants | Participants | S&A Qualification | 177.71 | 6.13 | Laura Kennedy | Green | GREEN |  |  |  |
| 2496 | 1.7.4.4.2.4 | Qualification Wave 3 Participants' to provide status of PIT completion and submit QT Test Plan | milestone | 0d | 2025-10-20 | 2025-10-20 |  | 2025-10-20 | 2025-10-20 | 0d | 554d | 0d | start no earlier than 2025-10-20 |  | Participants | Participants | S&A Qualification | 166.33 | 6.13 | Laura Kennedy | Green | GREEN | T3-QU-0103 | QAG | T3 |
| 2497 | 1.7.4.4.2.5 | Review of Participants' PIT Status and QT Test Plan |  | 15d | 2025-10-20 | 2025-11-07 | 2496 | 2025-10-20 | 2025-11-07 | 15d | 554d | 0d | start no earlier than 2025-09-08 |  | Code Bodies, Non-SIT S&A QT Test Team | Code Bodies, Non-SIT S&A QT Test Team | S&A Qualification | 166.33 | 6.13 | Laura Kennedy | Green | GREEN |  |  |  |
| 2498 | 1.7.4.4.2.6 | Qualification Test Plans for Wave 3 Participants approved | milestone | 0d | 2025-11-07 | 2025-11-07 | 2497 | 2025-11-07 | 2025-11-07 | 0d | 554d |  | start no earlier than 2025-09-26 |  | Non-SIT S&A QT Test Team | Non-SIT S&A QT Test Team | S&A Qualification | 184.71 | 6.13 | Laura Kennedy | Green | GREEN | T3-QU-0024 | QAG | T3 |
| 2499 | 1.7.4.4.2.7 | Qualification Wave 3 Participants have submitted PIT Test Completion Report and evidence for QT Entry | milestone | 0d | 2025-11-10 | 2025-11-10 |  | 2025-11-10 | 2025-11-10 | 0d | 355d | 0d | start no earlier than 2025-11-10 |  | Participants | Participants | S&A Qualification | 187.33 | 6.13 | Laura Kennedy | Green | GREEN | T3-QU-0104 | QAG | T3 |
| 2500 | 1.7.4.4.2.8 | Review of Participants' PIT Test Completion Report |  | 25d | 2025-11-10 | 2025-12-12 | 2499 | 2025-11-10 | 2025-12-12 | 30d | 355d | 0d | start no earlier than 2025-09-29 |  | Code Bodies, Non-SIT S&A QT Test Team | Code Bodies, Non-SIT S&A QT Test Team | S&A Qualification | 187.33 | 6.13 | Laura Kennedy | Green | GREEN |  |  |  |
| 2501 | 1.7.4.4.2.9 | Onboarding to QTF & ADO |  | 25d | 2025-11-10 | 2025-12-12 | 2500SS | 2025-11-10 | 2025-12-12 | 30d | 355d | 0d | finish no earlier than 2025-10-31 |  | Code Bodies, Non-SIT S&A QT Test Team |  | S&A Qualification | 187.33 | 6.13 | Laura Kennedy | Green | GREEN |  |  |  |
| 2502 | 1.7.4.4.3 | **Qualification Wave 3 QT Execution** |  | 102d | 2025-11-03 | 2026-03-24 |  | 2025-11-03 | 2026-03-24 | 100d |  |  |  | -0 | N/A | N/A | S&A Qualification | -154.67 | 6.13 | N/A |  |  |  |  |  |
| 2503 | 1.7.4.4.3.1 | Review Entry Criteria Evidence for each Wave 3 Participant |  | 5d | 2025-12-15 | 2025-12-19 | 2495, 2491FF, 2501 | 2025-12-15 | 2025-12-19 | 5d | 355d | 0d | start no earlier than 2025-11-03 |  | Non-SIT S&A QT Test Team | Non-SIT S&A QT Test Team | S&A Qualification | 222.33 | 6.13 | Laura Kennedy | Green | GREEN |  |  |  |
| 2504 | 1.7.4.4.3.2 | Qualification Wave 3 Participant Test Readiness confirmed | milestone | 0d | 2025-12-19 | 2025-12-19 | 2495, 2503 | 2025-12-19 | 2025-12-19 | 0d | 355d | 0d |  |  | Non-SIT S&A QT Test Team | Non-SIT S&A QT Test Team | S&A Qualification | 226.71 | 6.13 | Laura Kennedy | Green | GREEN | T3-QU-0038 | QAG | T3 |
| 2505 | 1.7.4.4.3.3 | Qualification Wave 3 Execution Start | milestone | 0d | 2026-01-12 | 2026-01-12 | 2504FS+16d, 2501FS+1d, 2403 | 2026-01-12 | 2026-01-12 | 0d | 355d | 0d | start no earlier than 2025-11-03 |  | Participants | Participants | S&A Qualification | 250.71 | 6.13 | Laura Kennedy | Green | GREEN | T3-QU-0039 | QAG | T3 |
| 2506 | 1.7.4.4.3.4 | Qualification Wave 3 QT Execution Window |  | 90d | 2026-01-12 | 2026-05-15 | 2503, 2505FS-1d | 2026-01-12 | 2026-05-15 | 95d | 360d | 0d |  |  | Participants | Participants | S&A Qualification | 250.33 | 6.13 | Laura Kennedy | Green | GREEN |  |  |  |
| 2507 | 1.7.4.4.3.5 | Qualification Wave 3 Projected Execution End | milestone | 0d | 2026-05-15 | 2026-05-15 | 2506 | 2026-05-15 | 2026-05-15 | 0d | 360d | 5d |  |  | Participants | Participants | S&A Qualification | 373.71 | 6.13 | Laura Kennedy | Green | GREEN | T3-QU-0056 | QAG | T3 |
| 2508 | 1.7.4.4.4 | **Qualification Wave 3 Exit** |  | 144d | 2026-01-12 | 2026-07-30 |  | 2026-01-12 | 2026-07-30 | 144d | 355d |  |  | -0 | N/A | N/A | S&A Qualification | -154.67 | 6.13 | N/A |  |  |  |  |  |
| 2509 | 1.7.4.4.4.1 | Final QAD Submission window opens | milestone | 0d | 2026-01-12 | 2026-01-12 | 2505 | 2026-01-12 | 2026-01-12 | 0d | 355d | 0d |  |  | Participants | Participants | S&A Qualification | 250.71 | 6.13 | Laura Kennedy | Green | GREEN |  |  |  |
| 2510 | 1.7.4.4.4.2 | Qualification Wave 3 Participants submit their Final QAD |  | 95d | 2026-01-12 | 2026-05-22 | 2509FS-1d | 2026-01-12 | 2026-05-22 | 100d | 355d | 0d |  |  | Participants | Participants | S&A Qualification | 250.33 | 6.13 | Laura Kennedy | Green | GREEN |  |  |  |
| 2511 | 1.7.4.4.4.3 | Qualification Wave 3 Participants have submitted their Final QAD | milestone | 0d | 2026-05-22 | 2026-05-22 | 2510, 2507 | 2026-05-22 | 2026-05-22 | 0d | 355d | 0d |  |  | Participants | Participants | S&A Qualification | 380.71 | 6.13 | Laura Kennedy | Green | GREEN | T3-QU-0105 | QAG | T3 |
| 2512 | 1.7.4.4.4.4 | Completion of Code Bodies review of Final QAD |  | 20d | 2026-05-25 | 2026-06-19 | 2511 | 2026-05-25 | 2026-06-19 | 20d | 355d | 0d |  |  | Code Bodies | Code Bodies | S&A Qualification | 383.33 | 6.13 | Laura Kennedy | Green | GREEN |  |  |  |
| 2513 | 1.7.4.4.4.5 | QAD Sign Off deadline |  | 1d | 2026-06-26 | 2026-06-26 | 2512FS+4d | 2026-06-26 | 2026-06-26 | 1d | 355d | 0d |  |  | Participants | Participants | S&A Qualification | 415.33 | 6.13 | Laura Kennedy | Green | GREEN |  |  |  |
| 2514 | 1.7.4.4.4.6 | Qualification Wave 3 Participants Qualification approved by BSC PAB and REC Manager | milestone | 0d | 2026-07-30 | 2026-07-30 | 2513FS+24d | 2026-07-30 | 2026-07-30 | 0d | 355d | 0d |  |  | Code Bodies | Code Bodies | S&A Qualification | 449.71 | 6.13 | Laura Kennedy | Green | GREEN | T2-QU-0250 | QAG | T2 |

| ID | WBS | Task | Type | Duration | Start | Finish | Predecessors | Remaining | Baseline start | Baseline finish | Baseline duration | Total slack | Free slack | Constraint | Baseline cost | Responsible | Involved | Text9 | Task Status | Update Version | MHHS Resource Name | Sched Status | RAG | Milestone ID | Text29 | Tier |
| --- | --- | --- | --- | --- | --- | --- | --- | --- | --- | --- | --- | --- | --- | --- | --- | --- | --- | --- | --- | --- | --- | --- | --- | --- | --- | --- |
| 2515 | 1.7.4.5 | **Qualification Wave 4** |  | 526d | 2025-01-23 A | 2027-01-28 |  | 523.54d | 2025-10-20 | 2027-01-28 | 249d | 235d |  |  | -0 | N/A | N/A | S&A Qualification | -133.67 | 6.13 | N/A |  |  |  |  |  |
| 2516 | 1.7.4.5.1 | **Qualification Wave 4 QAD Prep** |  | 95d | 2025-10-20 | 2026-02-27 |  |  | 2025-10-20 | 2026-02-27 | 99d | 235d |  |  | -0 | N/A | N/A | S&A Qualification | -155.67 | 6.13 | N/A |  |  |  |  |  |
| 2517 | 1.7.4.5.1.1 | Initial QAD Submission window opens | milestone | 0d | 2025-10-20 | 2025-10-20 | 2192FS+1d |  | 2025-10-20 | 2025-10-20 | 0d | 235d | 0d |  |  | Participants | Participants | S&A Qualification | 166.71 | 6.13 | Laura Kennedy | Green | GREEN |  |  |  |
| 2518 | 1.7.4.5.1.2 | Qualification Wave 4 Participants Submit Initial QAD |  | 65d | 2025-10-20 | 2026-01-16 | 2517FS-1d |  | 2025-10-20 | 2026-01-16 | 70d | 235d | 0d |  |  | Participants | Participants | S&A Qualification | 166.33 | 6.13 | Laura Kennedy | Green | GREEN |  |  |  |
| 2519 | 1.7.4.5.1.3 | Qualification Wave 4 Participants have submitted their Initial QAD | milestone | 0d | 2026-01-16 | 2026-01-16 | 2518 |  | 2026-01-16 | 2026-01-16 | 0d | 235d | 0d |  |  | Participants | Participants | S&A Qualification | 254.71 | 6.13 | Laura Kennedy | Green | GREEN | T3-QU-0106 | QAG | T3 |
| 2520 | 1.7.4.5.1.4 | Code Bodies review of Wave 4 Participants' Initial QAD |  | 30d | 2026-01-19 | 2026-02-27 | 2519 |  | 2026-01-19 | 2026-02-27 | 29d | 235d | 0d |  |  | Code Bodies | Code Bodies | S&A Qualification | 257.33 | 6.13 | Laura Kennedy | Green | GREEN |  |  |  |
| 2521 | 1.7.4.5.1.5 | Completion of Code Bodies review of Initial QAD | milestone | 0d | 2026-02-27 | 2026-02-27 | 2520 |  | 2026-02-27 | 2026-02-27 | 0d | 235d | 0d |  |  | Code Bodies | Code Bodies | S&A Qualification | 296.71 | 6.13 | Laura Kennedy | Green | GREEN |  |  |  |
| 2522 | 1.7.4.5.2 | **Qualification Wave 4 Test Prep** |  | 75d | 2025-11-03 | 2026-02-13 |  |  | 2025-11-03 | 2026-02-13 | 67d | 251d |  |  | -0 | N/A | N/A | S&A Qualification | -555.67 | 6.13 | N/A |  |  |  |  |  |
| 2523 | 1.7.4.5.2.1 | Confirmation from Qualification 4 Participants that DIP Onboarding has commenced | milestone | 0d | 2025-11-03 | 2025-11-03 |  |  | 2025-11-03 | 2025-11-03 | 0d | 285d | 0d | start no earlier than 2025-11-03 |  | Participants | Participants | S&A Qualification | 180.33 | 6.13 | Laura Kennedy | Green | GREEN | T3-QU-0031 | QAG | T3 |
| 2524 | 1.7.4.5.2.2 | Qualification Wave 4 Participants DIP Onboarding Window |  | 35d | 2025-11-03 | 2025-12-19 | 2523 |  | 2025-11-03 | 2025-12-19 | 42d | 285d | 0d |  |  | Participants | Participants | S&A Qualification | 180.33 | 6.13 | Laura Kennedy | Green | GREEN |  |  |  |
| 2525 | 1.7.4.5.2.3 | Confirmation from Qualification Wave 4 Participants that DIP onboarding has completed | milestone | 0d | 2025-12-19 | 2025-12-19 | 2524 |  | 2025-12-19 | 2025-12-19 | 0d | 285d | 50d |  |  | Participants | Participants | S&A Qualification | 226.71 | 6.13 | Laura Kennedy | Green | GREEN |  |  |  |
| 2526 | 1.7.4.5.2.4 | Qualification Wave 4 Participants' to provide status of PIT completion and submit QT Test Plan | milestone | 0d | 2025-12-08 | 2025-12-08 |  |  | 2025-12-08 | 2025-12-08 | 0d | 251d | 0d | start no earlier than 2025-12-08 |  | Participants | Participants | S&A Qualification | 215.33 | 6.13 | Laura Kennedy | Green | GREEN | T3-QU-0107 | QAG | T3 |
| 2527 | 1.7.4.5.2.5 | Review of Participants' PIT Status and QT Test Plan |  | 25d | 2025-12-08 | 2026-01-09 | 2526 |  | 2025-12-08 | 2026-01-09 | 16d | 251d | 0d |  |  | Code Bodies, Non-SIT S&A QT Test Team | Code Bodies, Non-SIT S&A QT Test Team | S&A Qualification | 215.33 | 6.13 | Laura Kennedy | Green | GREEN |  |  |  |
| 2528 | 1.7.4.5.2.6 | Qualification Test Plans for Qualification Wave 4 Participants approved | milestone | 0d | 2026-01-09 | 2026-01-09 | 2527 |  | 2026-01-09 | 2026-01-09 | 0d | 251d | 0d |  |  | Non-SIT S&A QT Test Team | Non-SIT S&A QT Test Team | S&A Qualification | 247.71 | 6.13 | Laura Kennedy | Green | GREEN | T3-QU-0030 | QAG | T3 |
| 2529 | 1.7.4.5.2.7 | Qualification Wave 4 Participants have submitted PIT Test Completion Report and evidence for QT entry | milestone | 0d | 2026-01-09 | 2026-01-09 | 2528 |  | 2026-01-09 | 2026-01-09 | 0d | 251d | 0d |  |  | Participants | Participants | S&A Qualification | 247.71 | 6.13 | Laura Kennedy | Green | GREEN | T3-QU-0108 | QAG | T3 |
| 2530 | 1.7.4.5.2.8 | Review of Participants' PIT Test Completion Report |  | 25d | 2026-01-12 | 2026-02-13 | 2529 |  | 2026-01-12 | 2026-02-13 | 30d | 251d | 0d |  |  | Code Bodies, Non-SIT S&A QT Test Team | Code Bodies, Non-SIT S&A QT Test Team | S&A Qualification | 250.33 | 6.13 | Laura Kennedy | Green | GREEN |  |  |  |
| 2531 | 1.7.4.5.2.9 | Onboarding to QTF & ADO |  | 25d | 2026-01-12 | 2026-02-13 | 2530SS |  | 2026-01-12 | 2026-02-13 | 30d | 251d | 16d | start no earlier than 2025-11-24 |  | Code Bodies, Non-SIT S&A QT Test Team | Code Bodies, Non-SIT S&A QT Test Team | S&A Qualification | 250.33 | 6.13 | Laura Kennedy | Green | GREEN |  |  |  |
| 2532 | 1.7.4.5.3 | **Qualification Wave 4 QT Execution** |  | 100d | 2026-03-02 | 2026-07-17 |  |  | 2026-03-02 | 2026-07-17 | 101d | 235d |  |  | -0 | N/A | N/A | S&A Qualification | -155.67 | 6.13 | N/A |  |  |  |  |  |
| 2533 | 1.7.4.5.3.1 | Review Entry Criteria Evidence for each Wave 4 Participant |  | 5d | 2026-03-02 | 2026-03-06 | 2521FF+5d, 2525 |  | 2026-03-02 | 2026-03-06 | 5d | 235d | 0d |  |  | Non-SIT S&A QT Test Team | Non-SIT S&A QT Test Team | S&A Qualification | 299.33 | 6.13 | Laura Kennedy | Green | GREEN |  |  |  |
| 2534 | 1.7.4.5.3.2 | Qualification Wave 4 Participant Test Readiness Confirmed | milestone | 0d | 2026-03-06 | 2026-03-06 | 2525, 2533 |  | 2026-03-06 | 2026-03-06 | 0d | 235d | 0d |  |  | Non-SIT S&A QT Test Team | Non-SIT S&A QT Test Team | S&A Qualification | 303.71 | 6.13 | Laura Kennedy | Green | GREEN | T3-QU-0043 | QAG | T3 |
| 2535 | 1.7.4.5.3.3 | Qualification Wave 4 QT Execution Start | milestone | 0d | 2026-03-09 | 2026-03-09 | 2534FS+1d, 2531, 2408 |  | 2026-03-09 | 2026-03-09 | 0d | 235d | 0d | start no earlier than 2026-01-07 |  | Participants | Participants | S&A Qualification | 306.71 | 6.13 | Laura Kennedy | Green | GREEN | T3-QU-0044 | QAG | T3 |
| 2536 | 1.7.4.5.3.4 | Qualification Wave 4 QT Execution Window |  | 95d | 2026-03-09 | 2026-07-17 | 2535FS-1d, 2533 |  | 2026-03-09 | 2026-07-17 | 96d | 240d | 0d |  |  | Participants | Participants | S&A Qualification | 306.33 | 6.13 | Laura Kennedy | Green | GREEN |  |  |  |
| 2537 | 1.7.4.5.3.5 | Qualification Wave 4 Projected Execution End | milestone | 0d | 2026-07-17 | 2026-07-17 | 2536 |  | 2026-07-17 | 2026-07-17 | 0d | 240d | 5d |  |  | Participants | Participants | S&A Qualification | 436.71 | 6.13 | Laura Kennedy | Green | GREEN | T3-QU-0057 | QAG | T3 |
| 2538 | 1.7.4.5.4 | **Qualification Wave 4 Exit** |  | 144d | 2026-03-09 | 2026-09-24 |  |  | 2026-03-09 | 2026-09-24 | 150d | 235d |  |  | -0 | N/A | N/A | S&A Qualification | -155.67 | 6.13 | N/A |  |  |  |  |  |
| 2539 | 1.7.4.5.4.1 | Final QAD Submission window opens | milestone | 0d | 2026-03-09 | 2026-03-09 | 2535 |  | 2026-03-09 | 2026-03-09 | 0d | 235d | 0d |  |  | Participants | Participants | S&A Qualification | 306.71 | 6.13 | Laura Kennedy | Green | GREEN |  |  |  |
| 2540 | 1.7.4.5.4.2 | Qualification Wave 4 Participants submit their Final QAD |  | 100d | 2026-03-09 | 2026-07-24 | 2539FS-1d |  | 2026-03-09 | 2026-07-24 | 101d | 235d | 0d |  |  | Participants | Participants | S&A Qualification | 306.33 | 6.13 | Laura Kennedy | Green | GREEN |  |  |  |
| 2541 | 1.7.4.5.4.3 | Qualification Wave 4 Participants have submitted their Final QAD | milestone | 0d | 2026-07-24 | 2026-07-24 | 2540, 2537 |  | 2026-07-24 | 2026-07-24 | 0d | 235d | 0d |  |  | Participants | Participants | S&A Qualification | 443.71 | 6.13 | Laura Kennedy | Green | GREEN | T3-QU-0109 | QAG | T3 |
| 2542 | 1.7.4.5.4.4 | Completion of Code Bodies review of Final QAD |  | 20d | 2026-07-27 | 2026-08-21 | 2541 |  | 2026-07-27 | 2026-08-21 | 25d | 235d | 0d |  |  | Code Bodies | Code Bodies | S&A Qualification | 446.33 | 6.13 | Laura Kennedy | Green | GREEN |  |  |  |
| 2543 | 1.7.4.5.4.5 | QAD Sign Off deadline |  | 1d | 2026-08-28 | 2026-08-28 | 2542FS+4d |  | 2026-08-28 | 2026-08-28 | 1d | 235d | 0d |  |  | Participants | Participants | S&A Qualification | 478.33 | 6.13 | Laura Kennedy | Green | GREEN |  |  |  |
| 2544 | 1.7.4.5.4.6 | Qualification Wave 4 Participants Qualification approved by BSC PAB and REC Manager | milestone | 0d | 2026-09-24 | 2026-09-24 | 2543FS+19d |  | 2026-09-24 | 2026-09-24 | 0d | 235d | 0d |  |  | Code Bodies | Code Bodies | S&A Qualification | 505.71 | 6.13 | Laura Kennedy | Green | GREEN | T2-QU-0300 | QAG | T3 |

| ID | WBS | Task | Type | Duration | Start | Finish | Predecessors | Complete | Remaining | Baseline start | Baseline finish | Baseline duration | Baseline 1 start | Baseline 1 finish | Total slack | Free slack | Constraint | Responsible | Text9 | Task Status | Update Version | Sched Status | Involved | MHHS Resource Name | MHHS Programme Phase | RAG | Milestone ID | Text29 | Tier |
| --- | --- | --- | --- | --- | --- | --- | --- | --- | --- | --- | --- | --- | --- | --- | --- | --- | --- | --- | --- | --- | --- | --- | --- | --- | --- | --- | --- | --- | --- |
| 2545 | 1.7.4.5.5 | **Qualification Tier 1 Milestone** |  | 66d | 2026-10-28 | 2027-01-28 |  |  |  | 2026-10-28 | 2027-01-28 | 0d |  |  | 235d |  |  | CPT | S&A Qualification | -686.67 | 6.13 | Overdue Start |  |  |  |  |  |  |  |
| 2546 | 1.7.4.5.5.1 | All suppliers must be able to access MPANs under the new TOM (M14) | milestone | 0d | 2026-10-28 | 2026-10-28 | 2544FS+24d |  |  | 2026-10-28 | 2026-10-28 | 0d | 2026-03-16 | 2026-03-16 | 235d | 0d | start no earlier than 2026-03-12 | CPT | S&A Qualification | 539.71 | 6.13 | Green | CPT | CPT | Migration | GREEN | T1-MI-5000 | PSG | T1 |
| 2547 | 1.7.4.5.5.2 | All suppliers must be able to access MPANs under the new TOM (M14*) - Late Exit | milestone | 0d | 2027-01-28 | 2027-01-28 | 2546FS+66d |  |  | 2027-01-28 | 2027-01-28 | 0d | 2026-06-16 | 2026-06-16 | 235d |  |  | CPT | S&A Qualification | 631.71 | 6.13 | Green | CPT | CPT | Migration | GREEN | T1-MI-5500 | PSG | T1 |
| 2548 | 1.7.4.5.6 | **PAB dates** |  | 235d | 2025-01-23 A | 2025-12-18 |  | 99% | 0d |  |  |  |  |  | 526d |  |  | S&A Qualification | S&A Qualification | -834.67 | 6.18 | Overdue Start |  |  |  |  |  |  |  |
| 2549 | 1.7.4.5.6.1 | PAB288 | milestone | 0d | 2025-01-23 A | 2025-01-23 A |  | 100% |  | 2025-01-23 | 2025-01-23 | 0d |  |  |  |  | start no earlier than 2025-01-23 | S&A Qualification | S&A Qualification |  | 6.18 | Complete |  | Laura Kennedy |  | COMPLETE |  | PAB |  |
| 2550 | 1.7.4.5.6.2 | PAB289 |  | 2d | 2025-02-26 A | 2025-02-27 A |  | 100% |  | 2025-02-26 | 2025-02-27 | 0d |  |  |  |  | start no earlier than 2025-02-26 | S&A Qualification | S&A Qualification |  | 6.18 | Complete |  | Laura Kennedy |  | COMPLETE |  | PAB |  |
| 2551 | 1.7.4.5.6.3 | PAB290 | milestone | 0d | 2025-03-12 A | 2025-03-12 A |  | 100% |  | 2025-03-12 | 2025-03-12 | 0d |  |  |  |  | start no earlier than 2025-03-12 | S&A Qualification | S&A Qualification |  | 6.18 | Complete |  | Laura Kennedy |  | COMPLETE |  | PAB |  |
| 2552 | 1.7.4.5.6.4 | PAB291 | milestone | 0d | 2025-03-27 A | 2025-03-27 A |  | 100% |  | 2025-03-27 | 2025-03-27 | 0d |  |  |  |  | start no earlier than 2025-03-27 | S&A Qualification | S&A Qualification |  | 6.18 | Complete |  | Laura Kennedy |  | COMPLETE |  | PAB |  |
| 2553 | 1.7.4.5.6.5 | PAB292 | milestone | 0d | 2025-04-09 A | 2025-04-09 A |  | 100% |  | 2025-04-09 | 2025-04-09 | 0d |  |  |  |  | start no earlier than 2025-04-09 | S&A Qualification | S&A Qualification |  | 6.18 | Complete |  | Laura Kennedy |  | COMPLETE |  | PAB |  |
| 2554 | 1.7.4.5.6.6 | PAB293 | milestone | 0d | 2025-04-24 A | 2025-04-24 A |  | 100% |  | 2025-04-24 | 2025-04-24 | 0d |  |  |  |  | start no earlier than 2025-04-24 | S&A Qualification | S&A Qualification |  | 6.18 | Complete |  | Laura Kennedy |  | COMPLETE |  | PAB |  |
| 2555 | 1.7.4.5.6.7 | PAB294 | milestone | 0d | 2025-05-14 | 2025-05-14 |  |  |  | 2025-05-14 | 2025-05-14 | 0d |  |  | 682d |  | start no earlier than 2025-05-14 | S&A Qualification | S&A Qualification | 7.33 | 6.18 | Green |  | Laura Kennedy |  | GREEN |  | PAB |  |
| 2556 | 1.7.4.5.6.8 | PAB295 | milestone | 0d | 2025-05-29 | 2025-05-29 |  |  |  | 2025-05-29 | 2025-05-29 | 0d |  |  | 671d |  | start no earlier than 2025-05-29 | S&A Qualification | S&A Qualification | 22.33 | 6.18 | Green |  | Laura Kennedy |  | GREEN |  | PAB |  |
| 2557 | 1.7.4.5.6.9 | PAB296 | milestone | 0d | 2025-06-11 | 2025-06-11 |  |  |  | 2025-06-11 | 2025-06-11 | 0d |  |  | 662d |  | start no earlier than 2025-06-11 | S&A Qualification | S&A Qualification | 35.33 | 6.18 | Green |  | Laura Kennedy |  | GREEN |  | PAB |  |
| 2558 | 1.7.4.5.6.10 | PAB297 | milestone | 0d | 2025-06-26 | 2025-06-26 |  |  |  | 2025-06-26 | 2025-06-26 | 0d |  |  | 651d |  | start no earlier than 2025-06-26 | S&A Qualification | S&A Qualification | 50.33 | 6.18 | Green |  | Laura Kennedy |  | GREEN |  | PAB |  |
| 2559 | 1.7.4.5.6.11 | PAB298 | milestone | 0d | 2025-07-16 | 2025-07-16 |  |  |  | 2025-07-16 | 2025-07-16 | 0d |  |  | 637d |  | start no earlier than 2025-07-16 | S&A Qualification | S&A Qualification | 70.33 | 6.18 | Green |  | Laura Kennedy |  | GREEN |  | PAB |  |
| 2560 | 1.7.4.5.6.12 | PAB299 | milestone | 0d | 2025-07-31 | 2025-07-31 |  |  |  | 2025-07-31 | 2025-07-31 | 0d |  |  | 626d |  | start no earlier than 2025-07-31 | S&A Qualification | S&A Qualification | 85.33 | 6.18 | Green |  | Laura Kennedy |  | GREEN |  | PAB |  |
| 2561 | 1.7.4.5.6.13 | PAB300 | milestone | 0d | 2025-08-13 | 2025-08-13 |  |  |  | 2025-08-13 | 2025-08-13 | 0d |  |  | 617d |  | start no earlier than 2025-08-13 | S&A Qualification | S&A Qualification | 98.33 | 6.18 | Green |  | Laura Kennedy |  | GREEN |  | PAB |  |
| 2562 | 1.7.4.5.6.14 | PAB301 | milestone | 0d | 2025-08-28 | 2025-08-28 |  |  |  | 2025-08-28 | 2025-08-28 | 0d |  |  | 606d |  | start no earlier than 2025-08-28 | S&A Qualification | S&A Qualification | 113.33 | 6.18 | Green |  | Laura Kennedy |  | GREEN |  | PAB |  |
| 2563 | 1.7.4.5.6.15 | PAB302 | milestone | 0d | 2025-09-10 | 2025-09-10 |  |  |  | 2025-09-10 | 2025-09-10 | 0d |  |  | 597d |  | start no earlier than 2025-09-10 | S&A Qualification | S&A Qualification | 126.33 | 6.18 | Green |  | Laura Kennedy |  | GREEN |  | PAB |  |
| 2564 | 1.7.4.5.6.16 | PAB303 | milestone | 0d | 2025-09-25 | 2025-09-25 |  |  |  | 2025-09-25 | 2025-09-25 | 0d |  |  | 8d | 1d | start no earlier than 2025-09-25 | S&A Qualification | S&A Qualification | 141.33 | 6.18 | Green |  | Laura Kennedy |  | GREEN |  | PAB |  |
| 2565 | 1.7.4.5.6.17 | PAB304 | milestone | 0d | 2025-10-15 | 2025-10-15 |  |  |  | 2025-10-15 | 2025-10-15 | 0d |  |  | 572d |  | start no earlier than 2025-10-15 | S&A Qualification | S&A Qualification | 161.33 | 6.18 | Green |  | Laura Kennedy |  | GREEN |  | PAB |  |
| 2566 | 1.7.4.5.6.18 | PAB305 | milestone | 0d | 2025-10-30 | 2025-10-30 |  |  |  | 2025-10-30 | 2025-10-30 | 0d |  |  | 561d |  | start no earlier than 2025-10-30 | S&A Qualification | S&A Qualification | 176.33 | 6.18 | Green |  | Laura Kennedy |  | GREEN |  | PAB |  |
| 2567 | 1.7.4.5.6.19 | PAB306 | milestone | 0d | 2025-11-12 | 2025-11-12 |  |  |  | 2025-11-12 | 2025-11-12 | 0d |  |  | 552d |  | start no earlier than 2025-11-12 | S&A Qualification | S&A Qualification | 189.33 | 6.18 | Green |  | Laura Kennedy |  | GREEN |  | PAB |  |
| 2568 | 1.7.4.5.6.20 | PAB307 | milestone | 0d | 2025-11-27 | 2025-11-27 |  |  |  | 2025-11-27 | 2025-11-27 | 0d |  |  | 541d |  | start no earlier than 2025-11-27 | S&A Qualification | S&A Qualification | 204.33 | 6.18 | Green |  | Laura Kennedy |  | GREEN |  | PAB |  |
| 2569 | 1.7.4.5.6.21 | PAB308 | milestone | 0d | 2025-12-18 | 2025-12-18 |  |  |  | 2025-12-18 | 2025-12-18 | 0d |  |  | 526d |  | start no earlier than 2025-12-18 | S&A Qualification | S&A Qualification | 225.33 | 6.18 | Green |  | Laura Kennedy |  | GREEN |  | PAB |  |

Notes:
- 2546: Future RAG: All suppliers must be able to accept MPANs under the new TOM (one way gate)
- 2547: Future RAG: All suppliers must be able to accept MPANs under the new TOM (one way gate)

| ID | WBS | Task | Type | Duration | Start | Finish | Predecessors | Complete | Remaining | Baseline start | Baseline finish | Baseline duration | Baseline 1 start | Baseline 1 finish | Total slack | Constraint | Baseline cost | Responsible | Involved | Text9 | Update Version | MHHS Resource Name | MHHS Programme Phase | Sched Status | RAG | Task Status | Artefact ID | Milestone ID | Text29 | Tier |
| --- | --- | --- | --- | --- | --- | --- | --- | --- | --- | --- | --- | --- | --- | --- | --- | --- | --- | --- | --- | --- | --- | --- | --- | --- | --- | --- | --- | --- | --- | --- |
| 2570 | 1.8 | **REGULATORY** |  | 823d | 2022-10-31 A | 2025-12-24 |  | 99% | 2.17d | 2022-10-31 | 2025-12-24 | 680d | 2022-10-31 | 2025-03-07 | 521d |  | -0 | N/A | N/A | Regulatory | 6.18 | N/A | Regulatory |  |  |  |  |  |  |  |
| 2571 | 1.8.1 | **Baseline MHHS Code Changes** |  | 475d | 2022-10-31 A | 2024-08-23 A |  | 100% |  | 2022-10-31 | 2024-08-23 | 475d | 2022-10-31 | 2024-08-23 |  |  | -0 | N/A | N/A | Regulatory | 5.0 | N/A | Regulatory |  |  |  |  |  |  |  |
| 2572 | 1.8.1.1 | **Preparation and planning** |  | 35d | 2022-10-31 A | 2022-12-16 A |  | 100% |  | 2022-10-31 | 2022-12-16 | 35d | 2022-10-31 | 2022-12-16 |  |  |  | N/A | N/A | Regulatory | 5.0 | N/A | Regulatory |  |  |  |  |  |  |  |
| 2573 | 1.8.1.1.1 | Impact assessment of Programme design on codes to determine required changes |  | 20d | 2022-10-31 A | 2022-11-25 A | 47 | 100% |  | 2022-10-31 | 2022-11-25 | 20d | 2022-10-31 | 2022-11-25 |  |  |  | Code Bodies,SRO Code Drafters | Code Drafting PM | Regulatory | 5.0 | Andrew Margan | Regulatory | Complete | COMPLETE |  |  |  |  |  |
| 2574 | 1.8.1.1.2 | Become 'code draft ready' |  | 35d | 2022-10-31 A | 2022-12-16 A |  | 100% |  | 2022-10-31 | 2022-12-16 | 35d | 2022-10-31 | 2022-12-16 |  |  |  | Code Bodies,SRO Code Drafters | Code Drafting PM | Regulatory | 5.0 | Andrew Margan | Regulatory | Complete | COMPLETE |  |  |  |  |  |
| 2575 | 1.8.1.1.3 | Soft start drafting where possible |  | 35d | 2022-10-31 A | 2022-12-16 A |  | 100% |  | 2022-10-31 | 2022-12-16 | 35d | 2022-10-31 | 2022-12-16 |  |  |  | Code Bodies,SRO Code Drafters | Code Drafting PM | Regulatory | 5.0 | Andrew Margan | Regulatory | Complete | COMPLETE |  |  |  |  |  |
| 2576 | 1.8.1.2 | **Code drafting** |  | 443d | 2022-12-12 A | 2024-08-21 A |  | 100% |  | 2022-12-12 | 2024-08-21 | 445d | 2022-12-12 | 2024-08-23 |  |  | -0 | N/A | N/A | Regulatory | 5.0 | N/A | Regulatory |  |  | M6 |  |  |  |  |
| 2577 | 1.8.1.2.1 | **Data Services (BSC driven)** |  | 118d | 2022-12-12 A | 2023-05-24 A |  | 100% |  | 2022-12-12 | 2023-05-24 | 118d | 2022-12-12 | 2023-05-24 |  |  |  | N/A | N/A | Regulatory | 5.0 | N/A | Regulatory |  |  | M6 |  |  |  |  |
| 2578 | 1.8.1.2.1.1 | Pre Code Drafting activities |  | 5d | 2022-12-12 A | 2022-12-16 A |  | 100% |  | 2022-12-12 | 2022-12-16 | 5d | 2022-12-12 | 2022-12-16 |  | start no earlier than 2022-12-12 |  | Code Drafting PM |  | Regulatory | 5.0 | Andrew Margan | Regulatory | Complete | COMPLETE |  |  |  |  |  |
| 2579 | 1.8.1.2.1.2 | Code and subsidiary document drafting takes place offline |  | 19d | 2023-01-03 A | 2023-01-27 A | 2578FS+11d | 100% |  | 2023-01-03 | 2023-01-27 | 19d | 2023-01-03 | 2023-01-27 |  |  |  | Code Bodies,SRO Design | Code Drafting PM | Regulatory | 5.0 | Andrew Margan | Regulatory | Complete | COMPLETE |  |  |  |  |  |
| 2580 | 1.8.1.2.1.3 | Internal review and cross-checking of drafting across code drafters |  | 11d | 2023-01-30 A | 2023-02-13 A | 2579 | 100% |  | 2023-01-30 | 2023-02-13 | 11d | 2023-01-30 | 2023-02-13 |  |  |  | Code Bodies,SRO Design | Code Drafting PM | Regulatory | 5.0 | Andrew Margan | Regulatory | Complete | COMPLETE |  |  |  |  |  |
| 2581 | 1.8.1.2.1.4 | External industry review via consultation |  | 20d | 2023-02-14 A | 2023-03-13 A | 2580 | 100% |  | 2023-02-14 | 2023-03-13 | 20d | 2023-02-14 | 2023-03-13 |  |  |  | PP | Code Drafting PM | Regulatory | 5.0 | Andrew Margan | Regulatory | Complete | COMPLETE |  |  |  |  |  |
| 2582 | 1.8.1.2.1.5 | Triage and action comments |  | 19d | 2023-03-10 A | 2023-04-05 A | 2581FS-2d | 100% |  | 2023-03-10 | 2023-04-05 | 19d | 2023-03-10 | 2023-04-05 |  |  |  | Code Bodies,SRO Design | Code Drafting PM | Regulatory | 5.0 | Andrew Margan | Regulatory | Complete | COMPLETE |  |  |  |  |  |
| 2583 | 1.8.1.2.1.6 | CDWG review |  | 30d | 2023-04-06 A | 2023-05-17 A | 2582 | 100% |  | 2023-04-06 | 2023-05-17 | 30d | 2023-04-06 | 2023-05-17 |  |  |  | PP | Code Drafting PM | Regulatory | 5.0 | Andrew Margan | Regulatory | Complete | COMPLETE |  |  |  |  |  |
| 2584 | 1.8.1.2.1.7 | CCAG review |  | 5d | 2023-05-18 A | 2023-05-24 A | 2583 | 100% |  | 2023-05-18 | 2023-05-24 | 5d | 2023-05-18 | 2023-05-24 |  |  |  | PP |  | Regulatory | 5.0 | Andrew Margan | Regulatory | Complete | COMPLETE |  |  |  |  |  |
| 2585 | 1.8.1.2.1.8 | Code drafting for Data Services topic area approved | milestone | 0d | 2023-05-24 A | 2023-05-24 A | 2584 | 100% |  | 2023-05-24 | 2023-05-24 | 0d | 2023-05-24 | 2023-05-24 |  |  |  | PP | Code Drafting PM | Regulatory | 5.0 | Andrew Margan | Regulatory | Complete | COMPLETE |  | MHHS-ART060 | T2-RE-0100 | CCAG | T2 |
| 2586 | 1.8.1.2.2 | **Metering (REC driven)** |  | 118d | 2022-12-12 A | 2023-05-24 A |  | 100% |  | 2022-12-12 | 2023-05-24 | 118d | 2022-12-12 | 2023-05-24 |  |  |  | N/A | N/A | Regulatory | 5.0 | N/A | Regulatory |  |  | M6 |  |  |  |  |
| 2587 | 1.8.1.2.2.1 | Pre Code Drafting activities |  | 5d | 2022-12-12 A | 2022-12-16 A | 2578SS | 100% |  | 2022-12-12 | 2022-12-16 | 5d | 2022-12-12 | 2022-12-16 |  |  |  | Code Drafting PM |  | Regulatory | 5.0 | Andrew Margan | Regulatory | Complete | COMPLETE |  |  |  |  |  |
| 2588 | 1.8.1.2.2.2 | Code and subsidiary document drafting takes place offline |  | 19d | 2023-01-03 A | 2023-01-27 A | 2587FS+11d | 100% |  | 2023-01-03 | 2023-01-27 | 19d | 2023-01-03 | 2023-01-27 |  |  |  | Code Bodies,SRO Design | Code Drafting PM | Regulatory | 5.0 | Andrew Margan | Regulatory | Complete | COMPLETE |  |  |  |  |  |
| 2589 | 1.8.1.2.2.3 | Internal review and cross-checking of drafting across code drafters |  | 11d | 2023-01-30 A | 2023-02-13 A | 2588 | 100% |  | 2023-01-30 | 2023-02-13 | 11d | 2023-01-30 | 2023-02-13 |  |  |  | Code Bodies,SRO Design | Code Drafting PM | Regulatory | 5.0 | Andrew Margan | Regulatory | Complete | COMPLETE |  |  |  |  |  |
| 2590 | 1.8.1.2.2.4 | External industry review via consultation |  | 20d | 2023-02-14 A | 2023-03-13 A | 2589 | 100% |  | 2023-02-14 | 2023-03-13 | 20d | 2023-02-14 | 2023-03-13 |  |  |  | PP | Code Drafting PM | Regulatory | 5.0 | Andrew Margan | Regulatory | Complete | COMPLETE |  |  |  |  |  |
| 2591 | 1.8.1.2.2.5 | Triage and action comments |  | 19d | 2023-03-10 A | 2023-04-05 A | 2590FS-2d | 100% |  | 2023-03-10 | 2023-04-05 | 19d | 2023-03-10 | 2023-04-05 |  |  |  | Code Bodies,SRO Design | Code Drafting PM | Regulatory | 5.0 | Andrew Margan | Regulatory | Complete | COMPLETE |  |  |  |  |  |
| 2592 | 1.8.1.2.2.6 | CDWG review |  | 30d | 2023-04-06 A | 2023-05-17 A | 2591 | 100% |  | 2023-04-06 | 2023-05-17 | 30d | 2023-04-06 | 2023-05-17 |  |  |  | PP | Code Drafting PM | Regulatory | 5.0 | Andrew Margan | Regulatory | Complete | COMPLETE |  |  |  |  |  |
| 2593 | 1.8.1.2.2.7 | CCAG review |  | 5d | 2023-05-18 A | 2023-05-24 A | 2592 | 100% |  | 2023-05-18 | 2023-05-24 | 5d | 2023-05-18 | 2023-05-24 |  |  |  | PP |  | Regulatory | 5.0 | Andrew Margan | Regulatory | Complete | COMPLETE |  |  |  |  |  |
| 2594 | 1.8.1.2.2.8 | Code drafting for Metering topic area approved | milestone | 0d | 2023-05-24 A | 2023-05-24 A | 2593 | 100% |  | 2023-05-24 | 2023-05-24 | 0d | 2023-05-24 | 2023-05-24 |  |  |  | PP | Code Drafting PM | Regulatory | 5.0 | Andrew Margan | Regulatory | Complete | COMPLETE |  | MHHS-ART060 | T2-RE-0150 | CCAG | T2 |

| ID | WBS | Task | Type | Duration | Start | Finish | Predecessors | Complete | Baseline start | Baseline finish | Baseline duration | Baseline 1 start | Baseline 1 finish | Constraint | Responsible | Involved | Text9 | Task Status | Update Version | MHHS Resource Name | MHHS Programme Phase | Sched Status | RAG | Artefact ID | Milestone ID | Text29 | Tier |
| --- | --- | --- | --- | --- | --- | --- | --- | --- | --- | --- | --- | --- | --- | --- | --- | --- | --- | --- | --- | --- | --- | --- | --- | --- | --- | --- | --- |
| 2595 | 1.8.1.2.3 | **BSC Central Services (BSC driven)** |  | 156d | 2023-02-22 A | 2023-09-27 A |  | 100% | 2023-02-22 | 2023-09-27 | 156d | 2023-02-22 | 2023-09-14 |  | N/A | N/A | Regulatory | M6 | 5.0 | N/A | Regulatory |  |  |  |  |  |  |
| 2596 | 1.8.1.2.3.1 | Pre Code Drafting activities |  | 5d | 2023-02-22 A | 2023-02-28 A | 2597SS-5d | 100% | 2023-02-22 | 2023-02-28 | 5d | 2023-02-22 | 2023-02-28 |  | Code Drafting PM |  | Regulatory |  | 5.0 | Andrew Margan | Regulatory | Complete | COMPLETE |  |  |  |  |
| 2597 | 1.8.1.2.3.2 | Code Drafting (offline) |  | 80d | 2023-03-01 A | 2023-06-20 A | 2581SS | 100% | 2023-03-01 | 2023-06-20 | 80d | 2023-03-01 | 2023-06-20 | must start on 2023-03-01 | Code Bodies,SRO Design | Code Drafting PM | Regulatory |  | 5.0 | Andrew Margan | Regulatory | Complete | COMPLETE |  |  |  |  |
| 2598 | 1.8.1.2.3.3 | Internal review and cross-checking of drafting across code drafters |  | 70d | 2023-03-15 A | 2023-06-20 A | 2597SS+10d | 100% | 2023-03-15 | 2023-06-20 | 70d | 2023-03-15 | 2023-06-20 |  | Code Bodies,SRO Design | Code Drafting PM | Regulatory |  | 5.0 | Andrew Margan | Regulatory | Complete | COMPLETE |  |  |  |  |
| 2599 | 1.8.1.2.3.4 | External industry review via consultation |  | 15d | 2023-06-21 A | 2023-07-11 A | 2598 | 100% | 2023-06-21 | 2023-07-11 | 15d | 2023-06-21 | 2023-07-11 |  | PP | Code Drafting PM | Regulatory |  | 5.0 | Andrew Margan | Regulatory | Complete | COMPLETE |  |  |  |  |
| 2600 | 1.8.1.2.3.5 | Triage and action comments |  | 19d | 2023-07-10 A | 2023-08-03 A | 2599FS-2d | 100% | 2023-07-10 | 2023-08-03 | 19d | 2023-07-10 | 2023-08-03 |  | Code Bodies,SRO Design | Code Drafting PM | Regulatory |  | 5.0 | Andrew Margan | Regulatory | Complete | COMPLETE |  |  |  |  |
| 2601 | 1.8.1.2.3.6 | CDWG review |  | 28d | 2023-08-04 A | 2023-09-12 A | 2600 | 100% | 2023-08-04 | 2023-09-12 | 28d | 2023-08-04 | 2023-09-07 |  | PP | Code Drafting PM | Regulatory |  | 5.0 | Andrew Margan | Regulatory | Complete | COMPLETE |  |  |  |  |
| 2602 | 1.8.1.2.3.7 | CCAG review |  | 11d | 2023-09-13 A | 2023-09-27 A | 2601 | 100% | 2023-09-13 | 2023-09-27 | 11d | 2023-09-08 | 2023-09-14 |  | PP |  | Regulatory |  | 5.0 | Andrew Margan | Regulatory | Complete | COMPLETE |  |  |  |  |
| 2603 | 1.8.1.2.3.8 | Code drafting for BSC Central Services topic area approved | milestone | 0d | 2023-09-27 A | 2023-09-27 A | 2602 | 100% | 2023-09-27 | 2023-09-27 | 0d | 2023-09-14 | 2023-09-14 |  | PP | Code Drafting PM | Regulatory |  | 5.0 | Andrew Margan | Regulatory | Complete | COMPLETE | MHHS-ART060 | T2-RE-0200 | CCAG | T2 |
| 2604 | 1.8.1.2.4 | **Registration (BSC & REC driven)** |  | 131d | 2023-02-22 A | 2023-08-23 A |  | 100% | 2023-02-22 | 2023-08-23 | 131d | 2023-02-22 | 2023-08-23 |  | N/A | N/A | Regulatory | M6 | 5.0 | N/A | Regulatory |  |  |  |  |  |  |
| 2605 | 1.8.1.2.4.1 | Pre Code Drafting activities |  | 5d | 2023-02-22 A | 2023-02-28 A | 2606SS-5d | 100% | 2023-02-22 | 2023-02-28 | 5d | 2023-02-22 | 2023-02-28 |  | Code Drafting PM |  | Regulatory |  | 5.0 | Andrew Margan | Regulatory | Complete | COMPLETE |  |  |  |  |
| 2606 | 1.8.1.2.4.2 | Code Drafting (offline) |  | 65d | 2023-03-01 A | 2023-05-30 A | 2580, 2589 | 100% | 2023-03-01 | 2023-05-30 | 65d | 2023-03-01 | 2023-05-30 | must start on 2023-03-01 | Code Bodies,SRO Design | Code Drafting PM | Regulatory |  | 5.0 | Andrew Margan | Regulatory | Complete | COMPLETE |  |  |  |  |
| 2607 | 1.8.1.2.4.3 | Internal review and cross-checking of drafting across code drafters |  | 55d | 2023-03-15 A | 2023-05-30 A | 2606SS+10d | 100% | 2023-03-15 | 2023-05-30 | 55d | 2023-03-15 | 2023-05-30 |  | Code Bodies,SRO Design | Code Drafting PM | Regulatory |  | 5.0 | Andrew Margan | Regulatory | Complete | COMPLETE |  |  |  |  |
| 2608 | 1.8.1.2.4.4 | External industry review via consultation |  | 15d | 2023-05-31 A | 2023-06-20 A | 2607 | 100% | 2023-05-31 | 2023-06-20 | 15d | 2023-05-31 | 2023-06-20 |  | PP | Code Drafting PM | Regulatory |  | 5.0 | Andrew Margan | Regulatory | Complete | COMPLETE |  |  |  |  |
| 2609 | 1.8.1.2.4.5 | Triage and action comments |  | 19d | 2023-06-19 A | 2023-07-13 A | 2608FS-2d | 100% | 2023-06-19 | 2023-07-13 | 19d | 2023-06-19 | 2023-07-13 |  | Code Bodies,SRO Design | Code Drafting PM | Regulatory |  | 5.0 | Andrew Margan | Regulatory | Complete | COMPLETE |  |  |  |  |
| 2610 | 1.8.1.2.4.6 | CDWG review |  | 18d | 2023-07-14 A | 2023-08-08 A | 2609 | 100% | 2023-07-14 | 2023-08-08 | 18d | 2023-07-14 | 2023-08-16 |  | PP | Code Drafting PM | Regulatory |  | 5.0 | Andrew Margan | Regulatory | Complete | COMPLETE |  |  |  |  |
| 2611 | 1.8.1.2.4.7 | CCAG review |  | 11d | 2023-08-09 A | 2023-08-23 A | 2610 | 100% | 2023-08-09 | 2023-08-23 | 11d | 2023-08-17 | 2023-08-23 |  | PP |  | Regulatory |  | 5.0 | Andrew Margan | Regulatory | Complete | COMPLETE |  |  |  |  |
| 2612 | 1.8.1.2.4.8 | Code drafting for Registration topic area approved | milestone | 0d | 2023-08-23 A | 2023-08-23 A | 2611 | 100% | 2023-08-23 | 2023-08-23 | 0d | 2023-08-23 | 2023-08-23 |  | PP | Code Drafting PM | Regulatory |  | 5.0 | Andrew Margan | Regulatory | Complete | COMPLETE | MHHS-ART060 | T2-RE-0250 | CCAG | T2 |
| 2613 | 1.8.1.2.5 | **Governance and Qualification (BSC & REC driven)** |  | 130d | 2023-05-25 A | 2023-11-22 A |  | 100% | 2023-05-25 | 2023-11-22 | 130d | 2023-05-25 | 2023-11-13 |  | N/A | N/A | Regulatory | M6 | 5.0 | N/A | Regulatory |  |  |  |  |  |  |
| 2614 | 1.8.1.2.5.1 | Pre Code Drafting activities |  | 5d | 2023-05-25 A | 2023-05-31 A | 2615SS-5d | 100% | 2023-05-25 | 2023-05-31 | 5d | 2023-05-25 | 2023-05-31 |  | Code Drafting PM |  | Regulatory |  | 5.0 | Andrew Margan | Regulatory | Complete | COMPLETE |  |  |  |  |
| 2615 | 1.8.1.2.5.2 | Code Drafting (offline) |  | 55d | 2023-06-01 A | 2023-08-16 A | 2608SS+1d | 100% | 2023-06-01 | 2023-08-16 | 55d | 2023-06-01 | 2023-08-16 |  | Code Bodies,SRO Design | Code Drafting PM | Regulatory |  | 5.0 | Andrew Margan | Regulatory | Complete | COMPLETE |  |  |  |  |
| 2616 | 1.8.1.2.5.3 | Internal review and cross-checking of drafting across code drafters |  | 45d | 2023-06-15 A | 2023-08-16 A | 2615SS+10d | 100% | 2023-06-15 | 2023-08-16 | 45d | 2023-06-15 | 2023-08-16 |  | Code Bodies,SRO Design | Code Drafting PM | Regulatory |  | 5.0 | Andrew Margan | Regulatory | Complete | COMPLETE |  |  |  |  |
| 2617 | 1.8.1.2.5.4 | External industry review via consultation |  | 15d | 2023-08-18 A | 2023-09-07 A | 2616FS+1d | 100% | 2023-08-18 | 2023-09-07 | 15d | 2023-08-18 | 2023-09-07 |  | PP | Code Drafting PM | Regulatory |  | 5.0 | Andrew Margan | Regulatory | Complete | COMPLETE |  |  |  |  |
| 2618 | 1.8.1.2.5.5 | Triage and action comments |  | 19d | 2023-09-06 A | 2023-10-02 A | 2617FS-2d | 100% | 2023-09-06 | 2023-10-02 | 19d | 2023-09-06 | 2023-10-02 |  | Code Bodies,SRO Design | Code Drafting PM | Regulatory |  | 5.0 | Andrew Margan | Regulatory | Complete | COMPLETE |  |  |  |  |
| 2619 | 1.8.1.2.5.6 | CDWG review |  | 31d | 2023-10-03 A | 2023-11-14 A | 2618 | 100% | 2023-10-03 | 2023-11-14 | 31d | 2023-10-03 | 2023-11-06 |  | PP | Code Drafting PM | Regulatory |  | 5.0 | Andrew Margan | Regulatory | Complete | COMPLETE |  |  |  |  |
| 2620 | 1.8.1.2.5.7 | CCAG review |  | 6d | 2023-11-15 A | 2023-11-22 A | 2619 | 100% | 2023-11-15 | 2023-11-22 | 6d | 2023-11-07 | 2023-11-13 |  | PP |  | Regulatory |  | 5.0 | Andrew Margan | Regulatory | Complete | COMPLETE |  |  |  |  |
| 2621 | 1.8.1.2.5.8 | Code drafting for Governance and Qualification topic areas approved | milestone | 0d | 2023-11-22 A | 2023-11-22 A | 2620 | 100% | 2023-11-22 | 2023-11-22 | 0d | 2023-11-13 | 2023-11-13 |  | PP | Code Drafting PM | Regulatory |  | 5.12 | Andrew Margan | Regulatory | Complete | COMPLETE | MHHS-ART060 | T3-RE-0300 | CCAG | T2 |

| ID | WBS | Task | Type | Duration | Start | Finish | Predecessors | Complete | Baseline start | Baseline finish | Baseline duration | Baseline 1 start | Baseline 1 finish | Constraint | Baseline cost | Responsible | Involved | Text9 | Task Status | Update Version | MHHS Resource Name | MHHS Programme Phase | Sched Status | RAG | Artefact ID | Milestone ID | Text29 | Tier |
| --- | --- | --- | --- | --- | --- | --- | --- | --- | --- | --- | --- | --- | --- | --- | --- | --- | --- | --- | --- | --- | --- | --- | --- | --- | --- | --- | --- | --- |
| 2622 | 1.8.1.2.6 | **Interfaces / Data Specification (REC driven)** |  | 174d | 2023-05-25 A | 2024-01-23 A |  | 100% | 2023-05-25 | 2024-01-23 | 175d | 2023-05-25 | 2023-11-13 |  |  | N/A | N/A | Regulatory | M6 | 5.2 | N/A | Regulatory |  |  |  |  |  |  |
| 2623 | 1.8.1.2.6.1 | Pre Code Drafting activities |  | 5d | 2023-05-25 A | 2023-05-31 A | 2624SS-5d | 100% | 2023-05-25 | 2023-05-31 | 5d | 2023-05-25 | 2023-05-31 |  |  | Code Drafting PM |  | Regulatory |  | 5.0 | Andrew Margan | Regulatory | Complete | COMPLETE |  |  |  |  |
| 2624 | 1.8.1.2.6.2 | Code Drafting (offline) |  | 94d | 2023-06-01 A | 2023-10-10 A | 2608SS+1d | 100% | 2023-06-01 | 2023-10-10 | 94d | 2023-06-01 | 2023-08-16 |  |  | Code Bodies,SRO Design | Code Drafting PM | Regulatory |  | 5.2 | Andrew Margan | Regulatory | Complete | COMPLETE |  |  |  |  |
| 2625 | 1.8.1.2.6.3 | Internal review and cross-checking of drafting across code drafters |  | 84d | 2023-06-15 A | 2023-10-10 A | 2624SS+10d | 100% | 2023-06-15 | 2023-10-10 | 84d | 2023-06-15 | 2023-08-16 |  |  | Code Bodies,SRO Design | Code Drafting PM | Regulatory |  | 5.2 | Andrew Margan | Regulatory | Complete | COMPLETE |  |  |  |  |
| 2626 | 1.8.1.2.6.4 | External industry review via consultation |  | 15d | 2023-10-11 A | 2023-10-31 A | 2625 | 100% | 2023-10-11 | 2023-10-31 | 15d | 2023-08-18 | 2023-09-07 |  |  | PP | Code Drafting PM | Regulatory |  | 5.2 | Andrew Margan | Regulatory | Complete | COMPLETE |  |  |  |  |
| 2627 | 1.8.1.2.6.5 | Triage and action comments |  | 20d | 2023-10-30 A | 2023-11-24 A | 2626FS-2d | 100% | 2023-10-30 | 2023-11-24 | 20d | 2023-09-06 | 2023-10-02 |  |  | Code Bodies,SRO Design | Code Drafting PM | Regulatory |  | 5.2 | Andrew Margan | Regulatory | Complete | COMPLETE |  |  |  |  |
| 2628 | 1.8.1.2.6.6 | CDWG review |  | 37d | 2023-11-27 A | 2024-01-16 A | 2627 | 100% | 2023-11-27 | 2024-01-16 | 32d | 2023-10-03 | 2023-11-06 |  |  | PP | Code Drafting PM | Regulatory |  | 5.2 | Andrew Margan | Regulatory | Complete | COMPLETE |  |  |  |  |
| 2629 | 1.8.1.2.6.7 | CCAG review |  | 5d | 2024-01-17 A | 2024-01-23 A | 2628 | 100% | 2024-01-17 | 2024-01-23 | 11d | 2023-11-07 | 2023-11-13 |  |  | PP | Code Drafting PM | Regulatory |  | 5.2 | Andrew Margan | Regulatory | Complete | COMPLETE |  |  |  |  |
| 2630 | 1.8.1.2.6.8 | Code drafting for Interfaces / Data Specification topic areas approved | milestone | 0d | 2024-01-23 A | 2024-01-23 A | 2629 | 100% | 2024-01-23 | 2024-01-23 | 0d | 2023-11-13 | 2023-11-13 |  |  | PP | Code Drafting PM | Regulatory |  | 5.16 | Andrew Margan | Regulatory | Complete | COMPLETE | MHHS-ART060 | T3-RE-0350 | CCAG | T2 |
| 2631 | 1.8.1.2.7 | **Migration (BSC & REC driven)** |  | 130d | 2023-05-25 A | 2023-11-22 A |  | 100% | 2023-05-25 | 2023-11-22 | 130d | 2023-05-25 | 2023-11-13 |  |  | N/A | N/A | Regulatory | M6 | 5.0 | N/A | Regulatory |  |  |  |  |  |  |
| 2632 | 1.8.1.2.7.1 | Pre Code Drafting activities |  | 5d | 2023-05-25 A | 2023-05-31 A | 2633SS-5d | 100% | 2023-05-25 | 2023-05-31 | 5d | 2023-05-25 | 2023-05-31 |  |  | Code Drafting PM |  | Regulatory |  | 5.0 | Andrew Margan | Regulatory | Complete | COMPLETE |  |  |  |  |
| 2633 | 1.8.1.2.7.2 | Code Drafting (offline) |  | 55d | 2023-06-01 A | 2023-08-16 A | 2608SS+1d | 100% | 2023-06-01 | 2023-08-16 | 55d | 2023-06-01 | 2023-08-16 |  |  | Code Bodies,SRO Design | Code Drafting PM | Regulatory |  | 5.0 | Andrew Margan | Regulatory | Complete | COMPLETE |  |  |  |  |
| 2634 | 1.8.1.2.7.3 | Internal review and cross-checking of drafting across code drafters |  | 45d | 2023-06-15 A | 2023-08-16 A | 2633SS+10d | 100% | 2023-06-15 | 2023-08-16 | 45d | 2023-06-15 | 2023-08-16 |  |  | Code Bodies,SRO Design | Code Drafting PM | Regulatory |  | 5.0 | Andrew Margan | Regulatory | Complete | COMPLETE |  |  |  |  |
| 2635 | 1.8.1.2.7.4 | External industry review via consultation |  | 15d | 2023-08-18 A | 2023-09-07 A | 2634FS+1d | 100% | 2023-08-18 | 2023-09-07 | 15d | 2023-08-18 | 2023-09-07 |  |  | PP | Code Drafting PM | Regulatory |  | 5.0 | Andrew Margan | Regulatory | Complete | COMPLETE |  |  |  |  |
| 2636 | 1.8.1.2.7.5 | Triage and action comments |  | 19d | 2023-09-06 A | 2023-10-02 A | 2635FS-2d | 100% | 2023-09-06 | 2023-10-02 | 19d | 2023-09-06 | 2023-10-02 |  |  | Code Bodies,SRO Design | Code Drafting PM | Regulatory |  | 5.0 | Andrew Margan | Regulatory | Complete | COMPLETE |  |  |  |  |
| 2637 | 1.8.1.2.7.6 | CDWG review |  | 31d | 2023-10-03 A | 2023-11-14 A | 2636 | 100% | 2023-10-03 | 2023-11-14 | 31d | 2023-10-03 | 2023-11-06 |  |  | PP | Code Drafting PM | Regulatory |  | 5.0 | Andrew Margan | Regulatory | Complete | COMPLETE |  |  |  |  |
| 2638 | 1.8.1.2.7.7 | CCAG review |  | 6d | 2023-11-15 A | 2023-11-22 A | 2637 | 100% | 2023-11-15 | 2023-11-22 | 6d | 2023-11-07 | 2023-11-13 |  |  | PP | Code Drafting PM | Regulatory |  | 5.0 | Andrew Margan | Regulatory | Complete | COMPLETE |  |  |  |  |
| 2639 | 1.8.1.2.7.8 | Code drafting for Migration topic area approved | milestone | 0d | 2023-11-22 A | 2023-11-22 A | 2638 | 100% | 2023-11-22 | 2023-11-22 | 0d | 2023-11-13 | 2023-11-13 |  |  | PP | Code Drafting PM | Regulatory |  | 5.12 | Andrew Margan | Regulatory | Complete | COMPLETE | MHHS-ART060 | T3-RE-0400 | CCAG | T2 |
| 2640 | 1.8.1.2.8 | **Consequential Code Change** |  | 109d | 2023-10-11 A | 2024-03-11 A |  | 100% | 2023-10-11 | 2024-03-11 | 108d | 2023-08-18 | 2024-03-08 |  | -0 | N/A | N/A | Regulatory |  | 5.0 | N/A | Regulatory |  |  |  |  |  |  |
| 2641 | 1.8.1.2.8.1 | External industry review via consultation - drop 1 (DCUSA) |  | 15d | 2023-10-11 A | 2023-10-31 A | 2647SS | 100% | 2023-10-11 | 2023-10-31 | 15d | 2023-08-18 | 2023-09-07 |  |  | Code Bodies | PP | Regulatory |  | 5.2 | Andrew Margan | Regulatory | Complete | COMPLETE |  |  |  |  |
| 2642 | 1.8.1.2.8.2 | External industry review via consultation - drop 2 (Elexon) |  | 16d | 2024-02-19 A | 2024-03-11 A | 2657SS | 100% | 2024-02-19 | 2024-03-11 | 15d | 2023-10-16 | 2023-11-03 | start no earlier than 2024-02-19 |  | Code Bodies | PP | Regulatory |  | 5.2 | Andrew Margan | Regulatory | Complete | COMPLETE |  |  |  |  |
| 2643 | 1.8.1.2.9 | **Transition Text (all codes)** |  | 118d | 2023-08-11 A | 2024-01-23 A |  | 100% | 2023-08-11 | 2024-01-23 | 119d | 2023-08-11 | 2024-01-25 |  |  | N/A | N/A | Regulatory | M6 | 5.2 | N/A | Regulatory |  |  |  |  |  |  |
| 2644 | 1.8.1.2.9.1 | Pre Code Drafting activities |  | 8d | 2023-08-11 A | 2023-08-22 A | 2645SS-5d | 100% | 2023-08-11 | 2023-08-22 | 8d | 2023-08-11 | 2023-08-17 |  |  | Code Drafting PM |  | Regulatory |  | 5.0 | Andrew Margan | Regulatory | Complete | COMPLETE |  |  |  |  |
| 2645 | 1.8.1.2.9.2 | Code Drafting (offline) |  | 38d | 2023-08-18 A | 2023-10-10 A | 2635SS | 100% | 2023-08-18 | 2023-10-10 | 38d | 2023-08-18 | 2023-10-12 |  |  | Code Bodies,SRO Design | Code Drafting PM | Regulatory |  | 5.2 | Andrew Margan | Regulatory | Complete | COMPLETE |  |  |  |  |
| 2646 | 1.8.1.2.9.3 | Internal review and cross-checking of drafting across code drafters |  | 28d | 2023-09-01 A | 2023-10-10 A | 2645SS+10d | 100% | 2023-09-01 | 2023-10-10 | 28d | 2023-09-01 | 2023-10-12 |  |  | Code Bodies,SRO Design | Code Drafting PM | Regulatory |  | 5.2 | Andrew Margan | Regulatory | Complete | COMPLETE |  |  |  |  |
| 2647 | 1.8.1.2.9.4 | External industry review via consultation |  | 15d | 2023-10-11 A | 2023-10-31 A | 2646 | 100% | 2023-10-11 | 2023-10-31 | 15d | 2023-10-16 | 2023-11-03 |  |  | PP | Code Drafting PM | Regulatory |  | 5.2 | Andrew Margan | Regulatory | Complete | COMPLETE |  |  |  |  |
| 2648 | 1.8.1.2.9.5 | Triage and action comments |  | 20d | 2023-10-30 A | 2023-11-24 A | 2647FS-2d | 100% | 2023-10-30 | 2023-11-24 | 20d | 2023-11-02 | 2023-11-21 |  |  | Code Bodies,SRO Design | Code Drafting PM | Regulatory |  | 5.2 | Andrew Margan | Regulatory | Complete | COMPLETE |  |  |  |  |
| 2649 | 1.8.1.2.9.6 | CDWG review |  | 37d | 2023-11-27 A | 2024-01-16 A | 2648 | 100% | 2023-11-27 | 2024-01-16 | 37d | 2023-11-22 | 2024-01-17 |  |  | PP | Code Drafting PM | Regulatory |  | 5.2 | Andrew Margan | Regulatory | Complete | COMPLETE |  |  |  |  |
| 2650 | 1.8.1.2.9.7 | CCAG review |  | 5d | 2024-01-17 A | 2024-01-23 A | 2649 | 100% | 2024-01-17 | 2024-01-23 | 6d | 2024-01-18 | 2024-01-25 |  |  | PP | Code Drafting PM | Regulatory |  | 5.2 | Andrew Margan | Regulatory | Complete | COMPLETE |  |  |  |  |
| 2651 | 1.8.1.2.9.8 | Code drafting for Transition Text topic area approved | milestone | 0d | 2024-01-23 A | 2024-01-23 A | 2650 | 100% | 2024-01-23 | 2024-01-23 | 0d | 2024-01-25 | 2024-01-25 |  |  | PP | Code Drafting PM | Regulatory |  | 5.16 | Andrew Margan | Regulatory | Complete | COMPLETE | MHHS-ART060 | T3-RE-0450 | CCAG | T2 |

Notes:
- 2645: Guidance: 14/8/23 - RECCo transition drafting activity is expected to take the full 38 days, noting BSE co-drafting will be expected to take approx. 21 days

| ID | WBS | Task | Type | Duration | Start | Finish | Predecessors | Complete | Baseline start | Baseline finish | Baseline duration | Baseline 1 start | Baseline 1 finish | Baseline cost | Responsible | Involved | Text9 | Task Status | Update Version | MHHS Resource Name | MHHS Programme Phase | Sched Status | RAG | Artefact ID | Milestone ID | Text29 | Tier |
| --- | --- | --- | --- | --- | --- | --- | --- | --- | --- | --- | --- | --- | --- | --- | --- | --- | --- | --- | --- | --- | --- | --- | --- | --- | --- | --- | --- |
| 2652 | 1.8.1.2.10 | **Final Code Drafting (mop-up) (all codes)** |  | 199d | 2023-08-18 A | 2024-05-22 A |  | 100% | 2023-08-18 | 2024-05-22 | 199d | 2023-08-18 | 2024-05-13 |  | N/A | N/A | Regulatory | M6 | 5.0 | N/A | Regulatory |  |  |  |  |  |  |
| 2653 | 1.8.1.2.10.1 | Forward look and confirm remaining plan |  | 15d | 2023-08-18 A | 2023-09-07 A | 2645SS | 100% | 2023-08-18 | 2023-09-07 | 15d | 2023-08-18 | 2023-09-07 |  | Code Drafting PM |  | Regulatory |  | 5.0 | Andrew Margan | Regulatory | Complete | COMPLETE |  |  |  |  |
| 2654 | 1.8.1.2.10.2 | Identify remaining or additional areas of code (e.g. consequential change requirements) to be completed |  | 15d | 2023-08-18 A | 2023-09-07 A | 2653SS | 100% | 2023-08-18 | 2023-09-07 | 15d | 2023-08-18 | 2023-09-07 |  | Code Bodies,SRO Design | Code Drafting PM | Regulatory |  | 5.0 | Andrew Margan | Regulatory | Complete | COMPLETE |  |  |  |  |
| 2655 | 1.8.1.2.10.3 | Code Drafting (offline) Interim Consultation (1) |  | 60d | 2023-09-08 A | 2023-11-30 A | 2654 | 100% | 2023-09-08 | 2023-11-30 | 60d | 2023-09-08 | 2024-02-15 |  | Code Bodies,SRO Design | Code Drafting PM | Regulatory |  | 5.0 | Andrew Margan | Regulatory | Complete | COMPLETE |  |  |  |  |
| 2656 | 1.8.1.2.10.4 | Internal review and cross-checking of drafting across code drafters Interim Consultation (1) |  | 50d | 2023-09-22 A | 2023-11-30 A | 2655SS+10d | 100% | 2023-09-22 | 2023-11-30 | 50d | 2023-09-22 | 2024-02-15 |  | Code Bodies,SRO Design | Code Drafting PM | Regulatory |  | 5.0 | Andrew Margan | Regulatory | Complete | COMPLETE |  |  |  |  |
| 2657 | 1.8.1.2.10.5 | External industry review via consultation Interim Consultation (1) |  | 23d | 2023-12-01 A | 2024-01-02 A | 2656 | 100% | 2023-12-01 | 2024-01-02 | 23d | 2024-02-19 | 2024-03-08 |  | PP | Code Drafting PM | Regulatory |  | 5.0 | Andrew Margan | Regulatory | Complete | COMPLETE |  |  |  |  |
| 2658 | 1.8.1.2.10.6 | Code Drafting (offline) Final Consultation (2) |  | 55d | 2023-12-01 A | 2024-02-15 A | 2656 | 100% | 2023-12-01 | 2024-02-15 | 55d | 2023-09-08 | 2024-02-15 |  | Code Bodies,SRO Design | Code Drafting PM | Regulatory |  | 5.0 | Andrew Margan | Regulatory | Complete | COMPLETE |  |  |  |  |
| 2659 | 1.8.1.2.10.7 | Internal review and cross-checking of drafting across code drafters Final Consultation (2) |  | 45d | 2023-12-15 A | 2024-02-15 A | 2658SS+10d | 100% | 2023-12-15 | 2024-02-15 | 45d | 2023-09-22 | 2024-02-15 |  | Code Bodies,SRO Design | Code Drafting PM | Regulatory |  | 5.0 | Andrew Margan | Regulatory | Complete | COMPLETE |  |  |  |  |
| 2660 | 1.8.1.2.10.8 | External industry review via consultation Final Consultation (2) |  | 16d | 2024-02-19 A | 2024-03-11 A | 2659FS+1d | 100% | 2024-02-19 | 2024-03-11 | 15d | 2024-02-19 | 2024-03-08 |  | PP | Code Drafting PM | Regulatory |  | 5.0 | Andrew Margan | Regulatory | Complete | COMPLETE |  |  |  |  |
| 2661 | 1.8.1.2.10.9 | Triage and action comments |  | 18d | 2024-03-11 A | 2024-04-03 A | 2660FS-1d | 100% | 2024-03-11 | 2024-04-03 | 18d | 2024-03-07 | 2024-04-03 |  | Code Bodies,SRO Design | Code Drafting PM | Regulatory |  | 5.0 | Andrew Margan | Regulatory | Complete | COMPLETE |  |  |  |  |
| 2662 | 1.8.1.2.10.10 | CDWG review |  | 29d | 2024-04-04 A | 2024-05-14 A | 2661 | 100% | 2024-04-04 | 2024-05-14 | 31d | 2024-04-04 | 2024-05-03 |  | PP | Code Drafting PM | Regulatory |  | 5.0 | Andrew Margan | Regulatory | Complete | COMPLETE |  |  |  |  |
| 2663 | 1.8.1.2.10.11 | CCAG review |  | 6d | 2024-05-15 A | 2024-05-22 A | 2662 | 100% | 2024-05-15 | 2024-05-22 | 6d | 2024-05-06 | 2024-05-13 |  | PP | Code Drafting PM | Regulatory |  | 5.0 | Andrew Margan | Regulatory | Complete | COMPLETE |  |  |  |  |
| 2664 | 1.8.1.2.10.12 | Final code drafting (mop-up) approved | milestone | 0d | 2024-05-22 A | 2024-05-22 A | 2663 | 100% | 2024-05-22 | 2024-05-22 | 0d | 2024-05-13 | 2024-05-13 |  | PP | Code Drafting PM | Regulatory |  | 5.25 | Andrew Margan | Regulatory | Complete | COMPLETE | MHHS-ART060 | T3-RE-0500 | CCAG | T2 |
| 2665 | 1.8.1.2.11 | **Final code review, consistency check and approval** |  | 100d | 2024-04-04 A | 2024-08-21 A |  | 100% | 2024-04-04 | 2024-08-21 | 102d | 2024-05-06 | 2024-08-23 | -0 | N/A | N/A | Regulatory | M6 | 5.0 | N/A | Regulatory |  |  |  |  |  |  |
| 2666 | 1.8.1.2.11.1 | Gap analysis of final code against design artefacts (reverse process to code drafting) |  | 38d | 2024-04-04 A | 2024-05-27 A | 2662SS | 100% | 2024-04-04 | 2024-05-27 | 38d | 2024-05-06 | 2024-05-17 |  | Code Bodies,SRO Design | Code Drafting PM | Regulatory |  | 5.0 | Andrew Margan | Regulatory | Complete | COMPLETE |  |  |  |  |
| 2667 | 1.8.1.2.11.2 | Outputs of gap analysis actioned offline |  | 11d | 2024-05-28 A | 2024-06-11 A | 2666 | 100% | 2024-05-28 | 2024-06-11 | 11d | 2024-05-20 | 2024-06-07 |  | Code Bodies,SRO Design | Code Drafting PM | Regulatory |  | 5.0 | Andrew Margan | Regulatory | Complete | COMPLETE |  |  |  |  |
| 2668 | 1.8.1.2.11.3 | Final documentation collated for final consultation |  | 8d | 2024-06-12 A | 2024-06-21 A | 2667 | 100% | 2024-06-12 | 2024-06-21 | 9d | 2024-06-10 | 2024-06-13 |  | Code Drafting PM | Code Bodies,SRO Design | Regulatory |  | 5.23 | Andrew Margan | Regulatory | Complete | COMPLETE |  |  |  |  |
| 2669 | 1.8.1.2.11.4 | External industry review via consultation |  | 15d | 2024-06-24 A | 2024-07-12 A | 2668 | 100% | 2024-06-24 | 2024-07-12 | 20d | 2024-06-14 | 2024-07-04 |  | PP | Code Drafting PM | Regulatory |  | 5.0 | Andrew Margan | Regulatory | Complete | COMPLETE |  |  |  |  |
| 2670 | 1.8.1.2.11.5 | Triage and action comments |  | 10d | 2024-07-15 A | 2024-07-26 A | 2669 | 100% | 2024-07-15 | 2024-07-26 | 13d | 2024-07-03 | 2024-07-19 |  | Code Bodies,SRO Design | Code Drafting PM | Regulatory |  | 5.0 | Andrew Margan | Regulatory | Complete | COMPLETE |  |  |  |  |
| 2671 | 1.8.1.2.11.6 | Final CDWG review |  | 8d | 2024-08-02 A | 2024-08-13 A | 2670FS+4d | 100% | 2024-08-02 | 2024-08-13 | 6d | 2024-07-22 | 2024-08-16 |  | PP | Code Drafting PM | Regulatory |  | 5.0 | Andrew Margan | Regulatory | Complete | COMPLETE |  |  |  |  |
| 2672 | 1.8.1.2.11.7 | Final CCAG review |  | 6d | 2024-08-14 A | 2024-08-21 A | 2671 | 100% | 2024-08-14 | 2024-08-21 | 8d | 2024-08-19 | 2024-08-23 |  | PP | Code Drafting PM | Regulatory |  | 5.0 | Andrew Margan | Regulatory | Complete | COMPLETE |  |  |  |  |
| 2673 | 1.8.1.2.11.8 | CCAG recommend final code to PSG for baselining | milestone | 0d | 2024-08-21 A | 2024-08-21 A | 2672 | 100% | 2024-08-21 | 2024-08-21 | 0d | 2024-08-23 | 2024-08-23 |  | PP | Code Drafting PM | Regulatory |  | 5.9 | Andrew Margan | Regulatory | Complete | COMPLETE | MHHS-ART060 | T3-RE-0550 | CCAG | T2 |
| 2674 | 1.8.1.3 | Code changes baselined (M6) | milestone | 0d | 2024-08-23 A | 2024-08-23 A | 2672FS+2d, 2664, 2651, 2639, 2630, 2621, 2612, 2603, 2594, 2585 | 100% | 2024-08-23 | 2024-08-23 | 0d | 2024-08-23 | 2024-08-23 |  | CPT | PP | Regulatory |  | 5.0 | Andrew Margan | Regulatory | Complete | COMPLETE | MHHS-ART012 | T1-RE-1000 | PSG | T1 |
| 2675 | 1.8.2 | **Ofgem preparation and enactment of SCR powers** |  | 225d | 2024-02-05 A | 2024-12-13 A |  | 100% | 2024-02-05 | 2024-12-13 | 225d | 2024-01-26 | 2024-11-12 | -0 | N/A | N/A | Regulatory | M7 | 5.0 | N/A | Regulatory |  |  |  |  |  |  |
| 2676 | 1.8.2.1 | **Preparation and enactment of SCR Powers** |  | 223d | 2024-02-05 A | 2024-12-11 A |  | 100% | 2024-02-05 | 2024-12-11 | 223d | 2024-01-26 | 2024-11-11 | -0 | N/A | N/A | Regulatory |  | 5.0 | N/A | Regulatory |  |  |  |  |  |  |
| 2677 | 1.8.2.1.1 | Ofgem to keep Ofgem legal informed of process followed and nature of Code drafting to ensure that prepared for SCR go/no go decision |  | 101d | 2024-02-05 A | 2024-06-24 A | 2678SF | 100% | 2024-02-05 | 2024-06-24 | 101d | 2024-01-26 | 2024-06-14 |  | Ofgem | Code Bodies | Regulatory |  | 5.0 | Andrew Margan | Regulatory | Complete | COMPLETE |  |  |  |  |
| 2678 | 1.8.2.1.2 | OFGEM Legal to review Code Artefacts deliver policy intent and process followed and confirm that SCR powers are appropriate to use rather than SMAP - SCR go/no go |  | 14d | 2024-06-24 A | 2024-07-11 A | 2669SS | 100% | 2024-06-24 | 2024-07-11 | 15d | 2024-06-14 | 2024-07-04 |  | Ofgem | Code Bodies | Regulatory |  | 5.0 | Andrew Margan | Regulatory | Complete | COMPLETE |  |  |  |  |
| 2679 | 1.8.2.1.3 | Code Bodies to draft MOD proposal forms |  | 20d | 2024-07-12 A | 2024-08-08 A | 2678 | 100% | 2024-07-12 | 2024-08-08 | 20d | 2024-07-05 | 2024-08-01 |  | Code Bodies | Ofgem | Regulatory |  | 5.0 | Andrew Margan | Regulatory | Complete | COMPLETE |  |  |  |  |
| 2680 | 1.8.2.1.4 | Ofgem discuss and agree code mod timetable with code bodies (and MHHSP in relation to the dates for expected decisions) |  | 20d | 2024-07-12 A | 2024-08-08 A | 2678 | 100% | 2024-07-12 | 2024-08-08 | 20d | 2024-07-05 | 2024-08-01 |  | Ofgem | Code Bodies | Regulatory |  | 5.0 | Andrew Margan | Regulatory | Complete | COMPLETE |  |  |  |  |
| 2681 | 1.8.2.1.5 | Ofgem to publish each Direction to each code body specifying the timetable for each modification |  | 1d | 2024-08-28 A | 2024-08-28 A | 2680FS+13d | 100% | 2024-08-28 | 2024-08-28 | 1d | 2024-08-28 | 2024-08-28 |  | Ofgem | Code Bodies | Regulatory |  | 5.0 | Andrew Margan | Regulatory | Complete | COMPLETE |  |  |  |  |
| 2682 | 1.8.2.1.6 | Formally submit (by separate email) Modification Proposal Forms and legal texts to each code body |  | 1d | 2024-08-28 A | 2024-08-28 A | 2680FS+13d | 100% | 2024-08-28 | 2024-08-28 | 1d | 2024-08-28 | 2024-08-28 |  | Ofgem | Code Bodies | Regulatory |  | 5.0 | Andrew Margan | Regulatory | Complete | COMPLETE |  |  |  |  |
| 2683 | 1.8.2.1.7 | Each Code Body publishes and issues Modification Proposal Forms |  | 3d | 2024-08-29 A | 2024-09-02 A | 2682, 2681 | 100% | 2024-08-29 | 2024-09-02 | 3d | 2024-08-29 | 2024-09-02 |  | Code Bodies | Ofgem | Regulatory |  | 5.0 | Andrew Margan | Regulatory | Complete | COMPLETE |  |  |  |  |
| 2684 | 1.8.2.1.8 | Each Code Body sends Modification Proposal Forms to Panel to approve Mod to go to consultation |  | 10d | 2024-09-03 A | 2024-09-16 A | 2683 | 100% | 2024-09-03 | 2024-09-16 | 10d | 2024-09-03 | 2024-09-16 |  | Code Bodies | Ofgem | Regulatory |  | 5.0 | Andrew Margan | Regulatory | Complete | COMPLETE |  |  |  |  |
| 2685 | 1.8.2.1.9 | Modification Proposal approved by Panel for Consultation |  | 1d | 2024-09-17 A | 2024-09-17 A | 2684 | 100% | 2024-09-17 | 2024-09-17 | 1d | 2024-09-17 | 2024-09-17 |  | Code Bodies | Ofgem | Regulatory |  | 5.0 | Andrew Margan | Regulatory | Complete | COMPLETE |  |  |  |  |
| 2686 | 1.8.2.1.10 | Draft Modification Report issued for consultation |  | 1d | 2024-09-18 A | 2024-09-18 A | 2685 | 100% | 2024-09-18 | 2024-09-18 | 1d | 2024-09-18 | 2024-09-18 |  | Code Bodies | Ofgem | Regulatory |  | 5.0 | Andrew Margan | Regulatory | Complete | COMPLETE |  |  |  |  |
| 2687 | 1.8.2.1.11 | Consultation Close-out for representations |  | 15d | 2024-09-19 A | 2024-10-09 A | 2686 | 100% | 2024-09-19 | 2024-10-09 | 15d | 2024-09-19 | 2024-10-09 |  | Code Bodies | Ofgem | Regulatory |  | 5.0 | Andrew Margan | Regulatory | Complete | COMPLETE |  |  |  |  |
| 2688 | 1.8.2.1.12 | Each Code Body reviews consultation response and drafts Modification Report |  | 10d | 2024-10-10 A | 2024-10-23 A | 2687 | 100% | 2024-10-10 | 2024-10-23 | 10d | 2024-10-10 | 2024-10-23 |  | Code Bodies | Ofgem | Regulatory |  | 5.0 | Andrew Margan | Regulatory | Complete | COMPLETE |  |  |  |  |
| 2689 | 1.8.2.1.13 | Final Modification Report sent to Panel for decision with recommendation to approve |  | 1d | 2024-10-24 A | 2024-10-24 A | 2688 | 100% | 2024-10-24 | 2024-10-24 | 1d | 2024-10-24 | 2024-10-24 |  | Code Bodies | Ofgem | Regulatory |  | 6.11 | Andrew Margan | Regulatory | Complete | COMPLETE |  |  |  |  |
| 2690 | 1.8.2.1.14 | Modification Panel decision |  | 1d | 2024-11-07 A | 2024-11-07 A | 2689FS+9d | 100% | 2024-11-07 | 2024-11-07 | 1d | 2024-11-07 | 2024-11-07 |  | Code Bodies | Ofgem | Regulatory |  | 6.11 | Andrew Margan | Regulatory | Complete | COMPLETE |  |  |  |  |
| 2691 | 1.8.2.1.15 | Code Bodies Submit Final Modification/Change Reports |  | 1d | 2024-11-08 A | 2024-11-08 A | 2690 | 100% | 2024-11-08 | 2024-11-08 | 1d |  |  |  | Code Bodies | Ofgem | Regulatory |  | 6.11 | Andrew Margan |  | Complete | COMPLETE |  |  |  |  |
| 2692 | 1.8.2.1.16 | Ofgem Reviews Final Modification/Change Reports |  | 10d | 2024-11-11 A | 2024-11-22 A | 2691 | 100% | 2024-11-11 | 2024-11-22 | 10d |  |  |  | Ofgem | Code Bodies | Regulatory |  | 6.11 | Andrew Margan |  | Complete | COMPLETE |  |  |  |  |
| 2693 | 1.8.2.1.17 | Ofgem Drafts Decision/Direction Letters |  | 17d | 2024-11-18 A | 2024-12-10 A | 2692SS+5d | 100% | 2024-11-18 | 2024-12-10 | 17d |  |  |  | Ofgem | Code Bodies | Regulatory |  | 6.11 | Andrew Margan |  | Complete | COMPLETE |  |  |  |  |
| 2694 | 1.8.2.1.18 | Ofgem Internally Signs Off the Decision/Direction Letters and Sends Them to the Code Bodies |  | 1d | 2024-12-11 A | 2024-12-11 A | 2693 | 100% | 2024-12-11 | 2024-12-11 | 1d |  |  |  | Ofgem | Code Bodies | Regulatory |  | 6.11 | Andrew Margan |  | Complete | COMPLETE |  |  |  |  |
| 2695 | 1.8.2.2 | Ofgem decisions on M6 baselined code modification proposals (M7) | milestone | 0d | 2024-12-11 A | 2024-12-11 A | 2674, 2694 | 100% | 2024-12-11 | 2024-12-11 | 0d | 2024-11-11 | 2024-11-11 |  | CPT | PP | Regulatory |  | 6.11 | Andrew Margan | Regulatory | Complete | COMPLETE | MHHS-ART012 | T2-RE-0600 | CCAG | T2 |
| 2696 | 1.8.2.3 | Ofgem Publishes the Decisions/Directions |  | 2d | 2024-12-12 A | 2024-12-13 A | 2695 | 100% | 2024-12-12 | 2024-12-13 | 2d |  |  |  | Ofgem | Code Bodies | Regulatory |  | 6.11 | Andrew Margan |  | Complete | COMPLETE |  |  |  |  |

Notes:
- 2695: Guidance: 5/8/25 - CR no52 and going to PSG on 7/8/24. 21/8/24: Milestone name and date change approved at psg on 7/8/24

| ID | WBS | Task | Type | Duration | Start | Finish | Predecessors | Complete | Remaining | Baseline start | Baseline finish | Baseline duration | Baseline 1 start | Baseline 1 finish | Total slack | Free slack | Constraint | Responsible | Involved | Text9 | Task Status | Update Version | MHHS Resource Name | MHHS Programme Phase | Sched Status | RAG | Milestone ID | Text29 | Artefact ID | Tier |
| --- | --- | --- | --- | --- | --- | --- | --- | --- | --- | --- | --- | --- | --- | --- | --- | --- | --- | --- | --- | --- | --- | --- | --- | --- | --- | --- | --- | --- | --- | --- |
| 2697 | 1.8.3 | **Deliver MHHS Code Changes** |  | 292d | 2024-11-12 A | 2025-12-24 |  | 93% | 20.86d | 2024-11-12 | 2025-12-24 | 149d | 2024-11-12 | 2025-03-07 | 521d |  |  | N/A | N/A | Regulatory | M8 | 6.11 | N/A | Regulatory |  |  |  |  |  |  |
| 2698 | 1.8.3.1 | **Releases** |  | 78d | 2024-11-12 A | 2025-02-27 A |  | 100% |  | 2024-11-12 | 2025-12-24 | 149d | 2024-11-12 | 2025-03-07 |  |  |  | N/A | N/A | Regulatory |  | 6.11 | N/A | Regulatory |  |  |  |  |  |  |
| 2699 | 1.8.3.1.1 | Impacted codes make resourcing provisions and prepare to implement new Code via internal code body change processes |  | 78d | 2024-11-12 A | 2025-02-27 A |  | 100% |  | 2024-11-12 | 2025-02-27 | 78d | 2024-11-12 | 2025-02-27 |  |  | start no earlier than 2024-11-12 | Code Bodies |  | Regulatory |  | 6.11 | Andrew Margan | Regulatory | Complete | COMPLETE |  |  |  |  |
| 2700 | 1.8.3.2 | **M8 Code Change Preperation** |  | 155d | 2025-01-31 A | 2025-09-05 |  |  | 155d | 2025-01-31 | 2025-12-24 | 0d |  |  | 599d |  |  |  |  | Regulatory | -876.67 | 6.21 | Andrew Margan |  |  |  |  |  |  |  |
| 2701 | 1.8.3.2.1 | Resources confirmed | milestone | 0d | 2025-01-31 A | 2025-01-31 A |  | 100% |  | 2025-01-31 | 2025-01-31 | 0d |  |  |  |  | finish no earlier than 2025-01-31 | All |  | Regulatory |  | 6.21 | Andrew Margan |  | Complete | COMPLETE | T3-RE-0600 | CCAG |  |  |
| 2702 | 1.8.3.2.2 | CDWG Endorsement | milestone | 0d | 2025-06-10 | 2025-06-10 |  |  |  | 2025-06-10 | 2025-06-10 | 0d |  |  | 662d |  | finish no earlier than 2025-06-10 | All |  | Regulatory | 34.71 | 6.21 | Andrew Margan |  | Green | GREEN | T3-RE-0650 | CCAG |  |  |
| 2703 | 1.8.3.2.3 | CCAG Endorsement | milestone | 0d | 2025-06-25 | 2025-06-25 |  |  |  | 2025-06-25 | 2025-06-25 | 0d |  |  | 651d |  | finish no earlier than 2025-06-25 | All |  | Regulatory | 49.71 | 6.21 | Andrew Margan |  | Green | GREEN | T3-RE-0700 | CCAG |  |  |
| 2704 | 1.8.3.2.4 | Send to Ofgem for SCR Direction | milestone | 0d | 2025-06-25 | 2025-06-25 |  |  |  | 2025-06-25 | 2025-06-25 | 0d |  |  | 651d |  | finish no earlier than 2025-06-25 | All |  | Regulatory | 49.71 | 6.21 | Andrew Margan |  | Green | GREEN | T3-RE-0750 | CCAG |  |  |
| 2705 | 1.8.3.2.5 | Freeze M8 Change Control Log 1.0 and create V2.0 | milestone | 0d | 2025-07-02 | 2025-07-02 |  |  |  | 2025-07-02 | 2025-07-02 | 0d |  |  | 646d |  | finish no earlier than 2025-07-02 | Code Bodies |  | Regulatory | 56.71 | 6.21 | Andrew Margan |  | Green | GREEN | T3-RE-0800 | CCAG |  |  |
| 2706 | 1.8.3.2.6 | Agree Fast Track Code Change Process | milestone | 0d | 2025-07-02 | 2025-07-02 |  |  |  | 2025-07-02 | 2025-07-02 | 0d |  |  | 646d |  | finish no earlier than 2025-07-02 | MHHSP |  | Regulatory | 56.71 | 6.21 | Andrew Margan |  | Green | GREEN | T3-RE-0850 | CCAG |  |  |
| 2707 | 1.8.3.2.7 | Ofgem direct SCR Code change | milestone | 0d | 2025-07-03 | 2025-07-03 |  |  |  | 2025-07-03 | 2025-07-03 | 0d |  |  | 645d |  | finish no earlier than 2025-07-03 | Code Bodies |  | Regulatory | 57.71 | 6.21 | Andrew Margan |  | Green | GREEN | T3-RE-0900 | CCAG |  |  |
| 2708 | 1.8.3.2.8 | Present to Panel | milestone | 0d | 2025-07-10 | 2025-07-10 |  |  |  | 2025-07-10 | 2025-07-10 | 0d |  |  | 640d |  | finish no earlier than 2025-07-10 | Ofgem/Code Bodies |  | Regulatory | 64.71 | 6.21 | Andrew Margan |  | Green | GREEN | T3-RE-0950 | CCAG |  |  |
| 2709 | 1.8.3.2.9 | Code Change Industry Consultation | milestone | 0d | 2025-07-29 | 2025-07-29 |  |  |  | 2025-07-29 | 2025-07-29 | 0d |  |  | 627d |  | finish no earlier than 2025-07-29 | All |  | Regulatory | 83.71 | 6.21 | Andrew Margan |  | Green | GREEN | T3-RE-1000 | CCAG |  |  |
| 2710 | 1.8.3.2.10 | Panel Recommendation | milestone | 0d | 2025-08-14 | 2025-08-14 |  |  |  | 2025-08-14 | 2025-08-14 | 0d |  |  | 615d |  | finish no earlier than 2025-08-14 | Code Bodies |  | Regulatory | 99.71 | 6.21 | Andrew Margan |  | Green | GREEN | T3-RE-1050 | CCAG |  |  |
| 2711 | 1.8.3.2.11 | Ofgem Decision | milestone | 0d | 2025-09-05 | 2025-09-05 |  |  |  | 2025-09-05 | 2025-09-05 | 0d |  |  | 532d | 11d | finish no earlier than 2025-09-05 | Ofgem |  | Regulatory | 121.71 | 6.21 | Andrew Margan |  | Green | GREEN | T3-RE-1100 | CCAG |  |  |
| 2712 | 1.8.3.3 | **Main Code Release** |  | 73d | 2025-09-15 | 2025-12-24 |  |  |  | 2025-09-17 | 2025-12-24 | 71d | 2025-02-28 | 2025-03-07 | 521d |  |  | N/A | N/A | Regulatory |  | 6.11 | N/A | Regulatory |  |  |  |  |  |  |
| 2713 | 1.8.3.3.1 | Release preparation (e.g. preparing release documentation) |  | 6d | 2025-09-15 | 2025-09-22 | 2714SF |  |  | 2025-09-17 | 2025-09-24 | 5d | 2025-02-28 | 2025-03-07 | 588d |  |  | Code Bodies |  | Regulatory | 131.33 | 6.11 | Andrew Margan | Regulatory | Green | GREEN |  |  |  |  |
| 2714 | 1.8.3.3.2 | Implement new code on day of code release | milestone | 0d | 2025-09-22 | 2025-09-22 | 2715SF |  |  | 2025-09-24 | 2025-09-24 | 1d | 2025-03-07 | 2025-03-07 | 588d | 0d |  | Code Bodies |  | Regulatory | 138.71 | 6.11 | Andrew Margan | Regulatory | Green | GREEN |  |  |  |  |
| 2715 | 1.8.3.3.3 | Code changes delivered (M8) | milestone | 0d | 2025-09-22 | 2025-09-22 | 2695, 2674, 1938SS-3d, 2711 |  |  | 2025-09-22 | 2025-09-22 | 0d | 2025-03-07 | 2025-03-07 | 521d | 0d | finish no earlier than 2025-09-22 | CPT | Code Bodies,PP | Regulatory | 138.71 | 6.21 | Andrew Margan | Regulatory | Green | GREEN | T2-RE-0650 | CCAG | MHHS-ART060 | T2 |
| 2716 | 1.8.3.3.4 | Code changes delivered (M8*) late exit | milestone | 0d | 2025-12-24 | 2025-12-24 | 2715FS+67d |  |  | 2025-12-24 | 2025-12-24 | 0d |  |  | 521d |  |  | CPT | Code Bodies,PP | Regulatory | 231.71 | 6.11 | Andrew Margan | Regulatory | Green | GREEN | T2-RE-0700 | CCAG | MHHS-ART060 | T2 |
| 2717 | 1.8.4 | **External Programme Dependency Management** |  | 38d | 2023-12-01 A | 2024-01-24 A |  | 100% |  | 2023-12-01 | 2024-01-24 | 38d | 2023-09-08 | 2024-01-24 |  |  |  | N/A | N/A | Regulatory |  | 5.0 | N/A | Regulatory |  |  |  |  |  |  |
| 2718 | 1.8.4.1 | **DCP397** |  | 38d | 2023-12-01 A | 2024-01-24 A |  | 100% |  | 2023-12-01 | 2024-01-24 | 38d | 2023-09-08 | 2024-01-24 |  |  |  | N/A | N/A | Regulatory |  | 5.0 | N/A | Regulatory |  |  |  |  |  |  |
| 2719 | 1.8.4.1.1 | Ensure DCP397 drafting included in mop-up code drafting activity (link to mop-up) |  | 20d | 2023-12-01 A | 2023-12-28 A | 2658SS, 2655SS | 100% |  | 2023-12-01 | 2023-12-28 | 20d | 2023-09-08 | 2023-10-05 |  |  |  | CPT | Code Bodies,SRO Design, Code Drafting PM | Regulatory |  | 5.0 | Andrew Margan | Regulatory | Complete | COMPLETE |  |  |  |  |
| 2720 | 1.8.4.1.2 | Implementation of DCP397 | milestone | 0d | 2024-01-24 A | 2024-01-24 A |  | 100% |  | 2024-01-24 | 2024-01-24 | 0d | 2024-01-24 | 2024-01-24 |  |  | start no earlier than 2024-01-24 | Code Bodies |  | Regulatory |  | 5.0 | Andrew Margan | Regulatory | Complete | COMPLETE |  |  |  |  |

Notes:
- 2701: 09/04/25 - New milestones added as agreed by CCAG (26/03/25), dates subject to change based on further discussions with Ofgem.
- 2702: 09/04/25 - New milestones added as agreed by CCAG (26/03/25), dates subject to change based on further discussions with Ofgem.
- 2703: 09/04/25 - New milestones added as agreed by CCAG (26/03/25), dates subject to change based on further discussions with Ofgem.
- 2704: 09/04/25 - New milestones added as agreed by CCAG (26/03/25), dates subject to change based on further discussions with Ofgem.
- 2705: 09/04/25 - New milestones added as agreed by CCAG (26/03/25), dates subject to change based on further discussions with Ofgem.
- 2706: 09/04/25 - New milestones added as agreed by CCAG (26/03/25), dates subject to change based on further discussions with Ofgem.
- 2707: 09/04/25 - New milestones added as agreed by CCAG (26/03/25), dates subject to change based on further discussions with Ofgem.
- 2708: 09/04/25 - New milestones added as agreed by CCAG (26/03/25), dates subject to change based on further discussions with Ofgem.
- 2709: 09/04/25 - New milestones added as agreed by CCAG (26/03/25), dates subject to change based on further discussions with Ofgem.
- 2710: 09/04/25 - New milestones added as agreed by CCAG (26/03/25), dates subject to change based on further discussions with Ofgem.
- 2711: 09/04/25 - New milestones added as agreed by CCAG (26/03/25), dates subject to change based on further discussions with Ofgem.
- 2715: 09/04/25 - New milestones added as agreed by CCAG (26/03/25), dates subject to change based on further discussions with Ofgem.

| ID | WBS | Task | Type | Duration | Start | Finish | Predecessors | Complete | Remaining | Baseline start | Baseline finish | Baseline duration | Baseline 1 start | Baseline 1 finish | Total slack | Constraint | Baseline cost | Responsible | Involved | Future RAG | Text9 | MHHS Resource Name | MHHS Programme Phase | Text29 | Update Version | Sched Status | RAG | Milestone ID | Tier |
| --- | --- | --- | --- | --- | --- | --- | --- | --- | --- | --- | --- | --- | --- | --- | --- | --- | --- | --- | --- | --- | --- | --- | --- | --- | --- | --- | --- | --- | --- |
| 2721 | 1.9 | **MIGRATION** |  | 1246d? | 2022-10-31 A | 2027-08-09 |  | 60% | 496.46d? | 2022-10-31 | 2027-08-09 | 1092d | 2022-10-31 | 2027-01-05 | 98d |  | -0 | N/A | N/A | 1 Oct 2024 - 31 Oct 2025 | Migration | N/A | Migration | MCAG (Migration) |  |  |  |  |  |
| 2722 | 1.9.1 | **Regulatory Governance** |  | 325d | 2024-04-01 A | 2025-06-27 |  | 73% | 89.14d | 2024-04-01 | 2025-01-01 | 173d |  |  | 649d |  | -0 | N/A | N/A |  | Migration | Warren Fulton |  | MCAG (Migration) | 5.28 |  |  |  |  |
| 2723 | 1.9.1.1 | Incentive Mods Created |  | 110d | 2024-04-01 A | 2024-08-30 A |  | 100% |  | 2024-04-01 | 2024-08-30 | 85d |  |  |  | start no earlier than 2024-04-01 |  | SRO Migration | SRO Migration,Code Bodies,PP |  | Migration | Warren Fulton |  | MCAG (Migration) | 5.28 | Complete | COMPLETE |  |  |
| 2724 | 1.9.1.2 | Incentives Implemented |  | 65d | 2025-03-31 A | 2025-06-27 | 2723 | 26% | 48d | 2025-03-31 | 2025-06-27 | 88d |  |  | 649d | start no earlier than 2025-03-31 |  | Code Bodies | Code Bodies,SRO Migration |  | Migration | Warren Fulton |  | MCAG (Migration) | 6.23 | Green | GREEN |  |  |
| 2725 | 1.9.2 | **Migration Framework Agreed and Implemented** |  | 324d? | 2024-02-01 A | 2025-04-29 A |  | 100% |  | 2024-02-01 | 2025-01-23 | 214d |  |  |  |  | -0 | N/A | N/A |  | Migration | Warren Fulton |  | MCAG (Migration) | 5.28 |  |  |  |  |
| 2726 | 1.9.2.1 | **Consultation 1 - Schedule** |  | 70d | 2024-02-01 A | 2024-05-08 A |  | 100% |  | 2024-02-01 | 2024-05-08 | 70d |  |  |  |  |  | N/A | N/A |  | Migration | Warren Fulton |  | MCAG (Migration) | 5.28 |  |  |  |  |
| 2727 | 1.9.2.1.1 | Prepare Artefacts for Consultation |  | 33d | 2024-02-01 A | 2024-03-18 A |  | 100% |  | 2024-02-01 | 2024-03-18 | 33d |  |  |  |  |  | SI Migration |  |  | Migration | Warren Fulton |  | MCAG (Migration) | 5.28 | Complete | COMPLETE |  |  |
| 2728 | 1.9.2.1.2 | Industry Consultation |  | 16d | 2024-03-18 A | 2024-04-08 A |  | 100% |  | 2024-03-18 | 2024-04-08 | 16d |  |  |  |  |  | SI Migration |  |  | Migration | Warren Fulton |  | MCAG (Migration) | 5.28 | Complete | COMPLETE |  |  |
| 2729 | 1.9.2.1.3 | Triage and Action Comments |  | 10d | 2024-04-08 A | 2024-04-19 A |  | 100% |  | 2024-04-08 | 2024-04-19 | 10d |  |  |  |  |  | SI Migration |  |  | Migration | Warren Fulton |  | MCAG (Migration) | 5.28 | Complete | COMPLETE |  |  |
| 2730 | 1.9.2.1.4 | Industry Assurance Review |  | 6d | 2024-04-19 A | 2024-04-26 A |  | 100% |  | 2024-04-19 | 2024-04-26 | 6d |  |  |  |  |  | SI Migration |  |  | Migration | Warren Fulton |  | MCAG (Migration) | 5.28 | Complete | COMPLETE |  |  |
| 2731 | 1.9.2.1.5 | MWG Recommendation |  | 1d | 2024-04-26 A | 2024-04-26 A |  | 100% |  | 2024-04-26 | 2024-04-26 | 1d |  |  |  |  |  | SI Migration |  |  | Migration | Warren Fulton |  | MCAG (Migration) | 5.28 | Complete | COMPLETE |  |  |
| 2732 | 1.9.2.1.6 | MCAG Interim Approval Artefacts |  | 1d | 2024-05-08 A | 2024-05-08 A |  | 100% |  | 2024-05-08 | 2024-05-08 | 1d |  |  |  |  |  | SI Migration |  |  | Migration | Warren Fulton |  | MCAG (Migration) | 5.28 | Complete | COMPLETE |  |  |
| 2733 | 1.9.2.2 | **Consultation 2 - Control** |  | 79d | 2024-04-08 A | 2024-07-25 A |  | 100% |  | 2024-04-08 | 2024-07-25 | 79d |  |  |  |  | -0 | N/A | N/A |  | Migration | Warren Fulton |  | MCAG (Migration) | 5.28 |  |  |  |  |
| 2734 | 1.9.2.2.1 | Prepare Artefacts for Consultation |  | 49d | 2024-04-08 A | 2024-06-13 A |  | 100% |  | 2024-04-08 | 2024-06-13 | 49d |  |  |  |  |  | SRO Migration |  |  | Migration | Warren Fulton |  | MCAG (Migration) | 5.28 | Complete | COMPLETE |  |  |
| 2735 | 1.9.2.2.2 | Industry Consultation |  | 11d | 2024-06-14 A | 2024-06-28 A | 2734 | 100% |  | 2024-06-14 | 2024-06-28 | 11d |  |  |  |  |  | PP |  |  | Migration | Warren Fulton |  | MCAG (Migration) | 5.28 | Complete | COMPLETE |  |  |
| 2736 | 1.9.2.2.3 | Triage and Action Comments |  | 9d | 2024-07-01 A | 2024-07-11 A | 2735 | 100% |  | 2024-07-01 | 2024-07-11 | 9d |  |  |  |  |  | SRO Migration | SRO Migration |  | Migration | Warren Fulton |  | MCAG (Migration) | 5.28 | Complete | COMPLETE |  |  |
| 2737 | 1.9.2.2.4 | Industry Assurance Review |  | 5d | 2024-07-12 A | 2024-07-18 A | 2736 | 100% |  | 2024-07-12 | 2024-07-18 | 5d |  |  |  |  |  | PP | PP,SRO Migration |  | Migration | Warren Fulton |  | MCAG (Migration) | 5.28 | Complete | COMPLETE |  |  |
| 2738 | 1.9.2.2.5 | MWG Recommendation | milestone | 0d | 2024-07-18 A | 2024-07-18 A | 2737 | 100% |  | 2024-07-18 | 2024-07-18 | 0d |  |  |  |  |  | PP | PP,SRO Migration |  | Migration | Warren Fulton |  | MCAG (Migration) | 5.28 | Complete | COMPLETE |  |  |
| 2739 | 1.9.2.2.6 | Consultation 2 - Control - MCAG Approval of Interim Artefacts | milestone | 0d | 2024-07-25 A | 2024-07-25 A | 2738FS+5d | 100% |  | 2024-07-25 | 2024-07-25 | 0d |  |  |  |  |  | PP | PP,SRO Migration |  | Migration | Warren Fulton |  | MCAG (Migration) | 5.30 | Complete | COMPLETE | T3-MI-0037 | T3 |
| 2740 | 1.9.2.3 | **Consultation 3 - Parameters** |  | 71d | 2024-11-18 A | 2025-02-25 A |  | 100% |  | 2024-11-18 | 2025-02-25 | 76d |  |  |  |  | -0 | N/A | N/A |  | Migration | Warren Fulton |  | MCAG (Migration) | 6.14 |  |  |  |  |
| 2741 | 1.9.2.3.1 | Prepare Artefacts for Consultation |  | 24d | 2024-11-18 A | 2024-12-19 A |  | 100% |  | 2024-11-18 | 2024-12-19 | 36d |  |  |  |  |  | SRO Migration | SRO Migration |  | Migration | Warren Fulton |  | MCAG (Migration) | 6.14 | Complete | COMPLETE |  |  |
| 2742 | 1.9.2.3.2 | Industry Consultation |  | 21d | 2024-12-20 A | 2025-01-17 A | 2741 | 100% |  | 2024-12-20 | 2025-01-17 | 10d |  |  |  |  |  | PP | PP,SRO Migration |  | Migration | Warren Fulton |  | MCAG (Migration) | 6.14 | Complete | COMPLETE |  |  |
| 2743 | 1.9.2.3.3 | Triage Response |  | 10d | 2025-01-20 A | 2025-01-31 A | 2742 | 100% |  | 2025-01-20 | 2025-01-31 | 10d |  |  |  |  |  | SRO Migration | SRO Migration |  | Migration | Warren Fulton |  | MCAG (Migration) | 6.14 | Complete | COMPLETE |  |  |
| 2744 | 1.9.2.3.4 | MWG paper day | milestone | 0d | 2025-02-06 A | 2025-02-06 A | 2743 | 100% |  | 2025-02-06 | 2025-02-06 | 0d |  |  |  | start no earlier than 2025-02-06 |  | SRO Migration |  |  | Migration |  |  | MCAG (Migration) | 6.18 | Complete | COMPLETE |  |  |
| 2745 | 1.9.2.3.5 | MWG Recommendation | milestone | 0d | 2025-02-13 A | 2025-02-13 A | 2744FS+6d | 100% |  | 2025-02-21 | 2025-02-21 | 0d |  |  |  |  |  | PP | PP,SRO Migration |  | Migration | Warren Fulton |  | MCAG (Migration) | 6.14 | Complete | COMPLETE |  |  |
| 2746 | 1.9.2.3.6 | MCAG Paper Day | milestone | 0d | 2025-02-18 A | 2025-02-18 A | 2745FS+3d | 100% |  | 2025-02-25 | 2025-02-25 | 0d |  |  |  |  |  | SRO Migration |  |  | Migration | Warren Fulton |  | MCAG (Migration) | 6.14 | Complete | COMPLETE |  |  |
| 2747 | 1.9.2.3.7 | MCAG Approval of Consultation 3 | milestone | 0d | 2025-02-25 A | 2025-02-25 A | 2745, 2746 | 100% |  | 2025-02-25 | 2025-02-25 | 0d |  |  |  | start no earlier than 2025-02-25 |  | PP | PP,SRO Migration |  | Migration | Warren Fulton |  | MCAG (Migration) | 6.17 | Complete | COMPLETE | T3-MI-0017 | T3 |

Notes:
- 2724: 15/04/25 - Activty updated in line with CR055, no impact to Critical Path.
- 2739: Guidance: 25/7/24: New Milestone approved at MCAG on 25/7/24
- 2747: Guidance: 25/7/24: Milestone name and date change approved at MCAG on 25/7/24. Date from 2/8/24 to 22/10/24. Name from 'Migration Processes & Procedures approved' to 'MCAG Approval of Migration Framework Artefacts (Baselined)’

| ID | WBS | Task | Type | Duration | Start | Finish | Predecessors | Complete | Remaining | Baseline start | Baseline finish | Baseline duration | Total slack | Free slack | Constraint | Baseline cost | Responsible | Text9 | Task Status | Update Version | MHHS Resource Name | Text29 | Sched Status | RAG | Milestone ID | Tier | Involved |
| --- | --- | --- | --- | --- | --- | --- | --- | --- | --- | --- | --- | --- | --- | --- | --- | --- | --- | --- | --- | --- | --- | --- | --- | --- | --- | --- | --- |
| 2748 | 1.9.2.4 | **Consultation 4** |  | 72d? | 2025-01-20 A | 2025-04-29 A |  | 100% |  | 2025-01-07 | 2025-05-07 | 0d |  |  |  |  | SI Migration | Migration | -770.67 | 6.17 | Warren Fulton | MCAG (Migration) |  |  |  |  |  |
| 2749 | 1.9.2.4.1 | Agree Consultation 4 Plan |  | 15d | 2025-01-20 A | 2025-02-07 A |  | 100% |  | 2025-01-20 | 2025-02-07 | 0d |  |  |  |  | SI Migration | Migration |  | 6.17 | Warren Fulton | MCAG (Migration) | Complete | COMPLETE |  |  |  |
| 2750 | 1.9.2.4.2 | Book MWG | milestone | 0d | 2025-02-07 A | 2025-02-07 A | 2749 | 100% |  | 2025-02-07 | 2025-02-07 | 0d |  |  |  |  | SI Migration | Migration |  | 6.18 | Warren Fulton | MCAG (Migration) | Complete | COMPLETE |  |  |  |
| 2751 | 1.9.2.4.3 | Prepare Consultation 4 content |  | 9d | 2025-02-10 A | 2025-02-20 A | 2750 | 100% |  | 2025-02-10 | 2025-02-20 | 0d |  |  |  |  | SI Migration | Migration |  | 6.18 | Warren Fulton | MCAG (Migration) | Complete | COMPLETE |  |  |  |
| 2752 | 1.9.2.4.4 | MWG paper day | milestone | 0d | 2025-02-20 A | 2025-02-20 A | 2751 | 100% |  | 2025-02-20 | 2025-02-20 | 0d |  |  |  |  | SI Migration | Migration |  | 6.18 | Warren Fulton | MCAG (Migration) | Complete | COMPLETE |  |  |  |
| 2753 | 1.9.2.4.5 | MWG recommend Consultation 4 content go for industry consultation | milestone | 0d | 2025-03-04 A | 2025-03-04 A | 2752FS+8d | 100% |  | 2025-02-27 | 2025-02-27 | 0d |  |  |  |  | SI Migration | Migration |  | 6.18 | Warren Fulton | MCAG (Migration) | Complete | COMPLETE |  |  |  |
| 2754 | 1.9.2.4.6 | Industry Consultation |  | 10d? | 2025-03-03 A | 2025-03-14 A | 2751 | 100% |  | 2025-03-12 | 2025-03-25 | 0d |  |  | finish no earlier than 2025-03-14 |  | PP | Migration |  | 6.17 | Warren Fulton | MCAG (Migration) | Complete | COMPLETE |  |  |  |
| 2755 | 1.9.2.4.7 | Comment responses by PPs |  | 10d? | 2025-03-17 A | 2025-03-28 A | 2754 | 100% |  | 2025-03-26 | 2025-04-08 | 0d |  |  | finish no earlier than 2025-03-28 |  | SI Migration | Migration |  | 6.17 | Warren Fulton | MCAG (Migration) | Complete | COMPLETE |  |  |  |
| 2756 | 1.9.2.4.8 | Respond to comments and issue artefacts |  | 10d? | 2025-03-31 A | 2025-04-11 A | 2755 | 100% |  | 2025-03-31 | 2025-04-11 | 0d |  |  | finish no earlier than 2025-04-11 |  | SI Migration | Migration |  | 6.18 | Warren Fulton | MCAG (Migration) | Complete | COMPLETE |  |  |  |
| 2757 | 1.9.2.4.9 | Assurance meeting | milestone | 0d | 2025-04-22 A | 2025-04-22 A | 2756FS+5d | 100% |  | 2025-04-09 | 2025-04-22 | 0d |  |  | finish no earlier than 2025-04-22 |  | SI Migration | Migration |  | 6.17 | Warren Fulton | MCAG (Migration) | Complete | COMPLETE |  |  |  |
| 2758 | 1.9.2.4.10 | MCAG paper day | milestone | 0d | 2025-04-22 A | 2025-04-22 A | 2757 | 100% |  | 2025-04-22 | 2025-04-22 | 0d |  |  | finish no earlier than 2025-04-22 |  | SI Migration | Migration |  | 6.18 | Warren Fulton | MCAG (Migration) | Complete | COMPLETE |  |  |  |
| 2759 | 1.9.2.4.11 | MCAG Approval of Consultation 4 | milestone | 0d | 2025-04-29 A | 2025-04-29 A | 2758FS+5d | 100% |  | 2025-04-29 | 2025-04-29 | 0d |  |  | finish no earlier than 2025-04-29 |  | SI Migration | Migration |  | 6.17 | Warren Fulton | MCAG (Migration) | Complete | COMPLETE | T3-MI-0041 | T3 |  |
| 2760 | 1.9.2.5 | Framework Baselined at MCAG | milestone | 0d | 2025-04-29 A | 2025-04-29 A | 2759 | 100% |  | 2025-04-29 | 2025-04-29 | 0d |  |  | finish no earlier than 2025-04-29 |  | SI Migration | Migration |  | 6.17 | Warren Fulton | MCAG (Migration) | Complete | COMPLETE | T2-MI-7000 | T2 |  |
| 2761 | 1.9.3 | **Migration Schedule Agreed and Maintained** |  | 125d? | 2024-07-01 A | 2024-12-20 A |  | 100% |  | 2022-10-31 | 2024-12-20 | 207d |  |  |  | -0 | SI Migration | Migration |  | 6.17 | Warren Fulton | MCAG (Migration) |  |  |  |  | N/A |
| 2762 | 1.9.3.1 | Schedule Production |  | 125d? | 2024-07-01 A | 2024-12-20 A |  | 100% |  | 2024-07-01 | 2024-12-20 | 0d |  |  | start no earlier than 2024-11-18 |  | SI Migration | Migration |  | 6.14 | Warren Fulton | MCAG (Migration) | Complete | COMPLETE |  | T3 |  |
| 2763 | 1.9.3.2 | Schedule Production Complete | milestone | 0d | 2024-12-20 A | 2024-12-20 A | 2762 | 100% |  | 2024-12-20 | 2024-12-20 | 0d |  |  |  |  | SI Migration | Migration |  | 6.14 | Warren Fulton | MCAG (Migration) | Complete | COMPLETE | T3-MI-0042 | T3 |  |
| 2764 | 1.9.4 | **V1.0 of Migration Schedule Baseline** |  | 81d | 2025-04-01 A | 2025-07-22 |  |  | 81d | 2025-04-01 | 2025-07-22 | 0d | 632d |  |  |  | SI Migration | Migration | -833.67 | 6.18 | Warren Fulton | MCAG (Migration) | Overdue Start |  |  |  |  |
| 2765 | 1.9.4.1 | Confirm Supplier Migration start dates, MPID groups (SIT & NonSIT) | milestone | 0d | 2025-04-01 A | 2025-04-01 A |  | 100% |  | 2025-04-01 | 2025-04-01 | 0d |  |  | start no earlier than 2025-04-01 |  | SI Migration | Migration |  | 6.18 | Warren Fulton | MCAG (Migration) | Complete | COMPLETE |  |  |  |
| 2766 | 1.9.4.2 | V1.0 of Migration Schedule Baseline Approved at MCAG | milestone | 0d | 2025-07-22 | 2025-07-22 | 2765FS+81d |  |  | 2025-07-22 | 2025-07-22 | 0d | 632d |  |  |  | SI Migration | Migration | 76.71 | 6.17 | Warren Fulton | MCAG (Migration) | Green | GREEN | T2-MI-7500 | T2 |  |
| 2767 | 1.9.5 | **Supplier Commission 2** |  | 102d? | 2025-03-03 A | 2025-07-22 |  | 96% | 4.43d? | 2025-03-03 | 2025-07-22 | 0d | 632d |  |  |  | SI Migration | Migration | 129.71 | 6.17 | Warren Fulton | MCAG (Migration) | Green | GREEN |  | T3 |  |
| 2768 | 1.9.5.1 | Confirm / validate contacts for all Suppliers |  | 22d | 2025-03-03 A | 2025-04-01 A |  | 100% |  | 2025-03-03 | 2025-04-01 | 0d |  |  | start no earlier than 2025-03-03 |  | SI Migration | Migration |  | 6.18 | Warren Fulton | MCAG (Migration) | Complete | COMPLETE |  |  |  |
| 2769 | 1.9.5.2 | Supplier submission issued | milestone | 0d | 2025-04-25 | 2025-04-25 | 2768FS+18d |  |  | 2025-04-25 | 2025-04-25 | 0d | 632d | 0d | start no earlier than 2025-04-25 |  | SI Migration | Migration | -11.29 | 6.18 | Warren Fulton | MCAG (Migration) | Overdue Start | RED |  |  |  |
| 2770 | 1.9.5.3 | Supplier submission deadline | milestone | 0d | 2025-06-20 | 2025-06-20 | 2769FS+40d |  |  | 2025-06-20 | 2025-06-20 | 0d | 632d | 0d |  |  | SI Migration | Migration | 44.71 | 6.18 | Warren Fulton | MCAG (Migration) | Green | GREEN |  |  |  |
| 2771 | 1.9.5.4 | Second Supplier Submission complete | milestone | 0d | 2025-06-20 | 2025-06-20 | 2770 |  |  | 2025-06-20 | 2025-06-20 | 0d | 632d | 0d |  |  | SI Migration | Migration | 44.71 | 6.18 | Warren Fulton | MCAG (Migration) | Green | GREEN | T3-MI-0043 | T3 |  |
| 2772 | 1.9.5.5 | Publish and baseline Migration Schedule |  | 1d? | 2025-07-22 | 2025-07-22 | 2771FS+21d |  |  | 2025-07-22 | 2025-07-22 | 0d | 632d |  |  |  | SI Migration | Migration | 76.33 | 6.18 | Warren Fulton | MCAG (Migration) | Green | GREEN |  |  |  |

| ID | WBS | Task | Type | Duration | Start | Finish | Predecessors | Complete | Remaining | Baseline start | Baseline finish | Baseline duration | Total slack | Free slack | Constraint | Responsible | Text9 | Task Status | Update Version | Sched Status | MHHS Resource Name | RAG | Text29 | Tier | Milestone ID |
| --- | --- | --- | --- | --- | --- | --- | --- | --- | --- | --- | --- | --- | --- | --- | --- | --- | --- | --- | --- | --- | --- | --- | --- | --- | --- |
| 2773 | 1.9.6 | **Supplier Submission Support** |  | 29d? | 2025-04-25 | 2025-06-04 |  |  |  | 2025-04-25 | 2025-06-04 | 0d | 666d |  |  | SI Migration | Migration | 247.71 | 6.17 | Green | Warren Fulton | GREEN | MCAG (Migration) | T2 |  |
| 2774 | 1.9.6.1 | Support guides issued |  | 1d? | 2025-04-25 | 2025-04-25 |  |  |  | 2025-04-25 | 2025-04-25 | 0d | 666d | 0d | start no earlier than 2025-04-25 | SI Migration | Migration | -11.67 | 6.18 | Overdue Start | Warren Fulton | RED | MCAG (Migration) |  |  |
| 2775 | 1.9.6.2 | Envelope webinar | milestone | 0d | 2025-05-02 | 2025-05-02 | 2774FS+5d |  |  | 2025-05-02 | 2025-05-02 | 0d | 666d | 0d |  | SI Migration | Migration | -4.29 | 6.18 | Overdue Start | Warren Fulton | RED | MCAG (Migration) |  |  |
| 2776 | 1.9.6.3 | De-minimus webinar | milestone | 0d | 2025-05-02 | 2025-05-02 | 2775 |  |  | 2025-05-02 | 2025-05-02 | 0d | 666d | 0d |  | SI Migration | Migration | -4.29 | 6.18 | Overdue Start | Warren Fulton | RED | MCAG (Migration) |  |  |
| 2777 | 1.9.6.4 | Drop-in session 1 | milestone | 0d | 2025-05-14 | 2025-05-14 | 2776FS+8d |  |  | 2025-05-14 | 2025-05-14 | 0d | 666d | 0d |  | SI Migration | Migration | 7.71 | 6.18 | Green | Warren Fulton | GREEN | MCAG (Migration) |  |  |
| 2778 | 1.9.6.5 | Drop-in session 2 | milestone | 0d | 2025-05-28 | 2025-05-28 | 2777FS+10d |  |  | 2025-05-28 | 2025-05-28 | 0d | 666d | 0d |  | SI Migration | Migration | 21.71 | 6.18 | Green | Warren Fulton | GREEN | MCAG (Migration) |  |  |
| 2779 | 1.9.6.6 | Drop-in session 3 | milestone | 0d | 2025-06-04 | 2025-06-04 | 2778FS+5d |  |  | 2025-06-04 | 2025-06-04 | 0d | 666d | 0d |  | SI Migration | Migration | 28.71 | 6.18 | Green | Warren Fulton | GREEN | MCAG (Migration) |  |  |
| 2780 | 1.9.6.7 | Q+A documents from sessions published | milestone | 0d | 2025-06-04 | 2025-06-04 | 2779 |  |  | 2025-06-04 | 2025-06-04 | 0d | 666d |  |  | SI Migration | Migration | 28.71 | 6.18 | Green | Warren Fulton | GREEN | MCAG (Migration) |  |  |
| 2781 | 1.9.7 | **MCC Stood up** |  | 265d? | 2024-11-18 A | 2025-11-21 |  | 40% | 158d? | 2024-11-18 | 2025-11-21 | 0d |  |  |  | SI Migration | Migration | -771.67 | 6.17 |  | Warren Fulton |  | MCAG (Migration) |  |  |
| 2782 | 1.9.7.1 | Migration Planning Management Tool Delivery | manual | 265d | 2024-11-18 A | 2025-11-21 |  | 40% | 158d | 2024-11-18 | 2025-11-21 | 0d |  |  |  | SI Migration | Migration |  | 6.17 | Green | Warren Fulton | GREEN | MCAG (Migration) |  |  |
| 2783 | 1.9.7.2 | **MCC Operational** |  | 93d | 2025-04-23 | 2025-08-29 |  |  |  | 2025-04-18 | 2025-08-29 | 0d | 604d |  |  | SI Migration | Migration | 220.71 | 6.17 |  | Warren Fulton |  | MCAG (Migration) |  |  |
| 2784 | 1.9.7.2.1 | **MCC Dress Rehersal 1 - Initialise Schedule (Weekly) Drop 1, 2** |  | 60d | 2025-04-23 | 2025-07-15 |  |  |  | 2025-04-18 | 2025-07-15 | 0d | 637d |  |  | SI Migration | Migration | -84.67 | 6.17 | Green | Warren Fulton | GREEN | MCAG (Migration) |  |  |
| 2785 | 1.9.7.2.1.1 | Issue Dress Rehearsal support information to Participants | milestone | 0d | 2025-04-23 | 2025-04-23 |  |  |  | 2025-04-23 | 2025-04-23 | 0d | 637d | 0d | start no earlier than 2025-04-23 | SI Migration | Migration | -13.67 | 6.18 | Overdue Start | Warren Fulton | RED | MCAG (Migration) |  |  |
| 2786 | 1.9.7.2.1.2 | Kestrel Webinar 1 | milestone | 0d | 2025-04-23 | 2025-04-23 | 2785 |  |  | 2025-04-23 | 2025-04-23 | 0d | 637d | 0d |  | SI Migration | Migration | -13.67 | 6.18 | Overdue Start | Warren Fulton | RED | MCAG (Migration) |  |  |
| 2787 | 1.9.7.2.1.3 | Onboard and connectivity testing - Dress Rehearsal with Suppliers (All SIT and Wave 1 mandatory) | milestone | 0d | 2025-04-25 | 2025-04-25 | 2786FS+3d |  |  | 2025-04-25 | 2025-04-25 | 0d | 637d | 0d |  | SI Migration | Migration | -11.29 | 6.18 | Overdue Start | Warren Fulton | RED | MCAG (Migration) |  |  |
| 2788 | 1.9.7.2.1.4 | Dress rehearsal start | milestone | 0d | 2025-04-28 | 2025-04-28 | 2787FS+1d |  |  | 2025-04-28 | 2025-04-28 | 0d | 637d | 0d |  | SI Migration | Migration | -8.29 | 6.18 | Overdue Start | Warren Fulton | RED | MCAG (Migration) |  |  |
| 2789 | 1.9.7.2.1.5 | Test execution report (weekly) | milestone | 0d | 2025-07-15 | 2025-07-15 | 2788FS+56d |  |  | 2025-07-15 | 2025-07-15 | 0d | 637d | 0d |  | SI Migration | Migration | 69.71 | 6.18 | Green | Warren Fulton | GREEN | MCAG (Migration) |  |  |
| 2790 | 1.9.7.2.1.6 | Dress rehearsal completion report | milestone | 0d | 2025-07-15 | 2025-07-15 | 2789 |  |  | 2025-07-15 | 2025-07-15 | 0d | 637d | 0d |  | SI Migration | Migration | 69.71 | 6.18 | Green | Warren Fulton | GREEN | MCAG (Migration) |  |  |
| 2791 | 1.9.7.2.1.7 | MCC Dress Rehersal 1 - complete | milestone | 0d | 2025-07-15 | 2025-07-15 | 2790 |  |  | 2025-07-15 | 2025-07-15 | 0d | 637d |  |  | SI Migration | Migration | 69.71 | 6.17 | Green | Warren Fulton | GREEN | MCAG (Migration) | T3 | T3-MI-0044 |
| 2792 | 1.9.7.2.2 | **MCC Dress Rehersal 2 - complete** |  | 35d | 2025-07-14 | 2025-08-29 |  |  |  | 2025-07-14 | 2025-08-29 | 0d | 604d | 0d |  | SI Migration | Migration | 199.33 | 6.17 | Green | Warren Fulton | GREEN | MCAG (Migration) |  |  |
| 2793 | 1.9.7.2.2.1 | Issue Dress Rehearsal support information to Participants | milestone | 0d | 2025-07-14 | 2025-07-14 |  |  |  | 2025-07-14 | 2025-07-14 | 0d | 604d | 0d | start no earlier than 2025-07-14 | SI Migration | Migration | 68.33 | 6.18 | Green | Warren Fulton | GREEN | MCAG (Migration) |  |  |
| 2794 | 1.9.7.2.2.2 | Kestrel Webinar 2 | milestone | 0d | 2025-07-14 | 2025-07-14 | 2793 |  |  | 2025-07-14 | 2025-07-14 | 0d | 604d | 0d |  | SI Migration | Migration | 68.33 | 6.18 | Green | Warren Fulton | GREEN | MCAG (Migration) |  |  |
| 2795 | 1.9.7.2.2.3 | Onboard and connectivity testing - Dress Rehearsal with Suppliers (remaining suppliers and non-supplier PPs) | milestone | 0d | 2025-07-21 | 2025-07-21 | 2794FS+6d |  |  | 2025-07-21 | 2025-07-21 | 0d | 604d | 0d |  | SI Migration | Migration | 75.71 | 6.18 | Green | Warren Fulton | GREEN | MCAG (Migration) |  |  |
| 2796 | 1.9.7.2.2.4 | Dress rehearsal start | milestone | 0d | 2025-07-21 | 2025-07-21 | 2795 |  |  | 2025-07-21 | 2025-07-21 | 0d | 604d | 0d |  | SI Migration | Migration | 75.71 | 6.18 | Green | Warren Fulton | GREEN | MCAG (Migration) |  |  |
| 2797 | 1.9.7.2.2.5 | Test execution report (weekly) | milestone | 0d | 2025-08-29 | 2025-08-29 | 2796FS+29d |  |  | 2025-08-29 | 2025-08-29 | 0d | 604d | 0d |  | SI Migration | Migration | 114.71 | 6.18 | Green | Warren Fulton | GREEN | MCAG (Migration) |  |  |
| 2798 | 1.9.7.2.2.6 | Dress rehearsal completion report | milestone | 0d | 2025-08-29 | 2025-08-29 | 2797 |  |  | 2025-08-29 | 2025-08-29 | 0d | 604d | 0d |  | SI Migration | Migration | 114.71 | 6.18 | Green | Warren Fulton | GREEN | MCAG (Migration) |  |  |
| 2799 | 1.9.7.2.2.7 | MCC Dress Rehersal 2 - complete | milestone | 0d | 2025-08-29 | 2025-08-29 | 2798 |  |  | 2025-08-29 | 2025-08-29 | 0d | 604d | 0d |  | SI Migration | Migration | 114.71 | 6.18 | Green | Warren Fulton | GREEN | MCAG (Migration) | T3 | T3-MI-0045 |
| 2800 | 1.9.7.3 | MCC Operational Complete | milestone | 0d | 2025-08-29 | 2025-08-29 | 2792, 2799 |  |  | 2025-08-29 | 2025-08-29 | 0d | 604d |  |  | SI Migration | Migration | 114.71 | 6.17 | Green | Warren Fulton | GREEN | MCAG (Migration) | T2 | T2-MI-0500 |

| ID | WBS | Task | Type | Duration | Start | Finish | Predecessors | Complete | Remaining | Baseline start | Baseline finish | Baseline duration | Baseline 1 start | Baseline 1 finish | Total slack | Constraint | Baseline cost | Responsible | Involved | Text9 | Update Version | MHHS Resource Name | Text29 | Sched Status | RAG | MHHS Programme Phase | Artefact ID | Milestone ID | Tier |
| --- | --- | --- | --- | --- | --- | --- | --- | --- | --- | --- | --- | --- | --- | --- | --- | --- | --- | --- | --- | --- | --- | --- | --- | --- | --- | --- | --- | --- | --- |
| 2801 | 1.9.8 | **SIT Participant's Prepared for Migration** |  | 218d | 2024-07-01 A | 2025-04-30 |  | 49% | 111.89d | 2024-07-01 | 2025-03-31 | 154d |  |  | 691d |  | -0 | N/A | N/A | Migration | 5.28 | Warren Fulton | MCAG (Migration) |  |  |  |  |  |  |
| 2802 | 1.9.8.1 | Prep for Envelope Webinar |  | 26d | 2024-07-01 A | 2024-08-05 A |  | 100% |  | 2024-07-01 | 2024-08-05 | 26d |  |  |  |  |  | SRO Migration | SRO Migration | Migration | 5.28 | Warren Fulton | MCAG (Migration) | Complete | COMPLETE |  |  |  |  |
| 2803 | 1.9.8.2 | Envelope/Submission Webinar |  | 1d | 2024-08-05 A | 2024-08-05 A | 2802FF | 100% |  | 2024-08-05 | 2024-08-05 | 1d |  |  |  |  |  | SRO Migration | SRO Migration,PP | Migration | 5.28 | Warren Fulton | MCAG (Migration) | Complete | COMPLETE |  |  |  |  |
| 2804 | 1.9.8.3 | Guides Creation |  | 41d | 2025-02-27 A | 2025-04-24 | 2747FS+2d | 34% | 27d | 2025-02-27 | 2025-04-30 | 45d |  |  | 695d | finish no earlier than 2025-04-24 |  | SRO Migration | SRO Migration,PP | Migration | 6.23 | Warren Fulton | MCAG (Migration) | Overdue | RED |  |  |  |  |
| 2805 | 1.9.8.4 | Support Channels |  | 45d | 2025-02-27 A | 2025-04-30 | 2747FS+2d | 31% | 31d | 2025-02-27 | 2025-04-30 | 45d |  |  | 691d |  |  | SRO Migration | SRO Migration,PP | Migration | 5.28 | Warren Fulton | MCAG (Migration) | Overdue | RED |  |  |  |  |
| 2806 | 1.9.9 | **Migration Artefact Development and Publication** |  | 1043d | 2022-10-31 A | 2026-10-28 |  | 65% | 363.9d | 2022-10-31 | 2025-09-03 | 635d | 2022-10-31 | 2025-04-04 | 301d |  | -0 | N/A | N/A | Migration | 5.0 | Warren Fulton | MCAG (Migration) |  |  | Migration |  |  |  |
| 2807 | 1.9.9.1 | **Migration Approach** |  | 28d | 2022-10-31 A | 2022-12-07 A |  | 100% |  | 2022-10-31 | 2022-12-07 | 28d | 2022-10-31 | 2022-12-07 |  |  |  | N/A | N/A | Migration | 5.0 | Warren Fulton | MCAG (Migration) |  |  | Migration |  |  |  |
| 2808 | 1.9.9.1.1 | Option analysis (via MWG and PPIR) and recommendation |  | 23d | 2022-10-31 A | 2022-11-30 A |  | 100% |  | 2022-10-31 | 2022-11-30 | 23d | 2022-10-31 | 2022-11-30 |  |  |  | PP | SI Migration | Migration | 5.0 | John Wiggins,Matthew Breen |  | Complete | COMPLETE | Migration |  |  |  |
| 2809 | 1.9.9.1.2 | Migration Approach approved | milestone | 0d | 2022-12-07 A | 2022-12-07 A | 2808FS+5d | 100% |  | 2022-12-07 | 2022-12-07 | 0d | 2022-12-07 | 2022-12-07 |  |  |  | SI Migration | PP,IPA | Migration | 5.0 | John Wiggins,Matthew Breen | PSG | Complete | COMPLETE | Migration | MHHS-DEL770 | T3-MI-0010 | T3 |
| 2810 | 1.9.9.2 | **Migration Design** |  | 100d | 2022-11-14 A | 2023-03-31 A |  | 100% |  | 2022-11-14 | 2023-03-31 | 100d | 2022-11-14 | 2023-03-31 |  |  |  | N/A | N/A | Migration | 5.0 | N/A |  |  |  | Migration |  |  |  |
| 2811 | 1.9.9.2.1 | Review and update existing design artefacts and socialise with participants ahead of MDSG |  | 10d | 2022-11-14 A | 2022-11-25 A |  | 100% |  | 2022-11-14 | 2022-11-25 | 10d | 2022-11-14 | 2022-11-25 |  |  |  | SI Migration | SRO Design,CPT | Migration | 5.0 | John Wiggins,Matthew Breen |  | Complete | COMPLETE | Migration |  |  |  |
| 2812 | 1.9.9.2.2 | Develop design artefacts and supporting technical documents in line with MDSG |  | 53d | 2022-11-30 A | 2023-02-10 A | 2811FS+2d | 100% |  | 2022-11-30 | 2023-02-10 | 53d | 2022-11-30 | 2023-02-10 |  |  |  | SI Migration | PP,SRO Function,CPT | Migration | 5.0 | John Wiggins,Matthew Breen |  | Complete | COMPLETE | Migration |  |  |  |
| 2813 | 1.9.9.2.3 | Migration design artefacts issued for consultation | milestone | 0d | 2023-02-13 A | 2023-02-13 A | 2812FS+1d | 100% |  | 2023-02-13 | 2023-02-13 | 0d | 2023-02-13 | 2023-02-13 |  |  |  | SI Migration | PP,SRO Function,CPT | Migration | 5.0 | John Wiggins,Matthew Breen | DAG | Complete | COMPLETE | Migration |  | T3-MI-0011 | T3 |
| 2814 | 1.9.9.2.4 | Industry consultation |  | 5d | 2023-02-14 A | 2023-02-20 A | 2813SS | 100% |  | 2023-02-14 | 2023-02-20 | 5d | 2023-02-14 | 2023-02-20 |  |  |  | PP | SI Migration | Migration | 5.0 | John Wiggins,Matthew Breen |  | Complete | COMPLETE | Migration |  |  |  |
| 2815 | 1.9.9.2.5 | Review consultation feedback, address comments and update artefacts |  | 5d | 2023-02-21 A | 2023-02-27 A | 2814 | 100% |  | 2023-02-21 | 2023-02-27 | 5d | 2023-02-21 | 2023-02-27 |  |  |  | SI Migration | PP | Migration | 5.0 | John Wiggins,Matthew Breen |  | Complete | COMPLETE | Migration |  |  |  |
| 2816 | 1.9.9.2.6 | Internal artefact review and comms preparation |  | 3d | 2023-02-28 A | 2023-03-02 A | 2815 | 100% |  | 2023-02-28 | 2023-03-02 | 3d | 2023-02-28 | 2023-03-02 |  |  |  | SI Migration | SRO Function | Migration | 5.0 | John Wiggins,Matthew Breen |  | Complete | COMPLETE | Migration |  |  |  |
| 2817 | 1.9.9.2.7 | Updated Migration Design artefacts issued to PPs for assurance review | milestone | 0d | 2023-03-03 A | 2023-03-03 A | 2816FS+1d | 100% |  | 2023-03-03 | 2023-03-03 | 0d | 2023-03-03 | 2023-03-03 |  |  |  | SI Migration | PP | Migration | 5.0 | John Wiggins,Matthew Breen | DAG | Complete | COMPLETE | Migration |  | T3-MI-0013 | T3 |
| 2818 | 1.9.9.2.8 | Final Migration Design artefacts walkthrough with PPs | milestone | 0d | 2023-03-22 A | 2023-03-22 A | 2817FS+13d | 100% |  | 2023-03-22 | 2023-03-22 | 0d | 2023-03-22 | 2023-03-22 |  |  |  | SI Migration | PP | Migration | 5.0 | John Wiggins,Matthew Breen |  | Complete | COMPLETE | Migration |  |  |  |
| 2819 | 1.9.9.2.9 | Migration Design approved | milestone | 0d | 2023-03-31 A | 2023-03-31 A | 2818FS+7d | 100% |  | 2023-03-31 | 2023-03-31 | 0d | 2023-03-31 | 2023-03-31 |  |  |  | SI Migration | PP,SRO Function,CPT | Migration | 5.0 | John Wiggins,Matthew Breen | DAG | Complete | COMPLETE | Migration |  | T2-MI-0050 | T2 |
| 2820 | 1.9.9.3 | **Transition Design** |  | 186d | 2023-03-01 A | 2023-11-15 A |  | 100% |  | 2023-03-01 | 2023-11-15 | 186d | 2023-03-01 | 2023-08-03 |  |  | -0 | N/A | N/A | Migration | 5.0 | N/A |  |  |  | Migration |  |  |  |
| 2821 | 1.9.9.3.1 | **Tranche 1** |  | 56d | 2023-03-01 A | 2023-05-17 A |  | 100% |  | 2023-03-01 | 2023-05-17 | 56d | 2023-03-01 | 2023-05-17 |  |  |  | N/A | N/A | Migration | 5.0 | N/A |  |  |  | Migration |  |  |  |
| 2822 | 1.9.9.3.1.1 | Develop design artefacts and supporting technical details with participants |  | 50d | 2023-03-01 A | 2023-05-09 A |  | 100% |  | 2023-03-01 | 2023-05-09 | 50d | 2023-03-01 | 2023-05-09 |  |  |  | SI Design | PP | Migration | 5.0 | Andrew Margan |  | Complete | COMPLETE | Migration |  |  |  |
| 2823 | 1.9.9.3.1.2 | Issue Material for DAG approval |  | 1d | 2023-05-10 A | 2023-05-10 A | 2822 | 100% |  | 2023-05-10 | 2023-05-10 | 1d | 2023-05-10 | 2023-05-10 |  |  |  | PP | SI Design | Migration | 5.0 | Andrew Margan |  | Complete | COMPLETE | Migration |  |  |  |
| 2824 | 1.9.9.3.1.3 | Tranche 1 Transition Design approved | milestone | 0d | 2023-05-17 A | 2023-05-17 A | 2823FS+5d | 100% |  | 2023-05-17 | 2023-05-17 | 0d | 2023-05-17 | 2023-05-17 |  |  |  | SI Design | PP | Migration | 5.0 | Andrew Margan | DAG | Complete | COMPLETE | Migration |  | T2-DB-0150 | T2 |

Notes:
- 2804: 15/04/25 - Programme is working on updating and developing these dates in the coming weeks.
- 2805: 15/04/25 - Programme is working on updating and developing these dates in the coming weeks.

| ID | WBS | Task | Type | Duration | Start | Finish | Predecessors | Complete | Baseline start | Baseline finish | Baseline duration | Baseline 1 start | Baseline 1 finish | Baseline cost | Responsible | Involved | Text9 | Update Version | MHHS Resource Name | MHHS Programme Phase | Sched Status | RAG | Guidance | Milestone ID | Text29 | Tier |
| --- | --- | --- | --- | --- | --- | --- | --- | --- | --- | --- | --- | --- | --- | --- | --- | --- | --- | --- | --- | --- | --- | --- | --- | --- | --- | --- |
| 2825 | 1.9.9.3.2 | **Tranche 2** |  | 130d | 2023-05-18 A | 2023-11-15 A |  | 100% | 2023-05-18 | 2023-11-15 | 130d | 2023-05-18 | 2023-08-03 | -0 | N/A | N/A | Migration | 5.0 | N/A | Migration |  |  |  |  |  |  |
| 2826 | 1.9.9.3.2.1 | Develop Initial design artefacts and supporting technical details |  | 76d | 2023-05-18 A | 2023-08-31 A | 2824 | 100% | 2023-05-18 | 2023-08-31 | 76d | 2023-05-18 | 2023-07-26 |  | SRO | PP, CPT, SRO Design | Migration | 5.5 | Andrew Margan | Migration | Complete | COMPLETE |  |  |  |  |
| 2827 | 1.9.9.3.2.2 | Communicate Initial Design Artefacts with Industry (MTDSG) |  | 1d | 2023-09-01 A | 2023-09-01 A | 2826 | 100% | 2023-09-01 | 2023-09-01 | 1d |  |  |  | SRO | PP, CPT, SRO Design | Migration | 5.5 | Andrew Margan | Migration | Complete | COMPLETE |  |  |  |  |
| 2828 | 1.9.9.3.2.3 | Host MTDSG |  | 1d | 2023-09-11 A | 2023-09-11 A | 2827FS+5d | 100% | 2023-09-11 | 2023-09-11 | 1d |  |  |  | SRO | PP, CPT, SRO Design | Migration | 5.5 | Andrew Margan | Migration | Complete | COMPLETE |  |  |  |  |
| 2829 | 1.9.9.3.2.4 | Process MTDSG Feedback and Amend Design Artefacts |  | 4d | 2023-09-12 A | 2023-09-15 A | 2828 | 100% | 2023-09-12 | 2023-09-15 | 4d |  |  |  | SRO | PP, CPT, SRO Design | Migration | 5.5 | Andrew Margan | Migration | Complete | COMPLETE |  |  |  |  |
| 2830 | 1.9.9.3.2.5 | Communicate Amended Design Artefacts with Industry |  | 1d | 2023-09-15 A | 2023-09-15 A | 2829FF | 100% | 2023-09-15 | 2023-09-15 | 1d |  |  |  | SRO | PP, CPT, SRO Design | Migration | 5.5 | Andrew Margan | Migration | Complete | COMPLETE |  |  |  |  |
| 2831 | 1.9.9.3.2.6 | Host MTDSG |  | 1d | 2023-09-26 A | 2023-09-26 A | 2830FS+6d | 100% | 2023-09-26 | 2023-09-26 | 1d |  |  |  | SRO | PP, CPT, SRO Design | Migration | 5.5 | Andrew Margan | Migration | Complete | COMPLETE |  |  |  |  |
| 2832 | 1.9.9.3.2.7 | Make Final Amendments to Design Artefact |  | 5d | 2023-09-27 A | 2023-10-03 A | 2831 | 100% | 2023-09-27 | 2023-10-03 | 5d |  |  |  | SRO | PP, CPT, SRO Design | Migration | 5.5 | Andrew Margan | Migration | Complete | COMPLETE |  |  |  |  |
| 2833 | 1.9.9.3.2.8 | Request DAG Consultation |  | 1d | 2023-10-04 A | 2023-10-04 A | 2832 | 100% | 2023-10-04 | 2023-10-04 | 1d |  |  |  | SRO | PP, CPT, SRO Design | Migration | 5.5 | Andrew Margan | Migration | Complete | COMPLETE |  |  |  |  |
| 2834 | 1.9.9.3.2.9 | Consultation Period |  | 11d | 2023-10-04 A | 2023-10-18 A | 2833SS | 100% | 2023-10-04 | 2023-10-18 | 11d |  |  |  | SRO | PP, CPT, SRO Design | Migration | 5.5 | Andrew Margan | Migration | Complete | COMPLETE |  |  |  |  |
| 2835 | 1.9.9.3.2.10 | Action Consultation Comments |  | 5d | 2023-10-19 A | 2023-10-25 A | 2834 | 100% | 2023-10-19 | 2023-10-25 | 5d |  |  |  | SRO | PP, CPT, SRO Design | Migration | 5.5 | Andrew Margan | Migration | Complete | COMPLETE |  |  |  |  |
| 2836 | 1.9.9.3.2.11 | Post Consultation Industry Assurance |  | 5d | 2023-10-26 A | 2023-11-01 A | 2835 | 100% | 2023-10-26 | 2023-11-01 | 5d |  |  |  | SRO | PP, CPT, SRO Design | Migration | 5.5 | Andrew Margan | Migration | Complete | COMPLETE |  |  |  |  |
| 2837 | 1.9.9.3.2.12 | Request DAG Approval |  | 1d | 2023-11-01 A | 2023-11-01 A | 2836FF | 100% | 2023-11-01 | 2023-11-01 | 1d |  |  |  | SRO | PP, CPT, SRO Design | Migration | 5.5 | Andrew Margan | Migration | Complete | COMPLETE |  |  |  |  |
| 2838 | 1.9.9.3.2.13 | DAG Transition Design Approved |  | 1d | 2023-11-08 A | 2023-11-08 A | 2837FS+4d | 100% | 2023-11-08 | 2023-11-08 | 1d |  |  |  | SRO | PP, CPT, SRO Design | Migration | 5.5 | Andrew Margan | Migration | Complete | COMPLETE |  |  |  |  |
| 2839 | 1.9.9.3.2.14 | Update Transition Design Admin |  | 5d | 2023-11-09 A | 2023-11-15 A | 2838 | 100% | 2023-11-09 | 2023-11-15 | 5d |  |  |  | SRO | PP, CPT, SRO Design | Migration | 5.5 | Andrew Margan | Migration | Complete | COMPLETE |  |  |  |  |
| 2840 | 1.9.9.3.2.15 | Tranche 2 Transition Design Baselined | milestone | 0d | 2023-11-15 A | 2023-11-15 A | 2839 | 100% | 2023-11-15 | 2023-11-15 | 0d | 2023-08-03 | 2023-08-03 |  | SRO | PP, CPT, SRO Design | Migration | 5.12 | Andrew Margan | Migration | Complete | COMPLETE | 14/8 - Date aligns with DAG | T2-DB-0250 | DAG | T2 |
| 2841 | 1.9.9.4 | **Data Assessment Report** |  | 61d | 2022-12-06 A | 2023-02-28 A |  | 100% | 2022-12-06 | 2023-02-28 | 61d | 2022-12-06 | 2023-02-28 |  | N/A | N/A | Migration | 5.0 | N/A | Migration |  |  |  |  |  |  |
| 2842 | 1.9.9.4.1 | Develop document with MWG |  | 49d | 2022-12-06 A | 2023-02-10 A |  | 100% | 2022-12-06 | 2023-02-10 | 49d | 2022-12-06 | 2023-02-10 |  | SI Migration |  | Migration | 5.0 | John Wiggins,Matthew Breen | Migration | Complete | COMPLETE |  |  |  |  |
| 2843 | 1.9.9.4.2 | Artefact review (via TMAG) and updates |  | 25d | 2023-01-18 A | 2023-02-21 A | 2842FS-18d | 100% | 2023-01-18 | 2023-02-21 | 25d | 2023-01-18 | 2023-02-21 |  | PP | IPA,SI Migration | Migration | 5.0 | John Wiggins,Matthew Breen | Migration | Complete | COMPLETE |  |  |  |  |
| 2844 | 1.9.9.4.3 | Data Assessment Report approved | milestone | 0d | 2023-02-28 A | 2023-02-28 A | 2843FS+5d | 100% | 2023-02-28 | 2023-02-28 | 0d | 2023-02-28 | 2023-02-28 |  | SI Migration | PP,IPA | Migration | 5.0 | John Wiggins,Matthew Breen | Migration | Complete | COMPLETE |  | T3-MI-0012 | MCAG | T3 |
| 2845 | 1.9.9.5 | **Migration, Cutover & Data Strategy (incl. Migration Entry Criteria)** |  | 102d | 2022-12-08 A | 2023-04-28 A |  | 100% | 2022-12-08 | 2023-04-28 | 102d | 2022-12-08 | 2023-04-28 |  | N/A | N/A | Migration | 5.0 | N/A | Migration |  |  |  |  |  |  |
| 2846 | 1.9.9.5.1 | Develop document with MWG |  | 67d | 2022-12-08 A | 2023-03-10 A | 2809 | 100% | 2022-12-08 | 2023-03-10 | 67d | 2022-12-08 | 2023-03-10 |  | SI Migration | PP | Migration | 5.0 | John Wiggins,Matthew Breen | Migration | Complete | COMPLETE |  |  |  |  |
| 2847 | 1.9.9.5.2 | Artefact review (via TMAG) and updates |  | 28d | 2023-03-15 A | 2023-04-21 A | 2846FS+2d | 100% | 2023-03-15 | 2023-04-21 | 28d | 2023-03-15 | 2023-04-21 |  | PP | SI Migration | Migration | 5.0 | John Wiggins,Matthew Breen | Migration | Complete | COMPLETE |  |  |  |  |
| 2848 | 1.9.9.5.3 | Migration, Cutover & Data Strategy approved | milestone | 0d | 2023-04-28 A | 2023-04-28 A | 2847FF+5d | 100% | 2023-04-28 | 2023-04-28 | 0d | 2023-04-28 | 2023-04-28 |  | SI Migration | PP | Migration | 5.0 | John Wiggins,Matthew Breen | Migration | Complete | COMPLETE |  | T3-MI-0014 | MCAG | T3 |

Notes:
- 2840: Action: 2/8/23 - needs to be replanned to 15//11/23. AM to raise CR as T2 milestone

| ID | WBS | Task | Type | Duration | Start | Finish | Predecessors | Complete | Remaining | Baseline start | Baseline finish | Baseline duration | Baseline 1 start | Baseline 1 finish | Total slack | Free slack | Constraint | Baseline cost | Responsible | Involved | Text9 | Update Version | MHHS Resource Name | MHHS Programme Phase | Sched Status | RAG | Milestone ID | Text29 | Tier | Task Status | Guidance |
| --- | --- | --- | --- | --- | --- | --- | --- | --- | --- | --- | --- | --- | --- | --- | --- | --- | --- | --- | --- | --- | --- | --- | --- | --- | --- | --- | --- | --- | --- | --- | --- |
| 2849 | 1.9.9.6 | **Data Cleanse Plan** |  | 670d | 2023-03-02 A | 2025-09-24 |  | 92% | 51.98d | 2023-03-02 | 2025-09-03 | 547d | 2023-03-02 | 2025-04-04 | 586d |  |  | -0 | N/A | N/A | Migration | 5.0 | N/A | Migration |  |  |  |  |  |  |  |
| 2850 | 1.9.9.6.1 | Develop document with MWG |  | 50d | 2023-03-02 A | 2023-05-10 A |  | 100% |  | 2023-03-02 | 2023-05-10 | 50d | 2023-03-02 | 2023-05-10 |  |  |  |  | SI Migration | PP | Migration | 5.0 | John Wiggins,Matthew Breen | Migration | Complete | COMPLETE |  |  |  |  |  |
| 2851 | 1.9.9.6.2 | Artefact review (via TMAG) and updates |  | 20d | 2023-05-11 A | 2023-06-07 A | 2850 | 100% |  | 2023-05-11 | 2023-06-07 | 20d | 2023-05-11 | 2023-06-07 |  |  |  |  | PP | SI Migration,IPA | Migration | 5.0 | John Wiggins,Matthew Breen | Migration | Complete | COMPLETE |  |  |  |  |  |
| 2852 | 1.9.9.6.3 | Data Cleanse Plan approved | milestone | 0d | 2023-07-19 A | 2023-07-19 A | 2851FS+30d | 100% |  | 2023-07-19 | 2023-07-19 | 0d | 2023-06-14 | 2023-06-14 |  |  |  |  | SI Migration | PP | Migration | 5.0 | John Wiggins,Matthew Breen | Migration | Complete | COMPLETE | T3-MI-0020 | MCAG | T3 |  |  |
| 2853 | 1.9.9.6.4 | Monitor Programme Participant adherence to Data Cleanse Plan |  | 467d | 2023-06-15 A | 2025-03-28 A | 2852 | 100% |  | 2023-06-15 | 2025-03-28 | 467d | 2023-06-15 | 2025-03-28 |  |  |  |  | SI Migration | PP | Migration | 5.0 | Matthew Breen | Migration | Complete | COMPLETE |  |  |  |  |  |
| 2854 | 1.9.9.6.5 | **MTDs** |  | 240d | 2024-08-16 A | 2025-07-18 |  | 77% | 54.63d | 2024-08-16 | 2025-01-31 | 91d |  |  | 634d |  |  | -0 | N/A | N/A | Transition | 5.4 | N/A | Migration |  |  |  |  |  |  |  |
| 2855 | 1.9.9.6.5.1 | **ESME ID** |  | 195d | 2024-08-16 A | 2025-05-16 |  | 93% | 12.79d | 2024-08-16 | 2024-12-20 | 90d |  |  | 679d |  |  | -0 | N/A | N/A | Transition | 5.4 | N/A | Migration |  |  |  |  |  |  |  |
| 2856 | 1.9.9.6.5.1.1 | DCC to extract ESME ID and share with LDSO | milestone | 0d | 2024-08-16 A | 2024-08-16 A | 2852FS+282d | 100% |  | 2024-08-16 | 2024-08-16 | 0d |  |  |  |  |  |  | DCC/SI |  | Transition | 5.5 | Matthew Breen | Migration | Complete | COMPLETE | T3-MI-0024 | MCAG (Transition) | T3 |  |  |
| 2857 | 1.9.9.6.5.1.2 | LDSO ‘full refresh’ between their Registration Service and the EES (ESME ID) |  | 16d | 2024-10-21 A | 2024-11-11 A | 2856FS+45d | 100% |  | 2024-10-21 | 2024-11-11 | 0d |  |  |  |  |  |  | LDSO/EES |  | Transition | 5.5 | Matthew Breen | Migration | Complete | COMPLETE | T3-MI-0025 | MCAG (Transition) | T3 |  |  |
| 2858 | 1.9.9.6.5.1.3 | Suppliers complete investigation of exceptions and resolution of exceptions |  | 1d | 2024-12-20 A | 2024-12-20 A | 2857FS+28d | 100% |  | 2024-12-20 | 2024-12-20 | 1d |  |  |  |  |  |  | Supplier |  | Transition | 5.4 | Matthew Breen | Migration | Complete | COMPLETE |  |  |  |  |  |
| 2859 | 1.9.9.6.5.1.4 | Suppliers complete Work Off plans |  | 105d | 2024-12-23 A | 2025-05-16 | 2858 | 92% | 8d | 2024-12-23 | 2025-05-16 | 0d |  |  | 679d | 0d | start no earlier than 2024-12-23 |  | Supplier |  | Transition | 6.19 | Matthew Breen |  | Green | GREEN |  |  |  |  |  |
| 2860 | 1.9.9.6.5.1.5 | ESME ID Complete | milestone | 0d | 2025-05-16 | 2025-05-16 | 2859 |  |  | 2025-05-16 | 2025-05-16 | 0d |  |  | 679d |  |  |  | SI Transition |  | Transition | 6.19 | Matthew Breen | Migration | Green | GREEN |  |  |  | 9.71 |  |
| 2861 | 1.9.9.6.5.2 | **Meter Location and Number of Displayed Register Digits** |  | 221d | 2024-09-13 A | 2025-07-18 |  | 64% | 80.23d | 2024-09-13 | 2025-01-31 | 91d |  |  | 634d |  |  |  | N/A | N/A | Transition | 5.4 | N/A | Migration |  |  |  |  |  |  |  |
| 2862 | 1.9.9.6.5.2.1 | MEM to extract data and share with LDSO |  | 6d | 2024-09-13 A | 2024-09-20 A | 2852FS+301d | 100% |  | 2024-09-13 | 2024-09-20 | 1d |  |  |  |  |  |  | MEM/SI |  | Transition | 5.4 | Matthew Breen | Migration | Complete | COMPLETE |  |  |  |  |  |
| 2863 | 1.9.9.6.5.2.2 | LDSO ‘full refresh’ between their Registration Service and the EES (Meter Location and Number of Displayed Register Digits) |  | 16d | 2024-10-21 A | 2024-11-15 A | 2862FS+25d | 100% |  | 2024-10-28 | 2024-11-18 | 0d |  |  |  |  |  |  | LDSO /EES |  | Transition | 5.5 | Matthew Breen | Migration | Complete | COMPLETE | T3-MI-0026 | MCAG (Transition) | T3 |  |  |
| 2864 | 1.9.9.6.5.2.3 | Suppliers complete investigation of exceptions and resolution of exceptions |  | 1d | 2025-01-24 A | 2025-01-24 A | 2863FS+49d | 100% |  | 2025-01-31 | 2025-01-31 | 1d |  |  |  |  |  |  | Supplier |  | Transition | 5.4 | Matthew Breen | Migration | Complete | COMPLETE |  |  |  |  |  |
| 2865 | 1.9.9.6.5.2.4 | Suppliers complete Work Off plans |  | 123d | 2025-01-29 A | 2025-07-18 | 2864 | 57% | 53d | 2025-01-29 | 2025-07-18 | 0d |  |  | 634d | 0d | finish no earlier than 2025-07-18 |  | Supplier |  | Transition | 6.19 | Matthew Breen |  | Green | GREEN |  |  |  |  |  |
| 2866 | 1.9.9.6.5.2.5 | Meter Location and Number of Displayed Register Digits Complete | milestone | 0d | 2025-07-18 | 2025-07-18 | 2864, 2865 |  |  | 2025-07-18 | 2025-07-18 | 0d |  |  | 634d |  |  |  | SI Transition |  | Transition | 6.19 | Matthew Breen | Migration | Green | GREEN |  |  |  | 72.71 |  |
| 2867 | 1.9.9.6.6 | **Registration Data** |  | 274d | 2024-09-06 A | 2025-09-24 |  | 85% | 41.1d | 2024-09-06 | 2025-09-03 | 147d |  |  | 586d |  |  |  | N/A | N/A | Transition | 5.4 | N/A | Migration |  |  |  |  |  |  |  |
| 2868 | 1.9.9.6.6.1 | **Connection Type** |  | 47d | 2024-09-06 A | 2024-11-11 A |  | 100% |  | 2024-09-06 | 2024-11-11 | 16d |  |  |  |  |  |  | N/A | N/A | Transition | 5.4 | N/A | Migration |  |  |  |  |  |  |  |
| 2869 | 1.9.9.6.6.1.1 | Automated Population of Connection Type for Measurement Classes ‘B’, ‘D’, ‘F’ & ‘G’ | milestone | 0d | 2024-10-04 A | 2024-10-04 A | 2852FS+317d | 100% |  | 2024-10-04 | 2024-10-04 | 0d |  |  |  |  | start no earlier than 2024-09-13 |  | LDSO |  | Transition | 5.5 | Matthew Breen | Migration | Complete | COMPLETE | T3-MI-0027 | MCAG (Transition) | T3 |  |  |
| 2870 | 1.9.9.6.6.1.2 | BAU Population of Connection Type for Site Specific LLFCs within Measurement Classes ‘C’ & ‘E’ | milestone | 0d | 2024-10-04 A | 2024-10-04 A | 2852FS+317d | 100% |  | 2024-10-04 | 2024-10-04 | 0d |  |  |  |  |  |  | LDSO |  | Transition | 5.5 | Matthew Breen | Migration | Complete | COMPLETE | T3-MI-0028 | MCAG (Transition) | T3 |  |  |
| 2871 | 1.9.9.6.6.1.3 | Automated Population of Connection Type for Smart Meters within Measurement Class ‘A’ | milestone | 0d | 2024-10-04 A | 2024-10-04 A | 2852FS+317d | 100% |  | 2024-10-04 | 2024-10-04 | 0d |  |  |  |  |  |  | LDSO |  | Transition | 5.5 | Matthew Breen | Migration | Complete | COMPLETE | T3-MI-0029 | MCAG (Transition) | T3 |  |  |
| 2872 | 1.9.9.6.6.1.4 | Population of Connection Type for Traditional and Advanced Meters within Measurement Class ‘A’ |  | 1d | 2024-09-06 A | 2024-09-06 A | 2852FS+296d | 100% |  | 2024-09-06 | 2024-09-06 | 1d |  |  |  |  |  |  | Suppliers |  | Transition | 5.4 | Matthew Breen | Migration | Complete | COMPLETE |  |  |  |  |  |
| 2873 | 1.9.9.6.6.1.5 | Automated Population of Null Connection Type | milestone | 0d | 2024-10-04 A | 2024-10-04 A | 2852FS+317d | 100% |  | 2024-10-04 | 2024-10-04 | 0d |  |  |  |  |  |  | LDSO |  | Transition | 5.5 | Matthew Breen | Migration | Complete | COMPLETE | T3-MI-0030 | MCAG (Transition) | T3 |  |  |
| 2874 | 1.9.9.6.6.1.6 | Full MPAN refresh to ESS |  | 16d | 2024-10-21 A | 2024-11-11 A | 2852FS+327d | 100% |  | 2024-10-21 | 2024-11-11 | 1d |  |  |  |  |  |  | LDSO/EES |  | Transition | 5.4 | Matthew Breen | Migration | Complete | COMPLETE |  |  |  |  | Actually takes place on 29/9/24 which is a Sunday |
| 2875 | 1.9.9.6.6.1.7 | Connection Type Complete | milestone | 0d | 2024-11-11 A | 2024-11-11 A | 2869, 2870, 2871, 2872, 2873, 2874 | 100% |  | 2024-11-11 | 2024-11-11 | 0d |  |  |  |  |  |  | SI Transition |  | Transition | 5.4 | Matthew Breen | Migration | Complete | COMPLETE |  |  |  |  |  |

Notes:
- 2860: Action: 2/8/24: is date right as different to baseline? Why was it 23rd?

| ID | WBS | Task | Type | Duration | Start | Finish | Predecessors | Complete | Remaining | Baseline start | Baseline finish | Baseline duration | Total slack | Free slack | Constraint | Responsible | Involved | Text9 | Update Version | MHHS Resource Name | MHHS Programme Phase | Guidance | Task Status | Sched Status | RAG | Text29 |
| --- | --- | --- | --- | --- | --- | --- | --- | --- | --- | --- | --- | --- | --- | --- | --- | --- | --- | --- | --- | --- | --- | --- | --- | --- | --- | --- |
| 2876 | 1.9.9.6.6.2 | **Domestic Premises Indicator** |  | 14d | 2025-09-05 | 2025-09-24 |  |  |  | 2025-08-08 | 2025-09-03 | 17d | 586d |  |  | N/A | N/A | Transition | 5.4 | N/A | Migration |  |  |  |  |  |
| 2877 | 1.9.9.6.6.2.1 | The DCC to extract Domestic Premises Indicator from the CSS and provide a file to each LDSO and EES. |  | 2d | 2025-09-05 | 2025-09-08 | 1938FS-14d |  |  | 2025-09-05 | 2025-09-08 | 1d | 597d | 11d | start no earlier than 2025-09-05 | DCC |  | Transition | 6.22 | Matthew Breen | Migration | 27/7 - needs to end on date of M10 7/3/25 | 121.33 | Green | GREEN | MCAG (Transition) |
| 2878 | 1.9.9.6.6.2.2 | Each LDSO notifies the MHHS Programme SI of any exceptions which have occurred because of the data load and the reason for that exception |  | 1d | 2025-09-24 | 2025-09-24 | 2877 |  |  | 2025-09-24 | 2025-09-24 | 1d | 586d | 0d | start no earlier than 2025-09-24 | LDSO |  | Transition | 6.22 | Matthew Breen | Migration | 27/7 - needs to end on date of M10 7/3/25 | 140.33 | Green | GREEN | MCAG (Transition) |
| 2879 | 1.9.9.6.6.2.3 | Domestic Premises Indicator Complete | milestone | 0d | 2025-09-24 | 2025-09-24 | 2878 |  |  | 2025-09-24 | 2025-09-24 | 0d | 586d |  | finish no earlier than 2025-09-24 | SI Transition |  | Transition | 6.22 | Matthew Breen | Migration |  | 140.71 | Green | GREEN | MCAG (Transition) |
| 2880 | 1.9.9.7 | **Connection Type and Meter Type Misalignments** |  | 433d | 2025-03-03 A | 2026-10-28 |  | 32% | 295.16d | 2025-03-03 | 2026-10-28 | 0d | 301d |  |  | SI Transition |  | Transition | 6.22 | Matthew Breen |  |  |  |  |  |  |
| 2881 | 1.9.9.7.1 | **Traditional Meters installed on Current Transformers** |  | 433d | 2025-03-03 A | 2026-10-28 |  | 10% | 391.8d | 2025-03-03 | 2026-10-28 | 0d | 301d |  |  | SI Transition |  | Transition | 6.22 | Matthew Breen |  |  | -890.67 |  |  |  |
| 2882 | 1.9.9.7.1.1 | Suppliers investigate all MPANs with Traditional Meters installed on a Current Transformer Connection Type |  | 65d | 2025-03-03 A | 2025-05-30 |  | 72% | 18d | 2025-03-03 | 2025-05-30 | 0d | 301d | 0d | finish no earlier than 2025-05-30 | SI Transition |  | Transition | 6.22 | Matthew Breen |  |  |  | Green | GREEN | MCAG (Transition) |
| 2883 | 1.9.9.7.1.2 | Suppliers to raise the relevant SDEP cases with LDSOs in pot 3 | milestone | 0d | 2025-05-30 | 2025-05-30 |  |  |  | 2025-05-30 | 2025-05-30 | 0d | 629d | 0d | finish no earlier than 2025-05-30 | SI Transition |  | Transition | 6.22 | Matthew Breen |  |  | 23.71 | Green | GREEN | MCAG (Transition) |
| 2884 | 1.9.9.7.1.3 | Suppliers to have ensured that Meter Operators have sent the necessary D0312s for MPANs in pot 2 |  | 21d | 2025-06-02 | 2025-06-30 | 2882 |  |  | 2025-06-02 | 2025-06-30 | 0d | 648d |  | start no earlier than 2025-06-02 | SI Transition |  | Transition | 6.22 | Matthew Breen |  |  | 26.33 | Green | GREEN | MCAG (Transition) |
| 2885 | 1.9.9.7.1.4 | LDSOs will be required to have corrected all of these Connection Types in pot 3 |  | 40d | 2025-06-02 | 2025-07-25 | 2883 |  |  | 2025-06-02 | 2025-07-25 | 0d | 629d |  | start no earlier than 2025-06-02 | SI Transition |  | Transition | 6.22 | Matthew Breen |  |  | 26.33 | Green | GREEN | MCAG (Transition) |
| 2886 | 1.9.9.7.1.5 | Suppliers to have completed meter exchanges for those MPANs in pot 1 |  | 368d | 2025-06-02 | 2026-10-28 | 2882 |  |  | 2025-06-02 | 2026-10-28 | 0d | 301d | 0d | start no earlier than 2025-06-02 | SI Transition |  | Transition | 6.22 | Matthew Breen |  |  | 26.33 | Green | GREEN | MCAG (Transition) |
| 2887 | 1.9.9.7.1.6 | Traditional Meters installed on Current Transformers complete | milestone | 0d | 2026-10-28 | 2026-10-28 | 2886 |  |  | 2026-10-28 | 2026-10-28 | 0d | 301d |  | finish no earlier than 2026-10-28 | SI Transition |  | Transition | 6.22 | Matthew Breen |  |  | 539.71 | Green | GREEN | MCAG (Transition) |
| 2888 | 1.9.9.7.2 | **CHECK Meters** |  | 66d | 2025-03-03 A | 2025-06-02 |  | 72% | 18.28d | 2025-05-30 | 2025-06-02 | 0d | 668d |  |  | SI Transition |  | Transition | 6.22 | Matthew Breen |  |  | -890.67 |  |  |  |
| 2889 | 1.9.9.7.2.1 | Suppliers and their appointed Meter Operator investigate MPANs within their portfolio that have incorrectly populated meters with the Meter Type CHECK within MPRS. Meter Operators are required to send a D0312 to remove the CHECK meter from MPRS. |  | 65d | 2025-03-03 A | 2025-05-30 |  | 72% | 18d | 2025-03-03 | 2025-05-30 | 0d | 669d | 1d | finish no earlier than 2025-05-30 | SI Transition |  | Transition | 6.22 | Matthew Breen |  |  |  | Green | GREEN | MCAG (Transition) |
| 2890 | 1.9.9.7.2.2 | Once CHECK meters are either removed from MPRS or the Meter Type is changed to a valid Meter Type, the LDSO should check that the Connection Type assigned to the MPAN is still valid. |  | 65d | 2025-03-03 A | 2025-05-30 |  | 72% | 18d | 2025-03-03 | 2025-05-30 | 0d | 669d | 1d | finish no earlier than 2025-05-30 | SI Transition |  | Transition | 6.22 | Matthew Breen |  |  |  | Green | GREEN | MCAG (Transition) |
| 2891 | 1.9.9.7.2.3 | Suppliers confirm to the Programme that they have completed this activity | milestone | 0d | 2025-06-02 | 2025-06-02 | 2889 |  |  | 2025-06-02 | 2025-06-02 | 0d | 668d |  | finish no earlier than 2025-06-02 | SI Transition |  | Transition | 6.22 | Matthew Breen |  |  | 26.71 | Green | GREEN | MCAG (Transition) |
| 2892 | 1.9.9.7.2.4 | CHECK Meters complete | milestone | 0d | 2025-06-02 | 2025-06-02 | 2890 |  |  | 2025-06-02 | 2025-06-02 | 0d | 668d |  | finish no earlier than 2025-06-02 | SI Transition |  | Transition | 6.22 | Matthew Breen |  |  | 26.71 | Green | GREEN | MCAG (Transition) |
| 2893 | 1.9.9.7.3 | **Smart Meter Types installed on CT Connection Types** |  | 90d | 2025-03-21 A | 2025-07-25 |  | 36% | 58d | 2025-03-21 | 2025-07-25 | 0d | 629d |  |  | SI Transition |  | Transition | 6.22 | Matthew Breen |  |  | -890.67 |  |  |  |
| 2894 | 1.9.9.7.3.1 | Programme shares data via email with LDSOs and Suppliers on the total number of misalignments to inform work they will have to complete | milestone | 0d | 2025-03-21 A | 2025-03-21 A |  | 100% |  | 2025-03-21 | 2025-03-21 | 0d |  |  | finish no earlier than 2025-03-21 | SI Transition |  | Transition | 6.22 | Matthew Breen |  |  |  | Complete | COMPLETE | MCAG (Transition) |
| 2895 | 1.9.9.7.3.2 | LDSOs investigate Connection Type misalignments and correct where appropriate |  | 50d | 2025-03-24 A | 2025-05-30 | 2894 | 64% | 18d | 2025-03-24 | 2025-05-30 | 0d | 629d | 0d | finish no earlier than 2025-05-30 | SI Transition |  | Transition | 6.22 | Matthew Breen |  |  |  | Green | GREEN | MCAG (Transition) |
| 2896 | 1.9.9.7.3.3 | LDSOs raise SDEP queries with Suppliers where they believe there is an issue | milestone | 0d | 2025-05-30 | 2025-05-30 | 2895 |  |  | 2025-05-30 | 2025-05-30 | 0d | 629d | 0d | finish no earlier than 2025-05-30 | SI Transition |  | Transition | 6.22 | Matthew Breen |  |  | 23.71 | Green | GREEN | MCAG (Transition) |
| 2897 | 1.9.9.7.3.4 | Suppliers resolve all issues |  | 40d | 2025-06-02 | 2025-07-25 | 2896 |  |  | 2025-06-02 | 2025-07-25 | 0d | 629d | 0d | finish no earlier than 2025-07-25 | SI Transition |  | Transition | 6.22 | Matthew Breen |  |  | 26.33 | Green | GREEN | MCAG (Transition) |
| 2898 | 1.9.9.7.3.5 | Smart Meter Types installed on CT Connection Types complete | milestone | 0d | 2025-07-25 | 2025-07-25 | 2897 |  |  | 2025-07-25 | 2025-07-25 | 0d | 629d |  | finish no earlier than 2025-07-25 | SI Transition |  | Transition | 6.22 | Matthew Breen |  |  | 79.71 | Green | GREEN | MCAG (Transition) |
| 2899 | 1.9.9.7.4 | **Linked Import / Export MPANs** |  | 105d | 2025-03-03 A | 2025-07-25 |  | 45% | 58d | 2025-03-03 | 2025-07-25 | 0d | 629d |  |  | SI Transition |  | Transition | 6.22 | Matthew Breen |  |  | -890.67 |  |  |  |
| 2900 | 1.9.9.7.4.1 | LDSOs review and correct linked Import / Export MPANs with Different Connection Types |  | 105d | 2025-03-03 A | 2025-07-25 |  | 45% | 58d | 2025-03-03 | 2025-07-25 | 0d | 629d | 0d | finish no earlier than 2025-07-25 | SI Transition |  | Transition | 6.22 | Matthew Breen |  |  |  | Green | GREEN | MCAG (Transition) |
| 2901 | 1.9.9.7.4.2 | LDSOs, Import and Export Suppliers review and correct linked Import / Export MPANs with meters in the Advanced and Traditional or Smart Meter Groups |  | 105d | 2025-03-03 A | 2025-07-25 |  | 45% | 58d | 2025-03-03 | 2025-07-25 | 0d | 629d | 0d | finish no earlier than 2025-07-25 | SI Transition |  | Transition | 6.22 | Matthew Breen |  |  |  | Green | GREEN | MCAG (Transition) |
| 2902 | 1.9.9.7.4.3 | Linked Import / Export MPANs complete | milestone | 0d | 2025-07-25 | 2025-07-25 | 2900, 2901 |  |  | 2025-07-25 | 2025-07-25 | 0d | 629d |  | finish no earlier than 2025-07-25 | SI Transition |  | Transition | 6.22 | Matthew Breen |  |  | 79.71 | Green | GREEN | MCAG (Transition) |

| ID | WBS | Task | Type | Duration | Start | Finish | Predecessors | Complete | Remaining | Baseline start | Baseline finish | Baseline duration | Baseline 1 start | Baseline 1 finish | Total slack | Free slack | Constraint | Baseline cost | Responsible | Text9 | Task Status | Update Version | MHHS Resource Name | Sched Status | RAG | Text29 | Involved | MHHS Programme Phase | Milestone ID | Tier |
| --- | --- | --- | --- | --- | --- | --- | --- | --- | --- | --- | --- | --- | --- | --- | --- | --- | --- | --- | --- | --- | --- | --- | --- | --- | --- | --- | --- | --- | --- | --- |
| 2903 | 1.9.9.7.5 | **Related MPANs** |  | 105d | 2025-03-03 A | 2025-07-25 |  | 45% | 58d | 2025-03-03 | 2025-07-25 | 0d |  |  | 629d |  |  |  | SI Transition | Transition | -890.67 | 6.22 | Matthew Breen |  |  |  |  |  |  |  |
| 2904 | 1.9.9.7.5.1 | LDSOs review and correct related MPANs with different Connection Types |  | 80d | 2025-03-03 A | 2025-06-20 |  | 59% | 33d | 2025-03-03 | 2025-06-20 | 0d |  |  | 629d | 0d |  |  | SI Transition | Transition |  | 6.22 | Matthew Breen | Green | GREEN | MCAG (Transition) |  |  |  |  |
| 2905 | 1.9.9.7.5.2 | Suppliers unrelate any MPANs required |  | 25d | 2025-06-23 | 2025-07-25 | 2904 |  |  | 2025-06-23 | 2025-07-25 | 0d |  |  | 629d | 0d | finish no earlier than 2025-07-25 |  | SI Transition | Transition | 47.33 | 6.22 | Matthew Breen | Green | GREEN | MCAG (Transition) |  |  |  |  |
| 2906 | 1.9.9.7.5.3 | Suppliers should investigate Related MPANs within different meter groups and verify that they are correct or request that their Meter Operators update the Meter Types where they are incorrect |  | 105d | 2025-03-03 A | 2025-07-25 |  | 45% | 58d | 2025-03-03 | 2025-07-25 | 0d |  |  | 629d | 0d | start no earlier than 2025-03-03 |  | SI Transition | Transition |  | 6.22 | Matthew Breen | Green | GREEN | MCAG (Transition) |  |  |  |  |
| 2907 | 1.9.9.7.5.4 | Related MPANs complete | milestone | 0d | 2025-07-25 | 2025-07-25 | 2905, 2906 |  |  | 2025-07-25 | 2025-07-25 | 0d |  |  | 629d |  | finish no earlier than 2025-07-25 |  | SI Transition | Transition | 79.71 | 6.22 | Matthew Breen | Green | GREEN | MCAG (Transition) |  |  |  |  |
| 2908 | 1.9.9.8 | **Export / Import MPANs** |  | 363d | 2024-03-22 A | 2025-08-13 |  | 99% | 0d | 2024-03-22 | 2024-10-18 | 151d |  |  | 617d |  |  |  | N/A | Transition |  | 5.4 | N/A |  |  |  | N/A | Migration |  |  |
| 2909 | 1.9.9.8.1 | **Linking of Export / Import MPANS** |  | 151d | 2024-03-22 A | 2024-10-18 A |  | 100% |  | 2024-03-22 | 2024-10-18 | 151d |  |  |  |  |  |  | N/A | Transition |  | 5.4 | N/A |  |  |  | N/A | Migration |  |  |
| 2910 | 1.9.9.8.1.1 | LDSO utilises BAU processing (DB05s) to populate each import/export association |  | 1d | 2024-03-22 A | 2024-03-22 A | 2852FS+176d | 100% |  | 2024-03-22 | 2024-03-22 | 1d |  |  |  |  |  |  | LDSO | Transition |  | 5.4 | Matthew Breen | Complete | COMPLETE |  |  | Migration |  |  |
| 2911 | 1.9.9.8.1.2 | Each LDSO notifies the Registered Supplier of any exceptions |  | 1d | 2024-04-19 A | 2024-04-19 A | 2910FS+19d | 100% |  | 2024-04-19 | 2024-04-19 | 1d |  |  |  |  |  |  | LDSO | Transition |  | 5.4 | Matthew Breen | Complete | COMPLETE |  |  | Migration |  |  |
| 2912 | 1.9.9.8.1.3 | Each Supplier completes investigation and resolution of exceptions |  | 1d | 2024-08-23 A | 2024-08-23 A | 2911FS+89d | 100% |  | 2024-08-23 | 2024-08-23 | 1d |  |  |  |  |  |  | Supplier | Transition |  | 5.4 | Matthew Breen | Complete | COMPLETE |  |  | Migration |  |  |
| 2913 | 1.9.9.8.1.4 | Each LDSO has linked al relevant import/export MPANS | milestone | 0d | 2024-10-18 A | 2024-10-18 A | 2912FS+40d | 100% |  | 2024-10-18 | 2024-10-18 | 0d |  |  |  |  |  |  | LDSO | Transition |  | 5.5 | Matthew Breen | Complete | COMPLETE | MCAG (Transition) |  | Migration | T3-MI-0031 | T3 |
| 2914 | 1.9.9.8.1.5 | Linking of Export / Import MPANS Complete | milestone | 0d | 2024-10-18 A | 2024-10-18 A | 2913 | 100% |  | 2024-10-18 | 2024-10-18 | 0d |  |  |  |  |  |  | SI Transition | Transition |  | 5.4 | Matthew Breen | Complete | COMPLETE |  |  | Migration |  |  |
| 2915 | 1.9.9.8.2 | Pre-migration data cleanse complete | milestone | 0d | 2025-08-13 | 2025-08-13 |  |  |  | 2025-08-13 | 2025-08-13 | 0d | 2025-04-04 | 2025-04-04 | 617d |  | start no earlier than 2025-08-13 |  | SI Migration | Transition | 98.33 | 5.0 | Matthew Breen | Green | GREEN | MCAG (Transition) | PP | Migration | T2-MI-0450 | T2 |
| 2916 | 1.9.10 | **Migration Period Planning** |  | 367d | 2023-07-03 A | 2024-11-26 |  | 83% | 61.71d | 2023-07-03 | 2024-11-26 | 851d | 2023-07-03 | 2026-10-05 | 678d |  |  | -0 | N/A | Transition | M10 | 5.0 | N/A |  |  |  | N/A | Migration |  |  |
| 2917 | 1.9.10.1 | **Migration Implementation Plan (incl. Migration Exit Criteria)** |  | 367d | 2023-07-03 A | 2024-11-26 |  | 83% | 61.71d | 2023-07-03 | 2024-11-26 | 851d | 2023-07-03 | 2026-10-05 | 678d |  |  | -0 | N/A | Transition |  | 5.0 | N/A |  |  |  | N/A | Migration |  |  |
| 2918 | 1.9.10.1.1 | **Migration Threshold Volumes** |  | 101d | 2023-07-03 A | 2023-11-20 A |  | 100% |  | 2023-07-03 | 2023-11-20 | 98d | 2023-07-03 | 2023-08-31 |  |  |  | -0 | N/A | Transition |  | 5.0 | N/A |  |  |  | N/A | Migration |  |  |
| 2919 | 1.9.10.1.1.1 | Threshold volumes reviewed by MWG |  | 54d | 2023-07-03 A | 2023-09-14 A |  | 100% |  | 2023-07-03 | 2023-09-14 | 54d | 2023-07-03 | 2023-07-28 |  |  |  |  | SI Migration | Transition |  | 5.6 | John Wiggins,Matthew Breen | Complete | COMPLETE |  | PP | Migration |  |  |
| 2920 | 1.9.10.1.1.2 | Artefact review (via TMAG) and updates |  | 47d | 2023-09-15 A | 2023-11-20 A | 2919 | 100% |  | 2023-09-15 | 2023-11-20 | 44d | 2023-07-31 | 2023-08-31 |  |  |  |  | PP | Transition |  | 5.9 | John Wiggins,Matthew Breen | Complete | COMPLETE |  | SI Migration | Migration |  |  |
| 2921 | 1.9.10.1.1.3 | Threshold volumes approved at TMAG | milestone | 0d | 2023-11-20 A | 2023-11-20 A | 2920 | 100% |  | 2023-11-20 | 2023-11-20 | 0d | 2023-08-31 | 2023-08-31 |  |  |  |  | SI Migration | Transition |  | 5.12 | John Wiggins,Matthew Breen | Complete | COMPLETE | SITAG | PP | Migration | T3-MI-0021 | T3 |
| 2922 | 1.9.10.1.2 | **Define acceptance criteria for M15** |  | 78d | 2023-09-04 A | 2023-12-20 A |  | 100% |  | 2023-09-04 | 2023-12-20 | 78d | 2023-09-04 | 2023-11-30 |  |  |  | -0 | N/A | Transition |  | 5.0 | N/A |  |  |  | N/A | Migration |  |  |
| 2923 | 1.9.10.1.2.1 | Review acceptance criteria and reporting requirements with MWG |  | 49d | 2023-09-04 A | 2023-11-09 A |  | 100% |  | 2023-09-04 | 2023-11-09 | 40d | 2023-09-04 | 2023-10-27 |  |  | start no earlier than 2023-09-04 |  | SI Migration | Transition |  | 5.0 | John Wiggins,Matthew Breen | Complete | COMPLETE |  |  | Migration |  |  |
| 2924 | 1.9.10.1.2.2 | Artefact review (via TMAG) and updates |  | 29d | 2023-11-10 A | 2023-12-20 A | 2923 | 100% |  | 2023-11-10 | 2023-12-20 | 29d | 2023-10-30 | 2023-11-30 |  |  | start no earlier than 2023-10-30 |  | PP | Transition |  | 5.0 | John Wiggins,Matthew Breen | Complete | COMPLETE |  | SI Migration | Migration |  |  |
| 2925 | 1.9.10.1.2.3 | Acceptance criteria for M15 agreed at TMAG | milestone | 0d | 2023-12-20 A | 2023-12-20 A | 2924 | 100% |  | 2023-12-20 | 2023-12-20 | 0d | 2023-11-30 | 2023-11-30 |  |  | finish no earlier than 2023-11-30 |  | SI Migration | Transition |  | 5.14 | John Wiggins,Matthew Breen | Complete | COMPLETE | SITAG |  | Migration | T3-MI-0022 | T3 |
| 2926 | 1.9.10.1.3 | **M10/M11 cut-over plan** |  | 119d | 2023-12-21 A | 2024-06-04 A |  | 100% |  | 2023-12-21 | 2024-06-04 | 119d | 2024-01-01 | 2024-05-31 |  |  |  | -0 | N/A | Transition |  | 5.16 | N/A |  |  |  | N/A | Migration |  |  |
| 2927 | 1.9.10.1.3.1 | Draft Document |  | 84d | 2023-12-21 A | 2024-04-16 A | 2925 | 100% |  | 2023-12-21 | 2024-04-16 | 84d |  |  |  |  |  |  | SI Transition | Transition |  | 5.16 | Matthew Breen | Complete | COMPLETE |  | SI Transition,PP,SRO | Migration |  |  |
| 2928 | 1.9.10.1.3.2 | Share Document with SRO |  | 1d | 2024-04-17 A | 2024-04-17 A | 2927 | 100% |  | 2024-04-17 | 2024-04-17 | 1d |  |  |  |  |  |  | SI Transition | Transition |  | 5.16 | Matthew Breen | Complete | COMPLETE |  | SI Transition,PP,SRO | Migration |  |  |
| 2929 | 1.9.10.1.3.3 | Industry Consultation |  | 11d | 2024-04-23 A | 2024-05-07 A | 2928FS+3d | 100% |  | 2024-04-23 | 2024-05-07 | 11d |  |  |  |  |  |  | SI Transition | Transition |  | 5.16 | Matthew Breen | Complete | COMPLETE |  | SI Transition,PP,SRO | Migration |  |  |
| 2930 | 1.9.10.1.3.4 | Assurance Meeting |  | 1d | 2024-05-21 A | 2024-05-21 A | 2929FS+9d | 100% |  | 2024-05-21 | 2024-05-21 | 1d |  |  |  |  |  |  | SI Transition | Transition |  | 5.16 | Matthew Breen | Complete | COMPLETE |  | SI Transition,PP,SRO | Migration |  |  |
| 2931 | 1.9.10.1.3.5 | MCAG Approval of M10/M11 Cut-over Plan | milestone | 0d | 2024-06-04 A | 2024-06-04 A | 2930FS+10d | 100% |  | 2024-06-04 | 2024-06-04 | 0d | 2024-05-31 | 2024-05-31 |  |  |  |  | SI Transition | Transition |  | 5.26 | Matthew Breen | Complete | COMPLETE | MCAG | SI Transition,PP,SRO | Migration | T3-MI-0023 | T3 |

| ID | WBS | Task | Type | Duration | Start | Finish | Predecessors | Complete | Remaining | Baseline start | Baseline finish | Baseline duration | Baseline 1 start | Baseline 1 finish | Total slack | Free slack | Constraint | Baseline cost | Responsible | Involved | Text9 | Update Version | MHHS Resource Name | MHHS Programme Phase | Sched Status | RAG | Task Status | Milestone ID | Text29 | Tier | Action |
| --- | --- | --- | --- | --- | --- | --- | --- | --- | --- | --- | --- | --- | --- | --- | --- | --- | --- | --- | --- | --- | --- | --- | --- | --- | --- | --- | --- | --- | --- | --- | --- |
| 2932 | 1.9.10.1.4 | **M16 Methodology** |  | 85d | 2024-07-31 A | 2024-11-26 |  | 10% | 76.9d | 2024-07-31 | 2024-11-26 | 85d | 2023-10-02 | 2024-04-26 | 678d |  |  | -0 | N/A | N/A | Transition | 5.0 | N/A | Migration |  |  |  |  |  |  |  |
| 2933 | 1.9.10.1.4.1 | Draft Document |  | 50d | 2024-07-31 A | 2024-10-08 |  | 12% | 44d | 2024-07-31 | 2024-10-08 | 50d | 2023-10-02 | 2023-12-29 | 678d | 0d |  |  | SI Transition | SI Transition,PP,SRO | Transition | 5.26 | Claire Silk | Migration | Overdue | RED |  |  |  |  |  |
| 2934 | 1.9.10.1.4.2 | Share Document with SRO |  | 1d | 2024-10-09 | 2024-10-09 | 2933 |  |  | 2024-10-09 | 2024-10-09 | 1d | 2024-01-01 | 2024-01-26 | 678d | 0d |  |  | SI Transition | SI Transition,PP,SRO | Transition | 5.26 | Claire Silk | Migration | Overdue Start | RED | -209.67 |  |  |  |  |
| 2935 | 1.9.10.1.4.3 | Industry Consultation |  | 11d | 2024-10-15 | 2024-10-29 | 2934FS+3d |  |  | 2024-10-15 | 2024-10-29 | 11d | 2024-01-29 | 2024-03-29 | 678d | 0d |  |  | SI Transition | SI Transition,PP,SRO | Transition | 5.26 | Claire Silk | Migration | Overdue Start | RED | -203.67 |  |  |  |  |
| 2936 | 1.9.10.1.4.4 | Assurance Meeting |  | 1d | 2024-11-12 | 2024-11-12 | 2935FS+9d |  |  | 2024-11-12 | 2024-11-12 | 1d | 2024-04-01 | 2024-04-26 | 678d | 0d |  |  | SI Transition | SI Transition,PP,SRO | Transition | 5.26 | Claire Silk | Migration | Overdue Start | RED | -175.67 |  |  |  |  |
| 2937 | 1.9.10.1.4.5 | M16 methodology approved | milestone | 0d | 2024-11-26 | 2024-11-26 | 2936FS+10d |  |  | 2024-11-26 | 2024-11-26 | 0d | 2024-04-26 | 2024-04-26 | 678d |  |  |  | SI Transition | SI Transition,PP,SRO | Transition | 5.26 | Claire Silk | Migration | Overdue Start | RED | -161.29 | T3-MI-0500 | MCAG (Transition) | T2 |  |
| 2938 | 1.9.11 | **Preparation for Cutover to Live** |  | 744d | 2024-06-28 A | 2027-05-05 |  | 8% | 687.13d | 2024-06-28 | 2025-10-22 | 201d | 2025-02-07 | 2025-04-04 | 166d |  |  | -0 | N/A | N/A | Transition | 6.11 | N/A | Migration |  |  |  |  |  |  |  |
| 2939 | 1.9.11.1 | **Central Systems Prepare for Cutover to Live** |  | 326d | 2024-06-28 A | 2025-09-26 |  | 19% | 264.88d | 2024-06-28 | 2025-09-26 | 186d | 2025-02-07 | 2025-03-07 | 584d |  |  | -0 | N/A | N/A | Transition | 6.11 | N/A | Migration |  |  | M13 |  |  |  |  |
| 2940 | 1.9.11.1.1 | DCC (Functionality available June 2024) | milestone | 0d | 2024-06-28 A | 2024-06-28 A |  | 100% |  | 2024-06-28 | 2024-06-28 | 0d |  |  |  |  | start no earlier than 2024-06-28 |  | DCC |  | Transition | 6.11 | Matthew Breen |  | Complete | COMPLETE |  |  |  |  |  |
| 2941 | 1.9.11.1.2 | **Development of Comms Approach and Declaration Guidance** |  | 79d | 2025-04-28 A | 2025-08-14 |  | 6% | 74.31d | 2025-03-03 | 2025-06-19 | 79d |  |  | 34d |  |  |  | N/A | N/A | Transition | 6.11 | N/A |  |  |  | 95.33 |  |  |  |  |
| 2942 | 1.9.11.1.2.1 | Draft Cutover Comms Approach |  | 59d | 2025-04-28 A | 2025-07-17 |  | 12% | 52d | 2025-04-28 | 2025-07-17 | 59d |  |  | 34d | 0d | start no earlier than 2025-04-28 |  | SI Transition | SI Transition | Transition | 6.11 | Matthew Breen |  | Green | GREEN |  |  |  |  |  |
| 2943 | 1.9.11.1.2.2 | Draft Cutover Comms Approach shared | milestone | 0d | 2025-07-17 | 2025-07-17 | 2942 |  |  | 2025-07-17 | 2025-07-17 | 0d |  |  | 34d | 0d |  |  | SI Transition | SI Transition | Transition | 6.11 | Matthew Breen |  | Green | GREEN | 71.71 |  |  |  |  |
| 2944 | 1.9.11.1.2.3 | Development of Implementation Group |  | 59d | 2025-04-28 | 2025-07-17 |  |  |  | 2025-04-28 | 2025-07-17 | 59d |  |  | 34d | 0d | start no earlier than 2025-04-28 |  | SI Transition | SI Transition | Transition | 6.11 | Matthew Breen |  | Overdue Start | GREEN | -8.67 |  |  |  |  |
| 2945 | 1.9.11.1.2.4 | Implementation Group Established | milestone | 0d | 2025-07-17 | 2025-07-17 | 2944 |  |  | 2025-07-17 | 2025-07-17 | 0d |  |  | 34d | 0d |  |  | SI Transition | SI Transition | Transition | 6.11 | Matthew Breen |  | Green | GREEN | 71.71 |  |  |  |  |
| 2946 | 1.9.11.1.2.5 | Finalised Cutover Comms Approach shared | milestone | 0d | 2025-08-14 | 2025-08-14 | 2943FS+20d, 2945FS+20d |  |  | 2025-08-14 | 2025-08-14 | 0d |  |  | 34d | 29d |  |  | SI Transition | SI Transition | Transition | 6.11 | Matthew Breen |  | Green | GREEN | 99.71 |  |  |  |  |
| 2947 | 1.9.11.1.3 | **Development of Cutover Plan requirements with Participants** |  | 96d | 2025-04-11 A | 2025-08-22 |  | 26% | 70.81d | 2025-03-03 | 2025-08-06 | 59d |  |  | 609d |  |  |  | N/A | N/A | Transition | 6.11 | N/A |  |  |  | -605.67 |  |  |  |  |
| 2948 | 1.9.11.1.3.1 | Development of Central Parties Cutover Plans |  | 26d | 2025-04-11 A | 2025-05-16 |  | 69% | 8d | 2025-04-28 | 2025-07-17 | 59d |  |  | 659d | 0d | start no earlier than 2025-04-11 |  | SI Transition | SI Transition | Transition | 6.23 | Matthew Breen |  | Green | GREEN |  |  |  |  |  |
| 2949 | 1.9.11.1.3.2 | Development of Programme Participant Cutover Plans |  | 56d | 2025-04-11 A | 2025-06-27 | 2948SS | 32% | 38d | 2025-07-17 | 2025-07-17 | 0d |  |  | 68d | 15d | finish no earlier than 2025-06-27 |  | SI Transition | SI Transition | Transition | 6.23 | Matthew Breen |  | Green | GREEN |  |  |  |  |  |
| 2950 | 1.9.11.1.3.3 | Central Party Cutover Plan Assurance |  | 45d | 2025-04-14 A | 2025-06-13 | 2948FF | 38% | 28d | 2025-04-14 | 2025-06-13 | 0d |  |  | 659d |  | start no earlier than 2025-04-14 |  | SI Transition |  | Transition | 6.23 | Matthew Breen |  | Green | GREEN |  |  |  |  |  |
| 2951 | 1.9.11.1.3.4 | Consolidated MHHS Cutover Plan Developed |  | 20d | 2025-05-19 | 2025-06-13 | 2948 |  |  | 2025-05-19 | 2025-06-13 | 0d |  |  | 659d |  | start no earlier than 2025-05-19 |  | SI Transition |  | Transition | 6.23 | Matthew Breen |  | Green | GREEN | 12.33 |  |  |  |  |
| 2952 | 1.9.11.1.3.5 | LDSO Cutover Plan Assurance |  | 15d | 2025-06-30 | 2025-07-18 | 2949FF |  |  | 2025-06-30 | 2025-07-18 | 0d |  |  | 634d |  | start no earlier than 2025-06-30 |  | SI Transition |  | Transition | 6.23 | Matthew Breen |  | Green | GREEN | 54.33 |  |  |  |  |
| 2953 | 1.9.11.1.3.6 | SIT Supplier and SIT Agent Cutover Plan Assurance |  | 40d | 2025-06-30 | 2025-08-22 | 2949FF |  |  | 2025-06-30 | 2025-08-22 | 0d |  |  | 28d | 23d | start no earlier than 2025-06-30 |  | SI Transition |  | Transition | 6.23 | Matthew Breen |  | Green | GREEN | 54.33 |  |  |  |  |
| 2954 | 1.9.11.1.4 | **M10/M11 Cutover Activities** |  | 15d | 2025-09-05 | 2025-09-26 |  |  |  | 2025-04-14 | 2025-09-26 | 15d |  |  | 12d |  |  | -0 |  |  | Transition | 6.11 |  |  |  |  | -608.67 |  |  |  |  |
| 2955 | 1.9.11.1.4.1 | Production DIP Portal (DIP Deployment) | milestone | 0d | 2025-09-05 | 2025-09-05 | 1763FS+10d |  |  | 2025-09-05 | 2025-09-05 | 0d |  |  | 12d | 7d |  |  | Elexon,DIP Manager | Elexon,DIP Manager, SI Transition | Transition | 6.11 | Matthew Breen |  | Green | GREEN | 121.71 |  |  |  |  |
| 2956 | 1.9.11.1.4.2 | Production Certificates (DIP Deployment) | milestone | 0d | 2025-09-05 | 2025-09-05 | 1763FS+10d |  |  | 2025-09-05 | 2025-09-05 | 0d |  |  | 12d | 7d |  |  | Elexon,DIP Manager | Elexon,DIP Manager, SI Transition | Transition | 6.11 | Matthew Breen |  | Green | GREEN | 121.71 |  |  |  |  |
| 2957 | 1.9.11.1.4.3 | Completion of the pre-M10 MHHS Data Cleanse | milestone | 0d | 2025-09-24 | 2025-09-24 | 1938 |  |  | 2025-09-24 | 2025-09-24 | 0d |  |  | 586d |  |  |  | PP,DCC,SI Transition | PP,DCC,SI Transition | Transition | 6.11 | Matthew Breen |  | Green | GREEN | 140.71 |  |  |  |  |
| 2958 | 1.9.11.1.4.4 | Market-wide Participant MHHS Supporting Functionality Ready - Confirmation from Code Bodies | milestone | 0d | 2025-09-15 | 2025-09-15 | 1938FS-8d |  |  | 2025-09-15 | 2025-09-15 | 0d |  |  | 594d |  |  |  | Code Bodies | Code Bodies,SI Transition | Transition | 6.11 | Matthew Breen |  | Green | GREEN | 131.33 |  |  |  |  |
| 2959 | 1.9.11.1.4.5 | Market-wide Participant MHHS Supporting Functionality Ready | milestone | 0d | 2025-09-22 | 2025-09-22 | 1938FS-3d |  |  | 2025-09-22 | 2025-09-22 | 0d |  |  | 589d |  |  |  | PP | PP,SI Transition | Transition | 6.11 | Matthew Breen |  | Green | GREEN | 138.33 |  |  |  |  |
| 2960 | 1.9.11.1.4.6 | Elexon Central Services Deployment | milestone | 0d | 2025-09-19 | 2025-09-19 | 2985 |  |  | 2025-09-19 | 2025-09-19 | 0d |  |  | 5d | 0d |  |  | DIP Manager,Elexon | DIP Manager,Elexon,SI Transition | Transition | 6.11 | Matthew Breen |  | Green | GREEN | 135.71 |  |  |  |  |
| 2961 | 1.9.11.1.4.7 | Service Management Go-Live | milestone | 0d | 2025-09-19 | 2025-09-19 | 2985 |  |  | 2025-09-19 | 2025-09-19 | 0d |  |  | 5d | 0d |  |  | Elexon | Elexon,SI Transition | Transition | 6.11 | Matthew Breen |  | Green | GREEN | 135.71 |  |  |  |  |
| 2962 | 1.9.11.1.4.8 | Data Transfer Service (DTS) New Functionality Deployment | milestone | 0d | 2025-09-19 | 2025-09-19 | 2985 |  |  | 2025-09-19 | 2025-09-19 | 0d |  |  | 5d | 0d |  |  | Code Bodies,Electralink | Code Bodies,SI Transition | Transition | 6.11 | Matthew Breen |  | Green | GREEN | 135.71 |  |  |  |  |
| 2963 | 1.9.11.1.4.9 | Electricity Enquiry Service (EES) Deployment | milestone | 0d | 2025-09-19 | 2025-09-19 | 2985 |  |  | 2025-09-19 | 2025-09-19 | 0d |  |  | 5d | 0d |  |  | Code Bodies | Code Bodies,SI Transition | Transition | 6.11 | Matthew Breen |  | Green | GREEN | 135.71 |  |  |  |  |
| 2964 | 1.9.11.1.4.10 | MPRS, UMSO Role, LDSO Role Operational | milestone | 0d | 2025-09-19 | 2025-09-19 | 2985 |  |  | 2025-09-19 | 2025-09-19 | 0d |  |  | 5d | 0d |  |  | PP | SI Transition,PP | Transition | 6.11 | Matthew Breen |  | Green | GREEN | 135.71 |  |  |  |  |
| 2965 | 1.9.11.1.4.11 | Population of Domestic Premises Indicator | milestone | 0d | 2025-09-19 | 2025-09-19 | 2985 |  |  | 2025-09-19 | 2025-09-19 | 0d |  |  | 5d | 0d |  |  | PP,DCC,SI Transition | PP,DCC,SI Transition | Transition | 6.11 | Matthew Breen |  | Green | GREEN | 135.71 |  |  |  |  |
| 2966 | 1.9.11.1.4.12 | Population of Market Segment | milestone | 0d | 2025-09-19 | 2025-09-19 | 2985 |  |  | 2025-09-19 | 2025-09-19 | 0d |  |  | 5d | 0d |  |  | PP,SI Transition | PP,SI Transition | Transition | 6.11 | Matthew Breen |  | Green | GREEN | 135.71 |  |  |  |  |
| 2967 | 1.9.11.1.4.13 | Early Life Support Implemented | milestone | 0d | 2025-09-19 | 2025-09-19 | 2985 |  |  | 2025-09-19 | 2025-09-19 | 0d |  |  | 8d | 3d |  |  | SI Transition,Elexon,Central Services | SI Transition,Elexon,Central Services | Transition | 6.11 | Matthew Breen |  | Green | GREEN | 135.71 |  |  |  |  |
| 2968 | 1.9.11.1.4.14 | MCC Tested and Ready to Operate | milestone | 0d | 2025-09-19 | 2025-09-19 |  |  |  | 2025-09-19 | 2025-09-19 | 0d |  |  | 590d | 0d | start no earlier than 2025-09-19 |  | SI Migration | SI Migration | Transition | 6.11 | Matthew Breen |  | Green | GREEN | 135.33 |  |  |  | 1/7: To link into migration/service activation |
| 2969 | 1.9.11.1.4.15 | MCC Operational | milestone | 0d | 2025-09-19 | 2025-09-19 | 2968 |  |  | 2025-09-19 | 2025-09-19 | 0d |  |  | 590d |  |  |  | SI Migration | SI Migration | Transition | 6.11 | Matthew Breen |  | Green | GREEN | 135.33 |  |  |  | 1/7: To link into migration/service activation |
| 2970 | 1.8.4.1.4 | Central Systems live and Codes designated at 00:00 | milestone | 0d | 2025-09-22 | 2025-09-22 | 2960FS+1d, 2961FS+1d, 2962FS+1d, 2963FS+1d, 2964FS+1d, 2965FS+1d, 2966FS+1d, 2940FS+1d |  |  | 2025-09-22 | 2025-09-22 | 0d |  |  | 5d | 0d |  |  | SI Transition | SI Transition | Transition | 6.11 | Matthew Breen |  | Green | GREEN | 138.71 | T3-MI-0034 | MCAG (Transition) | T3 |  |
| 2971 | 1.9.11.1.4.17 | SIT Participant Qualification - The final date by which participant qualification status can be confirmed for participants to be ready for the start of Migration at M11. | milestone | 0d | 2025-09-26 | 2025-09-26 | 1763FS+25d |  |  | 2025-09-26 | 2025-09-26 | 0d |  |  | 20d | 15d |  |  | PP,Code Bodies,BSC PAB | SI Transition,PP,Code Bodies,BSC PAB | Transition | 6.11 | Matthew Breen |  | Green | GREEN | 142.71 |  |  |  |  |

Notes:
- 2933: 25/03/25 - Transition Design (which underpins the M16 criteria) industry consultation, closed on 14/03/25. An internal working group between the Programme and BSCCo is drafting a response and looking agree the approach to defining the M16 criteria.
- 2934: 25/03/25 - Transition Design (which underpins the M16 criteria) industry consultation, closed on 14/03/25. An internal working group between the Programme and BSCCo is drafting a response and looking agree the approach to defining the M16 criteria.
- 2935: 25/03/25 - Transition Design (which underpins the M16 criteria) industry consultation, closed on 14/03/25. An internal working group between the Programme and BSCCo is drafting a response and looking agree the approach to defining the M16 criteria.
- 2936: 25/03/25 - Transition Design (which underpins the M16 criteria) industry consultation, closed on 14/03/25. An internal working group between the Programme and BSCCo is drafting a response and looking agree the approach to defining the M16 criteria.
- 2937: 25/03/25 - Transition Design (which underpins the M16 criteria) industry consultation, closed on 14/03/25. An internal working group between the Programme and BSCCo is drafting a response and looking agree the approach to defining the M16 criteria.
- 2970: Guidance: 25/7/24: New Milestone approved at MCAG on 25/7/24. It was initially approved at MCAG on 4/6 but didn't follow the usual process so addded to July MCAG for noting

| ID | WBS | Task | Type | Duration | Start | Finish | Predecessors | Baseline start | Baseline finish | Baseline duration | Total slack | Free slack | Constraint | Responsible | Involved | Text9 | Task Status | Update Version | MHHS Resource Name | Sched Status | RAG | Milestone ID | Text29 | Tier |
| --- | --- | --- | --- | --- | --- | --- | --- | --- | --- | --- | --- | --- | --- | --- | --- | --- | --- | --- | --- | --- | --- | --- | --- | --- |
| 2972 | 1.9.11.2 | **Cutover Governance M10** |  | 17d | 2025-09-01 | 2025-09-24 |  | 2025-07-30 | 2025-09-24 | 27d | 7d |  |  | N/A | N/A | Transition | -595.67 | 6.11 | N/A |  |  |  |  |  |
| 2973 | 1.9.11.2.1 | Confirmation that all LDSOs have deployed MPRS 9 to production | milestone | 0d | 2025-09-01 | 2025-09-01 |  | 2025-09-01 | 2025-09-01 | 0d | 16d | 5d | finish no earlier than 2025-09-01 | SI Transition |  | Transition | 117.71 | 6.21 | Matthew Breen | Green | GREEN |  |  |  |
| 2974 | 1.9.11.2.2 | Confirmation that population of Domestic Premises Indicator is complete | milestone | 0d | 2025-09-08 | 2025-09-08 | 2973 | 2025-09-08 | 2025-09-08 | 0d | 11d | 1d | finish no earlier than 2025-09-08 | SI Transition |  | Transition | 124.71 | 6.21 | Matthew Breen | Green | GREEN |  |  |  |
| 2975 | 1.9.11.2.3 | Confirmation that Pre-migration Data Cleanse Activities have successfully taken place | milestone | 0d | 2025-09-10 | 2025-09-10 | 2974 | 2025-09-10 | 2025-09-10 | 0d | 10d | 5d | start no earlier than 2025-09-10 | PP | SI Transition,PP | Transition | 126.33 | 6.11 | Matthew Breen | Green | GREEN |  |  |  |
| 2976 | 1.9.11.2.4 | Confirmation that Market Segment has been populated for 95% of LDSO portfolios | milestone | 0d | 2025-09-12 | 2025-09-12 |  |  |  |  | 5d | 0d | finish no earlier than 2025-09-12 | SI Transition |  |  | 128.71 |  | Matthew Breen | No BL | GREEN |  |  |  |
| 2977 | 1.9.11.2.5 | Confirmation of Helix E2E Settlement Testing Complete | milestone | 0d | 2025-09-15 | 2025-09-15 | 2976 | 2025-09-15 | 2025-09-15 | 0d | 5d | 0d | start no earlier than 2025-09-15 | Helix |  | Transition | 131.33 | 6.11 | Matthew Breen | Green | GREEN |  |  |  |
| 2978 | 1.9.11.2.6 | Confirmation of assurance of Helix E2E Settlement Testing | milestone | 0d | 2025-09-15 | 2025-09-15 |  | 2025-09-15 | 2025-09-15 | 0d | 5d | 0d | start no earlier than 2025-09-15 | Helix |  | Transition | 131.33 | 6.11 | Matthew Breen | Green | GREEN |  |  |  |
| 2979 | 1.9.11.2.7 | Confirmation of Qualification Status for SIT MVC | milestone | 0d | 2025-09-15 | 2025-09-15 |  | 2025-09-15 | 2025-09-15 | 0d | 7d | 2d | start no earlier than 2025-09-15 | SIT MVC,Code Bodies | SI Transition,SIT MVC,Code Bodies | Transition | 131.33 | 6.11 | Matthew Breen | Green | GREEN |  |  |  |
| 2980 | 1.9.11.2.8 | Confirmation of Qualification Status for Non-SIT LDSOs | milestone | 0d | 2025-09-15 | 2025-09-15 |  | 2025-09-15 | 2025-09-15 | 0d | 5d | 0d | start no earlier than 2025-09-15 | PP,Code Bodies | SI Transition,PP,Code Bodies | Transition | 131.33 | 6.11 | Matthew Breen | Green | GREEN |  |  |  |
| 2981 | 1.9.11.2.9 | Confirmation of Qualification Status of at least one Supplier and their contracted Agents | milestone | 0d | 2025-09-15 | 2025-09-15 |  | 2025-09-15 | 2025-09-15 | 0d | 5d | 0d | start no earlier than 2025-09-15 | S&A Qualification | SI Transition,S&A Qualification | Transition | 131.33 | 6.11 | Matthew Breen | Green | GREEN |  |  |  |
| 2982 | 1.9.11.2.10 | Declaration from all Central Services and LDSOs that they are in a position to move forwards | milestone | 0d | 2025-09-15 | 2025-09-15 |  | 2025-09-15 | 2025-09-15 | 0d | 8d | 3d | start no earlier than 2025-09-15 | DIP Manager,Elexon,PP,Code Bodies | SI Transition,DIP Manager,Elexon,PP,Code Bodies | Transition | 131.33 | 6.11 | Matthew Breen | Green | GREEN |  |  |  |
| 2983 | 1.9.11.2.11 | Market-wide Participant MHHS Migration Supporting Functionality is Live | milestone | 0d | 2025-09-15 | 2025-09-15 |  | 2025-09-15 | 2025-09-15 | 0d | 8d | 3d | start no earlier than 2025-09-15 | Helix |  | Transition | 131.33 | 6.11 | Matthew Breen | Green | GREEN |  |  |  |
| 2984 | 1.9.11.2.12 | TORWG (Recommendation from TORWG that the Programme should enter M10) | milestone | 0d | 2025-09-17 | 2025-09-17 | 2975FS+1d, 2979FS+1d, 2981FS+3d, 2955FS+1d, 2956FS+1d, 3137FS+1d, 2977FS+3d, 2978FS+3d, 2980FS+3d, 2982, 2983 | 2025-09-17 | 2025-09-17 | 0d | 5d | 0d |  | SI Transition | SI Transition | Transition | 133.71 | 6.11 | Matthew Breen | Green | GREEN |  |  |  |
| 2985 | 1.8.4.1.4 | MCAG (Confirm that the Programme can Enter M10) | milestone | 0d | 2025-09-19 | 2025-09-19 | 2984FS+2d, 3143 | 2025-09-19 | 2025-09-19 | 0d | 5d | 0d |  | SI Migration | SI Transition,SI Migration | Transition | 135.71 | 6.11 | Matthew Breen | Green | GREEN | T3-MI-0035 | MCAG (Transition) | T3 |
| 2986 | 1.9.11.2.14 | Self-Declaration from all Central Services and LDSOs that Cutover activities have been successfully carried out | milestone | 0d | 2025-09-22 | 2025-09-22 | 2985FS+1d | 2025-09-22 | 2025-09-22 | 0d | 7d | 0d |  | PP,DCC,Code Bodies | SI Transition,PP,DCC,Code Bodies | Transition | 138.71 | 6.11 | Matthew Breen | Green | GREEN |  |  |  |
| 2987 | 1.9.11.2.15 | Confirmation that DIP and ECS have been deployed, Service management is active, ISD has been populated | milestone | 0d | 2025-09-22 | 2025-09-22 | 2985FS+1d | 2025-09-22 | 2025-09-22 | 0d | 7d | 0d |  | Elexon,DIP Manager | SI Transition,Elexon,DIP Manager | Transition | 138.71 | 6.11 | Matthew Breen | Green | GREEN |  |  |  |
| 2988 | 1.9.11.2.16 | Self-Declarations against all M10 Data Cleanse Activities | milestone | 0d | 2025-09-22 | 2025-09-22 | 2985FS+1d | 2025-09-22 | 2025-09-22 | 0d | 7d | 0d |  | PP | SI Transition,PP | Transition | 138.71 | 6.11 | Matthew Breen | Green | GREEN |  |  |  |
| 2989 | 1.9.11.2.17 | IF-047 has been sent | milestone | 0d | 2025-09-22 | 2025-09-22 | 2985FS+1d | 2025-09-22 | 2025-09-22 | 0d | 7d | 0d |  | ECS | SI Transition,ECS | Transition | 138.71 | 6.11 | Matthew Breen | Green | GREEN |  |  |  |
| 2990 | 1.9.11.2.18 | Recommendation from TORWG that PSG should approve M10 | milestone | 0d | 2025-09-23 | 2025-09-23 | 2986FS+1d, 2987FS+1d, 2988FS+1d, 2989FS+1d, 3141 | 2025-09-23 | 2025-09-23 | 0d | 7d | 0d |  | SI Transition | SI Transition | Transition | 139.71 | 6.11 | Matthew Breen | Green | GREEN |  |  |  |
| 2991 | 1.9.11.2.19 | PSG (OFGEM and PSG to Approve That Conditions of M10 and M13 Have Been Met) | milestone | 0d | 2025-09-24 | 2025-09-24 | 2990FS+1d | 2025-09-24 | 2025-09-24 | 0d | 7d | 0d |  | SI Transition,Ofgem | SI Transition,Ofgem | Transition | 140.71 | 6.11 | Matthew Breen | Green | GREEN |  |  |  |
| 2992 | 1.9.11.3 | **Cutover Governance M11** |  | 19d | 2025-09-26 | 2025-10-22 |  | 2025-09-26 | 2025-10-22 | 0d | 5d |  |  |  |  | Transition | -687.67 | 6.11 |  |  |  |  |  |  |
| 2993 | 1.9.11.3.1 | Confirmation of Qualified Parties from Code Bodies |  | 13d | 2025-09-26 | 2025-10-14 | 2991FS+1d, 2564 | 2025-09-26 | 2025-10-14 | 11d | 7d | 2d |  | Code Bodies,SIT Participants | SI Transition,Code Bodies,SIT Participants | Transition | 142.33 | 6.21 | Matthew Breen | Green | GREEN |  |  |  |
| 2994 | 1.9.11.3.2 | Self-Declaration that MHHS Functionality will be deployed to Production by Qualified parties | milestone | 0d | 2025-10-14 | 2025-10-14 | 2991FS+12d | 2025-10-14 | 2025-10-14 | 0d | 7d | 2d | finish no earlier than 2025-10-14 | PP | SI Transition,PP | Transition | 160.71 | 6.21 | Matthew Breen | Green | GREEN |  |  |  |
| 2995 | 1.9.11.3.3 | Production Service Activation Activities have taken place | milestone | 0d | 2025-10-14 | 2025-10-14 | 2991FS+12d | 2025-10-14 | 2025-10-14 | 0d | 7d | 2d | finish no earlier than 2025-10-14 | PP | SI Transition,PP | Transition | 160.71 | 6.21 | Matthew Breen | Green | GREEN |  |  |  |
| 2996 | 1.9.11.3.4 | TORWG (Confirmation of Qualified Parties from TORWG) | milestone | 0d | 2025-10-17 | 2025-10-17 | 2993FS+1d, 2994FS+1d, 2995FS+1d, 2971, 3138, 3142 | 2025-10-17 | 2025-10-17 | 0d | 5d | 0d | finish no earlier than 2025-10-17 | SI Transition | SI Transition | Transition | 163.71 | 6.21 | Matthew Breen | Green | GREEN |  |  |  |
| 2997 | 1.9.11.3.5 | MCAG (Provide recommendation to PSG on M11 decision) | milestone | 0d | 2025-10-20 | 2025-10-20 | 2996FS+1d | 2025-10-20 | 2025-10-20 | 0d | 5d | 0d | finish no earlier than 2025-10-20 | SI Migration | SI Transition,SI Migration | Transition | 166.71 | 6.21 | Matthew Breen | Green | GREEN | T3-MI-0036 | MCAG (Transition) | T3 |
| 2998 | 1.9.11.3.6 | PSG (OFGEM and PSG Decision to Confirm M11 and M12) | milestone | 0d | 2025-10-22 | 2025-10-22 | 2997FS+2d | 2025-10-22 | 2025-10-22 | 0d | 5d | 0d |  | SI Transition | SI Transition | Transition | 168.71 | 6.21 | Matthew Breen | Green | GREEN |  |  |  |

Notes:
- 2985: Guidance: 25/7/24: New Milestone approved at MCAG on 25/7/24. It was initially approved at MCAG on 4/6 but didn't follow the usual process so addded to July MCAG for noting
- 2995: Guidance: 12/8/24: Think this is covered in Service activation prep section below
- 2997: Guidance: 25/7/24: New Milestone approved at MCAG on 25/7/24. It was initially approved at MCAG on 4/6 but didn't follow the usual process so addded to July MCAG for noting

| ID | WBS | Task | Type | Duration | Start | Finish | Predecessors | Baseline start | Baseline finish | Baseline duration | Total slack | Free slack | Constraint | Responsible | Task Status | Update Version | Text9 | MHHS Resource Name | Sched Status | RAG | Milestone ID | Text29 | Tier |
| --- | --- | --- | --- | --- | --- | --- | --- | --- | --- | --- | --- | --- | --- | --- | --- | --- | --- | --- | --- | --- | --- | --- | --- |
| 2999 | 1.9.11.4 | **Migration Sprints** |  | 420d | 2025-09-25 | 2027-05-05 |  |  |  |  | 166d |  |  | SI Migration | -846.67 | 6.19 |  |  |  |  |  |  |  |
| 3000 | 1.9.11.4.1 | **Migration Sprint 0** |  | 94d | 2025-09-25 | 2026-02-03 |  | 2025-09-25 | 2026-02-03 | 0d | 492d |  |  | SI Migration | -833.67 | 6.18 | Migration | Warren Fulton |  |  |  |  |  |
| 3001 | 1.9.11.4.1.1 | Sprint 0 Planning start date |  | 6d | 2025-09-25 | 2025-10-02 |  | 2025-09-25 | 2025-10-02 | 0d | 492d | 0d | start no earlier than 2025-09-25 | SI Migration | 141.33 | 6.18 | Migration | Warren Fulton | Green | GREEN |  |  |  |
| 3002 | 1.9.11.4.1.2 | Issue Envelope | milestone | 0d | 2025-10-02 | 2025-10-02 | 3001 | 2025-10-02 | 2025-10-02 | 0d | 492d | 0d |  | SI Migration | 148.71 | 6.18 | Migration | Warren Fulton | Green | GREEN |  |  |  |
| 3003 | 1.9.11.4.1.3 | Supplier Submission Deadline | milestone | 0d | 2025-10-09 | 2025-10-09 | 3002FS+5d | 2025-10-09 | 2025-10-09 | 0d | 492d | 0d |  | SI Migration, SIT PP | 155.71 | 6.18 | Migration | Warren Fulton | Green | GREEN |  |  |  |
| 3004 | 1.9.11.4.1.4 | Baseline Schedule Publication | milestone | 0d | 2025-10-16 | 2025-10-16 | 3003FS+5d | 2025-10-16 | 2025-10-16 | 0d | 492d | 0d |  | SI Migration | 162.71 | 6.18 | Migration | Warren Fulton | Green | GREEN |  |  |  |
| 3005 | 1.9.11.4.1.5 | Migration Sprint 0 Schedule Baselined | milestone | 0d | 2025-10-16 | 2025-10-16 | 3004 | 2025-10-16 | 2025-10-16 | 0d | 492d | 0d |  | SI Migration | 162.71 | 6.18 | Migration | Warren Fulton | Green | GREEN | T2-MI-8000 | MCAG (Migration) | T2 |
| 3006 | 1.9.11.4.1.6 | Sprint Execution Start | milestone | 0d | 2025-10-23 | 2025-10-23 | 3005FS+5d, 3143, 3098 | 2025-10-23 | 2025-10-23 | 0d | 492d | 0d |  | SI Migration | 169.71 | 6.18 | Migration | Warren Fulton | Green | GREEN |  |  | T2 |
| 3007 | 1.9.11.4.1.7 | Sprint Execution |  | 73d | 2025-10-24 | 2026-02-03 | 3006 | 2025-10-24 | 2026-02-03 | 0d | 492d | 0d |  | SI Migration, SIT PP | 170.33 | 6.18 | Migration | Warren Fulton | Green | GREEN |  |  |  |
| 3008 | 1.9.11.4.1.8 | Sprint Execution End | milestone | 0d | 2026-02-03 | 2026-02-03 | 3007 | 2026-02-03 | 2026-02-03 | 0d | 492d |  |  | SI Migration | 272.71 | 6.18 | Migration | Warren Fulton | Green | GREEN |  |  |  |
| 3009 | 1.9.11.4.2 | **Migration Sprint 1** |  | 60d | 2026-01-07 | 2026-03-31 |  | 2026-01-07 | 2026-03-31 | 0d | 452d |  |  | SI Migration | -833.67 | 6.18 | Migration | Warren Fulton |  |  |  |  |  |
| 3010 | 1.9.11.4.2.1 | Sprint 1 Planning start date |  | 6d | 2026-01-07 | 2026-01-14 |  | 2026-01-07 | 2026-01-14 | 0d | 452d | 0d | start no earlier than 2026-01-07 | SI Migration | 245.33 | 6.18 | Migration | Warren Fulton | Green | GREEN |  |  |  |
| 3011 | 1.9.11.4.2.2 | Issue Envelope | milestone | 0d | 2026-01-14 | 2026-01-14 | 3010 | 2026-01-14 | 2026-01-14 | 0d | 452d | 0d |  | SI Migration | 252.71 | 6.18 | Migration | Warren Fulton | Green | GREEN |  |  |  |
| 3012 | 1.9.11.4.2.3 | Supplier Submission Deadline | milestone | 0d | 2026-01-21 | 2026-01-21 | 3011FS+5d | 2026-01-21 | 2026-01-21 | 0d | 452d | 0d |  | SI Migration, SIT PP | 259.71 | 6.18 | Migration | Warren Fulton | Green | GREEN |  |  |  |
| 3013 | 1.9.11.4.2.4 | Baseline Schedule Publication | milestone | 0d | 2026-01-28 | 2026-01-28 | 3012FS+5d | 2026-01-28 | 2026-01-28 | 0d | 452d | 0d |  | SI Migration | 266.71 | 6.18 | Migration | Warren Fulton | Green | GREEN |  |  |  |
| 3014 | 1.9.11.4.2.5 | Migration Sprint 1 Schedule Baselined | milestone | 0d | 2026-01-28 | 2026-01-28 | 3013 | 2026-01-28 | 2026-01-28 | 0d | 452d | 0d |  | SI Migration | 266.71 | 6.18 | Migration | Warren Fulton | Green | GREEN |  |  |  |
| 3015 | 1.9.11.4.2.6 | Sprint Execution Start | milestone | 0d | 2026-02-04 | 2026-02-04 | 3014FS+5d | 2026-02-04 | 2026-02-04 | 0d | 452d | 0d |  | SI Migration | 273.71 | 6.18 | Migration | Warren Fulton | Green | GREEN |  |  |  |
| 3016 | 1.9.11.4.2.7 | Sprint Execution |  | 39d | 2026-02-05 | 2026-03-31 | 3015 | 2026-02-05 | 2026-03-31 | 0d | 452d | 0d |  | SI Migration, SIT PP | 274.33 | 6.18 | Migration | Warren Fulton | Green | GREEN |  |  |  |
| 3017 | 1.9.11.4.2.8 | Sprint Execution End | milestone | 0d | 2026-03-31 | 2026-03-31 | 3016 | 2026-03-31 | 2026-03-31 | 0d | 452d |  |  | SI Migration | 328.71 | 6.18 | Migration | Warren Fulton | Green | GREEN |  |  |  |
| 3018 | 1.9.11.4.3 | **Migration Sprint 2** |  | 65d | 2026-03-04 | 2026-06-02 |  | 2026-03-04 | 2026-06-02 | 0d | 407d |  |  | SI Migration | -833.67 | 6.18 | Migration | Warren Fulton |  |  |  |  |  |
| 3019 | 1.9.11.4.3.1 | Sprint 2 Planning start date |  | 6d | 2026-03-04 | 2026-03-11 |  | 2026-03-04 | 2026-03-11 | 0d | 407d | 0d | start no earlier than 2026-03-04 | SI Migration | 301.33 | 6.18 | Migration | Warren Fulton | Green | GREEN |  |  |  |
| 3020 | 1.9.11.4.3.2 | Issue Envelope | milestone | 0d | 2026-03-11 | 2026-03-11 | 3019 | 2026-03-11 | 2026-03-11 | 0d | 407d | 0d |  | SI Migration, PP | 308.71 | 6.18 | Migration | Warren Fulton | Green | GREEN |  |  |  |
| 3021 | 1.9.11.4.3.3 | Supplier Submission Deadline | milestone | 0d | 2026-03-18 | 2026-03-18 | 3020FS+5d | 2026-03-18 | 2026-03-18 | 0d | 407d | 0d |  | SI Migration | 315.71 | 6.18 | Migration | Warren Fulton | Green | GREEN |  |  |  |
| 3022 | 1.9.11.4.3.4 | Baseline Schedule Publication | milestone | 0d | 2026-03-25 | 2026-03-25 | 3021FS+5d | 2026-03-25 | 2026-03-25 | 0d | 407d | 0d |  | SI Migration | 322.71 | 6.18 | Migration | Warren Fulton | Green | GREEN |  |  |  |
| 3023 | 1.9.11.4.3.5 | Migration Sprint 2 Schedule Baselined | milestone | 0d | 2026-03-25 | 2026-03-25 | 3022 | 2026-03-25 | 2026-03-25 | 0d | 407d | 0d |  | SI Migration | 322.71 | 6.18 | Migration | Warren Fulton | Green | GREEN |  |  |  |
| 3024 | 1.9.11.4.3.6 | Sprint Execution Start | milestone | 0d | 2026-04-01 | 2026-04-01 | 3023FS+5d | 2026-04-01 | 2026-04-01 | 0d | 407d | 0d |  | SI Migration | 329.71 | 6.18 | Migration | Warren Fulton | Green | GREEN |  |  |  |
| 3025 | 1.9.11.4.3.7 | Sprint Execution |  | 44d | 2026-04-02 | 2026-06-02 | 3024 | 2026-04-02 | 2026-06-02 | 0d | 407d | 0d |  | SI Migration, PP | 330.33 | 6.18 | Migration | Warren Fulton | Green | GREEN |  |  |  |
| 3026 | 1.9.11.4.3.8 | Non-SIT Participants Migration Start | milestone | 0d | 2026-05-15 | 2026-05-15 | 3182FS+1d | 2026-05-15 | 2026-05-15 | 0d | 419d |  |  | SI Migration | 373.71 | 6.18 | Migration | Warren Fulton | Green | GREEN | T2-MI-8500 | MCAG (Migration) | T2 |
| 3027 | 1.9.11.4.3.9 | Sprint Execution End | milestone | 0d | 2026-06-02 | 2026-06-02 | 3025 | 2026-06-02 | 2026-06-02 | 0d | 407d |  |  | SI Migration | 391.71 | 6.18 | Migration | Warren Fulton | Green | GREEN |  |  |  |

| ID | WBS | Task | Type | Duration | Start | Finish | Predecessors | Baseline start | Baseline finish | Baseline duration | Total slack | Free slack | Constraint | Responsible | Text9 | Task Status | Update Version | MHHS Resource Name | Sched Status | RAG |
| --- | --- | --- | --- | --- | --- | --- | --- | --- | --- | --- | --- | --- | --- | --- | --- | --- | --- | --- | --- | --- |
| 3028 | 1.9.11.4.4 | **Migration Sprint 3** |  | 65d | 2026-05-06 | 2026-08-04 |  | 2026-05-06 | 2026-08-04 | 0d | 362d |  |  | SI Migration | Migration | -833.67 | 6.20 | Warren Fulton |  |  |
| 3029 | 1.9.11.4.4.1 | Sprint 3 Planning start date |  | 6d | 2026-05-06 | 2026-05-13 |  | 2026-05-06 | 2026-05-13 | 0d | 362d | 0d | start no earlier than 2026-05-06 | SI Migration | Migration | 364.33 | 6.20 | Warren Fulton | Green | GREEN |
| 3030 | 1.9.11.4.4.2 | Issue Envelope | milestone | 0d | 2026-05-13 | 2026-05-13 | 3029 | 2026-05-13 | 2026-05-13 | 0d | 362d | 0d |  | SI Migration, PP | Migration | 371.71 | 6.20 | Warren Fulton | Green | GREEN |
| 3031 | 1.9.11.4.4.3 | Supplier Submission Deadline | milestone | 0d | 2026-05-20 | 2026-05-20 | 3030FS+5d | 2026-05-20 | 2026-05-20 | 0d | 362d | 0d |  | SI Migration | Migration | 378.71 | 6.20 | Warren Fulton | Green | GREEN |
| 3032 | 1.9.11.4.4.4 | Baseline Schedule Publication | milestone | 0d | 2026-05-27 | 2026-05-27 | 3031FS+5d | 2026-05-27 | 2026-05-27 | 0d | 362d | 0d |  | SI Migration | Migration | 385.71 | 6.20 | Warren Fulton | Green | GREEN |
| 3033 | 1.9.11.4.4.5 | Migration Sprint 3 Schedule Baselined | milestone | 0d | 2026-05-27 | 2026-05-27 | 3032 | 2026-05-27 | 2026-05-27 | 0d | 362d | 0d |  | SI Migration | Migration | 385.71 | 6.20 | Warren Fulton | Green | GREEN |
| 3034 | 1.9.11.4.4.6 | Sprint Execution Start | milestone | 0d | 2026-06-03 | 2026-06-03 | 3033FS+5d | 2026-06-03 | 2026-06-03 | 0d | 362d | 0d |  | SI Migration | Migration | 392.71 | 6.20 | Warren Fulton | Green | GREEN |
| 3035 | 1.9.11.4.4.7 | Sprint Execution |  | 44d | 2026-06-04 | 2026-08-04 | 3034 | 2026-06-04 | 2026-08-04 | 0d | 362d | 0d |  | SI Migration, PP | Migration | 393.33 | 6.20 | Warren Fulton | Green | GREEN |
| 3036 | 1.9.11.4.4.8 | Sprint Execution End | milestone | 0d | 2026-08-04 | 2026-08-04 | 3035 | 2026-08-04 | 2026-08-04 | 0d | 362d |  |  | SI Migration | Migration | 454.71 | 6.20 | Warren Fulton | Green | GREEN |
| 3037 | 1.9.11.4.5 | **Migration Sprint 4** |  | 65d | 2026-07-08 | 2026-10-06 |  | 2026-07-08 | 2026-10-06 | 0d | 317d |  |  | SI Migration | Migration | -833.67 | 6.18 | Warren Fulton |  |  |
| 3038 | 1.9.11.4.5.1 | Sprint 4 Planning start date |  | 6d | 2026-07-08 | 2026-07-15 |  | 2026-07-08 | 2026-07-15 | 0d | 317d | 0d | start no earlier than 2026-07-08 | SI Migration | Migration | 427.33 | 6.18 | Warren Fulton | Green | GREEN |
| 3039 | 1.9.11.4.5.2 | Issue Envelope | milestone | 0d | 2026-07-15 | 2026-07-15 | 3038 | 2026-07-15 | 2026-07-15 | 0d | 317d | 0d |  | SI Migration, PP | Migration | 434.71 | 6.18 | Warren Fulton | Green | GREEN |
| 3040 | 1.9.11.4.5.3 | Supplier Submission Deadline | milestone | 0d | 2026-07-22 | 2026-07-22 | 3039FS+5d | 2026-07-22 | 2026-07-22 | 0d | 317d | 0d |  | SI Migration | Migration | 441.71 | 6.18 | Warren Fulton | Green | GREEN |
| 3041 | 1.9.11.4.5.4 | Baseline Schedule Publication | milestone | 0d | 2026-07-29 | 2026-07-29 | 3040FS+5d | 2026-07-29 | 2026-07-29 | 0d | 317d | 0d |  | SI Migration | Migration | 448.71 | 6.18 | Warren Fulton | Green | GREEN |
| 3042 | 1.9.11.4.5.5 | Migration Sprint 4 Schedule Baselined | milestone | 0d | 2026-07-29 | 2026-07-29 | 3041 | 2026-07-29 | 2026-07-29 | 0d | 317d | 0d |  | SI Migration | Migration | 448.71 | 6.18 | Warren Fulton | Green | GREEN |
| 3043 | 1.9.11.4.5.6 | Sprint Execution Start | milestone | 0d | 2026-08-05 | 2026-08-05 | 3042FS+5d | 2026-08-05 | 2026-08-05 | 0d | 317d | 0d |  | SI Migration | Migration | 455.71 | 6.18 | Warren Fulton | Green | GREEN |
| 3044 | 1.9.11.4.5.7 | Sprint Execution |  | 44d | 2026-08-06 | 2026-10-06 | 3043 | 2026-08-06 | 2026-10-06 | 0d | 317d | 0d |  | SI Migration, PP | Migration | 456.33 | 6.18 | Warren Fulton | Green | GREEN |
| 3045 | 1.9.11.4.5.8 | Sprint Execution End | milestone | 0d | 2026-10-06 | 2026-10-06 | 3044 | 2026-10-06 | 2026-10-06 | 0d | 317d |  |  | SI Migration | Migration | 517.71 | 6.18 | Warren Fulton | Green | GREEN |
| 3046 | 1.9.11.4.6 | **Migration Sprint 5** |  | 60d | 2026-09-09 | 2026-12-01 |  | 2026-09-09 | 2026-12-01 | 0d | 277d |  |  | SI Migration | Migration | -833.67 | 6.18 | Warren Fulton |  |  |
| 3047 | 1.9.11.4.6.1 | Sprint 5 Planning start date |  | 6d | 2026-09-09 | 2026-09-16 |  | 2026-09-09 | 2026-09-16 | 0d | 277d | 0d | start no earlier than 2026-09-09 | SI Migration | Migration | 490.33 | 6.18 | Warren Fulton | Green | GREEN |
| 3048 | 1.9.11.4.6.2 | Issue Envelope | milestone | 0d | 2026-09-16 | 2026-09-16 | 3047 | 2026-09-16 | 2026-09-16 | 0d | 277d | 0d |  | SI Migration, PP | Migration | 497.71 | 6.18 | Warren Fulton | Green | GREEN |
| 3049 | 1.9.11.4.6.3 | Supplier Submission Deadline | milestone | 0d | 2026-09-23 | 2026-09-23 | 3048FS+5d | 2026-09-23 | 2026-09-23 | 0d | 277d | 0d |  | SI Migration | Migration | 504.71 | 6.18 | Warren Fulton | Green | GREEN |
| 3050 | 1.9.11.4.6.4 | Baseline Schedule Publication | milestone | 0d | 2026-09-30 | 2026-09-30 | 3049FS+5d | 2026-09-30 | 2026-09-30 | 0d | 277d | 0d |  | SI Migration | Migration | 511.71 | 6.18 | Warren Fulton | Green | GREEN |
| 3051 | 1.9.11.4.6.5 | Migration Sprint 5 Schedule Baselined | milestone | 0d | 2026-09-30 | 2026-09-30 | 3050 | 2026-09-30 | 2026-09-30 | 0d | 277d | 0d |  | SI Migration | Migration | 511.71 | 6.18 | Warren Fulton | Green | GREEN |
| 3052 | 1.9.11.4.6.6 | Sprint Execution Start | milestone | 0d | 2026-10-07 | 2026-10-07 | 3051FS+5d | 2026-10-07 | 2026-10-07 | 0d | 277d | 0d |  | SI Migration | Migration | 518.71 | 6.18 | Warren Fulton | Green | GREEN |
| 3053 | 1.9.11.4.6.7 | Sprint Execution |  | 39d | 2026-10-08 | 2026-12-01 | 3052 | 2026-10-08 | 2026-12-01 | 0d | 277d | 0d |  | SI Migration, PP | Migration | 519.33 | 6.18 | Warren Fulton | Green | GREEN |
| 3054 | 1.9.11.4.6.8 | Sprint Execution End | milestone | 0d | 2026-12-01 | 2026-12-01 | 3053 | 2026-12-01 | 2026-12-01 | 0d | 277d |  |  | SI Migration | Migration | 573.71 | 6.18 | Warren Fulton | Green | GREEN |

| ID | WBS | Task | Type | Duration | Start | Finish | Predecessors | Baseline start | Baseline finish | Baseline duration | Total slack | Free slack | Constraint | Responsible | Text9 | Task Status | Update Version | MHHS Resource Name | Sched Status | RAG | Milestone ID | Text29 | Tier |
| --- | --- | --- | --- | --- | --- | --- | --- | --- | --- | --- | --- | --- | --- | --- | --- | --- | --- | --- | --- | --- | --- | --- | --- |
| 3055 | 1.9.11.4.7 | **Migration Sprint 6** |  | 65d | 2026-11-04 | 2027-02-02 |  | 2026-11-04 | 2027-02-02 | 0d | 232d |  |  | SI Migration | Migration | -833.67 | 6.18 | Warren Fulton |  |  |  |  |  |
| 3056 | 1.9.11.4.7.1 | Sprint 6 Planning start date |  | 6d | 2026-11-04 | 2026-11-11 |  | 2026-11-04 | 2026-11-11 | 0d | 232d | 0d | start no earlier than 2026-11-04 | SI Migration | Migration | 546.33 | 6.18 | Warren Fulton | Green | GREEN |  |  |  |
| 3057 | 1.9.11.4.7.2 | Issue Envelope | milestone | 0d | 2026-11-11 | 2026-11-11 | 3056 | 2026-11-11 | 2026-11-11 | 0d | 232d | 0d |  | SI Migration, PP | Migration | 553.71 | 6.18 | Warren Fulton | Green | GREEN |  |  |  |
| 3058 | 1.9.11.4.7.3 | Supplier Submission Deadline | milestone | 0d | 2026-11-18 | 2026-11-18 | 3057FS+5d | 2026-11-18 | 2026-11-18 | 0d | 232d | 0d |  | SI Migration | Migration | 560.71 | 6.18 | Warren Fulton | Green | GREEN |  |  |  |
| 3059 | 1.9.11.4.7.4 | Baseline Schedule Publication | milestone | 0d | 2026-11-25 | 2026-11-25 | 3058FS+5d | 2026-11-25 | 2026-11-25 | 0d | 232d | 0d |  | SI Migration | Migration | 567.71 | 6.18 | Warren Fulton | Green | GREEN |  |  |  |
| 3060 | 1.9.11.4.7.5 | Migration Sprint 6 Schedule Baselined | milestone | 0d | 2026-11-25 | 2026-11-25 | 3059 | 2026-11-25 | 2026-11-25 | 0d | 232d | 0d |  | SI Migration | Migration | 567.71 | 6.18 | Warren Fulton | Green | GREEN |  |  |  |
| 3061 | 1.9.11.4.7.6 | Sprint Execution Start | milestone | 0d | 2026-12-02 | 2026-12-02 | 3060FS+5d | 2026-12-02 | 2026-12-02 | 0d | 232d | 0d |  | SI Migration | Migration | 574.71 | 6.18 | Warren Fulton | Green | GREEN |  |  |  |
| 3062 | 1.9.11.4.7.7 | Sprint Execution |  | 44d | 2026-12-03 | 2027-02-02 | 3061 | 2026-12-03 | 2027-02-02 | 0d | 232d | 0d |  | SI Migration, PP | Migration | 575.33 | 6.18 | Warren Fulton | Green | GREEN |  |  |  |
| 3063 | 1.9.11.4.7.8 | Sprint Execution End | milestone | 0d | 2027-02-02 | 2027-02-02 | 3062 | 2027-02-02 | 2027-02-02 | 0d | 232d |  |  | SI Migration | Migration | 636.71 | 6.18 | Warren Fulton | Green | GREEN |  |  |  |
| 3064 | 1.9.11.4.8 | **Migration Sprint 7** |  | 65d | 2027-01-06 | 2027-04-06 |  | 2027-01-06 | 2027-04-06 | 0d | 187d |  |  | SI Migration | Migration | -833.67 | 6.18 | Warren Fulton |  |  |  |  |  |
| 3065 | 1.9.11.4.8.1 | Sprint 6 Planning start date |  | 6d | 2027-01-06 | 2027-01-13 |  | 2027-01-06 | 2027-01-13 | 0d | 187d | 0d | start no earlier than 2027-01-06 | SI Migration | Migration | 609.33 | 6.18 | Warren Fulton | Green | GREEN |  |  |  |
| 3066 | 1.9.11.4.8.2 | Issue Envelope | milestone | 0d | 2027-01-13 | 2027-01-13 | 3065 | 2027-01-13 | 2027-01-13 | 0d | 187d | 0d |  | SI Migration, PP | Migration | 616.71 | 6.18 | Warren Fulton | Green | GREEN |  |  |  |
| 3067 | 1.9.11.4.8.3 | Supplier Submission Deadline | milestone | 0d | 2027-01-20 | 2027-01-20 | 3066FS+5d | 2027-01-20 | 2027-01-20 | 0d | 187d | 0d |  | SI Migration | Migration | 623.71 | 6.18 | Warren Fulton | Green | GREEN |  |  |  |
| 3068 | 1.9.11.4.8.4 | Baseline Schedule Publication | milestone | 0d | 2027-01-27 | 2027-01-27 | 3067FS+5d | 2027-01-27 | 2027-01-27 | 0d | 187d | 0d |  | SI Migration | Migration | 630.71 | 6.18 | Warren Fulton | Green | GREEN |  |  |  |
| 3069 | 1.9.11.4.8.5 | Migration Sprint 7 Schedule Baselined | milestone | 0d | 2027-01-27 | 2027-01-27 | 3068 | 2027-01-27 | 2027-01-27 | 0d | 187d | 0d |  | SI Migration | Migration | 630.71 | 6.18 | Warren Fulton | Green | GREEN |  |  |  |
| 3070 | 1.9.11.4.8.6 | Sprint Execution Start | milestone | 0d | 2027-02-03 | 2027-02-03 | 3069FS+5d | 2027-02-03 | 2027-02-03 | 0d | 187d | 0d |  | SI Migration | Migration | 637.71 | 6.18 | Warren Fulton | Green | GREEN |  |  |  |
| 3071 | 1.9.11.4.8.7 | Sprint Execution |  | 44d | 2027-02-04 | 2027-04-06 | 3070 | 2027-02-04 | 2027-04-06 | 0d | 187d | 0d |  | SI Migration, PP | Migration | 638.33 | 6.18 | Warren Fulton | Green | GREEN |  |  |  |
| 3072 | 1.9.11.4.8.8 | Sprint Execution End | milestone | 0d | 2027-04-06 | 2027-04-06 | 3071 | 2027-04-06 | 2027-04-06 | 0d | 187d |  |  | SI Migration | Migration | 699.71 | 6.18 | Warren Fulton | Green | GREEN |  |  |  |
| 3073 | 1.9.11.4.9 | **Migration Sprint 8** |  | 48d | 2027-03-01 | 2027-05-05 |  | 2027-03-01 | 2027-05-05 | 0d | 0d |  |  | SI Migration | Migration | -833.67 | 6.18 | Warren Fulton |  |  |  |  |  |
| 3074 | 1.9.11.4.9.1 | Sprint 8 Planning start date |  | 6d | 2027-03-01 | 2027-03-08 |  | 2027-03-01 | 2027-03-08 | 0d | 0d |  | start no earlier than 2027-03-01 | SI Migration | Migration | 663.33 | 6.18 | Warren Fulton | Green | GREEN |  |  |  |
| 3075 | 1.9.11.4.9.2 | Issue Envelope | milestone | 0d | 2027-03-08 | 2027-03-08 | 3074 | 2027-03-08 | 2027-03-08 | 0d | 0d |  |  | SI Migration, PP | Migration | 670.71 | 6.18 | Warren Fulton | Green | GREEN |  |  |  |
| 3076 | 1.9.11.4.9.3 | Supplier Submission Deadline | milestone | 0d | 2027-03-15 | 2027-03-15 | 3075FS+5d | 2027-03-15 | 2027-03-15 | 0d | 0d |  |  | SI Migration | Migration | 677.71 | 6.18 | Warren Fulton | Green | GREEN |  |  |  |
| 3077 | 1.9.11.4.9.4 | Baseline Schedule Publication | milestone | 0d | 2027-03-22 | 2027-03-22 | 3076FS+5d | 2027-03-22 | 2027-03-22 | 0d | 0d |  |  | SI Migration | Migration | 684.71 | 6.18 | Warren Fulton | Green | GREEN |  |  |  |
| 3078 | 1.9.11.4.9.5 | Migration Sprint 8 Schedule Baselined | milestone | 0d | 2027-03-22 | 2027-03-22 | 3077 | 2027-03-22 | 2027-03-22 | 0d | 0d |  |  | SI Migration | Migration | 684.71 | 6.18 | Warren Fulton | Green | GREEN |  |  |  |
| 3079 | 1.9.11.4.9.6 | Sprint Execution Start | milestone | 0d | 2027-03-29 | 2027-03-29 | 3078FS+5d | 2027-03-29 | 2027-03-29 | 0d | 0d |  |  | SI Migration | Migration | 691.71 | 6.18 | Warren Fulton | Green | GREEN |  |  |  |
| 3080 | 1.9.11.4.9.7 | Sprint Execution |  | 27d | 2027-03-30 | 2027-05-05 | 3079 | 2027-03-30 | 2027-05-05 | 0d | 0d |  |  | SI Migration, PP | Migration | 692.33 | 6.18 | Warren Fulton | Green | GREEN |  |  |  |
| 3081 | 1.9.11.4.9.8 | Sprint Execution End | milestone | 0d | 2027-05-05 | 2027-05-05 | 3080 | 2027-05-05 | 2027-05-05 | 0d | 0d |  |  | SI Migration | Migration | 728.71 | 6.18 | Warren Fulton | Green | GREEN | T2-MI-9000 | MCAG (Migration) | T2 |

| ID | WBS | Task | Type | Duration | Start | Finish | Predecessors | Complete | Remaining | Baseline start | Baseline finish | Baseline duration | Baseline 1 start | Baseline 1 finish | Total slack | Free slack | Constraint | Baseline cost | Responsible | Involved | Text9 | Update Version | MHHS Resource Name | MHHS Programme Phase | Sched Status | RAG | Task Status | Milestone ID | Text29 | Tier | Future RAG |
| --- | --- | --- | --- | --- | --- | --- | --- | --- | --- | --- | --- | --- | --- | --- | --- | --- | --- | --- | --- | --- | --- | --- | --- | --- | --- | --- | --- | --- | --- | --- | --- |
| 3082 | 1.9.12 | **External Programme Dependency Management** |  | 740d | 2022-10-31 A | 2025-08-29 |  | 66% | 253.44d | 2022-10-31 | 2025-08-29 | 827d | 2022-10-31 | 2025-07-01 | 604d |  |  | -0 | N/A | N/A | Transition | 5.0 | N/A | Migration |  |  |  |  |  |  |  |
| 3083 | 1.9.12.1 | **BSC Mod P432 & REC CP R0015** |  | 392d | 2022-10-31 A | 2024-04-30 A |  | 100% |  | 2022-10-31 | 2024-04-30 | 827d | 2022-10-31 | 2025-07-01 |  |  |  | -0 | N/A | N/A | Transition | 5.0 | N/A | Migration |  |  |  |  |  |  |  |
| 3084 | 1.9.12.1.1 | MHHSP engagement with BSCCo until Ofgem decision |  | 316d | 2022-10-31 A | 2024-01-15 A |  | 100% |  | 2022-10-31 | 2024-01-15 | 400d | 2022-10-31 | 2022-12-30 |  |  |  |  | CPT,SRO Function | Code Bodies | Transition | 5.0 | MHHS Programme | Migration | Complete | COMPLETE |  |  |  |  |  |
| 3085 | 1.9.12.1.2 | Monitor progress and await implementation date |  | 76d | 2024-01-16 A | 2024-04-30 A | 3084 | 100% |  | 2024-01-16 | 2024-04-30 | 652d | 2023-01-02 | 2025-07-01 |  |  |  |  | CPT,SRO Function | Code Bodies | Transition | 5.0 | MHHS Programme | Migration | Complete | COMPLETE |  |  |  |  |  |
| 3086 | 1.9.12.2 | **BSC Mod P434** |  | 713d | 2022-10-31 A | 2025-07-23 |  | 57% | 310d | 2022-10-31 | 2025-07-23 | 713d | 2022-10-31 | 2025-07-01 | 631d |  |  |  | N/A | N/A | Transition | 5.0 | N/A | Migration |  |  |  |  |  |  |  |
| 3087 | 1.9.12.2.1 | MHHSP engagement with BSCCo until Ofgem decision |  | 61d | 2022-10-31 A | 2023-01-23 A |  | 100% |  | 2022-10-31 | 2023-01-23 | 61d | 2022-10-31 | 2022-12-30 |  |  |  |  | CPT,SRO Function | Code Bodies | Transition | 5.0 | MHHS Programme | Migration | Complete | COMPLETE |  |  |  |  |  |
| 3088 | 1.9.12.2.2 | Monitor progress and await implementation date |  | 652d | 2023-01-24 A | 2025-07-23 | 3087 | 52% | 310d | 2023-01-24 | 2025-07-23 | 652d | 2023-01-02 | 2025-07-01 | 631d |  |  |  | CPT,SRO Function | Code Bodies | Transition | 5.0 | MHHS Programme | Migration | Green | GREEN |  |  |  |  |  |
| 3089 | 1.9.12.3 | **Elexon System Capacity Upgrade** |  | 697d | 2022-10-31 A | 2025-07-01 |  | 58% | 294d | 2022-10-31 | 2025-07-01 | 697d | 2022-10-31 | 2025-07-01 | 647d |  |  |  | N/A | N/A | Transition | 5.0 | N/A | Migration |  |  |  |  |  |  |  |
| 3090 | 1.9.12.3.1 | Monitor progress to implementation |  | 697d | 2022-10-31 A | 2025-07-01 |  | 58% | 294d | 2022-10-31 | 2025-07-01 | 697d | 2022-10-31 | 2025-07-01 | 647d | 0d |  |  | SI Migration | PP | Transition | 5.0 | MHHS Programme | Migration | Green | GREEN |  |  |  |  |  |
| 3091 | 1.9.12.3.2 | Implementation date | milestone | 0d | 2025-07-01 | 2025-07-01 | 3090 |  |  | 2025-07-01 | 2025-07-01 | 0d | 2025-07-01 | 2025-07-01 | 647d |  |  |  | PP | SI Migration | Transition | 5.0 | MHHS Programme | Migration | Green | GREEN | 55.71 |  |  |  |  |
| 3092 | 1.9.12.4 | **DCC System Capacity Upgrade** |  | 25d | 2025-07-28 | 2025-08-29 |  |  |  | 2025-07-28 | 2025-08-29 | 25d | 2025-01-13 | 2025-02-14 | 604d |  |  |  | N/A | N/A | Transition | 5.0 | N/A | Migration |  |  |  |  |  |  |  |
| 3093 | 1.9.12.4.1 | Assurance of DCC capacity upgrade to ensure suitability to support migration |  | 20d | 2025-07-28 | 2025-08-22 | 1938FF-23d |  |  | 2025-07-28 | 2025-08-22 | 20d | 2025-01-13 | 2025-02-07 | 604d | 0d |  |  | SI Migration | PP | Transition | 5.0 | MHHS Programme | Migration | Green | GREEN | 82.33 |  |  |  |  |
| 3094 | 1.9.12.4.2 | DCC Capacity Upgrade Operational | milestone | 0d | 2025-08-29 | 2025-08-29 | 3093FS+5d |  |  | 2025-08-29 | 2025-08-29 | 0d | 2025-02-14 | 2025-02-14 | 604d |  |  |  | PP | SI Migration,IPA | Transition | 5.0 | MHHS Programme | Migration | Green | GREEN | 114.71 | T2-MI-0350 | MCAG | T2 |  |
| 3095 | 1.9.13 | **Migration - Tier 1 Milestones** |  | 488d | 2025-09-24 | 2027-08-09 |  |  |  | 2025-09-24 | 2027-08-09 | 477d | 2025-03-07 | 2027-01-05 | 25d |  |  |  | N/A | N/A | Transition | 5.0 | N/A | Migration |  |  |  |  |  |  |  |
| 3096 | 1.9.13.1 | Load Shaping Service switched on (M13) | milestone | 0d | 2025-09-24 | 2025-09-24 | 1938 |  |  | 2025-09-24 | 2025-09-24 | 0d | 2025-03-07 | 2025-03-07 | 25d | 0d |  |  | CPT | CPT | Transition | 6.1 | CPT | Migration | Green | GREEN | 140.71 | T1-MI-2000 | PSG | T1 | Load Shaping Service switched on |
| 3097 | 1.9.13.2 | Load Shaping Service switched on (M13*) - Late Exit | milestone | 0d | 2025-12-24 | 2025-12-24 | 3096FS+65d |  |  | 2025-12-24 | 2025-12-24 | 0d | 2025-06-06 | 2025-06-06 | 521d |  |  |  | CPT | CPT | Transition | 6.1 | CPT | Migration | Green | GREEN | 231.71 | T2-MI-2500 | PSG | T1 | Load Shaping Service switched on |
| 3098 | 1.9.13.3 | Start of 18-month migration for UMS / Advanced (M11) | milestone | 0d | 2025-10-22 | 2025-10-22 | 3096, 2997, 2998, 3143, 1938FS+20d |  |  | 2025-10-22 | 2025-10-22 | 0d | 2025-04-04 | 2025-04-04 | 5d | 0d |  |  | CPT | CPT | Transition | 6.1 | CPT | Migration | Green | GREEN | 168.71 | T1-MI-3000 | PSG | T1 | Start of 1 year migration for UMS / Advanced |
| 3099 | 1.9.13.4 | Start of 18-month migration for UMS / Advanced (M11*) - Late Exit | milestone | 0d | 2026-01-21 | 2026-01-21 | 3098FS+65d |  |  | 2026-01-21 | 2026-01-21 | 0d | 2025-07-04 | 2025-07-04 | 501d |  |  |  | CPT | CPT | Transition | 6.1 | CPT | Migration | Green | GREEN | 259.71 | T2-MI-3500 | PSG | T1 | Start of 1 year migration for UMS / Advanced |
| 3100 | 1.9.13.5 | Start of 18-month migration for Smart / Non-smart (M12) | milestone | 0d | 2025-10-22 | 2025-10-22 | 3096, 1938FS+20d |  |  | 2025-10-22 | 2025-10-22 | 0d | 2025-04-04 | 2025-04-04 | 501d | 0d |  |  | CPT | CPT | Transition | 6.1 | CPT | Migration | Green | GREEN | 168.71 | T1-MI-4000 | PSG | T1 | Start of 1 year migration for Smart / Non-smart |
| 3101 | 1.9.13.6 | Start of 18-month migration for Smart / Non-smart (M12*) - Late Exit | milestone | 0d | 2026-01-21 | 2026-01-21 | 3100FS+65d |  |  | 2026-01-21 | 2026-01-21 | 0d | 2025-07-04 | 2025-07-04 | 501d |  |  |  | CPT | CPT | Transition | 6.1 | CPT | Migration | Green | GREEN | 259.71 | T2-MI-4500 | PSG | T1 | Start of 1 year migration for Smart / Non-smart |
| 3102 | 1.9.13.7 | Full transition complete (M15) | milestone | 0d | 2027-05-07 | 2027-05-07 | 3081FS+2d |  |  | 2027-05-07 | 2027-05-07 | 0d | 2026-10-05 | 2026-10-05 | 0d |  |  |  | CPT | CPT | Transition | 6.1 | CPT | Migration | Green | GREEN | 730.71 | T1-MI-6000 | PSG | T1 | Full transition complete |
| 3103 | 1.9.13.8 | Full transition complete (M15*) - Late Exit | milestone | 0d | 2027-08-09 | 2027-08-09 | 3102FS+66d |  |  | 2027-08-09 | 2027-08-09 | 0d | 2027-01-05 | 2027-01-05 | 98d |  |  |  | CPT | CPT | Transition | 6.1 | CPT | Migration | Green | GREEN | 824.71 | T2-MI-6500 | PSG | T1 | Full transition complete |
| 3104 | 1.10 | **BUSINESS & OPERATIONAL READINESS** |  | 1344d? | 2022-10-31 A | 2027-12-23 |  | 11% | 1197.75d? | 2022-10-31 | 2027-12-23 | 964d | 2023-03-01 | 2026-12-07 | 0d |  |  | -0 | N/A | N/A | Business & Operation Readiness |  | N/A | Business & Operational Readiness |  |  |  |  |  |  |  |
| 3105 | 1.10.1 | **Service Management** |  | 838d | 2022-10-31 A | 2026-01-14 |  | 42% | 482.6d | 2023-09-19 | 2027-06-24 | 840d | 2023-03-01 | 2026-12-07 | 506d |  |  | -0 | N/A | N/A | Business & Operation Readiness | 5.0 | N/A | Business & Operational Readiness |  |  |  |  |  |  |  |
| 3106 | 1.10.1.1 | **Service Management Strategy** |  | 116d | 2023-09-19 A | 2024-02-27 A |  | 100% |  | 2023-09-19 | 2024-02-27 | 116d | 2023-03-01 | 2023-05-31 |  |  |  | -0 | N/A | N/A | Business & Operation Readiness | 5.0 | N/A | Business & Operational Readiness |  |  |  |  |  |  |  |
| 3107 | 1.10.1.1.1 | Develop document with relevant participants (incl. review of the design baseline to ensure service management arrangements are in place across the solution architecture) |  | 84d | 2023-09-19 A | 2024-01-12 A |  | 100% |  | 2023-09-19 | 2024-01-12 | 84d | 2023-03-01 | 2023-04-28 |  |  | start no earlier than 2023-09-19 |  | SI Design |  | Business & Operation Readiness | 5.0 | Matthew Breen | Business & Operational Readiness | Complete | COMPLETE |  |  |  |  |  |
| 3108 | 1.10.1.1.2 | Artefact review (via relevant Advisory Group) and updates |  | 31d | 2024-01-15 A | 2024-02-26 A | 3107 | 100% |  | 2024-01-15 | 2024-02-26 | 31d | 2023-05-01 | 2023-05-24 |  |  |  |  | PP | SI Design,IPA | Business & Operation Readiness | 5.0 | Matthew Breen | Business & Operational Readiness | Complete | COMPLETE |  |  |  |  |  |
| 3109 | 1.10.1.1.3 | Service Management Strategy approved | milestone | 0d | 2024-02-27 A | 2024-02-27 A | 3108FS+1d | 100% |  | 2024-02-27 | 2024-02-27 | 0d | 2023-05-31 | 2023-05-31 |  |  |  |  | SI Design | PP | Business & Operation Readiness | 5.16 | Matthew Breen | Business & Operational Readiness | Complete | COMPLETE |  | T3-BC-0010 | MCAG | T3 |  |

| ID | WBS | Task | Type | Duration | Start | Finish | Predecessors | Complete | Baseline start | Baseline finish | Baseline duration | Baseline 1 start | Baseline 1 finish | Total slack | Free slack | Constraint | Baseline cost | Responsible | Involved | Text9 | Task Status | Update Version | MHHS Resource Name | MHHS Programme Phase | Sched Status | RAG | Milestone ID | Text29 | Tier |
| --- | --- | --- | --- | --- | --- | --- | --- | --- | --- | --- | --- | --- | --- | --- | --- | --- | --- | --- | --- | --- | --- | --- | --- | --- | --- | --- | --- | --- | --- |
| 3110 | 1.10.1.2 | **Early Life Support Model** |  | 305d | 2024-02-28 A | 2025-04-29 A |  | 100% | 2024-02-28 | 2024-07-30 | 110d |  |  |  |  |  | -0 | N/A | N/A | Business & Operation Readiness | -441.67 | 5.16 | Matthew Breen | Business & Operational Readiness |  |  |  |  |  |
| 3111 | 1.10.1.2.1 | Draft Document |  | 252d | 2024-02-28 A | 2025-02-13 A | 3109 | 100% | 2024-02-28 | 2024-06-10 | 74d |  |  |  |  | finish no earlier than 2025-02-13 |  | SI Transition | SI Transition,PP,SRO | Business & Operation Readiness |  | 6.19 | Matthew Breen | Business & Operational Readiness | Complete | COMPLETE |  |  |  |
| 3112 | 1.10.1.2.2 | Share Document with SRO |  | 1d | 2025-02-14 A | 2025-02-14 A | 3111 | 100% | 2024-06-11 | 2024-06-11 | 1d |  |  |  |  |  |  | SI Transition | SI Transition,PP,SRO | Business & Operation Readiness |  | 6.19 | Matthew Breen | Business & Operational Readiness | Complete | COMPLETE |  |  |  |
| 3113 | 1.10.1.2.3 | Industry Consultation |  | 11d | 2025-02-21 A | 2025-03-07 A | 3112FS+4d | 100% | 2024-06-18 | 2024-07-02 | 11d |  |  |  |  |  |  | SI Transition | SI Transition,PP,SRO | Business & Operation Readiness |  | 6.19 | Matthew Breen | Business & Operational Readiness | Complete | COMPLETE |  |  |  |
| 3114 | 1.10.1.2.4 | Assurance Meeting |  | 1d | 2025-04-03 A | 2025-04-03 A | 3113FS+9d | 100% | 2025-04-03 | 2025-04-03 | 1d |  |  |  |  | finish no earlier than 2025-04-03 |  | SI Transition | SI Transition,PP,SRO | Business & Operation Readiness |  | 6.19 | Matthew Breen | Business & Operational Readiness | Complete | COMPLETE |  |  |  |
| 3115 | 1.10.1.2.5 | MCAG Approval of Early Life Support Model | milestone | 0d | 2025-04-29 A | 2025-04-29 A | 3114FS+10d | 100% | 2025-04-29 | 2025-04-29 | 0d |  |  |  |  | finish no earlier than 2025-04-29 |  | SI Transition | PP,SRO,SI Transition | Business & Operation Readiness |  | 6.22 | Matthew Breen | Business & Operational Readiness | Complete | COMPLETE | T3-MI-0033 | MCAG (Transition) | T3 |
| 3116 | 1.10.1.3 | **Service Management Arrangements Implementation** |  | 838d | 2022-10-31 | 2026-01-14 |  |  | 2025-09-25 | 2027-06-24 | 453d | 2025-03-10 | 2026-12-07 | 506d |  |  | -0 | N/A | N/A | Business & Operation Readiness |  | 5.0 | N/A | Business & Operational Readiness |  |  |  |  |  |
| 3117 | 1.10.1.3.1 | Hypercare post M10 |  | 80d | 2025-09-25 | 2026-01-14 | 1938 |  | 2025-09-25 | 2026-01-14 | 80d | 2025-03-10 | 2025-06-27 | 506d |  |  |  | SI Design | PP | Business & Operation Readiness | 141.33 | 5.0 | Claire Silk | Business & Operational Readiness | Green | GREEN |  |  |  |
| 3118 | 1.10.1.3.2 | Monitor Elexon implementation of Service Management arrangements |  | 436d | 2022-10-31 | 2024-07-01 |  |  | 2025-10-23 | 2027-06-24 | 436d | 2025-04-07 | 2026-12-07 | 908d |  |  |  | PP | SI Design | Business & Operation Readiness | -918.67 | 5.0 | Claire Silk | Business & Operational Readiness | Overdue Start | GREEN |  |  |  |
| 3119 | 1.10.2 | **Service Activation** |  | 1043d? | 2022-10-31 | 2026-10-28 |  |  | 2022-10-31 | 2026-10-22 | 289d |  |  | 301d |  |  | -0 | N/A | N/A | Business & Operation Readiness | -555.67 | 5.24 | N/A |  |  |  |  |  |  |
| 3120 | 1.10.2.1 | **Phase 1 - Preparation** |  | 840d? | 2022-10-31 | 2026-01-16 |  |  |  |  |  |  |  | 504d |  |  |  |  |  |  | -836.67 |  |  |  | Overdue Start | RED |  |  |  |
| 3121 | 1.10.2.1.1 | **SIT MVC** |  | 770d? | 2022-10-31 | 2025-10-10 |  |  | 2025-02-03 | 2025-09-22 | 0d |  |  | 574d |  |  |  |  |  | Business & Operation Readiness | -650.67 | 5.31 |  |  | Overdue Start | RED |  |  |  |
| 3122 | 1.10.2.1.1.1 | **SIT MVC Service Activation Preparation Tasks** |  | 20d | 2025-02-03 | 2025-02-28 |  |  | 2025-02-03 | 2025-02-28 | 0d |  |  | 164d |  |  |  |  |  | Business & Operation Readiness |  | 5.31 |  |  |  |  |  |  |  |
| 3123 | 1.10.2.1.1.1.1 | Identify operational resources |  | 5d | 2025-02-03 | 2025-02-07 |  |  | 2025-02-03 | 2025-02-07 | 0d |  |  | 749d |  | finish no earlier than 2025-02-07 |  |  |  | Business & Operation Readiness | -92.67 | 5.31 |  |  | Overdue Start | RED |  |  |  |
| 3124 | 1.10.2.1.1.1.2 | Define and approve operational support model |  | 5d | 2025-02-10 | 2025-02-14 |  |  | 2025-02-10 | 2025-02-14 | 0d |  |  | 744d |  | finish no earlier than 2025-02-14 |  |  |  | Business & Operation Readiness | -85.67 | 5.31 |  |  | Overdue Start | RED |  |  |  |
| 3125 | 1.10.2.1.1.1.3 | Confirm SA Training completed |  | 10d | 2025-02-10 | 2025-02-21 |  |  | 2025-02-10 | 2025-02-21 | 0d |  |  | 739d |  | finish no earlier than 2025-02-21 |  |  |  | Business & Operation Readiness | -85.67 | 5.31 |  |  | Overdue Start | RED |  |  |  |
| 3126 | 1.10.2.1.1.1.4 | Participant Engagement / Communications |  | 15d | 2025-02-10 | 2025-02-28 |  |  | 2025-02-10 | 2025-02-28 | 0d |  |  | 734d |  | finish no earlier than 2025-02-28 |  |  |  | Business & Operation Readiness | -85.67 | 5.31 |  |  | Overdue Start | RED |  |  |  |
| 3127 | 1.10.2.1.1.1.5 | Internal Communications |  | 15d | 2025-02-10 | 2025-02-28 |  |  | 2025-02-10 | 2025-02-28 | 0d |  |  | 734d |  | finish no earlier than 2025-02-28 |  |  |  | Business & Operation Readiness | -85.67 | 5.31 |  |  | Overdue Start | RED |  |  |  |
| 3128 | 1.10.2.1.1.1.6 | Validate User Access |  | 5d | 2025-02-17 | 2025-02-21 |  |  | 2025-02-17 | 2025-02-21 | 0d |  |  | 739d |  | finish no earlier than 2025-02-21 |  |  |  | Business & Operation Readiness | -78.67 | 5.31 |  |  | Overdue Start | RED |  |  |  |
| 3129 | 1.10.2.1.1.1.7 | Target Systems and Environments Ready |  | 3d | 2025-02-20 | 2025-02-24 |  |  | 2025-02-20 | 2025-02-24 | 0d |  |  | 738d |  | finish no earlier than 2025-02-24 |  |  |  | Business & Operation Readiness | -75.67 | 5.31 |  |  | Overdue Start | RED |  |  |  |
| 3130 | 1.10.2.1.1.1.8 | Provide opeartional resources with LWIs |  | 5d | 2025-02-17 | 2025-02-21 |  |  | 2025-02-17 | 2025-02-21 | 0d |  |  | 739d |  | finish no earlier than 2025-02-21 |  |  |  | Business & Operation Readiness | -78.67 | 5.31 |  |  | Overdue Start | RED |  |  |  |
| 3131 | 1.10.2.1.1.1.9 | Business Readiness Governance Approval |  | 3d | 2025-02-17 | 2025-02-19 |  |  | 2025-02-17 | 2025-02-19 | 0d |  |  | 741d |  | finish no earlier than 2025-02-19 |  |  |  | Business & Operation Readiness | -78.67 | 5.31 |  |  | Overdue Start | RED |  |  |  |
| 3132 | 1.10.2.1.1.1.10 | SIT MVC Service Activation Preparation Tasks Complete | milestone | 0d | 2025-02-28 | 2025-02-28 |  |  | 2025-02-28 | 2025-02-28 | 0d |  |  | 144d | 0d | finish no earlier than 2025-02-28 |  |  |  | Business & Operation Readiness | -67.29 | 5.31 |  |  | Overdue Start | RED |  |  |  |
| 3133 | 1.10.2.1.1.2 | MHHSP Confirms SIT MVC PPs MHHS Enabled |  | 1d | 2022-10-31 | 2022-10-31 |  |  | 2025-04-15 | 2025-04-15 | 0d |  |  | 753d | 748d |  |  |  |  | Business & Operation Readiness | -918.67 | 5.28 |  |  | Overdue Start | RED |  |  |  |

Notes:
- 3115: 01/04/25 - ELS timings updated, MCAG approved this at the March meeting (01/04).
- 3119: 23/04/25 - Work ongoing between MHHS and Helix to update the Service Activation activities in the MHHS Programme Plan.

| ID | WBS | Task | Type | Duration | Start | Finish | Predecessors | Baseline start | Baseline finish | Baseline duration | Total slack | Free slack | Constraint | Text9 | Update Version | Task Status | Sched Status | RAG | Involved |
| --- | --- | --- | --- | --- | --- | --- | --- | --- | --- | --- | --- | --- | --- | --- | --- | --- | --- | --- | --- |
| 3134 | 1.10.2.1.1.3 | **SIT MVC Service Activation Implementation** |  | 7d? | 2025-09-12 | 2025-09-22 |  | 2025-09-12 | 2025-09-22 | 0d | 5d |  |  | Business & Operation Readiness | 6.13 |  |  |  |  |
| 3135 | 1.10.2.1.1.3.1 | Add EFD to DIP |  | 1d | 2025-09-12 | 2025-09-12 | 3133, 3132, 2212SS+3d | 2025-09-12 | 2025-09-12 | 0d | 5d | 0d |  | Business & Operation Readiness | 6.13 | 128.33 | Green | GREEN |  |
| 3136 | 1.10.2.1.1.3.2 | DIP Promoted to Production |  | 1d? | 2025-09-15 | 2025-09-15 | 3135 | 2025-09-15 | 2025-09-15 | 0d | 5d | 0d |  | Business & Operation Readiness | 6.13 | 131.33 | Green | GREEN |  |
| 3137 | 1.10.2.1.1.3.3 | SIT LDSOs Create Certificates and Test Connectivity |  | 1d? | 2025-09-16 | 2025-09-16 | 3136 | 2025-09-16 | 2025-09-16 | 0d | 5d | 0d |  | Business & Operation Readiness | 6.13 | 132.33 | Green | GREEN |  |
| 3138 | 1.10.2.1.1.3.4 | SIT MVC S&As Create Certificates and Test Connectivity |  | 1d? | 2025-09-16 | 2025-09-16 | 3136 | 2025-09-16 | 2025-09-16 | 0d | 28d | 23d |  | Business & Operation Readiness | 6.13 | 132.33 | Green | GREEN |  |
| 3139 | 1.10.2.1.1.3.5 | Create M16 in Customer Solution |  | 2d | 2025-09-16 | 2025-09-17 | 3136 | 2025-09-16 | 2025-09-17 | 0d | 5d | 0d | finish no earlier than 2025-03-07 | Business & Operation Readiness | 6.13 | 132.33 | Green | GREEN |  |
| 3140 | 1.10.2.1.1.3.6 | Publish ISD |  | 2d | 2025-09-18 | 2025-09-19 | 3139 | 2025-09-18 | 2025-09-19 | 0d | 5d | 0d | finish no earlier than 2025-03-07 | Business & Operation Readiness | 6.13 | 134.33 | Green | GREEN |  |
| 3141 | 1.10.2.1.1.3.7 | SIT LDSOs to update systems with ISD |  | 1d? | 2025-09-22 | 2025-09-22 | 3140 | 2025-09-22 | 2025-09-22 | 0d | 8d | 1d |  | Business & Operation Readiness | 6.13 | 138.33 | Green | GREEN |  |
| 3142 | 1.10.2.1.1.3.8 | SIT MVC S&As to update systems with ISD |  | 1d? | 2025-09-22 | 2025-09-22 | 3140 | 2025-09-22 | 2025-09-22 | 0d | 24d | 19d |  | Business & Operation Readiness | 6.13 | 138.33 | Green | GREEN |  |
| 3143 | 1.10.2.1.1.3.9 | SIT MVC Service Activation Implementation Complete | milestone | 0d | 2025-09-19 | 2025-09-19 | 3140 | 2025-09-19 | 2025-09-19 | 0d | 5d | 0d | finish no earlier than 2025-03-07 | Business & Operation Readiness | 6.13 | 135.71 | Green | GREEN |  |
| 3144 | 1.10.2.1.1.4 | **SIT MVC Service Activation Implementation MDD** |  | 15d | 2025-09-22 | 2025-10-10 |  | 2025-03-06 | 2025-03-25 | 0d | 574d |  |  | Business & Operation Readiness | 6.24 |  |  |  |  |
| 3145 | 1.10.2.1.1.4.1 | MDD Manual Load |  | 7d | 2025-09-22 | 2025-09-30 | 3140 | 2025-03-06 | 2025-03-14 | 0d | 574d | 0d | finish no earlier than 2025-03-14 | Business & Operation Readiness | 6.24 | 138.33 | Red | RED |  |
| 3146 | 1.10.2.1.1.4.2 | MDD Update |  | 8d | 2025-10-01 | 2025-10-10 | 3145 | 2025-03-14 | 2025-03-25 | 0d | 574d | 0d | finish no earlier than 2025-03-25 | Business & Operation Readiness | 6.24 | 147.33 | Red | RED |  |
| 3147 | 1.10.2.1.1.4.3 | SIT MVC Service Activation Implementation MDD Complete | milestone | 0d | 2025-10-10 | 2025-10-10 | 3146 | 2025-03-25 | 2025-03-25 | 0d | 574d |  | finish no earlier than 2025-03-25 | Business & Operation Readiness | 6.24 | 156.71 | Red | RED |  |
| 3148 | 1.10.2.1.1.5 | **SIT MVC Service Activation Hypercare** |  | 21d | 2025-09-12 | 2025-10-10 |  | 2025-03-03 | 2025-03-26 | 0d | 574d |  |  | Business & Operation Readiness | 6.24 |  |  |  |  |
| 3149 | 1.10.2.1.1.5.1 | Service & Process Monitoring |  | 18d | 2025-09-12 | 2025-10-07 | 3135SS | 2025-03-03 | 2025-03-26 | 0d | 577d |  | finish no earlier than 2025-03-26 | Business & Operation Readiness | 6.24 | 128.33 | Red | RED |  |
| 3150 | 1.10.2.1.1.5.2 | Daily Reporting |  | 18d | 2025-09-12 | 2025-10-07 | 3135SS | 2025-03-03 | 2025-03-26 | 0d | 577d |  | finish no earlier than 2025-03-26 | Business & Operation Readiness | 6.24 | 128.33 | Red | RED |  |
| 3151 | 1.10.2.1.1.5.3 | Issue Management |  | 18d | 2025-09-12 | 2025-10-07 | 3135SS | 2025-03-03 | 2025-03-26 | 0d | 577d |  | finish no earlier than 2025-03-26 | Business & Operation Readiness | 6.24 | 128.33 | Red | RED |  |
| 3152 | 1.10.2.1.1.5.4 | SA Hypercare Close Down Activities |  | 18d | 2025-09-12 | 2025-10-07 | 3135SS | 2025-03-03 | 2025-03-26 | 0d | 574d | 0d | finish no earlier than 2025-03-26 | Business & Operation Readiness | 6.24 | 128.33 | Red | RED |  |
| 3153 | 1.10.2.1.1.5.5 | Handover to MHHSP |  | 3d | 2025-10-08 | 2025-10-10 | 3152 | 2025-03-21 | 2025-03-25 | 0d | 574d | 0d | finish no earlier than 2025-03-25 | Business & Operation Readiness | 6.24 | 154.33 | Red | RED | MHHSP |
| 3154 | 1.10.2.1.1.5.6 | SIT MVC Service Activation Hypercare Complete | milestone | 0d | 2025-10-10 | 2025-10-10 | 3153 | 2025-03-25 | 2025-03-25 | 0d | 574d |  | finish no earlier than 2025-03-25 | Business & Operation Readiness | 6.24 | 156.71 | Red | RED |  |
| 3155 | 1.10.2.1.2 | **SIT Non-MVC** |  | 840d? | 2022-10-31 | 2026-01-16 |  | 2022-10-31 | 2026-01-01 | 0d | 504d |  |  | Business & Operation Readiness | 6.13 | -650.67 | Overdue Start | RED |  |
| 3156 | 1.10.2.1.2.1 | **SIT Non-MVC Service Activation Preparation Tasks** |  | 610d | 2022-10-31 | 2025-02-28 |  | 2022-10-31 | 2022-10-31 | 0d | 734d |  |  | Business & Operation Readiness | 6.13 | -651.67 | Overdue Start | RED |  |
| 3157 | 1.10.2.1.2.1.1 | Helix Preparatory Activities Complete | milestone | 0d | 2025-02-28 | 2025-02-28 | 3132 | 2022-10-31 | 2022-10-31 | 0d | 734d |  |  | Business & Operation Readiness | 6.13 | -67.29 | Overdue Start | RED |  |
| 3158 | 1.10.2.1.2.1.2 | MHHSP Confirms SIT Non-MVC PPs MHHS Enabled |  | 1d | 2022-10-31 | 2022-10-31 |  | 2022-10-31 | 2022-10-31 | 0d | 1322d | 739d |  | Business & Operation Readiness | 6.13 | -918.67 | Overdue Start | RED |  |

Notes:
- 3144: 07/05/25 - Service Activation plan still under going development, but dates have been amended.
- 3145: 07/05/25 - Service Activation plan still under going development, but dates have been amended.
- 3146: 07/05/25 - Service Activation plan still under going development, but dates have been amended.
- 3147: 07/05/25 - Service Activation plan still under going development, but dates have been amended.
- 3148: 07/05/25 - Service Activation plan still under going development, but dates have been amended.
- 3149: 07/05/25 - Service Activation plan still under going development, but dates have been amended.
- 3150: 07/05/25 - Service Activation plan still under going development, but dates have been amended.
- 3151: 07/05/25 - Service Activation plan still under going development, but dates have been amended.
- 3152: 07/05/25 - Service Activation plan still under going development, but dates have been amended.
- 3153: 07/05/25 - Service Activation plan still under going development, but dates have been amended. / Action: 12/8/24: Why is ths a dep into us?
- 3154: 07/05/25 - Service Activation plan still under going development, but dates have been amended.
- 3157: Action: 12/8/24: Emailed helix to clarify what needs to go in the prep section and if hypercare is required

| ID | WBS | Task | Type | Duration | Start | Finish | Predecessors | Baseline start | Baseline finish | Baseline duration | Total slack | Free slack | Constraint | Text9 | Update Version | Task Status | Sched Status | RAG | Involved |
| --- | --- | --- | --- | --- | --- | --- | --- | --- | --- | --- | --- | --- | --- | --- | --- | --- | --- | --- | --- |
| 3159 | 1.10.2.1.2.2 | **SIT Non-MVC Service Activation Implementation** |  | 7d? | 2025-12-18 | 2025-12-26 |  | 2025-12-23 | 2026-01-01 | 0d | 505d |  |  | Business & Operation Readiness | 5.31 |  |  |  |  |
| 3160 | 1.10.2.1.2.2.1 | Add EDF to DIP |  | 1d | 2025-12-18 | 2025-12-18 | 2231SS, 3158 | 2025-12-23 | 2025-12-24 | 0d | 505d | 0d | finish no earlier than 2025-06-04 | Business & Operation Readiness | 5.31 | 225.33 | Green | GREEN |  |
| 3161 | 1.10.2.1.2.2.2 | DIP Promoted to Production |  | 1d | 2025-12-19 | 2025-12-19 | 3160 | 2025-12-25 | 2025-12-26 | 0d | 505d | 0d | finish no earlier than 2025-06-05 | Business & Operation Readiness | 6.13 | 226.33 | Green | GREEN |  |
| 3162 | 1.10.2.1.2.2.3 | SIT non-MVC S&As Create Certificates and Test Connectivity |  | 1d? | 2025-12-22 | 2025-12-22 | 3161 | 2025-12-23 | 2025-12-23 | 0d | 523d |  |  | SIT | 6.17 | 229.33 | Green | GREEN |  |
| 3163 | 1.10.2.1.2.2.4 | Create M16 in Customer Solution |  | 2d | 2025-12-22 | 2025-12-23 | 3161 | 2025-12-29 | 2025-12-30 | 0d | 505d | 0d | finish no earlier than 2025-06-06 | Business & Operation Readiness | 6.13 | 229.33 | Green | GREEN |  |
| 3164 | 1.10.2.1.2.2.5 | Publish ISD |  | 2d | 2025-12-24 | 2025-12-25 | 3163 | 2025-12-31 | 2026-01-01 | 0d | 505d | 0d | finish no earlier than 2025-06-06 | Business & Operation Readiness | 6.13 | 231.33 | Green | GREEN |  |
| 3165 | 1.10.2.1.2.2.6 | SIT non-MVC S&As to update systems with ISD |  | 1d? | 2025-12-26 | 2025-12-26 | 3164 | 2025-12-29 | 2025-12-29 | 0d | 519d |  |  | SIT | 6.17 | 233.33 | Green | GREEN |  |
| 3166 | 1.10.2.1.2.2.7 | SIT Non-MVC Service Activation Implementation Complete | milestone | 0d | 2025-12-25 | 2025-12-25 | 3164 | 2026-01-01 | 2026-01-01 | 0d | 520d |  | finish no earlier than 2025-06-06 | Business & Operation Readiness | 6.13 | 232.71 | Green | GREEN |  |
| 3167 | 1.10.2.1.2.3 | **SIT Non-MVC Service Activation Implementation MDD** |  | 15d | 2025-12-26 | 2026-01-15 |  | 2025-06-05 | 2025-06-24 | 0d | 505d |  |  | Business & Operation Readiness | 6.13 |  |  |  |  |
| 3168 | 1.10.2.1.2.3.1 | MDD Manual Load |  | 7d | 2025-12-26 | 2026-01-05 | 3164 | 2025-06-05 | 2025-06-13 | 0d | 505d | 0d | finish no earlier than 2025-06-13 | Business & Operation Readiness | 6.13 | 233.33 | Red | RED |  |
| 3169 | 1.10.2.1.2.3.2 | MDD Update |  | 8d | 2026-01-06 | 2026-01-15 | 3168 | 2025-06-13 | 2025-06-24 | 0d | 505d | 0d | finish no earlier than 2025-06-24 | Business & Operation Readiness | 6.13 | 244.33 | Red | RED |  |
| 3170 | 1.10.2.1.2.3.3 | SIT Non-MVC Service Activation Implementation MDD Complete | milestone | 0d | 2026-01-15 | 2026-01-15 | 3169 | 2025-06-24 | 2025-06-24 | 0d | 505d |  | finish no earlier than 2025-06-24 | Business & Operation Readiness | 6.13 | 253.71 | Red | RED |  |
| 3171 | 1.10.2.1.2.4 | **Non-SIT MVC Service Activation Hypercare** |  | 22d | 2025-12-18 | 2026-01-16 |  | 2025-06-02 | 2025-06-26 | 0d | 504d |  |  | Business & Operation Readiness | 6.13 |  |  |  |  |
| 3172 | 1.10.2.1.2.4.1 | Service& Process Monitoring |  | 18d | 2025-12-18 | 2026-01-12 | 3160SS | 2025-06-02 | 2025-06-25 | 0d | 508d |  | finish no earlier than 2025-06-25 | Business & Operation Readiness | 6.13 | 225.33 | Red | RED |  |
| 3173 | 1.10.2.1.2.4.2 | Daily Reporting |  | 18d | 2025-12-18 | 2026-01-12 | 3160SS | 2025-06-02 | 2025-06-25 | 0d | 508d |  | finish no earlier than 2025-06-25 | Business & Operation Readiness | 6.13 | 225.33 | Red | RED |  |
| 3174 | 1.10.2.1.2.4.3 | Issue Management |  | 18d | 2025-12-18 | 2026-01-12 | 3160SS | 2025-06-02 | 2025-06-25 | 0d | 508d |  | finish no earlier than 2025-06-25 | Business & Operation Readiness | 6.13 | 225.33 | Red | RED |  |
| 3175 | 1.10.2.1.2.4.4 | SA Hypercare Close Down Activities |  | 18d | 2025-12-18 | 2026-01-12 | 3160SS | 2025-06-02 | 2025-06-25 | 0d | 504d | 0d | finish no earlier than 2025-06-25 | Business & Operation Readiness | 6.13 | 225.33 | Red | RED |  |
| 3176 | 1.10.2.1.2.4.5 | Handover to MHHSP |  | 4d | 2026-01-13 | 2026-01-16 | 3175 | 2025-06-23 | 2025-06-26 | 0d | 504d | 0d | finish no earlier than 2025-06-26 | Business & Operation Readiness | 6.13 | 251.33 | Red | RED | MHHSP |
| 3177 | 1.10.2.1.2.4.6 | Non-SIT MVC Service Activation Hypercare Complete (M) | milestone | 0d | 2026-01-16 | 2026-01-16 | 3176 | 2025-06-25 | 2025-06-25 | 0d | 504d |  | finish no earlier than 2025-06-25 | Business & Operation Readiness | 6.13 | 254.71 | Red | RED |  |
| 3178 | 1.10.2.2 | **Wave 1** |  | 924d | 2022-10-31 | 2026-05-14 |  | 2022-10-31 | 2026-05-14 | 0d | 420d |  |  | Business & Operation Readiness | 5.31 | -650.67 | Overdue Start | RED |  |
| 3179 | 1.10.2.2.1 | **SIT Non-MVC Service Activation Preparation Tasks** |  | 924d | 2022-10-31 | 2026-05-14 |  | 2022-10-31 | 2026-05-14 | 0d | 420d |  |  | Business & Operation Readiness | 5.31 | -651.67 | Overdue Start | RED |  |
| 3180 | 1.10.2.2.1.1 | Helix Preparatory Activities Complete | milestone | 0d | 2022-10-31 | 2022-10-31 |  | 2022-10-31 | 2022-10-31 | 0d | 1344d |  |  | Business & Operation Readiness | 5.29 | -918.67 | Overdue Start | RED |  |
| 3181 | 1.10.2.2.1.2 | MHHSP Confirms Wave 1 PPs MHHS Enabled |  | 1d | 2022-10-31 | 2022-10-31 |  | 2022-10-31 | 2022-10-31 | 0d | 1321d | 902d |  | Business & Operation Readiness | 5.28 | -918.67 | Overdue Start | RED |  |
| 3182 | 1.10.2.2.1.3 | Wave 1 Service Activation |  | 21d | 2026-04-16 | 2026-05-14 | 2454, 3181 | 2026-04-13 | 2026-05-14 | 25d | 419d | 0d |  | Business & Operation Readiness | 6.13 | 344.33 | Green | GREEN |  |

Notes:
- 3167: 07/05/25 - Service Activation plan still under going development, but dates have been amended.
- 3168: 07/05/25 - Service Activation plan still under going development, but dates have been amended.
- 3169: 07/05/25 - Service Activation plan still under going development, but dates have been amended.
- 3170: 07/05/25 - Service Activation plan still under going development, but dates have been amended.
- 3171: 07/05/25 - Service Activation plan still under going development, but dates have been amended.
- 3172: 07/05/25 - Service Activation plan still under going development, but dates have been amended.
- 3173: 07/05/25 - Service Activation plan still under going development, but dates have been amended.
- 3174: 07/05/25 - Service Activation plan still under going development, but dates have been amended.
- 3175: 07/05/25 - Service Activation plan still under going development, but dates have been amended.
- 3176: 07/05/25 - Service Activation plan still under going development, but dates have been amended.
- 3177: 07/05/25 - Service Activation plan still under going development, but dates have been amended.
- 3178: 07/05/25 - Service Activation plan still under going development, but dates have been amended.
- 3179: 07/05/25 - Service Activation plan still under going development, but dates have been amended.
- 3180: 07/05/25 - Service Activation plan still under going development, but dates have been amended. / Action: 12/8/24: Emailed helix to clarify what needs to go in the prep section and if hypercare is required
- 3181: 07/05/25 - Service Activation plan still under going development, but dates have been amended.
- 3182: 07/05/25 - Service Activation plan still under going development, but dates have been amended.

| ID | WBS | Task | Type | Duration | Start | Finish | Predecessors | Baseline start | Baseline finish | Baseline duration | Total slack | Free slack | Constraint | Text9 | Update Version | Task Status | Sched Status | RAG | Future RAG |
| --- | --- | --- | --- | --- | --- | --- | --- | --- | --- | --- | --- | --- | --- | --- | --- | --- | --- | --- | --- |
| 3183 | 1.10.2.2.2 | **Wave 1 - Service Activation Implementation** |  | 171d | 2025-09-01 | 2026-04-27 |  | 2025-09-01 | 2025-09-05 | 0d | 433d |  |  | Business & Operation Readiness | 5.31 |  |  |  |  |
| 3184 | 1.10.2.2.2.1 | MHHSP Enabled Confirmation |  | 2d | 2025-09-01 | 2025-09-02 | 3158 | 2025-09-01 | 2025-09-02 | 0d | 602d |  | finish no earlier than 2025-09-02 | Business & Operation Readiness | 5.31 | 117.33 | Green | GREEN |  |
| 3185 | 1.10.2.2.2.2 | PAB Approval |  | 2d | 2026-04-16 | 2026-04-17 | 2454 | 2025-09-01 | 2025-09-02 | 0d | 439d |  | finish no earlier than 2025-09-02 | Business & Operation Readiness | 5.31 | 344.33 | Red | RED |  |
| 3186 | 1.10.2.2.2.3 | Add EFD to DIP |  | 2d | 2026-04-16 | 2026-04-17 | 2454 | 2025-09-02 | 2025-09-03 | 0d | 422d | 0d | finish no earlier than 2025-09-03 | Business & Operation Readiness | 5.31 | 344.33 | Red | RED |  |
| 3187 | 1.10.2.2.2.4 | DIP Promoted to Production |  | 2d | 2026-04-20 | 2026-04-21 | 3186 | 2025-09-03 | 2025-09-04 | 0d | 422d | 0d | finish no earlier than 2025-09-04 | Business & Operation Readiness | 5.31 | 348.33 | Red | RED |  |
| 3188 | 1.10.2.2.2.5 | Create M16 in Customer Solution |  | 2d | 2026-04-22 | 2026-04-23 | 3187 | 2025-09-04 | 2025-09-05 | 0d | 422d | 0d | finish no earlier than 2025-09-05 | Business & Operation Readiness | 5.31 | 350.33 | Red | RED |  |
| 3189 | 1.10.2.2.2.6 | Publish ISD |  | 2d | 2026-04-24 | 2026-04-27 | 3188 | 2025-09-04 | 2025-09-05 | 0d | 422d | 0d | finish no earlier than 2025-09-05 | Business & Operation Readiness | 5.31 | 352.33 | Red | RED |  |
| 3190 | 1.10.2.2.2.7 | Wave 1 - Service Activation Implementation Complete (M) | milestone | 0d | 2026-04-27 | 2026-04-27 | 3189 | 2025-09-05 | 2025-09-05 | 0d | 433d |  | finish no earlier than 2025-09-05 | Business & Operation Readiness | 5.31 | 355.71 | Red | RED |  |
| 3191 | 1.10.2.2.3 | **Wave 1 - Service Activation Implementation MDD** |  | 11d | 2026-04-28 | 2026-05-12 |  | 2025-09-04 | 2025-09-17 | 0d | 422d |  |  | Business & Operation Readiness | 5.31 |  |  |  |  |
| 3192 | 1.10.2.2.3.1 | MDD Manual Load |  | 5d | 2026-04-28 | 2026-05-04 | 3189 | 2025-09-04 | 2025-09-10 | 0d | 422d | 0d | finish no earlier than 2025-09-10 | Business & Operation Readiness | 5.31 | 356.33 | Red | RED |  |
| 3193 | 1.10.2.2.3.2 | MDD Update |  | 6d | 2026-05-05 | 2026-05-12 | 3192 | 2025-09-10 | 2025-09-17 | 0d | 422d | 0d | finish no earlier than 2025-09-17 | Business & Operation Readiness | 5.31 | 363.33 | Red | RED |  |
| 3194 | 1.10.2.2.3.3 | Wave 1 - Service Activation Implementation MDD Complete (M) | milestone | 0d | 2026-05-12 | 2026-05-12 | 3193 | 2025-09-17 | 2025-09-17 | 0d | 422d |  | finish no earlier than 2025-09-17 | Business & Operation Readiness | 5.31 | 370.71 | Red | RED |  |
| 3195 | 1.10.2.2.4 | **Wave 1 - Service Activation Hypercare** |  | 177d | 2025-09-01 | 2026-05-05 |  | 2022-10-31 | 2025-09-18 | 0d | 427d |  |  | Business & Operation Readiness | 5.31 |  |  |  |  |
| 3196 | 1.10.2.2.4.1 | Service& Process Monitoring |  | 14d | 2026-04-16 | 2026-05-05 | 3186SS | 2025-09-01 | 2025-09-18 | 0d | 427d |  | finish no earlier than 2025-09-18 | Business & Operation Readiness | 5.31 | 344.33 | Red | RED |  |
| 3197 | 1.10.2.2.4.2 | Daily Reporting |  | 14d | 2026-04-16 | 2026-05-05 | 3186SS | 2025-09-01 | 2025-09-18 | 0d | 427d |  | finish no earlier than 2025-09-18 | Business & Operation Readiness | 5.31 | 344.33 | Red | RED |  |
| 3198 | 1.10.2.2.4.3 | Issue Management |  | 14d | 2026-04-16 | 2026-05-05 | 3186SS | 2025-09-01 | 2025-09-18 | 0d | 427d |  | finish no earlier than 2025-09-18 | Business & Operation Readiness | 5.31 | 344.33 | Red | RED |  |
| 3199 | 1.10.2.2.4.4 | SA Hypercare Close Down Activities |  | 14d | 2025-09-01 | 2025-09-18 |  | 2025-09-01 | 2025-09-18 | 0d | 586d | 0d | finish no earlier than 2025-09-18 | Business & Operation Readiness | 5.31 | 117.33 | Green | GREEN |  |
| 3200 | 1.10.2.2.4.5 | Handover to MHHSP |  | 4d | 2025-09-19 | 2025-09-24 | 3199 | 2025-09-15 | 2025-09-18 | 0d | 586d | 0d | finish no earlier than 2025-09-18 | Business & Operation Readiness | 5.31 | 135.33 | yellow | RED |  |
| 3201 | 1.10.2.2.4.6 | Non-SIT LDSO Service Activation Hypercare Complete (M) | milestone | 0d | 2025-09-24 | 2025-09-24 | 3200 | 2022-10-31 | 2022-10-31 | 0d | 586d |  |  | Business & Operation Readiness | 5.31 | 140.71 | Red | RED | Dates to be confirmed |
| 3202 | 1.10.2.3 | **Wave 2** |  | 958d | 2022-10-31 | 2026-07-01 |  | 2022-10-31 | 2026-06-30 | 0d | 386d |  |  | Business & Operation Readiness | 5.31 | -650.67 | Overdue Start | RED |  |
| 3203 | 1.10.2.3.1 | **SIT Non-MVC Service Activation Preparation Tasks** |  | 958d | 2022-10-31 | 2026-07-01 |  | 2022-10-31 | 2026-06-30 | 0d | 386d |  |  | Business & Operation Readiness | 5.31 | -651.67 | Overdue Start | RED |  |
| 3204 | 1.10.2.3.1.1 | Helix Preparatory Activities Complete | milestone | 0d | 2022-10-31 | 2022-10-31 |  | 2022-10-31 | 2022-10-31 | 0d | 1344d |  |  | Business & Operation Readiness | 5.29 | -918.67 | Overdue Start | RED |  |
| 3205 | 1.10.2.3.1.2 | MHHSP Confirms Wave 2 PPs MHHS Enabled |  | 1d | 2022-10-31 | 2022-10-31 |  | 2022-10-31 | 2022-10-31 | 0d | 1319d | 933d |  | Business & Operation Readiness | 5.28 | -918.67 | Overdue Start | RED |  |
| 3206 | 1.10.2.3.1.3 | Wave 2 Service Activation |  | 24d | 2026-05-29 | 2026-07-01 | 2484, 3205 | 2026-05-28 | 2026-06-30 | 25d | 386d |  |  | Business & Operation Readiness | 5.24 | 387.33 | yellow | RED |  |

Notes:
- 3183: 07/05/25 - Service Activation plan still under going development, but dates have been amended.
- 3184: 07/05/25 - Service Activation plan still under going development, but dates have been amended.
- 3185: 07/05/25 - Service Activation plan still under going development, but dates have been amended.
- 3186: 07/05/25 - Service Activation plan still under going development, but dates have been amended.
- 3187: 07/05/25 - Service Activation plan still under going development, but dates have been amended.
- 3188: 07/05/25 - Service Activation plan still under going development, but dates have been amended.
- 3189: 07/05/25 - Service Activation plan still under going development, but dates have been amended.
- 3190: 07/05/25 - Service Activation plan still under going development, but dates have been amended.
- 3191: 07/05/25 - Service Activation plan still under going development, but dates have been amended.
- 3192: 07/05/25 - Service Activation plan still under going development, but dates have been amended.
- 3193: 07/05/25 - Service Activation plan still under going development, but dates have been amended.
- 3194: 07/05/25 - Service Activation plan still under going development, but dates have been amended.
- 3195: 07/05/25 - Service Activation plan still under going development, but dates have been amended.
- 3196: 07/05/25 - Service Activation plan still under going development, but dates have been amended.
- 3197: 07/05/25 - Service Activation plan still under going development, but dates have been amended.
- 3198: 07/05/25 - Service Activation plan still under going development, but dates have been amended.
- 3199: 07/05/25 - Service Activation plan still under going development, but dates have been amended.
- 3200: 07/05/25 - Service Activation plan still under going development, but dates have been amended.
- 3201: 07/05/25 - Service Activation plan still under going development, but dates have been amended.
- 3202: 07/05/25 - Service Activation plan still under going development, but dates have been amended.
- 3203: 07/05/25 - Service Activation plan still under going development, but dates have been amended.
- 3204: 07/05/25 - Service Activation plan still under going development, but dates have been amended. / Action: 12/8/24: Emailed helix to clarify what needs to go in the prep section and if hypercare is required
- 3205: 07/05/25 - Service Activation plan still under going development, but dates have been amended.
- 3206: 07/05/25 - Service Activation plan still under going development, but dates have been amended.

| ID | WBS | Task | Type | Duration | Start | Finish | Predecessors | Baseline start | Baseline finish | Baseline duration | Total slack | Free slack | Constraint | Text9 | Update Version | Task Status | Sched Status | RAG | Involved |
| --- | --- | --- | --- | --- | --- | --- | --- | --- | --- | --- | --- | --- | --- | --- | --- | --- | --- | --- | --- |
| 3207 | 1.10.2.3.2 | **Wave 2 - Service Activation Implementation** |  | 157d | 2025-11-03 | 2026-06-09 |  | 2025-11-03 | 2025-11-07 | 0d | 402d |  |  | Business & Operation Readiness | 5.31 |  |  |  |  |
| 3208 | 1.10.2.3.2.1 | MHHSP Enabled Confirmation |  | 2d | 2025-11-03 | 2025-11-04 |  | 2025-11-03 | 2025-11-04 | 0d | 557d |  | finish no earlier than 2025-11-04 | Business & Operation Readiness | 5.31 | 180.33 | Green | GREEN |  |
| 3209 | 1.10.2.3.2.2 | PAB Approval |  | 2d | 2026-05-29 | 2026-06-01 | 2484 | 2025-11-03 | 2025-11-04 | 0d | 408d |  | finish no earlier than 2025-11-04 | Business & Operation Readiness | 5.31 | 387.33 | Red | RED |  |
| 3210 | 1.10.2.3.2.3 | Add EFD to DIP |  | 2d | 2026-05-29 | 2026-06-01 | 2484 | 2025-11-04 | 2025-11-05 | 0d | 402d | 0d | finish no earlier than 2025-11-05 | Business & Operation Readiness | 5.31 | 387.33 | Red | RED |  |
| 3211 | 1.10.2.3.2.4 | DIP Promoted to Production |  | 2d | 2026-06-02 | 2026-06-03 | 3210 | 2025-11-05 | 2025-11-06 | 0d | 402d | 0d | finish no earlier than 2025-11-06 | Business & Operation Readiness | 5.31 | 391.33 | Red | RED |  |
| 3212 | 1.10.2.3.2.5 | Create M16 in Customer Solution |  | 2d | 2026-06-04 | 2026-06-05 | 3211 | 2025-11-06 | 2025-11-07 | 0d | 402d | 0d | finish no earlier than 2025-11-07 | Business & Operation Readiness | 5.31 | 393.33 | Red | RED |  |
| 3213 | 1.10.2.3.2.6 | Publish ISD |  | 2d | 2026-06-08 | 2026-06-09 | 3212 | 2025-11-06 | 2025-11-07 | 0d | 402d | 0d | finish no earlier than 2025-11-07 | Business & Operation Readiness | 5.31 | 397.33 | Red | RED |  |
| 3214 | 1.10.2.3.2.7 | Wave 2 - Service Activation Implementation Complete (M) | milestone | 0d | 2026-06-09 | 2026-06-09 | 3213 | 2025-11-07 | 2025-11-07 | 0d | 402d |  | finish no earlier than 2025-11-07 | Business & Operation Readiness | 5.31 | 398.71 | Red | RED |  |
| 3215 | 1.10.2.3.3 | **Wave 2 - Service Activation Implementation MDD** |  | 10d | 2025-11-06 | 2025-11-19 |  | 2025-11-06 | 2025-11-19 | 0d | 546d |  |  | Business & Operation Readiness | 5.31 |  |  |  |  |
| 3216 | 1.10.2.3.3.1 | MDD Manual Load |  | 5d | 2025-11-06 | 2025-11-12 |  | 2025-11-06 | 2025-11-12 | 0d | 551d |  | finish no earlier than 2025-11-12 | Business & Operation Readiness | 5.31 | 183.33 | Green | GREEN |  |
| 3217 | 1.10.2.3.3.2 | MDD Update |  | 6d | 2025-11-12 | 2025-11-19 |  | 2025-11-12 | 2025-11-19 | 0d | 546d |  | finish no earlier than 2025-11-19 | Business & Operation Readiness | 5.31 | 189.33 | Green | GREEN |  |
| 3218 | 1.10.2.3.3.3 | Wave 2 - Service Activation Implementation MDD Complete (M) | milestone | 0d | 2025-11-19 | 2025-11-19 |  | 2025-11-19 | 2025-11-19 | 0d | 546d |  | finish no earlier than 2025-11-19 | Business & Operation Readiness | 5.31 | 196.71 | Green | GREEN |  |
| 3219 | 1.10.2.3.4 | **Wave 2 - Service Activation Hypercare** |  | 14d | 2025-11-03 | 2025-11-20 |  | 2025-11-03 | 2025-11-20 | 0d | 545d |  |  | Business & Operation Readiness | 5.31 |  |  |  |  |
| 3220 | 1.10.2.3.4.1 | Service& Process Monitoring |  | 14d | 2025-11-03 | 2025-11-20 |  | 2025-11-03 | 2025-11-20 | 0d | 545d |  | finish no earlier than 2025-11-20 | Business & Operation Readiness | 5.31 | 180.33 | Green | GREEN |  |
| 3221 | 1.10.2.3.4.2 | Daily Reporting |  | 14d | 2025-11-03 | 2025-11-20 |  | 2025-11-03 | 2025-11-20 | 0d | 545d |  | finish no earlier than 2025-11-20 | Business & Operation Readiness | 5.31 | 180.33 | Green | GREEN |  |
| 3222 | 1.10.2.3.4.3 | Issue Management |  | 14d | 2025-11-03 | 2025-11-20 |  | 2025-11-03 | 2025-11-20 | 0d | 545d |  | finish no earlier than 2025-11-20 | Business & Operation Readiness | 5.31 | 180.33 | Green | GREEN |  |
| 3223 | 1.10.2.3.4.4 | SA Hypercare Close Down Activities |  | 14d | 2025-11-03 | 2025-11-20 |  | 2025-11-03 | 2025-11-20 | 0d | 545d |  | finish no earlier than 2025-11-20 | Business & Operation Readiness | 5.31 | 180.33 | Green | GREEN |  |
| 3224 | 1.10.2.3.4.5 | Handover to MHHSP |  | 4d | 2025-11-17 | 2025-11-20 |  | 2025-11-17 | 2025-11-20 | 0d | 545d |  | finish no earlier than 2025-11-20 | Business & Operation Readiness | 5.31 | 194.33 | Green | GREEN | MHHSP |
| 3225 | 1.10.2.3.4.6 | Wave 2 - Service Activation Hypercare Complete (M) | milestone | 0d | 2025-11-19 | 2025-11-19 |  | 2025-11-19 | 2025-11-19 | 0d | 546d |  | finish no earlier than 2025-11-19 | Business & Operation Readiness | 5.31 | 196.71 | Green | GREEN |  |
| 3226 | 1.10.2.4 | **Wave 3** |  | 989d | 2022-10-31 | 2026-08-13 |  | 2022-10-31 | 2026-08-26 | 0d | 355d |  |  | Business & Operation Readiness | 5.31 | -650.67 | Overdue Start | RED |  |
| 3227 | 1.10.2.4.1 | **SIT Non-MVC Service Activation Preparation Tasks** |  | 989d | 2022-10-31 | 2026-08-13 |  | 2022-10-31 | 2026-08-26 | 0d | 355d |  |  | Business & Operation Readiness | 5.31 | -651.67 | Overdue Start | RED |  |
| 3228 | 1.10.2.4.1.1 | Helix Preparatory Activities Complete | milestone | 0d | 2022-10-31 | 2022-10-31 |  | 2022-10-31 | 2022-10-31 | 0d | 1344d |  |  | Business & Operation Readiness | 5.29 | -918.67 | Overdue Start | RED |  |
| 3229 | 1.10.2.4.1.2 | MHHSP Confirms Wave 3 PPs MHHS Enabled |  | 1d | 2022-10-31 | 2022-10-31 |  | 2022-10-31 | 2022-10-31 | 0d | 1333d | 978d |  | Business & Operation Readiness | 5.28 | -918.67 | Overdue Start | RED |  |
| 3230 | 1.10.2.4.1.3 | Wave 3 Service Activation |  | 10d | 2026-07-31 | 2026-08-13 | 2514, 3229 | 2026-07-24 | 2026-08-26 | 25d | 355d |  |  | Business & Operation Readiness | 5.24 | 450.33 | Green | GREEN |  |

Notes:
- 3207: 07/05/25 - Service Activation plan still under going development, but dates have been amended.
- 3208: 07/05/25 - Service Activation plan still under going development, but dates have been amended.
- 3209: 07/05/25 - Service Activation plan still under going development, but dates have been amended.
- 3210: 07/05/25 - Service Activation plan still under going development, but dates have been amended.
- 3211: 07/05/25 - Service Activation plan still under going development, but dates have been amended.
- 3212: 07/05/25 - Service Activation plan still under going development, but dates have been amended.
- 3213: 07/05/25 - Service Activation plan still under going development, but dates have been amended.
- 3214: 07/05/25 - Service Activation plan still under going development, but dates have been amended.
- 3215: 07/05/25 - Service Activation plan still under going development, but dates have been amended.
- 3216: 07/05/25 - Service Activation plan still under going development, but dates have been amended.
- 3217: 07/05/25 - Service Activation plan still under going development, but dates have been amended.
- 3218: 07/05/25 - Service Activation plan still under going development, but dates have been amended.
- 3219: 07/05/25 - Service Activation plan still under going development, but dates have been amended.
- 3220: 07/05/25 - Service Activation plan still under going development, but dates have been amended.
- 3221: 07/05/25 - Service Activation plan still under going development, but dates have been amended.
- 3222: 07/05/25 - Service Activation plan still under going development, but dates have been amended.
- 3223: 07/05/25 - Service Activation plan still under going development, but dates have been amended.
- 3224: 07/05/25 - Service Activation plan still under going development, but dates have been amended.
- 3225: 07/05/25 - Service Activation plan still under going development, but dates have been amended.
- 3226: 07/05/25 - Service Activation plan still under going development, but dates have been amended.
- 3227: 07/05/25 - Service Activation plan still under going development, but dates have been amended.
- 3228: 07/05/25 - Service Activation plan still under going development, but dates have been amended. / Action: 12/8/24: Emailed helix to clarify what needs to go in the prep section and if hypercare is required
- 3229: 07/05/25 - Service Activation plan still under going development, but dates have been amended.
- 3230: 07/05/25 - Service Activation plan still under going development, but dates have been amended.

| ID | WBS | Task | Type | Duration | Start | Finish | Predecessors | Baseline start | Baseline finish | Baseline duration | Total slack | Free slack | Constraint | Text9 | Update Version | Task Status | Sched Status | RAG | Future RAG | Involved |
| --- | --- | --- | --- | --- | --- | --- | --- | --- | --- | --- | --- | --- | --- | --- | --- | --- | --- | --- | --- | --- |
| 3231 | 1.10.2.4.2 | **Wave 3 - Service Activation Implementation** |  | 169d | 2025-12-22 | 2026-08-13 |  | 2025-12-22 | 2025-12-30 | 0d | 355d |  |  | Business & Operation Readiness | 5.31 |  |  |  |  |  |
| 3232 | 1.10.2.4.2.1 | MHHSP Enabled Confirmation |  | 2d | 2025-12-22 | 2025-12-23 |  | 2025-12-22 | 2025-12-23 | 0d | 522d |  | finish no earlier than 2025-12-23 | Business & Operation Readiness | 5.31 | 229.33 | Green | GREEN |  |  |
| 3233 | 1.10.2.4.2.2 | PAB Approval |  | 2d | 2026-07-31 | 2026-08-03 | 2514 | 2025-12-22 | 2025-12-23 | 0d | 355d | 0d | finish no earlier than 2025-12-23 | Business & Operation Readiness | 5.31 | 450.33 | Red | RED |  |  |
| 3234 | 1.10.2.4.2.3 | Add EFD to DIP |  | 2d | 2026-08-04 | 2026-08-05 | 2514, 3233 | 2025-12-23 | 2025-12-24 | 0d | 355d | 0d | finish no earlier than 2025-12-24 | Business & Operation Readiness | 5.31 | 454.33 | Red | RED |  |  |
| 3235 | 1.10.2.4.2.4 | DIP Promoted to Production |  | 2d | 2026-08-06 | 2026-08-07 | 3234 | 2025-12-29 | 2025-12-30 | 0d | 355d | 0d | finish no earlier than 2025-12-30 | Business & Operation Readiness | 5.31 | 456.33 | Red | RED |  |  |
| 3236 | 1.10.2.4.2.5 | Create M16 in Customer Solution |  | 2d | 2026-08-10 | 2026-08-11 | 3235 | 2025-12-29 | 2025-12-30 | 0d | 355d | 0d | finish no earlier than 2025-12-30 | Business & Operation Readiness | 5.31 | 460.33 | Red | RED |  |  |
| 3237 | 1.10.2.4.2.6 | Publish ISD |  | 2d | 2026-08-12 | 2026-08-13 | 3236 | 2025-12-29 | 2025-12-30 | 0d | 355d | 0d | finish no earlier than 2025-12-30 | Business & Operation Readiness | 5.31 | 462.33 | Red | RED |  |  |
| 3238 | 1.10.2.4.2.7 | Wave 3 - Service Activation Implementation Complete (M) | milestone | 0d | 2026-08-13 | 2026-08-13 | 3237 | 2025-12-30 | 2025-12-30 | 0d | 355d |  | finish no earlier than 2025-12-30 | Business & Operation Readiness | 5.31 | 463.71 | Red | RED |  |  |
| 3239 | 1.10.2.4.3 | **Wave 3 - Service Activation Implementation MDD** |  | 839d | 2022-10-31 | 2026-01-15 |  | 2022-10-31 | 2026-01-15 | 0d | 505d |  |  | Business & Operation Readiness | 5.31 |  |  |  |  |  |
| 3240 | 1.10.2.4.3.1 | MDD Manual Load |  | 7d | 2025-12-29 | 2026-01-06 |  | 2025-12-29 | 2026-01-06 | 0d | 512d |  | finish no earlier than 2026-01-06 | Business & Operation Readiness | 5.31 | 236.33 | Green | GREEN |  |  |
| 3241 | 1.10.2.4.3.2 | MDD Update |  | 269d | 2025-01-06 | 2026-01-15 |  | 2025-01-06 | 2026-01-15 | 0d | 505d |  | finish no earlier than 2026-01-15 | Business & Operation Readiness | 5.31 | -120.67 | Overdue Start | GREEN |  |  |
| 3242 | 1.10.2.4.3.3 | Wave 3 - Service Activation Implementation MDD Complete (M) | milestone | 0d | 2022-10-31 | 2022-10-31 |  | 2022-10-31 | 2022-10-31 | 0d | 1344d |  |  | Business & Operation Readiness | 5.31 | -918.67 | Overdue Start | RED | Dates to be confirmed |  |
| 3243 | 1.10.2.4.4 | **Wave 3 - Service Activation Hypercare** |  | 840d | 2022-10-31 | 2026-01-16 |  | 2022-10-31 | 2026-01-16 | 0d | 504d |  |  | Business & Operation Readiness | 5.31 |  |  |  |  |  |
| 3244 | 1.10.2.4.4.1 | Service& Process Monitoring |  | 20d | 2025-12-22 | 2026-01-16 |  | 2025-12-22 | 2026-01-16 | 0d | 504d |  | finish no earlier than 2026-01-16 | Business & Operation Readiness | 5.31 | 229.33 | Green | GREEN |  |  |
| 3245 | 1.10.2.4.4.2 | Daily Reporting |  | 20d | 2025-12-22 | 2026-01-16 |  | 2025-12-22 | 2026-01-16 | 0d | 504d |  | finish no earlier than 2026-01-16 | Business & Operation Readiness | 5.31 | 229.33 | Green | GREEN |  |  |
| 3246 | 1.10.2.4.4.3 | Issue Management |  | 20d | 2025-12-22 | 2026-01-16 |  | 2025-12-22 | 2026-01-16 | 0d | 504d |  | finish no earlier than 2026-01-16 | Business & Operation Readiness | 5.31 | 229.33 | Green | GREEN |  |  |
| 3247 | 1.10.2.4.4.4 | SA Hypercare Close Down Activities |  | 20d | 2025-12-22 | 2026-01-16 |  | 2025-12-22 | 2026-01-16 | 0d | 504d |  | finish no earlier than 2026-01-16 | Business & Operation Readiness | 5.31 | 229.33 | Green | GREEN |  |  |
| 3248 | 1.10.2.4.4.5 | Handover to MHHSP |  | 4d | 2026-01-12 | 2026-01-15 |  | 2026-01-12 | 2026-01-15 | 0d | 505d |  | finish no earlier than 2026-01-15 | Business & Operation Readiness | 5.31 | 250.33 | Green | GREEN |  | MHHSP |
| 3249 | 1.10.2.4.4.6 | Wave 3 Service Activation Hypercare Complete (M) | milestone | 0d | 2022-10-31 | 2022-10-31 |  | 2022-10-31 | 2022-10-31 | 0d | 1344d |  |  | Business & Operation Readiness | 5.31 | -918.67 | Overdue Start | RED | Date to be confirmed |  |
| 3250 | 1.10.2.5 | **Wave 4** |  | 1043d | 2022-10-31 | 2026-10-28 |  | 2022-10-31 | 2026-10-22 | 0d | 301d |  |  | Business & Operation Readiness | 5.31 | -650.67 | Overdue Start | RED |  |  |
| 3251 | 1.10.2.5.1 | **SIT Non-MVC Service Activation Preparation Tasks** |  | 1043d | 2022-10-31 | 2026-10-28 |  | 2022-10-31 | 2026-10-22 | 0d | 301d |  |  | Business & Operation Readiness | 5.31 | -651.67 | Overdue Start | RED |  |  |
| 3252 | 1.10.2.5.1.1 | Helix Preparatory Activities Complete | milestone | 0d | 2022-10-31 | 2022-10-31 |  | 2022-10-31 | 2022-10-31 | 0d | 1344d |  |  | Business & Operation Readiness | 5.29 | -918.67 | Overdue Start | RED |  |  |
| 3253 | 1.10.2.5.1.2 | MHHSP Confirms Wave 4 PPs MHHS Enabled |  | 1d | 2022-10-31 | 2022-10-31 |  | 2022-10-31 | 2022-10-31 | 0d | 1319d | 1018d |  | Business & Operation Readiness | 5.28 | -918.67 | Overdue Start | RED |  |  |
| 3254 | 1.10.2.5.1.3 | Wave 4 Service Activation |  | 24d | 2026-09-25 | 2026-10-28 | 2544, 3253 | 2026-09-21 | 2026-10-22 | 25d | 301d |  |  | Business & Operation Readiness | 5.24 | 506.33 | yellow | RED |  |  |

Notes:
- 3231: 07/05/25 - Service Activation plan still under going development, but dates have been amended.
- 3232: 07/05/25 - Service Activation plan still under going development, but dates have been amended.
- 3233: 07/05/25 - Service Activation plan still under going development, but dates have been amended.
- 3234: 07/05/25 - Service Activation plan still under going development, but dates have been amended.
- 3235: 07/05/25 - Service Activation plan still under going development, but dates have been amended.
- 3236: 07/05/25 - Service Activation plan still under going development, but dates have been amended.
- 3237: 07/05/25 - Service Activation plan still under going development, but dates have been amended.
- 3238: 07/05/25 - Service Activation plan still under going development, but dates have been amended.
- 3239: 07/05/25 - Service Activation plan still under going development, but dates have been amended.
- 3240: 07/05/25 - Service Activation plan still under going development, but dates have been amended.
- 3241: 07/05/25 - Service Activation plan still under going development, but dates have been amended.
- 3242: 07/05/25 - Service Activation plan still under going development, but dates have been amended.
- 3243: 07/05/25 - Service Activation plan still under going development, but dates have been amended.
- 3244: 07/05/25 - Service Activation plan still under going development, but dates have been amended.
- 3245: 07/05/25 - Service Activation plan still under going development, but dates have been amended.
- 3246: 07/05/25 - Service Activation plan still under going development, but dates have been amended.
- 3247: 07/05/25 - Service Activation plan still under going development, but dates have been amended.
- 3248: 07/05/25 - Service Activation plan still under going development, but dates have been amended.
- 3249: 07/05/25 - Service Activation plan still under going development, but dates have been amended.
- 3250: 07/05/25 - Service Activation plan still under going development, but dates have been amended.
- 3251: 07/05/25 - Service Activation plan still under going development, but dates have been amended.
- 3252: 07/05/25 - Service Activation plan still under going development, but dates have been amended. / Action: 12/8/24: Emailed helix to clarify what needs to go in the prep section and if hypercare is required
- 3253: 07/05/25 - Service Activation plan still under going development, but dates have been amended.
- 3254: 07/05/25 - Service Activation plan still under going development, but dates have been amended.

| ID | WBS | Task | Type | Duration | Start | Finish | Predecessors | Baseline start | Baseline finish | Baseline duration | Total slack | Free slack | Constraint | Text9 | Update Version | Task Status | Sched Status | RAG | Involved | Responsible |
| --- | --- | --- | --- | --- | --- | --- | --- | --- | --- | --- | --- | --- | --- | --- | --- | --- | --- | --- | --- | --- |
| 3255 | 1.10.2.5.2 | **Wave 4 - Service Activation Implementation** |  | 158d | 2026-03-02 | 2026-10-07 |  | 2025-03-03 | 2026-03-06 | 0d | 316d |  |  | Business & Operation Readiness | 5.31 |  |  |  |  |  |
| 3256 | 1.10.2.5.2.1 | MHHSP Enabled Confirmation |  | 2d | 2026-03-02 | 2026-03-03 |  | 2026-03-02 | 2026-03-03 | 0d | 472d |  | finish no earlier than 2026-03-03 | Business & Operation Readiness | 5.31 | 299.33 | Green | GREEN |  |  |
| 3257 | 1.10.2.5.2.2 | PAB Approval |  | 1d | 2026-09-25 | 2026-09-25 | 2544 | 2025-03-03 | 2025-03-03 | 0d | 316d | 0d | finish no earlier than 2025-03-03 | Business & Operation Readiness | 5.31 | 506.33 | Red | RED |  |  |
| 3258 | 1.10.2.5.2.3 | Add EFD to DIP |  | 2d | 2026-09-28 | 2026-09-29 | 3257 | 2026-03-03 | 2026-03-04 | 0d | 316d | 0d | finish no earlier than 2026-03-04 | Business & Operation Readiness | 5.31 | 509.33 | Red | RED |  |  |
| 3259 | 1.10.2.5.2.4 | DIP Promoted to Production |  | 2d | 2026-09-30 | 2026-10-01 | 3258 | 2026-03-04 | 2026-03-05 | 0d | 316d | 0d | finish no earlier than 2026-03-05 | Business & Operation Readiness | 5.31 | 511.33 | Red | RED |  |  |
| 3260 | 1.10.2.5.2.5 | Create M16 in Customer Solution |  | 2d | 2026-10-02 | 2026-10-05 | 3259 | 2026-03-05 | 2026-03-06 | 0d | 316d | 0d | finish no earlier than 2026-03-06 | Business & Operation Readiness | 5.31 | 513.33 | Red | RED |  |  |
| 3261 | 1.10.2.5.2.6 | Publish ISD |  | 2d | 2026-10-06 | 2026-10-07 | 3260 | 2026-03-05 | 2026-03-06 | 0d | 316d | 0d | finish no earlier than 2026-03-06 | Business & Operation Readiness | 5.31 | 517.33 | Red | RED |  |  |
| 3262 | 1.10.2.5.2.7 | Wave 4 - Service Activation Implementation Complete (M) | milestone | 0d | 2026-10-07 | 2026-10-07 | 3261 | 2026-03-06 | 2026-03-06 | 0d | 316d |  | finish no earlier than 2026-03-06 | Business & Operation Readiness | 5.31 | 518.71 | Red | RED |  |  |
| 3263 | 1.10.2.5.3 | **Wave 4 - Service Activation Implementation MDD** |  | 15d | 2026-03-06 | 2026-03-26 |  | 2026-03-06 | 2026-03-26 | 0d | 455d |  |  | Business & Operation Readiness | 5.31 |  |  |  |  |  |
| 3264 | 1.10.2.5.3.1 | MDD Manual Load |  | 7d | 2026-03-06 | 2026-03-16 |  | 2026-03-06 | 2026-03-16 | 0d | 463d |  | finish no earlier than 2026-03-16 | Business & Operation Readiness | 5.31 | 303.33 | Green | GREEN |  |  |
| 3265 | 1.10.2.5.3.2 | MDD Update |  | 9d | 2026-03-16 | 2026-03-26 |  | 2026-03-16 | 2026-03-26 | 0d | 455d |  | finish no earlier than 2026-03-26 | Business & Operation Readiness | 5.31 | 313.33 | Green | GREEN |  |  |
| 3266 | 1.10.2.5.3.3 | Wave 4 - Service Activation Implementation MDD Complete | milestone | 0d | 2026-03-25 | 2026-03-25 |  | 2026-03-25 | 2026-03-25 | 0d | 456d |  | finish no earlier than 2026-03-25 | Business & Operation Readiness | 5.31 | 322.71 | Green | GREEN |  |  |
| 3267 | 1.10.2.5.4 | **Wave 4 - Service Activation Hypercare** |  | 19d | 2026-03-02 | 2026-03-26 |  | 2026-03-02 | 2026-03-26 | 0d | 455d |  |  | Business & Operation Readiness | 5.31 |  |  |  |  |  |
| 3268 | 1.10.2.5.4.1 | Service& Process Monitoring |  | 19d | 2026-03-02 | 2026-03-26 |  | 2026-03-02 | 2026-03-26 | 0d | 455d |  | finish no earlier than 2026-03-26 | Business & Operation Readiness | 5.31 | 299.33 | Green | GREEN |  |  |
| 3269 | 1.10.2.5.4.2 | Daily Reporting |  | 19d | 2026-03-02 | 2026-03-26 |  | 2026-03-02 | 2026-03-26 | 0d | 455d |  | finish no earlier than 2026-03-26 | Business & Operation Readiness | 5.31 | 299.33 | Green | GREEN |  |  |
| 3270 | 1.10.2.5.4.3 | Issue Management |  | 19d | 2026-03-02 | 2026-03-26 |  | 2026-03-02 | 2026-03-26 | 0d | 455d |  | finish no earlier than 2026-03-26 | Business & Operation Readiness | 5.31 | 299.33 | Green | GREEN |  |  |
| 3271 | 1.10.2.5.4.4 | SA Hypercare Close Down Activities |  | 19d | 2026-03-02 | 2026-03-26 |  | 2026-03-02 | 2026-03-26 | 0d | 455d |  | finish no earlier than 2026-03-26 | Business & Operation Readiness | 5.31 | 299.33 | Green | GREEN |  |  |
| 3272 | 1.10.2.5.4.5 | Handover to MHHSP |  | 4d | 2026-03-02 | 2026-03-05 |  | 2026-03-02 | 2026-03-05 | 0d | 470d |  | finish no earlier than 2026-03-05 | Business & Operation Readiness | 5.31 | 299.33 | Green | GREEN | MHHSP |  |
| 3273 | 1.10.2.5.4.6 | Wave 4 - Service Activation Hypercare Complete (M) | milestone | 0d | 2026-03-25 | 2026-03-25 |  | 2026-03-25 | 2026-03-25 | 0d | 456d |  | finish no earlier than 2026-03-25 | Business & Operation Readiness | 5.31 | 322.71 | Green | GREEN |  |  |
| 3274 | 1.10.2.6 | **Non-SIT LDSO** |  | 754d | 2022-10-31 | 2025-09-18 |  | 2022-10-31 | 2025-09-01 | 0d | 590d |  |  | Business & Operation Readiness | 5.31 | -650.67 | Overdue Start | RED |  |  |
| 3275 | 1.10.2.6.1 | **Non-SIT LDSO Service Activation Data Loading** |  | 176d | 2024-06-07 | 2025-02-07 |  | 2024-06-07 | 2025-02-07 | 0d | 749d |  |  | Business & Operation Readiness | 5.31 |  |  |  |  |  |
| 3276 | 1.10.2.6.1.1 | Define pre Non-SIT LDSO upfront activities |  | 7d | 2024-06-07 | 2024-06-17 |  | 2024-06-07 | 2024-06-17 | 0d | 918d |  | finish no earlier than 2024-06-17 | Business & Operation Readiness | 5.31 | -333.67 | Overdue Start | RED |  |  |
| 3277 | 1.10.2.6.1.2 | **Execute Non-SIT LDSO Activities** |  | 5d | 2025-02-03 | 2025-02-07 |  | 2025-02-03 | 2025-02-07 | 0d | 749d |  |  | Business & Operation Readiness | 5.31 |  |  |  |  |  |
| 3278 | 1.10.2.6.1.2.1 | Create Entity Forms in Customer Solution |  | 3d | 2025-02-03 | 2025-02-05 |  | 2025-02-03 | 2025-02-05 | 0d | 751d |  | finish no earlier than 2025-02-05 | Business & Operation Readiness | 5.31 | -92.67 | Overdue Start | RED |  | PMP |
| 3279 | 1.10.2.6.1.2.2 | DIP - Promote to Production Environment |  | 3d | 2025-02-03 | 2025-02-05 |  | 2025-02-03 | 2025-02-05 | 0d | 751d |  | finish no earlier than 2025-02-05 | Business & Operation Readiness | 5.31 | -92.67 | Overdue Start | RED |  | DIP |
| 3280 | 1.10.2.6.1.2.3 | DIP - Enable Technology capabilities for participants |  | 3d | 2025-02-03 | 2025-02-05 |  | 2025-02-03 | 2025-02-05 | 0d | 751d |  | finish no earlier than 2025-02-05 | Business & Operation Readiness | 5.31 | -92.67 | Overdue Start | RED |  | DIP |
| 3281 | 1.10.2.6.1.2.4 | DIP - Add EFD to DIP |  | 3d | 2025-02-03 | 2025-02-05 |  | 2025-02-03 | 2025-02-05 | 0d | 751d |  | finish no earlier than 2025-02-05 | Business & Operation Readiness | 5.31 | -92.67 | Overdue Start | RED |  | DIP |
| 3282 | 1.10.2.6.1.2.5 | ISD - Replicate Entity Forms from CS |  | 2d | 2025-02-06 | 2025-02-07 |  | 2025-02-06 | 2025-02-07 | 0d | 749d |  | finish no earlier than 2025-02-07 | Business & Operation Readiness | 5.31 | -89.67 | Overdue Start | RED |  | HELIX |
| 3283 | 1.10.2.6.1.2.6 | MDD - Load MHHS roles |  | 3d | 2025-02-03 | 2025-02-05 |  | 2025-02-03 | 2025-02-05 | 0d | 751d |  | finish no earlier than 2025-02-05 | Business & Operation Readiness | 5.31 | -92.67 | Overdue Start | RED |  | PMP |
| 3284 | 1.10.2.6.1.3 | Non-SIT LDSO Service Activation Data Loading Completed (M) | milestone | 0d | 2025-02-07 | 2025-02-07 |  | 2025-02-07 | 2025-02-07 | 0d | 749d |  | finish no earlier than 2025-02-07 | Business & Operation Readiness | 5.31 | -88.29 | Overdue Start | RED |  |  |

Notes:
- 3255: 07/05/25 - Service Activation plan still under going development, but dates have been amended.
- 3256: 07/05/25 - Service Activation plan still under going development, but dates have been amended.
- 3257: 07/05/25 - Service Activation plan still under going development, but dates have been amended.
- 3258: 07/05/25 - Service Activation plan still under going development, but dates have been amended.
- 3259: 07/05/25 - Service Activation plan still under going development, but dates have been amended.
- 3260: 07/05/25 - Service Activation plan still under going development, but dates have been amended.
- 3261: 07/05/25 - Service Activation plan still under going development, but dates have been amended.
- 3262: 07/05/25 - Service Activation plan still under going development, but dates have been amended.
- 3263: 07/05/25 - Service Activation plan still under going development, but dates have been amended.
- 3264: 07/05/25 - Service Activation plan still under going development, but dates have been amended.
- 3265: 07/05/25 - Service Activation plan still under going development, but dates have been amended.
- 3266: 07/05/25 - Service Activation plan still under going development, but dates have been amended.
- 3267: 07/05/25 - Service Activation plan still under going development, but dates have been amended.
- 3268: 07/05/25 - Service Activation plan still under going development, but dates have been amended.
- 3269: 07/05/25 - Service Activation plan still under going development, but dates have been amended.
- 3270: 07/05/25 - Service Activation plan still under going development, but dates have been amended.
- 3271: 07/05/25 - Service Activation plan still under going development, but dates have been amended.
- 3272: 07/05/25 - Service Activation plan still under going development, but dates have been amended.
- 3273: 07/05/25 - Service Activation plan still under going development, but dates have been amended.
- 3274: 07/05/25 - Service Activation plan still under going development, but dates have been amended.
- 3275: 07/05/25 - Service Activation plan still under going development, but dates have been amended.
- 3276: 07/05/25 - Service Activation plan still under going development, but dates have been amended.
- 3277: 07/05/25 - Service Activation plan still under going development, but dates have been amended.
- 3278: 07/05/25 - Service Activation plan still under going development, but dates have been amended.
- 3279: 07/05/25 - Service Activation plan still under going development, but dates have been amended.
- 3280: 07/05/25 - Service Activation plan still under going development, but dates have been amended.
- 3281: 07/05/25 - Service Activation plan still under going development, but dates have been amended.
- 3282: 07/05/25 - Service Activation plan still under going development, but dates have been amended.
- 3283: 07/05/25 - Service Activation plan still under going development, but dates have been amended.
- 3284: 07/05/25 - Service Activation plan still under going development, but dates have been amended.

| ID | WBS | Task | Type | Duration | Start | Finish | Predecessors | Baseline start | Baseline finish | Baseline duration | Total slack | Free slack | Constraint | Text9 | Task Status | Update Version | Sched Status | RAG | Responsible | Involved |
| --- | --- | --- | --- | --- | --- | --- | --- | --- | --- | --- | --- | --- | --- | --- | --- | --- | --- | --- | --- | --- |
| 3285 | 1.10.2.6.2 | **SIT Non-MVC Service Activation Preparation Tasks** |  | 754d | 2022-10-31 | 2025-09-18 |  | 2022-10-31 | 2025-09-01 | 0d | 590d |  |  | Business & Operation Readiness | -651.67 | 5.31 | Overdue Start | RED |  |  |
| 3286 | 1.10.2.6.2.1 | Helix Preparatory Activities Complete | milestone | 0d | 2022-10-31 | 2022-10-31 |  | 2022-10-31 | 2022-10-31 | 0d | 1344d |  |  | Business & Operation Readiness | -918.67 | 5.29 | Overdue Start | RED |  |  |
| 3287 | 1.10.2.6.2.2 | MHHSP Confirms Non-SIT LDSO PPs MHHS Enabled |  | 1d | 2022-10-31 | 2022-10-31 |  | 2022-10-31 | 2022-10-31 | 0d | 756d | 747d |  | Business & Operation Readiness | -918.67 | 5.28 | Overdue Start | RED |  |  |
| 3288 | 1.10.2.6.2.3 | Non-SIT LDSO Service Activation |  | 6d | 2025-09-11 | 2025-09-18 | 3287, 2243 | 2025-08-25 | 2025-09-01 | 9d | 9d | 4d |  | Business & Operation Readiness | 127.33 | 6.12 | Red | RED |  |  |
| 3289 | 1.10.2.6.3 | **Non-SIT LDSO Service Activation Implementation** |  | 4d | 2025-02-24 | 2025-02-27 |  | 2025-02-24 | 2025-02-27 | 0d | 735d |  |  | Business & Operation Readiness |  | 5.31 |  |  |  |  |
| 3290 | 1.10.2.6.3.1 | MHHSP Enabled Confirmation |  | 2d | 2025-02-24 | 2025-02-25 |  | 2025-02-24 | 2025-02-25 | 0d | 737d |  | finish no earlier than 2025-02-25 | Business & Operation Readiness | -71.67 | 5.31 | Overdue Start | RED | MHHSP |  |
| 3291 | 1.10.2.6.3.2 | PAB Approval |  | 2d | 2025-02-24 | 2025-02-25 |  | 2025-02-24 | 2025-02-25 | 0d | 737d |  | finish no earlier than 2025-02-25 | Business & Operation Readiness | -71.67 | 5.31 | Overdue Start | RED | QUALF |  |
| 3292 | 1.10.2.6.3.3 | Add EFD to DIP |  | 2d | 2025-02-25 | 2025-02-26 |  | 2025-02-25 | 2025-02-26 | 0d | 736d |  | finish no earlier than 2025-02-26 | Business & Operation Readiness | -70.67 | 5.31 | Overdue Start | RED | DIP |  |
| 3293 | 1.10.2.6.3.4 | DIP Promoted to Production |  | 2d | 2025-02-26 | 2025-02-27 |  | 2025-02-26 | 2025-02-27 | 0d | 735d |  | finish no earlier than 2025-02-27 | Business & Operation Readiness | -69.67 | 5.31 | Overdue Start | RED | DIP |  |
| 3294 | 1.10.2.6.3.5 | Create M16 in Customer Solution |  | 2d | 2025-02-26 | 2025-02-27 |  | 2025-02-26 | 2025-02-27 | 0d | 735d |  | finish no earlier than 2025-02-27 | Business & Operation Readiness | -69.67 | 5.31 | Overdue Start | RED | PMP |  |
| 3295 | 1.10.2.6.3.6 | Publish ISD |  | 2d | 2025-02-26 | 2025-02-27 |  | 2025-02-26 | 2025-02-27 | 0d | 735d |  | finish no earlier than 2025-02-27 | Business & Operation Readiness | -69.67 | 5.31 | Overdue Start | RED |  |  |
| 3296 | 1.10.2.6.3.7 | Non-SIT LDSO Service Activation Implementation Completed (M) | milestone | 0d | 2025-02-27 | 2025-02-27 |  | 2025-02-27 | 2025-02-27 | 0d | 735d |  | finish no earlier than 2025-02-27 | Business & Operation Readiness | -68.29 | 5.31 | Overdue Start | RED |  |  |
| 3297 | 1.10.2.6.4 | **Non-SIT LDSO Service Activation Implementation MDD** |  | 14d | 2025-02-27 | 2025-03-18 |  | 2025-02-27 | 2025-03-18 | 0d | 722d |  |  | Business & Operation Readiness |  | 5.31 |  |  |  |  |
| 3298 | 1.10.2.6.4.1 | MDD Manual Load |  | 7d | 2025-02-27 | 2025-03-07 |  | 2025-02-27 | 2025-03-07 | 0d | 729d |  | finish no earlier than 2025-03-07 | Business & Operation Readiness | -68.67 | 5.31 | Overdue Start | RED | PMP |  |
| 3299 | 1.10.2.6.4.2 | MDD Update |  | 8d | 2025-03-07 | 2025-03-18 |  | 2025-03-07 | 2025-03-18 | 0d | 722d |  | finish no earlier than 2025-03-18 | Business & Operation Readiness | -60.67 | 5.31 | Overdue Start | RED | PMP |  |
| 3300 | 1.10.2.6.4.3 | Non-SIT LDSO Service Activation Implementation MDD Complete (M) | milestone | 0d | 2025-03-18 | 2025-03-18 |  | 2025-03-18 | 2025-03-18 | 0d | 722d |  | finish no earlier than 2025-03-18 | Business & Operation Readiness | -49.29 | 5.31 | Overdue Start | RED |  |  |
| 3301 | 1.10.2.6.5 | **Non-SIT LDSO Service Activation Hypercare** |  | 18d | 2025-02-24 | 2025-03-19 |  | 2025-02-24 | 2025-03-19 | 0d | 721d |  |  | Business & Operation Readiness |  | 5.31 |  |  |  |  |
| 3302 | 1.10.2.6.5.1 | **Non-SIT LDSO Service Activation Hypercare Support** |  | 18d | 2025-02-24 | 2025-03-19 |  | 2025-02-24 | 2025-03-19 | 0d | 721d |  |  | Business & Operation Readiness |  | 5.31 |  |  |  |  |
| 3303 | 1.10.2.6.5.1.1 | Service& Process Monitoring |  | 18d | 2025-02-24 | 2025-03-19 |  | 2025-02-24 | 2025-03-19 | 0d | 721d |  | finish no earlier than 2025-03-19 | Business & Operation Readiness | -71.67 | 5.31 | Overdue Start | RED |  |  |
| 3304 | 1.10.2.6.5.1.2 | Daily Reporting |  | 18d | 2025-02-24 | 2025-03-19 |  | 2025-02-24 | 2025-03-19 | 0d | 721d |  | finish no earlier than 2025-03-19 | Business & Operation Readiness | -71.67 | 5.31 | Overdue Start | RED |  |  |
| 3305 | 1.10.2.6.5.1.3 | Issue Management |  | 18d | 2025-02-24 | 2025-03-19 |  | 2025-02-24 | 2025-03-19 | 0d | 721d |  | finish no earlier than 2025-03-19 | Business & Operation Readiness | -71.67 | 5.31 | Overdue Start | RED |  |  |
| 3306 | 1.10.2.6.5.1.4 | SA Hypercare Close Down Activities |  | 18d | 2025-02-24 | 2025-03-19 |  | 2025-02-24 | 2025-03-19 | 0d | 721d |  | finish no earlier than 2025-03-19 | Business & Operation Readiness | -71.67 | 5.31 | Overdue Start | RED |  |  |
| 3307 | 1.10.2.6.5.1.5 | Handover to MHHSP |  | 3d | 2025-03-14 | 2025-03-18 |  | 2025-03-14 | 2025-03-18 | 0d | 722d |  | finish no earlier than 2025-03-18 | Business & Operation Readiness | -53.67 | 5.31 | Overdue Start | RED |  | MHHSP |
| 3308 | 1.10.2.6.5.1.6 | Non-SIT LDSO Service Activation Hypercare Complete (M) | milestone | 0d | 2025-03-18 | 2025-03-18 |  | 2025-03-18 | 2025-03-18 | 0d | 722d |  | finish no earlier than 2025-03-18 | Business & Operation Readiness | -49.29 | 5.31 | Overdue Start | RED |  |  |

Notes:
- 3285: 07/05/25 - Service Activation plan still under going development, but dates have been amended.
- 3286: 07/05/25 - Service Activation plan still under going development, but dates have been amended. / Action: 12/8/24: Emailed helix to clarify what needs to go in the prep section and if hypercare is required
- 3287: 07/05/25 - Service Activation plan still under going development, but dates have been amended.
- 3288: 07/05/25 - Service Activation plan still under going development, but dates have been amended.
- 3289: 07/05/25 - Service Activation plan still under going development, but dates have been amended.
- 3290: 07/05/25 - Service Activation plan still under going development, but dates have been amended.
- 3291: 07/05/25 - Service Activation plan still under going development, but dates have been amended.
- 3292: 07/05/25 - Service Activation plan still under going development, but dates have been amended.
- 3293: 07/05/25 - Service Activation plan still under going development, but dates have been amended.
- 3294: 07/05/25 - Service Activation plan still under going development, but dates have been amended.
- 3295: 07/05/25 - Service Activation plan still under going development, but dates have been amended.
- 3296: 07/05/25 - Service Activation plan still under going development, but dates have been amended.
- 3297: 07/05/25 - Service Activation plan still under going development, but dates have been amended.
- 3298: 07/05/25 - Service Activation plan still under going development, but dates have been amended.
- 3299: 07/05/25 - Service Activation plan still under going development, but dates have been amended.
- 3300: 07/05/25 - Service Activation plan still under going development, but dates have been amended.
- 3301: 07/05/25 - Service Activation plan still under going development, but dates have been amended.
- 3302: 07/05/25 - Service Activation plan still under going development, but dates have been amended.
- 3303: 07/05/25 - Service Activation plan still under going development, but dates have been amended.
- 3304: 07/05/25 - Service Activation plan still under going development, but dates have been amended.
- 3305: 07/05/25 - Service Activation plan still under going development, but dates have been amended.
- 3306: 07/05/25 - Service Activation plan still under going development, but dates have been amended.
- 3307: 07/05/25 - Service Activation plan still under going development, but dates have been amended.
- 3308: 07/05/25 - Service Activation plan still under going development, but dates have been amended.

| ID | WBS | Task | Type | Duration | Start | Finish | Predecessors | Baseline start | Baseline finish | Baseline duration | Baseline 1 start | Baseline 1 finish | Total slack | Free slack | Constraint | Baseline cost | Responsible | Involved | Text9 | Update Version | MHHS Resource Name | MHHS Programme Phase | Artefact ID | Task Status | Sched Status | RAG | Action | Milestone ID | Text29 | Tier |
| --- | --- | --- | --- | --- | --- | --- | --- | --- | --- | --- | --- | --- | --- | --- | --- | --- | --- | --- | --- | --- | --- | --- | --- | --- | --- | --- | --- | --- | --- | --- |
| 3309 | 1.10.3 | **Implement Early Life Support Plan** |  | 55d | 2025-07-07 | 2025-09-19 |  | 2025-07-07 | 2025-09-19 | 45d | 2025-01-06 | 2025-02-28 | 589d |  |  | -0 | N/A | N/A | Business & Operation Readiness | 5.0 | N/A | Business & Operational Readiness |  |  |  |  |  |  |  |  |
| 3310 | 1.10.3.1 | Implement Early Life Support Plan |  | 55d | 2025-07-07 | 2025-09-19 |  | 2025-07-07 | 2025-09-19 | 45d | 2025-02-28 | 2025-02-28 | 589d |  | start no earlier than 2025-07-07 |  | SI Transition | SI Transition,CPT | Business & Operation Readiness | 5.23 | Matthew Breen | Business & Operational Readiness | MHHS-ART095 | 61.33 | Green | GREEN |  |  |  |  |
| 3311 | 1.10.4 | **Business Continuity and Disaster Recovery Plan** |  | 40d | 2025-07-31 | 2025-09-24 |  | 2025-07-31 | 2025-09-24 | 40d | 2025-01-13 | 2025-03-07 | 586d |  |  |  | N/A | N/A | Business & Operation Readiness | 5.0 | N/A | Business & Operational Readiness |  |  |  |  |  |  |  |  |
| 3312 | 1.10.4.1 | Central Parties BCDRs in Place |  | 20d | 2025-07-31 | 2025-08-27 | 2715FS-38d | 2025-07-31 | 2025-08-27 | 20d | 2025-01-13 | 2025-02-07 | 586d | 0d |  |  | SI Design |  | Business & Operation Readiness | 5.0 | MHHS Programme | Business & Operational Readiness |  | 85.33 | Green | GREEN |  |  |  |  |
| 3313 | 1.10.4.2 | Risk Based Assurance of Cental Party BCDRs |  | 20d | 2025-08-28 | 2025-09-24 | 3312 | 2025-08-28 | 2025-09-24 | 20d | 2025-02-10 | 2025-03-07 | 586d |  |  |  | PP | SI Design | Business & Operation Readiness | 5.0 | MHHS Programme | Business & Operational Readiness |  | 113.33 | Green | GREEN |  |  |  |  |
| 3314 | 1.10.5 | **Training and Support Materials** |  | 39d | 2025-08-21 | 2025-10-14 |  | 2025-08-21 | 2025-10-14 | 40d | 2025-02-03 | 2025-03-28 | 572d |  |  |  | N/A | N/A | Business & Operation Readiness | 5.0 | N/A | Business & Operational Readiness |  |  |  |  | 10/5: To be reworked with better clarity (LH) |  |  |  |
| 3315 | 1.10.5.1 | Develop document |  | 20d | 2025-08-21 | 2025-09-17 | 3100FS-45d | 2025-08-21 | 2025-09-17 | 20d | 2025-02-03 | 2025-02-28 | 572d | 0d |  |  | SI Migration | CPT | Business & Operation Readiness | 5.0 | PPC | Business & Operational Readiness |  | 106.33 | Green | GREEN |  |  |  |  |
| 3316 | 1.10.5.2 | Document review and update |  | 19d | 2025-09-18 | 2025-10-14 | 3315 | 2025-09-18 | 2025-10-14 | 20d | 2025-03-03 | 2025-03-28 | 572d | 0d |  |  | SI Migration | PMO,CPT,IPA,PP | Business & Operation Readiness | 5.0 | PPC | Business & Operational Readiness |  | 134.33 | Green | GREEN |  |  |  |  |
| 3317 | 1.10.5.3 | Training and Support Materials approved | milestone | 0d | 2025-10-14 | 2025-10-14 | 3316 | 2025-10-14 | 2025-10-14 | 0d | 2025-03-28 | 2025-03-28 | 572d |  |  |  | SI Migration | PMO,CPT | Business & Operation Readiness | 5.0 | PPC | Business & Operational Readiness | MHHS-ART118 | 160.71 | Green | GREEN |  |  |  |  |
| 3318 | 1.10.6 | **PP Business Change** |  | 129d | 2025-02-03 | 2025-07-31 |  | 2025-02-03 | 2025-07-31 | 129d | 2025-02-03 | 2025-07-31 | 625d |  |  |  | N/A | N/A | Business & Operation Readiness | 5.0 | N/A | Business & Operational Readiness |  | M11 |  |  | 10/5: Review with PPC (LH) |  |  |  |
| 3319 | 1.10.6.1 | Plan stakeholder management |  | 129d | 2025-02-03 | 2025-07-31 |  | 2025-02-03 | 2025-07-31 | 129d | 2025-02-03 | 2025-07-31 | 625d |  | start no earlier than 2025-02-03 |  | PP | PPC | Business & Operation Readiness | 5.0 | PPC | Business & Operational Readiness |  | -92.67 | Overdue Start | GREEN |  |  |  |  |
| 3320 | 1.10.6.2 | Manage stakeholders |  | 129d | 2025-02-03 | 2025-07-31 |  | 2025-02-03 | 2025-07-31 | 129d | 2025-02-03 | 2025-07-31 | 625d |  | start no earlier than 2025-02-03 |  | PP | PPC | Business & Operation Readiness | 5.0 | PPC | Business & Operational Readiness |  | -92.67 | Overdue Start | GREEN |  |  |  |  |
| 3321 | 1.10.6.3 | Develop & implement changes to KPIs, organisation & people management |  | 129d | 2025-02-03 | 2025-07-31 |  | 2025-02-03 | 2025-07-31 | 129d | 2025-02-03 | 2025-07-31 | 625d |  | start no earlier than 2025-02-03 |  | PP | PPC | Business & Operation Readiness | 5.0 | PPC | Business & Operational Readiness |  | -92.67 | Overdue Start | GREEN |  |  |  |  |
| 3322 | 1.10.6.4 | Develop & test changes to business processes |  | 129d | 2025-02-03 | 2025-07-31 |  | 2025-02-03 | 2025-07-31 | 129d | 2025-02-03 | 2025-07-31 | 625d |  | start no earlier than 2025-02-03 |  | PP | PPC | Business & Operation Readiness | 5.0 | PPC | Business & Operational Readiness |  | -92.67 | Overdue Start | GREEN |  |  |  |  |
| 3323 | 1.10.6.5 | Develop and deliver training |  | 129d | 2025-02-03 | 2025-07-31 |  | 2025-02-03 | 2025-07-31 | 129d | 2025-02-03 | 2025-07-31 | 625d |  | start no earlier than 2025-02-03 |  | PP | PPC | Business & Operation Readiness | 5.0 | PPC | Business & Operational Readiness |  | -92.67 | Overdue Start | GREEN |  |  |  |  |
| 3324 | 1.10.6.6 | Programme support for PP Business Change activities |  | 129d | 2025-02-03 | 2025-07-31 |  | 2025-02-03 | 2025-07-31 | 129d | 2025-02-03 | 2025-07-31 | 625d |  | start no earlier than 2025-02-03 |  | PPC | PP | Business & Operation Readiness | 5.0 | PPC | Business & Operational Readiness |  | -92.67 | Overdue Start | GREEN |  |  |  |  |
| 3325 | 1.10.7 | **Transition to New Settlement Timetable (M16)** |  | 566d | 2025-10-22 | 2027-12-23 |  | 2025-10-22 | 2027-12-23 | 560d |  |  | 0d |  |  | -0 | N/A | N/A | Business & Operation Readiness | 5.15 | N/A | Business & Operational Readiness |  | -434.67 |  |  |  |  |  |  |
| 3326 | 1.10.7.1 | Elexon to produce Settlement Calendar for Settlement Year 2025/2026 | milestone | 0d | 2025-10-22 | 2025-10-22 | 3098 | 2025-10-22 | 2025-10-22 | 0d |  |  | 5d | 0d |  |  | PP | PP, Code Bodies | Business & Operation Readiness | 5.15 | Matthew Breen | Business & Operational Readiness |  | 168.71 | Green | GREEN |  |  |  |  |
| 3327 | 1.10.7.2 | Elexon monitor settlement data of migrated MPANs |  | 436d | 2025-10-23 | 2027-06-24 | 3326 | 2025-10-23 | 2027-06-24 | 436d |  |  | 6d |  |  |  | PP | PP, Code Bodies | Business & Operation Readiness | 5.15 | Matthew Breen | Business & Operational Readiness |  | 169.33 | Green | GREEN |  |  |  |  |
| 3328 | 1.10.7.3 | M16 Checkpoint 1 | milestone | 0d | 2026-06-25 | 2026-06-25 | 3326FS+176d | 2026-06-25 | 2026-06-25 | 0d |  |  | 5d | 0d |  |  | PP | PP, Code Bodies | Business & Operation Readiness | 5.15 | Matthew Breen | Business & Operational Readiness |  | 414.71 | Green | GREEN |  |  |  |  |
| 3329 | 1.10.7.4 | Confirm if M16 date retained as 07/12/2026 | milestone | 0d | 2026-07-23 | 2026-07-23 | 3328FS+20d | 2026-07-23 | 2026-07-23 | 0d |  |  | 5d | 0d |  |  | CPT | PP | Business & Operation Readiness | 5.15 | Matthew Breen | Business & Operational Readiness |  | 442.71 | Green | GREEN |  |  |  |  |
| 3330 | 1.10.7.5 | Readiness assessment of participants' readiness to transition to new Settlement Timetable | milestone | 0d | 2026-08-20 | 2026-08-20 | 3329FS+20d | 2026-08-20 | 2026-08-20 | 0d |  |  | 5d | 0d |  |  | CPT | PP | Business & Operation Readiness | 5.15 | Matthew Breen | Business & Operational Readiness |  | 470.71 | Green | GREEN |  |  |  |  |
| 3331 | 1.10.7.6 | Elexon to produce Settlement Calendar for Settlement Year 2026 up until day before M16 cutover | milestone | 0d | 2026-10-19 | 2026-10-19 | 3330FS+42d | 2026-10-19 | 2026-10-19 | 0d |  |  | 5d | 0d |  |  | PP | PP, Code Bodies | Business & Operation Readiness | 5.15 | Matthew Breen | Business & Operational Readiness |  | 530.71 | Green | GREEN |  |  |  |  |
| 3332 | 1.10.7.7 | M16 Checkpoint 2 | milestone | 0d | 2027-04-02 | 2027-04-02 | 3331FS+119d | 2027-04-02 | 2027-04-02 | 0d |  |  | 5d | 0d |  |  | PP | PP, Code Bodies | Business & Operation Readiness | 5.15 | Matthew Breen | Business & Operational Readiness |  | 695.71 | Green | GREEN |  |  |  |  |
| 3333 | 1.10.7.8 | Readiness assessment of participants' readiness to transition to new Settlement Timetable | milestone | 0d | 2027-04-19 | 2027-04-19 | 3332FS+11d | 2027-04-19 | 2027-04-19 | 0d |  |  | 5d | 0d |  |  | CPT | PP | Business & Operation Readiness | 5.15 | Matthew Breen | Business & Operational Readiness |  | 712.71 | Green | GREEN |  |  |  |  |
| 3334 | 1.10.7.9 | Confirm M16 Date | milestone | 0d | 2027-04-30 | 2027-04-30 | 3333FS+9d | 2027-04-30 | 2027-04-30 | 1d |  |  | 5d | 0d |  |  | CPT | Code Bodies,CPT,PP,SRO | Business & Operation Readiness | 5.3 | Matthew Breen | Business & Operational Readiness |  | 723.71 | Green | GREEN |  | T2-EL-0100 | PSG/BSC PAB | T2 |
| 3335 | 1.10.7.10 | Raise fast track change to ISD (November publish) | milestone | 0d | 2027-04-30 | 2027-04-30 | 3334 | 2027-04-30 | 2027-04-30 | 0d |  |  | 45d |  |  |  | PP | PP,CPT,Code Bodies | Business & Operation Readiness | 5.15 | Matthew Breen | Business & Operational Readiness |  | 723.71 | Green | GREEN |  |  |  |  |

| ID | WBS | Task | Type | Duration | Start | Finish | Predecessors | Baseline start | Baseline finish | Baseline duration | Baseline 1 start | Baseline 1 finish | Total slack | Free slack | Responsible | Involved | Text9 | Task Status | Update Version | Sched Status | MHHS Resource Name | MHHS Programme Phase | RAG | Milestone ID | Text29 | Tier | Future RAG | Artefact ID |
| --- | --- | --- | --- | --- | --- | --- | --- | --- | --- | --- | --- | --- | --- | --- | --- | --- | --- | --- | --- | --- | --- | --- | --- | --- | --- | --- | --- | --- |
| 3336 | 1.10.7.11 | **M16 Approval Window** |  | 129d | 2027-06-25 | 2027-12-23 |  | 2027-06-25 | 2027-12-23 | 124d | 2026-12-07 | 2027-05-24 | 0d |  | N/A | N/A | Business & Operation Readiness | 966.71 | 5.0 | Green | N/A | Business & Operational Readiness | GREEN |  |  |  |  |  |
| 3337 | 1.10.7.11.1 | Panel approval that M16 criteria met | milestone | 0d | 2027-06-25 | 2027-06-25 | 3334FS+40d | 2027-06-25 | 2027-06-25 | 0d | 2026-12-07 | 2026-12-07 | 5d |  | Panel | Code Bodies,CPT,PP,SRO | Business & Operation Readiness | 779.71 | 5.0 | Green | Matthew Breen | Business & Operational Readiness | GREEN |  |  |  |  |  |
| 3338 | 1.10.7.11.2 | Cut over to new settlement timetable (M16) | milestone | 0d | 2027-07-02 | 2027-07-02 | 3337, 3102FS+40d, 3327, 3335, 2937 | 2027-07-02 | 2027-07-02 | 0d | 2026-12-07 | 2026-12-07 | 0d |  | CPT | PP | Business & Operation Readiness | 786.71 | 5.0 | Green | Matthew Breen | Business & Operational Readiness | GREEN | T1-EL-1000 | PSG | T1 |  |  |
| 3339 | 1.10.7.11.3 | Maximum 6-month window for approval of M16 |  | 124d | 2027-07-05 | 2027-12-23 | 3338 | 2027-07-05 | 2027-12-23 | 124d | 2026-12-08 | 2027-05-24 | 0d |  | CPT |  | Business & Operation Readiness | 789.33 | 5.0 | Green | Matthew Breen | Business & Operational Readiness | GREEN |  |  |  |  |  |
| 3340 | 1.10.7.11.4 | Cut over to new settlement timetable (M16*) - Late Exit | milestone | 0d | 2027-12-23 | 2027-12-23 | 3339 | 2027-12-23 | 2027-12-23 | 0d | 2027-05-24 | 2027-05-24 | 0d |  | CPT | PP | Business & Operation Readiness | 960.71 | 5.0 | Green | Matthew Breen | Business & Operational Readiness | GREEN | T1-EL-2000 | PSG | T1 |  |  |
| 3341 | 1.11 | **EARLY LIVE RUNNING** |  | 45d | 2027-05-10 | 2027-07-09 |  | 2027-05-10 | 2027-07-09 | 889d | 2024-01-02 | 2027-05-28 | 119d |  | N/A | N/A | Business & Operation Readiness |  |  |  | N/A | Early Live Running |  |  |  |  | 1 Nov 2025 - 30 Apr 2026 |  |
| 3342 | 1.11.1 | **Early Live Running Stabilisation Period** |  | 45d | 2027-05-10 | 2027-07-09 |  | 2027-05-10 | 2027-07-09 | 45d | 2026-10-06 | 2026-12-07 | 119d |  | N/A | N/A | Business & Operation Readiness |  | 5.0 |  | N/A | Early Live Running |  |  |  |  |  |  |
| 3343 | 1.11.1.1 | Manage Early Live Running stabilisation period |  | 45d | 2027-05-10 | 2027-07-09 | 3102 | 2027-05-10 | 2027-07-09 | 45d | 2026-10-06 | 2026-12-07 | 119d | 0d | Code Bodies | PP | Business & Operation Readiness | 733.33 | 5.0 | Green | Matthew Breen | Early Live Running | GREEN |  |  |  |  |  |
| 3344 | 1.11.1.2 | Monitor Early Live Running stabilisation period |  | 45d | 2027-05-10 | 2027-07-09 | 3343SS | 2027-05-10 | 2027-07-09 | 45d | 2026-10-06 | 2026-12-07 | 119d |  | SI Migration | Code Bodies,PP | Business & Operation Readiness | 733.33 | 5.0 | Green | Matthew Breen | Early Live Running | GREEN |  |  |  |  |  |
| 3345 | 1.12 | **PROGRAMME CLOSURE** |  | 80d | 2027-03-08 | 2027-06-25 |  | 2027-03-08 | 2027-06-25 | 85d | 2026-08-04 | 2026-11-30 | 129d |  | N/A | N/A | Programme Closure |  |  |  | N/A | Programme Closure |  |  |  |  |  |  |
| 3346 | 1.12.1 | **Handover Pack** |  | 80d | 2027-03-08 | 2027-06-25 |  | 2027-03-08 | 2027-06-25 | 85d | 2026-08-04 | 2026-11-30 | 129d |  | N/A | N/A | Programme Closure |  | 5.0 |  | N/A | Programme Closure |  |  |  |  |  |  |
| 3347 | 1.12.1.1 | **Draft Handover Pack (for M15)** |  | 40d | 2027-03-08 | 2027-04-30 |  | 2027-03-08 | 2027-04-30 | 40d | 2026-08-04 | 2026-09-28 | 169d |  | N/A | N/A | Programme Closure |  | 5.0 |  | N/A | Programme Closure |  |  |  |  |  |  |
| 3348 | 1.12.1.1.1 | Develop document |  | 20d | 2027-03-08 | 2027-04-02 | 3102FS-45d | 2027-03-08 | 2027-04-02 | 20d | 2026-08-04 | 2026-08-31 | 169d | 0d | PMO | CPT | Programme Closure | 670.33 | 5.0 | Green |  | Programme Closure | GREEN |  |  |  |  |  |
| 3349 | 1.12.1.1.2 | Document review and update |  | 20d | 2027-04-05 | 2027-04-30 | 3348 | 2027-04-05 | 2027-04-30 | 20d | 2026-09-01 | 2026-09-28 | 169d | 0d | SRO | PMO,CPT,IPA,PP | Programme Closure | 698.33 | 5.0 | Green |  | Programme Closure | GREEN |  |  |  |  |  |
| 3350 | 1.12.1.1.3 | Draft Handover Pack approved | milestone | 0d | 2027-04-30 | 2027-04-30 | 3349 | 2027-04-30 | 2027-04-30 | 0d | 2026-09-28 | 2026-09-28 | 169d |  | SRO | PMO,CPT | Programme Closure | 723.71 | 5.0 | Green |  | Programme Closure | GREEN |  |  |  |  | MHHS-ART126 |
| 3351 | 1.12.1.2 | **Master Handover Pack (for M16)** |  | 40d | 2027-05-03 | 2027-06-25 |  | 2027-05-03 | 2027-06-25 | 40d | 2026-10-06 | 2026-11-30 | 129d |  | N/A | N/A | Programme Closure |  | 5.0 |  | N/A | Programme Closure |  |  |  |  |  |  |
| 3352 | 1.12.1.2.1 | Update document |  | 20d | 2027-05-03 | 2027-05-28 | 3338FS-45d | 2027-05-03 | 2027-05-28 | 20d | 2026-10-06 | 2026-11-02 | 129d | 0d | PMO | CPT | Programme Closure | 726.33 | 5.0 | Green |  | Programme Closure | GREEN |  |  |  |  |  |
| 3353 | 1.12.1.2.2 | Document review and update |  | 20d | 2027-05-31 | 2027-06-25 | 3352 | 2027-05-31 | 2027-06-25 | 20d | 2026-11-03 | 2026-11-30 | 129d | 0d | SRO | PMO,CPT,IPA,PP | Programme Closure | 754.33 | 5.0 | Green |  | Programme Closure | GREEN |  |  |  |  |  |
| 3354 | 1.12.1.2.3 | Master Handover Pack approved | milestone | 0d | 2027-06-25 | 2027-06-25 | 3353 | 2027-06-25 | 2027-06-25 | 0d | 2026-11-30 | 2026-11-30 | 129d |  | SRO | PMO,CPT | Programme Closure | 779.71 | 5.0 | Green |  | Programme Closure | GREEN |  |  |  |  | MHHS-ART126 |
| 3355 | 1.12.2 | **Programme Lessons Learned** |  | 40d | 2027-03-08 | 2027-04-30 |  | 2027-03-08 | 2027-04-30 | 40d | 2026-08-04 | 2026-09-28 | 169d |  | N/A | N/A | Programme Closure |  | 5.0 |  | N/A | Programme Closure |  |  |  |  |  |  |
| 3356 | 1.12.2.1 | Develop document |  | 20d | 2027-03-08 | 2027-04-02 | 3102FS-45d | 2027-03-08 | 2027-04-02 | 20d | 2026-08-04 | 2026-08-31 | 169d | 0d | PMO | CPT | Programme Closure | 670.33 | 5.0 | Green |  | Programme Closure | GREEN |  |  |  |  |  |
| 3357 | 1.12.2.2 | Document review and update |  | 20d | 2027-04-05 | 2027-04-30 | 3356 | 2027-04-05 | 2027-04-30 | 20d | 2026-09-01 | 2026-09-28 | 169d | 0d | SRO | PMO,CPT,IPA | Programme Closure | 698.33 | 5.0 | Green |  | Programme Closure | GREEN |  |  |  |  |  |
| 3358 | 1.12.2.3 | Programme Lessons Learned document approved | milestone | 0d | 2027-04-30 | 2027-04-30 | 3357 | 2027-04-30 | 2027-04-30 | 0d | 2026-09-28 | 2026-09-28 | 169d |  | SRO | PMO,CPT | Programme Closure | 723.71 | 5.0 | Green |  | Programme Closure | GREEN |  |  |  |  | MHHS-ART131 |
| 3359 | 1.12.3 | **Programme Closure Report** |  | 40d | 2027-03-08 | 2027-04-30 |  | 2027-03-08 | 2027-04-30 | 40d | 2026-08-04 | 2026-09-28 | 169d |  | N/A | N/A | Programme Closure |  | 5.0 |  | N/A | Programme Closure |  |  |  |  |  |  |
| 3360 | 1.12.3.1 | Develop document |  | 20d | 2027-03-08 | 2027-04-02 | 3102FS-45d | 2027-03-08 | 2027-04-02 | 20d | 2026-08-04 | 2026-08-31 | 169d | 0d | PMO | CPT | Programme Closure | 670.33 | 5.0 | Green |  | Programme Closure | GREEN |  |  |  |  |  |
| 3361 | 1.12.3.2 | Document review and update |  | 20d | 2027-04-05 | 2027-04-30 | 3360 | 2027-04-05 | 2027-04-30 | 20d | 2026-09-01 | 2026-09-28 | 169d | 0d | Ofgem | PMO,CPT,IPA,SRO | Programme Closure | 698.33 | 5.0 | Green |  | Programme Closure | GREEN |  |  |  |  |  |
| 3362 | 1.12.3.3 | Programme Closure Report approved | milestone | 0d | 2027-04-30 | 2027-04-30 | 3361 | 2027-04-30 | 2027-04-30 | 0d | 2026-09-28 | 2026-09-28 | 169d |  | Ofgem | PMO,CPT,IPA,SRO | Programme Closure | 723.71 | 5.0 | Green |  | Programme Closure | GREEN |  |  |  |  | MHHS-ART130 |

| ID | WBS | Task | Type | Duration | Start | Finish | Predecessors | Complete | Remaining | Baseline start | Baseline finish | Baseline duration | Baseline 1 start | Baseline 1 finish | Total slack | Free slack | Responsible | Involved | Text9 | Update Version | MHHS Resource Name | MHHS Programme Phase | Task Status | Sched Status | RAG | Artefact ID | Milestone ID | Text29 | Tier |
| --- | --- | --- | --- | --- | --- | --- | --- | --- | --- | --- | --- | --- | --- | --- | --- | --- | --- | --- | --- | --- | --- | --- | --- | --- | --- | --- | --- | --- | --- |
| 3363 | 1.12.4 | **Benefit Realisation Report** |  | 45d | 2027-03-08 | 2027-05-07 |  |  |  | 2027-03-08 | 2027-05-07 | 45d | 2026-08-04 | 2026-10-05 | 164d |  | N/A | N/A | Programme Closure | 5.0 | N/A | Programme Closure |  |  |  |  |  |  |  |
| 3364 | 1.12.4.1 | Develop document |  | 20d | 2027-03-08 | 2027-04-02 | 3102FS-45d |  |  | 2027-03-08 | 2027-04-02 | 20d | 2026-08-04 | 2026-08-31 | 164d | 0d | PMO | CPT | Programme Closure | 5.0 |  | Programme Closure | 670.33 | Green | GREEN |  |  |  |  |
| 3365 | 1.12.4.2 | Document review and update |  | 20d | 2027-04-05 | 2027-04-30 | 3364 |  |  | 2027-04-05 | 2027-04-30 | 20d | 2026-09-01 | 2026-09-28 | 164d | 0d | PP | PMO,CPT,IPA,SRO | Programme Closure | 5.0 |  | Programme Closure | 698.33 | Green | GREEN |  |  |  |  |
| 3366 | 1.12.4.3 | Benefit Realisation Report approved | milestone | 0d | 2027-05-07 | 2027-05-07 | 3365FS+5d |  |  | 2027-05-07 | 2027-05-07 | 0d | 2026-10-05 | 2026-10-05 | 164d |  | PMO | CPT,PP,IPA,SRO | Programme Closure | 5.0 |  | Programme Closure | 730.71 | Green | GREEN | MHHS-ART124 | T3-PC-0010 | PSG | T3 |
| 3367 | 1.12.5 | **Operating Model Gap Review with recommendations** |  | 45d | 2027-03-08 | 2027-05-07 |  |  |  | 2027-03-08 | 2027-05-07 | 45d | 2026-08-04 | 2026-10-05 | 164d |  | N/A | N/A | Programme Closure | 5.0 | N/A | Programme Closure |  |  |  |  |  |  |  |
| 3368 | 1.12.5.1 | Develop document |  | 20d | 2027-03-08 | 2027-04-02 | 3102FS-45d |  |  | 2027-03-08 | 2027-04-02 | 20d | 2026-08-04 | 2026-08-31 | 164d | 0d | PMO | CPT | Programme Closure | 5.0 |  | Programme Closure | 670.33 | Green | GREEN |  |  |  |  |
| 3369 | 1.12.5.2 | Document review and update |  | 20d | 2027-04-05 | 2027-04-30 | 3368 |  |  | 2027-04-05 | 2027-04-30 | 20d | 2026-09-01 | 2026-09-28 | 164d | 0d | PP | PMO,CPT,IPA,SRO | Programme Closure | 5.0 |  | Programme Closure | 698.33 | Green | GREEN |  |  |  |  |
| 3370 | 1.12.5.3 | Operating Model Gap Review with recommendations approved | milestone | 0d | 2027-05-07 | 2027-05-07 | 3369FS+5d |  |  | 2027-05-07 | 2027-05-07 | 0d | 2026-10-05 | 2026-10-05 | 164d |  | Paul Pettitt | CPT,PP,IPA,SRO | Programme Closure | 5.0 | Paul Pettitt | Programme Closure | 730.71 | Green | GREEN | MHHS-ART128 | T3-PC-0020 | DAG | T3 |
| 3371 | 1.12.6 | **Post-Implementation Review** |  | 45d | 2027-03-08 | 2027-05-07 |  |  |  | 2027-03-08 | 2027-05-07 | 45d | 2026-08-04 | 2026-10-05 | 164d |  | N/A | N/A | Programme Closure | 5.0 | N/A | Programme Closure |  |  |  |  |  |  |  |
| 3372 | 1.12.6.1 | Develop document |  | 20d | 2027-03-08 | 2027-04-02 | 3102FS-45d |  |  | 2027-03-08 | 2027-04-02 | 20d | 2026-08-04 | 2026-08-31 | 164d | 0d | PMO | CPT | Programme Closure | 5.0 |  | Programme Closure | 670.33 | Green | GREEN |  |  |  |  |
| 3373 | 1.12.6.2 | Document review and update |  | 20d | 2027-04-05 | 2027-04-30 | 3372 |  |  | 2027-04-05 | 2027-04-30 | 20d | 2026-09-01 | 2026-09-28 | 164d | 0d | PP | PMO,CPT,IPA,SRO | Programme Closure | 5.0 |  | Programme Closure | 698.33 | Green | GREEN |  |  |  |  |
| 3374 | 1.12.6.3 | Post-Implementation Review approved | milestone | 0d | 2027-05-07 | 2027-05-07 | 3373FS+5d |  |  | 2027-05-07 | 2027-05-07 | 0d | 2026-10-05 | 2026-10-05 | 164d |  | PMO | CPT,PP,IPA,SRO | Programme Closure | 5.0 |  | Programme Closure | 730.71 | Green | GREEN | MHHS-ART129 | T3-PC-0030 | PSG | T3 |
| 3375 | 1.12.7 | **Reinforcement Guide** |  | 45d | 2027-03-08 | 2027-05-07 |  |  |  | 2027-03-08 | 2027-05-07 | 45d | 2026-08-04 | 2026-10-05 | 164d |  | N/A | N/A | Programme Closure | 5.0 | N/A | Programme Closure |  |  |  |  |  |  |  |
| 3376 | 1.12.7.1 | Develop document |  | 20d | 2027-03-08 | 2027-04-02 | 3102FS-45d |  |  | 2027-03-08 | 2027-04-02 | 20d | 2026-08-04 | 2026-08-31 | 164d | 0d | PMO | CPT | Programme Closure | 5.0 |  | Programme Closure | 670.33 | Green | GREEN |  |  |  |  |
| 3377 | 1.12.7.2 | Document review and update |  | 20d | 2027-04-05 | 2027-04-30 | 3376 |  |  | 2027-04-05 | 2027-04-30 | 20d | 2026-09-01 | 2026-09-28 | 164d | 0d | PP | PMO,CPT,IPA,SRO | Programme Closure | 5.0 |  | Programme Closure | 698.33 | Green | GREEN |  |  |  |  |
| 3378 | 1.12.7.3 | Reinforcement Guide approved | milestone | 0d | 2027-05-07 | 2027-05-07 | 3377FS+5d |  |  | 2027-05-07 | 2027-05-07 | 0d | 2026-10-05 | 2026-10-05 | 164d |  | PMO | CPT,PP,IPA,SRO | Programme Closure | 5.0 |  | Programme Closure | 730.71 | Green | GREEN | MHHS-ART133 | T3-PC-0040 | PSG | T3 |
| 3379 | 1.12.8 | **Material and Licenses Transfer** |  | 60d | 2027-04-05 | 2027-06-25 |  |  |  | 2027-04-05 | 2027-06-25 | 60d | 2026-09-08 | 2026-11-30 | 129d |  | N/A | N/A | Programme Closure | 5.0 | N/A | Programme Closure |  |  |  |  |  |  |  |
| 3380 | 1.12.8.1 | Transfer of Programme material to Elexon and perpetual licenses as appropriate |  | 60d | 2027-04-05 | 2027-06-25 | 3338FF-5d |  |  | 2027-04-05 | 2027-06-25 | 60d | 2026-09-08 | 2026-11-30 | 129d |  | PMO | CPT,PP | Programme Closure | 5.0 |  | Programme Closure | 698.33 | Green | GREEN | MHHS-ART139 |  |  |  |
| 3381 | 1.13 | **READINESS ASSESSMENTS** |  | 988d | 2023-09-05 A | 2027-06-17 |  | 23% | 764.9d | 2023-09-05 | 2027-06-17 | 849d | 2023-09-11 | 2026-12-04 | 135d |  | N/A | N/A | Readiness Assessment |  | N/A | Readiness Assessments |  |  |  |  |  |  |  |
| 3382 | 1.13.1 | **Readiness Assessment 3 - Design and Build Progress Check and CP2 Check** |  | 60d | 2023-09-05 A | 2023-11-27 A |  | 100% |  | 2023-09-05 | 2023-11-27 | 50d | 2023-09-11 | 2023-11-17 |  |  | N/A | N/A | Readiness Assessment | 5.5 | N/A | Readiness Assessments | M5,M6 |  |  |  |  |  |  |
| 3383 | 1.13.1.1 | Launch Readiness Assessment survey | milestone | 0d | 2023-09-05 A | 2023-09-05 A | 1521FS-40d | 100% |  | 2023-09-05 | 2023-09-05 | 0d | 2023-09-11 | 2023-09-11 |  |  | PPC |  | Readiness Assessment | 5.5 | PPC | Readiness Assessments |  | Complete | COMPLETE |  |  |  |  |
| 3384 | 1.13.1.2 | PPs submit survey responses |  | 15d | 2023-09-05 A | 2023-09-25 A | 3383 | 100% |  | 2023-09-05 | 2023-09-25 | 15d | 2023-09-11 | 2023-09-29 |  |  | PP | PPC | Readiness Assessment | 5.5 | PPC | Readiness Assessments |  | Complete | COMPLETE |  |  |  |  |
| 3385 | 1.13.1.3 | Analyse survey responses |  | 15d | 2023-09-26 A | 2023-10-16 A | 3384 | 100% |  | 2023-09-26 | 2023-10-16 | 15d | 2023-10-02 | 2023-10-20 |  |  | PPC | CPT | Readiness Assessment | 5.5 | PPC | Readiness Assessments |  | Complete | COMPLETE |  |  |  |  |
| 3386 | 1.13.1.4 | Conduct deep-dive interviews (sample of PPs) |  | 15d | 2023-09-26 A | 2023-10-16 A | 3384 | 100% |  | 2023-09-26 | 2023-10-16 | 15d | 2023-10-02 | 2023-10-20 |  |  | PPC | CPT | Readiness Assessment | 5.5 | PPC | Readiness Assessments |  | Complete | COMPLETE |  |  |  |  |
| 3387 | 1.13.1.5 | Produce Readiness Assessment Reports (Overall Report & Individual Participant Reports) |  | 25d | 2023-10-17 A | 2023-11-20 A | 3385, 3386 | 100% |  | 2023-10-17 | 2023-11-20 | 15d | 2023-10-23 | 2023-11-10 |  |  | PPC |  | Readiness Assessment | 5.5 | PPC | Readiness Assessments |  | Complete | COMPLETE |  |  |  |  |
| 3388 | 1.13.1.6 | Readiness Assessment 3 - Design & Build Checkpoint 1 - Completed (incl. Readiness Assessment Report approval) | milestone | 0d | 2023-11-27 A | 2023-11-27 A | 3387FS+5d | 100% |  | 2023-11-27 | 2023-11-27 | 0d | 2023-11-17 | 2023-11-17 |  |  | CPT | PPC | Readiness Assessment | 5.13 | PPC | Readiness Assessments |  | Complete | COMPLETE |  | T2-RA-0200 | PSG | T2 |

Notes:
- 3370: Action: 5/2 - PP said ask MB if belonged to him. MB says doesn't sit with him

| ID | WBS | Task | Type | Duration | Start | Finish | Predecessors | Baseline start | Baseline finish | Baseline duration | Baseline 1 start | Baseline 1 finish | Total slack | Free slack | Constraint | Responsible | Involved | Future RAG | Text9 | Task Status | Update Version | MHHS Resource Name | MHHS Programme Phase | Sched Status | RAG | Milestone ID | Text29 | Tier |
| --- | --- | --- | --- | --- | --- | --- | --- | --- | --- | --- | --- | --- | --- | --- | --- | --- | --- | --- | --- | --- | --- | --- | --- | --- | --- | --- | --- | --- |
| 3389 | 1.13.2 | **Readiness Assessment 5 / 6 - Start of Qualification and Participant Readiness for M10 and M11 and CP3/CP4 check** |  | 47d | 2025-04-28 | 2025-07-01 |  | 2025-04-21 | 2025-06-24 | 49d | 2024-11-12 | 2025-01-17 | 647d |  |  | N/A | N/A | D25 - RA6 Readiness Report | Readiness Assessment | M11 | 6.18 | N/A | Readiness Assessments |  |  |  |  |  |
| 3390 | 1.13.2.1 | Launch Readiness Assessment survey | milestone | 0d | 2025-04-28 | 2025-04-28 |  | 2025-04-28 | 2025-04-28 | 0d | 2024-11-12 | 2024-11-12 | 647d | 0d | start no earlier than 2025-04-28 | PPC |  |  | Readiness Assessment | -8.67 | 6.18 | PPC | Readiness Assessments | Overdue Start | RED |  |  |  |
| 3391 | 1.13.2.2 | PPs submit survey responses |  | 15d | 2025-04-28 | 2025-05-16 | 3390 | 2025-04-28 | 2025-05-16 | 15d | 2024-11-12 | 2024-12-02 | 647d | 0d |  | PP | PPC |  | Readiness Assessment | -8.67 | 6.18 | PPC | Readiness Assessments | Overdue Start | GREEN |  |  |  |
| 3392 | 1.13.2.3 | Analyse survey responses |  | 15d | 2025-05-19 | 2025-06-06 | 3391 | 2025-05-19 | 2025-06-06 | 15d | 2024-12-03 | 2024-12-23 | 647d | 0d |  | PPC | CPT |  | Readiness Assessment | 12.33 | 6.18 | PPC | Readiness Assessments | Green | GREEN |  |  |  |
| 3393 | 1.13.2.4 | Conduct deep-dive interviews (sample of PPs) |  | 15d | 2025-05-19 | 2025-06-06 | 3391 | 2025-05-19 | 2025-06-06 | 15d | 2024-12-03 | 2024-12-23 | 647d | 0d |  | PPC | CPT |  | Readiness Assessment | 12.33 | 6.18 | PPC | Readiness Assessments | Green | GREEN |  |  |  |
| 3394 | 1.13.2.5 | Produce Readiness Assessment Reports (Overall Report & Individual Participant Reports) |  | 15d | 2025-06-09 | 2025-06-27 | 3392, 3393 | 2025-06-09 | 2025-06-27 | 15d | 2024-12-24 | 2025-01-13 | 647d | 0d |  | PPC |  |  | Readiness Assessment | 33.33 | 6.18 | PPC | Readiness Assessments | Green | GREEN |  |  |  |
| 3395 | 1.13.2.6 | Readiness Assessment 5 / 6 - Start of Qualification and Participant Readiness for M10 and M11 and CP3/CP4 check (incl. Readiness Assessment Report approval) Completed | milestone | 0d | 2025-07-01 | 2025-07-01 | 3394FS+2d | 2025-07-01 | 2025-07-01 | 0d | 2025-01-17 | 2025-01-17 | 647d | 0d |  | CPT | PPC |  | Readiness Assessment | 55.71 | 6.18 | PPC | Readiness Assessments | Green | GREEN | T2-RA-0400 | PSG | T2 |
| 3396 | 1.13.3 | **Readiness Assessment 7 - Migration Checkpoint** |  | 49d | 2026-01-12 | 2026-03-19 |  | 2026-01-12 | 2026-03-19 | 49d | 2025-08-04 | 2025-10-09 | 460d |  |  | N/A | N/A | D29 - RA8 Readiness Report | Readiness Assessment | M14 | 5.0 | N/A | Readiness Assessments |  |  |  |  |  |
| 3397 | 1.13.3.1 | Launch Readiness Assessment survey | milestone | 0d | 2026-01-12 | 2026-01-12 |  | 2026-01-12 | 2026-01-12 | 0d | 2025-08-04 | 2025-08-04 | 460d | 0d | start no earlier than 2026-01-12 | PPC |  |  | Readiness Assessment | 250.33 | 5.0 | PPC | Readiness Assessments | Green | GREEN |  |  |  |
| 3398 | 1.13.3.2 | PPs submit survey responses |  | 15d | 2026-01-12 | 2026-01-30 | 3397 | 2026-01-12 | 2026-01-30 | 15d | 2025-08-04 | 2025-08-22 | 460d | 0d |  | PP | PPC |  | Readiness Assessment | 250.33 | 5.0 | PPC | Readiness Assessments | Green | GREEN |  |  |  |
| 3399 | 1.13.3.3 | Analyse survey responses |  | 15d | 2026-02-02 | 2026-02-20 | 3398 | 2026-02-02 | 2026-02-20 | 15d | 2025-08-25 | 2025-09-12 | 460d | 0d |  | PPC | CPT |  | Readiness Assessment | 271.33 | 5.0 | PPC | Readiness Assessments | Green | GREEN |  |  |  |
| 3400 | 1.13.3.4 | Conduct deep-dive interviews (sample of PPs) |  | 15d | 2026-02-02 | 2026-02-20 | 3398 | 2026-02-02 | 2026-02-20 | 15d | 2025-08-25 | 2025-09-12 | 460d | 0d |  | PPC | CPT |  | Readiness Assessment | 271.33 | 5.0 | PPC | Readiness Assessments | Green | GREEN |  |  |  |
| 3401 | 1.13.3.5 | Produce Readiness Assessment Reports (Overall Report & Individual Participant Reports) |  | 15d | 2026-02-23 | 2026-03-13 | 3399, 3400 | 2026-02-23 | 2026-03-13 | 15d | 2025-09-15 | 2025-10-03 | 460d | 0d |  | PPC |  |  | Readiness Assessment | 292.33 | 5.0 | PPC | Readiness Assessments | Green | GREEN |  |  |  |
| 3402 | 1.13.3.6 | Readiness Assessment 7 - Migration Checkpoint - Completed (incl. Readiness Assessment Report approval) | milestone | 0d | 2026-03-19 | 2026-03-19 | 3401FS+4d | 2026-03-19 | 2026-03-19 | 0d | 2025-10-09 | 2025-10-09 | 460d | 0d |  | CPT | PPC |  | Readiness Assessment | 316.71 | 5.0 | PPC | Readiness Assessments | Green | GREEN | T2-RA-0600 | PSG | T2 |
| 3403 | 1.13.4 | **Readiness Assessment 8 - Ready to Accept New MPANs** |  | 49d | 2026-08-06 | 2026-10-13 |  | 2026-08-06 | 2026-10-13 | 49d | 2026-01-06 | 2026-03-13 | 312d |  |  | N/A | N/A | D29 - RA8 Readiness Report | Readiness Assessment | M14 | 5.0 | N/A | Readiness Assessments |  |  |  |  |  |
| 3404 | 1.13.4.1 | Launch Readiness Assessment survey | milestone | 0d | 2026-08-06 | 2026-08-06 | 2546FS-60d | 2026-08-06 | 2026-08-06 | 0d | 2026-01-06 | 2026-01-06 | 312d | 0d |  | PPC |  |  | Readiness Assessment | 456.33 | 5.0 | PPC | Readiness Assessments | Green | GREEN |  |  |  |
| 3405 | 1.13.4.2 | PPs submit survey responses |  | 15d | 2026-08-06 | 2026-08-26 | 3404 | 2026-08-06 | 2026-08-26 | 15d | 2026-01-06 | 2026-01-26 | 312d | 0d |  | PP | PPC |  | Readiness Assessment | 456.33 | 5.0 | PPC | Readiness Assessments | Green | GREEN |  |  |  |
| 3406 | 1.13.4.3 | Analyse survey responses |  | 15d | 2026-08-27 | 2026-09-16 | 3405 | 2026-08-27 | 2026-09-16 | 15d | 2026-01-27 | 2026-02-16 | 312d | 0d |  | PPC | CPT |  | Readiness Assessment | 477.33 | 5.0 | PPC | Readiness Assessments | Green | GREEN |  |  |  |
| 3407 | 1.13.4.4 | Conduct deep-dive interviews (sample of PPs) |  | 15d | 2026-08-27 | 2026-09-16 | 3405 | 2026-08-27 | 2026-09-16 | 15d | 2026-01-27 | 2026-02-16 | 312d | 0d |  | PPC | CPT |  | Readiness Assessment | 477.33 | 5.0 | PPC | Readiness Assessments | Green | GREEN |  |  |  |
| 3408 | 1.13.4.5 | Produce Readiness Assessment Reports (Overall Report & Individual Participant Reports) |  | 15d | 2026-09-17 | 2026-10-07 | 3406, 3407 | 2026-09-17 | 2026-10-07 | 15d | 2026-02-17 | 2026-03-09 | 312d | 0d |  | PPC |  |  | Readiness Assessment | 498.33 | 5.0 | PPC | Readiness Assessments | Green | GREEN |  |  |  |
| 3409 | 1.13.4.6 | Readiness Assessment 8 - Ready to Accept New MPANs - Completed (incl. Readiness Assessment Report approval) | milestone | 0d | 2026-10-13 | 2026-10-13 | 3408FS+4d | 2026-10-13 | 2026-10-13 | 0d | 2026-03-13 | 2026-03-13 | 312d | 0d |  | CPT | PPC |  | Readiness Assessment | 524.71 | 5.0 | PPC | Readiness Assessments | Green | GREEN | T2-RA-0700 | PSG | T2 |
| 3410 | 1.13.5 | **Readiness Assessment 9 - Ready for New Settlement Timetable and CP5 Check** |  | 49d | 2027-04-12 | 2027-06-17 |  | 2027-04-12 | 2027-06-17 | 49d | 2026-09-29 | 2026-12-04 | 135d |  |  | N/A | N/A | D32 - RA10 Readiness Report | Readiness Assessment | M16 | 5.0 | N/A | Readiness Assessments |  |  |  |  |  |
| 3411 | 1.13.5.1 | Launch Readiness Assessment survey | milestone | 0d | 2027-04-12 | 2027-04-12 | 3338FS-60d | 2027-04-12 | 2027-04-12 | 0d | 2026-09-29 | 2026-09-29 | 135d | 0d |  | PPC |  |  | Readiness Assessment | 705.33 | 5.0 | PPC | Readiness Assessments | Green | GREEN |  |  |  |
| 3412 | 1.13.5.2 | PPs submit survey responses |  | 15d | 2027-04-12 | 2027-04-30 | 3411 | 2027-04-12 | 2027-04-30 | 15d | 2026-09-29 | 2026-10-19 | 135d | 0d |  | PP | PPC |  | Readiness Assessment | 705.33 | 5.0 | PPC | Readiness Assessments | Green | GREEN |  |  |  |
| 3413 | 1.13.5.3 | Analyse survey responses |  | 15d | 2027-05-03 | 2027-05-21 | 3412 | 2027-05-03 | 2027-05-21 | 15d | 2026-10-20 | 2026-11-09 | 135d | 0d |  | PPC | CPT |  | Readiness Assessment | 726.33 | 5.0 | PPC | Readiness Assessments | Green | GREEN |  |  |  |
| 3414 | 1.13.5.4 | Conduct deep-dive interviews (sample of PPs) |  | 15d | 2027-05-03 | 2027-05-21 | 3412 | 2027-05-03 | 2027-05-21 | 15d | 2026-10-20 | 2026-11-09 | 135d | 0d |  | PPC | CPT |  | Readiness Assessment | 726.33 | 5.0 | PPC | Readiness Assessments | Green | GREEN |  |  |  |
| 3415 | 1.13.5.5 | Produce Readiness Assessment Reports (Overall Report & Individual Participant Reports) |  | 15d | 2027-05-24 | 2027-06-11 | 3413, 3414 | 2027-05-24 | 2027-06-11 | 15d | 2026-11-10 | 2026-11-30 | 135d | 0d |  | PPC |  |  | Readiness Assessment | 747.33 | 5.0 | PPC | Readiness Assessments | Green | GREEN |  |  |  |
| 3416 | 1.13.5.6 | Readiness Assessment 9 - Readiness for New Settlement Timetable - Completed (incl. Readiness Assessment Report approval) | milestone | 0d | 2027-06-17 | 2027-06-17 | 3415FS+4d | 2027-06-17 | 2027-06-17 | 0d | 2026-12-04 | 2026-12-04 | 135d | 0d |  | CPT | PPC |  | Readiness Assessment | 771.71 | 5.0 | PPC | Readiness Assessments | Green | GREEN | T2-RA-0800 | PSG | T2 |

| ID | WBS | Task | Type | Duration | Start | Finish | Predecessors | Complete | Remaining | Baseline start | Baseline finish | Baseline duration | Baseline 1 start | Baseline 1 finish | Total slack | Free slack | Constraint | Responsible | Involved | Text9 | Update Version | MHHS Resource Name | MHHS Programme Phase | Task Status | Sched Status | RAG | Milestone ID | Text29 | Tier | Future RAG |
| --- | --- | --- | --- | --- | --- | --- | --- | --- | --- | --- | --- | --- | --- | --- | --- | --- | --- | --- | --- | --- | --- | --- | --- | --- | --- | --- | --- | --- | --- | --- |
| 3417 | 1.13.6 | **Readiness Assessments - Tier 1 Milestones** |  | 512d | 2025-07-01 | 2027-06-17 |  |  |  | 2025-06-24 | 2027-06-17 | 799d | 2023-11-17 | 2026-12-04 | 135d |  |  | N/A | N/A | Readiness Assessment | 5.0 | N/A | Readiness Assessments |  |  |  |  |  |  |  |
| 3418 | 1.13.6.1 | Readiness Assessment 6 - Start of Migration - Completed (incl. Readiness Assessment Report approval) | milestone | 0d | 2025-07-01 | 2025-07-01 | 3395 |  |  | 2025-07-01 | 2025-07-01 | 0d | 2025-04-04 | 2025-04-04 | 647d |  | finish no earlier than 2025-04-04 | CPT | PPC | Readiness Assessment | 6.18 | PPC | Readiness Assessments | 55.71 | Green | GREEN | T2-RA-0500 | PSG | T2 |  |
| 3419 | 1.13.6.2 | Readiness Assessment 7 - Migration Checkpoint - Completed (incl. Readiness Assessment Report approval) | milestone | 0d | 2026-03-19 | 2026-03-19 | 3402 |  |  | 2026-03-19 | 2026-03-19 | 0d | 2025-10-09 | 2025-10-09 | 460d |  |  | CPT | PPC | Readiness Assessment | 5.0 | PPC | Readiness Assessments | 316.71 | Green | GREEN | T2-RA-0600 | PSG | T2 |  |
| 3420 | 1.13.6.3 | Readiness Assessment 8 - Ready to Accept New MPANs - Completed (incl. Readiness Assessment Report approval) | milestone | 0d | 2026-10-13 | 2026-10-13 | 3409 |  |  | 2026-10-13 | 2026-10-13 | 0d | 2026-03-13 | 2026-03-13 | 312d |  |  | CPT | PPC | Readiness Assessment | 5.0 | PPC | Readiness Assessments | 524.71 | Green | GREEN | T2-RA-0700 | PSG | T2 |  |
| 3421 | 1.13.6.4 | Readiness Assessment 9 - Readiness for New Settlement Timetable - Completed (incl. Readiness Assessment Report approval) | milestone | 0d | 2027-06-17 | 2027-06-17 | 3416 |  |  | 2027-06-17 | 2027-06-17 | 0d | 2026-12-04 | 2026-12-04 | 135d |  |  | CPT | PPC | Readiness Assessment | 5.0 | PPC | Readiness Assessments | 771.71 | Green | GREEN | T2-RA-0800 | PSG | T2 |  |
| 3422 | 1.14 | **CONTROL POINTS** |  | 1204d | 2022-11-10 A | 2027-06-23 |  | 51% | 591.8d | 2022-11-10 | 2027-06-23 | 1063d | 2022-11-10 | 2026-12-07 | 132d |  |  | N/A | N/A | Control Points |  | N/A | Control Points |  |  |  |  |  |  |  |
| 3423 | 1.14.1 | **Control Point 1 - Start of System Design, Build & Test** |  | 20d | 2022-11-10 A | 2022-12-07 A |  | 100% |  | 2022-11-10 | 2022-12-07 | 20d | 2022-11-10 | 2022-12-07 |  |  |  | N/A | N/A | Control Points | 5.0 | N/A | Control Points |  |  |  |  |  |  |  |
| 3424 | 1.14.1.1 | Control Point 1 Preparation (incl. Control Point Report development and review) |  | 15d | 2022-11-10 A | 2022-11-30 A | 3425SS-20d | 100% |  | 2022-11-10 | 2022-11-30 | 15d | 2022-11-10 | 2022-11-30 |  |  |  | CPT | PMO | Control Points | 5.0 | PMO | Control Points |  | Complete | COMPLETE |  |  |  |  |
| 3425 | 1.14.1.2 | Control Point 1 - Start of System Design, Build & Test (incl. Control Point Report approval) | milestone | 0d | 2022-12-07 A | 2022-12-07 A |  | 100% |  | 2022-12-07 | 2022-12-07 | 0d | 2022-12-07 | 2022-12-07 |  |  | must finish on 2022-12-07 | CPT | PMO | Control Points | 5.0 | PMO | Control Points |  | Complete | COMPLETE | T1-CP-1000 | PSG | T1 | D24 - CP2 Approval |
| 3426 | 1.14.2 | **Control Point 2 - Start of Integration & Test** |  | 20d | 2023-10-02 A | 2023-10-30 A |  | 100% |  | 2023-10-02 | 2023-10-30 | 20d | 2023-10-02 | 2023-10-30 |  |  |  | N/A | N/A | Control Points | 5.0 | N/A | Control Points |  |  |  |  |  |  |  |
| 3427 | 1.14.2.1 | Control Point 2 Preparation (incl. Control Point Report development and review) |  | 15d | 2023-10-02 A | 2023-10-20 A | 3428SS-20d | 100% |  | 2023-10-02 | 2023-10-20 | 15d | 2023-10-02 | 2023-10-20 |  |  |  | CPT | PMO | Control Points | 5.0 | PMO | Control Points |  | Complete | COMPLETE |  |  |  |  |
| 3428 | 1.14.2.2 | Control Point 2 - Start of Integration & Test (incl. Control Point Report approval) | milestone | 0d | 2023-10-30 A | 2023-10-30 A | 1521 | 100% |  | 2023-10-30 | 2023-10-30 | 0d | 2023-10-30 | 2023-10-30 |  |  |  | CPT | PMO | Control Points | 5.11 | PMO | Control Points |  | Complete | COMPLETE | T1-CP-2000 | PSG | T1 | D24 - CP2 Approval |
| 3429 | 1.14.3 | **Control Point 3/4 - Readiness for Migration** |  | 20d | 2025-08-21 | 2025-09-18 |  |  |  | 2025-08-21 | 2025-09-18 | 20d | 2025-03-03 | 2025-03-28 | 591d |  |  | N/A | N/A | Control Points | 5.0 | N/A | Control Points |  |  |  |  |  |  | D26 - CP3 Approval |
| 3430 | 1.14.3.1 | Control Point 3/4 Preparation (incl. Control Point Report development and review) |  | 14d | 2025-08-21 | 2025-09-09 | 3431SS-20d |  |  | 2025-08-21 | 2025-09-09 | 14d | 2025-03-03 | 2025-03-21 | 597d |  |  | CPT | PMO | Control Points | 5.0 | PMO | Control Points | 106.33 | Green | GREEN |  |  |  |  |
| 3431 | 1.14.3.2 | Control Point 3/4 - Readiness for Migration (incl. Control Point Report approval) | milestone | 0d | 2025-09-18 | 2025-09-18 | 1938FS-5d |  |  | 2025-09-18 | 2025-09-18 | 0d | 2025-03-28 | 2025-03-28 | 591d | 0d |  | CPT | PMO | Control Points | 5.0 | PMO | Control Points | 134.33 | Green | GREEN | T1-CP-3000 | PSG | T1 |  |
| 3432 | 1.14.4 | **Control Point 5 - Cut Over to New Settlement Timetable** |  | 20d | 2027-05-26 | 2027-06-23 |  |  |  | 2027-05-26 | 2027-06-23 | 20d | 2026-11-10 | 2026-12-07 | 132d |  |  | N/A | N/A | Control Points | 5.0 | N/A | Control Points | M16 |  |  |  |  |  | D33 - Control Point 6 Approval |
| 3433 | 1.14.4.1 | Control Point 5 Preparation (incl. Control Point Report development and review) |  | 15d | 2027-05-26 | 2027-06-15 | 3434SS-20d |  |  | 2027-05-26 | 2027-06-15 | 15d | 2026-11-10 | 2026-11-30 | 137d |  |  | CPT | PP | Control Points | 5.0 | PMO | Control Points | 749.33 | Green | GREEN |  |  |  |  |
| 3434 | 1.14.4.2 | Control Point 5 - Cut Over to New Settlement Timetable (incl. Control Point Report approval) | milestone | 0d | 2027-06-23 | 2027-06-23 | 3338FS-8d |  |  | 2027-06-23 | 2027-06-23 | 0d | 2026-12-07 | 2026-12-07 | 132d | 0d |  | CPT | CPT | Control Points | 5.0 | PMO | Control Points | 777.33 | Green | GREEN | T1-CP-4000 | PSG | T1 | D33 - Control Point 6 Approval |
| 3435 | 1.14.5 | **Control Points - Tier 1 Milestones** |  | 1184d | 2022-12-07 A | 2027-06-23 |  |  | 1184d | 2022-12-07 | 2027-06-23 | 1043d | 2022-12-07 | 2026-12-07 | 132d |  |  | N/A | N/A | Control Points | 5.0 | N/A | Control Points |  |  |  |  |  |  |  |
| 3436 | 1.14.5.1 | Control Point 1 - Start of System Design, Build & Test (incl. Control Point Report approval) | milestone | 0d | 2022-12-07 A | 2022-12-07 A | 3425SS | 100% |  | 2022-12-07 | 2022-12-07 | 0d | 2022-12-07 | 2022-12-07 |  |  |  | CPT | PMO | Control Points | 5.0 | PMO | Control Points |  | Complete | COMPLETE | T1-CP-1000 | PSG | T1 |  |
| 3437 | 1.14.5.2 | Control Point 2 - Start of Integration & Test (incl. Control Point Report approval) | milestone | 0d | 2023-10-30 A | 2023-10-30 A | 3428SS | 100% |  | 2023-10-30 | 2023-10-30 | 0d | 2023-10-30 | 2023-10-30 |  |  |  | CPT | PMO | Control Points | 5.11 | PMO | Control Points |  | Complete | COMPLETE | T1-CP-2000 | PSG | T1 | D24 - CP2 Approval |
| 3438 | 1.14.5.3 | Control Point 3/4 - Readiness for Migration (incl. Control Point Report approval) | milestone | 0d | 2025-09-18 | 2025-09-18 | 3431SS |  |  | 2025-09-18 | 2025-09-18 | 0d | 2025-03-28 | 2025-03-28 | 591d |  |  | CPT | PMO | Control Points | 5.0 | PMO | Control Points | 134.33 | Green | GREEN | T1-CP-3000 | PSG | T1 |  |
| 3439 | 1.14.5.4 | Control Point 5 - Cut Over to New Settlement Timetable (incl. Control Point Report approval) | milestone | 0d | 2027-06-23 | 2027-06-23 | 3434SS |  |  | 2027-06-23 | 2027-06-23 | 0d | 2026-12-07 | 2026-12-07 | 132d |  |  | CPT | CPT | Control Points | 5.0 | PMO | Control Points | 777.33 | Green | GREEN | T1-CP-4000 | PSG | T1 | D33 - Control Point 6 Approval |
| 3440 | 1.15 | **MILESTONE RANGE CHECKPOINTS** |  | 442d | 2025-07-31 | 2027-04-12 |  |  |  | 2022-10-31 | 2027-04-12 | 436d | 2025-01-13 | 2026-09-15 | 184d |  |  | N/A | N/A | Milestone Range Checkpoints |  | N/A | Milestone Range Checkpoints |  |  |  |  |  |  |  |
| 3441 | 1.15.1 | **M10, M11, M12 and M13 milestone checkpoint** |  | 0d | 2025-07-31 | 2025-07-31 |  |  |  | 2025-07-31 | 2025-07-31 | 0d | 2025-01-13 | 2025-01-13 | 626d |  |  | N/A | N/A | Milestone Range Checkpoints | 5.0 | N/A | Milestone Range Checkpoints |  |  |  |  |  |  |  |
| 3442 | 1.15.1.1 | M10, M11, M12, and M13 milestone checkpoint - date approval | milestone | 0d | 2025-07-31 | 2025-07-31 | 3098FS-3mo, 3100FS-3mo, 3096FS-3mo, 1938FS-3mo |  |  | 2025-07-31 | 2025-07-31 | 0d | 2025-01-13 | 2025-01-13 | 626d |  |  | CPT | CPT | Milestone Range Checkpoints | 5.0 | PMO | Milestone Range Checkpoints | 85.33 | Green | GREEN | T2-MR-0100 | PSG | T2 |  |

| ID | WBS | Task | Type | Duration | Start | Finish | Predecessors | Baseline start | Baseline finish | Baseline duration | Baseline 1 start | Baseline 1 finish | Total slack | Responsible | Involved | Text9 | Update Version | MHHS Resource Name | MHHS Programme Phase | Task Status | Sched Status | RAG | Milestone ID | Text29 | Tier |
| --- | --- | --- | --- | --- | --- | --- | --- | --- | --- | --- | --- | --- | --- | --- | --- | --- | --- | --- | --- | --- | --- | --- | --- | --- | --- |
| 3443 | 1.15.2 | **M14 milestone checkpoint** |  | 0d | 2026-08-06 | 2026-08-06 |  | 2026-08-06 | 2026-08-06 | 0d | 2025-12-23 | 2025-12-23 | 361d | N/A | N/A | Milestone Range Checkpoints | 5.0 | N/A | Milestone Range Checkpoints |  |  |  |  |  |  |
| 3444 | 1.15.2.1 | M14 milestone checkpoint - date approval | milestone | 0d | 2026-08-06 | 2026-08-06 | 2546FS-3mo | 2026-08-06 | 2026-08-06 | 0d | 2025-12-23 | 2025-12-23 | 361d | CPT | CPT | Milestone Range Checkpoints | 5.0 | PMO | Milestone Range Checkpoints | 456.33 | Green | GREEN | T2-MR-0200 | PSG | T2 |
| 3445 | 1.15.3 | **M15 milestone checkpoint** |  | 0d | 2027-02-15 | 2027-02-15 |  | 2027-02-15 | 2027-02-15 | 0d | 2026-07-14 | 2026-07-14 | 224d | N/A | N/A | Milestone Range Checkpoints | 5.0 | N/A | Milestone Range Checkpoints |  |  |  |  |  |  |
| 3446 | 1.15.3.1 | M15 milestone checkpoint - date approval | milestone | 0d | 2027-02-15 | 2027-02-15 | 3102FS-3mo | 2027-02-15 | 2027-02-15 | 0d | 2026-07-14 | 2026-07-14 | 224d | CPT | CPT | Milestone Range Checkpoints | 5.0 | PMO | Milestone Range Checkpoints | 649.33 | Green | GREEN | T2-MR-0300 | PSG | T2 |
| 3447 | 1.15.4 | **M16 milestone checkpoint** |  | 0d | 2027-04-12 | 2027-04-12 |  | 2022-10-31 | 2027-04-12 | 0d | 2026-09-15 | 2026-09-15 | 184d | N/A | N/A | Milestone Range Checkpoints | 5.0 | N/A | Milestone Range Checkpoints |  |  |  |  |  |  |
| 3448 | 1.15.4.1 | M16 milestone checkpoint - date approval | milestone | 0d | 2027-04-12 | 2027-04-12 | 3338FS-3mo | 2027-04-12 | 2027-04-12 | 0d | 2026-09-15 | 2026-09-15 | 184d | CPT | CPT | Milestone Range Checkpoints | 5.0 | PMO | Milestone Range Checkpoints | 705.33 | Green | GREEN | T2-MR-0400 | PSG | T2 |
