# Outline ELEXON Plan_kc

Schedule from MS Project, 2022-10-31 to 2149-08-26, status date 2024-08-23, A marks actual dates.

## Calendars

- Standard: Mon-Fri 08:00-12:00, 13:00-17:00; Sat-Sun off.

## Resources

| Resource |
| --- |
| PMO |
| SI |
| PPC |
| Lead Workstream |
| CPT |
| PP |
| SI Design |
| SI Design |
| SI Design |
| Design |
| SI DevOps |
| SI Test |
| PSG |
| DAG |
| TMAG |
| CCAG |
| Code drafters (SRO Design Team |
| Code Bodies) |
| CCAG PM |
| Programme Participants |
| Code drafters |
| CDWG |
| SRO Design Team |
| Code Bodies |
| Ofgem |
| Elexon resources TBC |
| LDP Programme Manager |
| SRO Client Programme Director |
| IPA |
| LDP |
| SRO |
| )) |
| ? |
| TBC |
| OOC |
| MHHSP |
| Adrian Page |
| Amy Clayton |
| Anand Kaveripatna |
| Berlinda Kugara |
| Cesar Lopes |
| Charlie Blanks |
| Chetan Ubale |
| Daniel Callender |
| Daniel Gee |
| David Hollinshead |
| Dean Bailey |
| Dominic Mooney |
| Elayaraja Jeyaraman |
| Georgi Rabotov |
| Giles Clayden |
| Helen Richardson |
| Ishti Bhatti |
| Jafer Shah |
| Jason Brogden |
| John Edmonds Bell |
| John Wiggins |
| Karthikeyan Ganesan |
| Kasimali Hajiyani |
| Kate Goodman |
| Keegan Moodley |
| Keith Clark |
| Keith Lawlor |
| kevin Davis |
| Kishore Konduru |
| Kyle Abraham |
| Mahjabeen Newaz |
| Martin Freeman |
| Matt Hall |
| Matthew Breen |
| Michael Inije |
| Michael Walton |
| Ming Li |
| Nathalia Revlien |
| Nick Sewell |
| Nigel Hunt |
| Oskar Cahill |
| Paul Pettitt |
| Rakhee Shah |
| Rebecca Farooq |
| Renu Rathor |
| Robert Short |
| Robert Topley |
| Saadia Sajjad |
| Sean Tuffy |
| Shaid Hussain |
| Sharmeen Shaikh |
| Simon Berry |
| Steve Bradford |
| Steve Weston |
| Taaran Suri |
| Waseem Mohammed |
| Zak Hussain |
| berli |
| SI Migration |
| v |
| Andrew Margan |
| Lee Cox |
| DIP SP |
| DIPS SP |
| DIPSP |
| Ian Smith |
| N/A |
| SIT Component Integration Testing 2 Preparation Complete (incl. approval of SI SIT Component Integration Test Readiness Report) |
| Nich |
| Nicola Farley |
| Warren Fulton |
| Richard Puddephatt |
| Matthew Bray |
| Programme |
| LDSOs |
| Ben Wickins |
| paul |
| LDSO |
| Simon chidwick |
| Stuart Scott |
| MHHS Programme |
| Claire Silk |
| Laura Kennedy |
| Rowan B |
| FD |
| MB |
| AM |
| Roger Robar |
| Laura Kennedy. |

## Schedule

| ID | WBS | Task | Type | Duration | Start | Finish | Complete | Remaining | Baseline start | Baseline finish | Baseline duration | Baseline 1 start | Baseline 1 finish | Total slack | Constraint | Baseline cost | Responsible | Involved | Update Version | MHHS Resource Name | Sched Status | RAG | Task Status | Text3 |
| --- | --- | --- | --- | --- | --- | --- | --- | --- | --- | --- | --- | --- | --- | --- | --- | --- | --- | --- | --- | --- | --- | --- | --- | --- |
| 1 | 1 | **PROGRAMME PLAN.** |  | 33087d? | 2022-10-31 A | 2149-08-26 | 51% | 16074.5d? | 2022-10-31 | 2027-05-28 | 1195d |  |  | 0d |  | -0 | N/A | N/A | 5.0 | N/A |  |  |  |  |
| 2 | 1.1 | MHHS Programme Start | milestone | 0d | 2022-10-31 A | 2022-10-31 A | 100% |  | 2022-10-31 | 2022-10-31 | 0d |  |  |  |  |  | N/A | N/A | 5.7 | N/A | Complete | COMPLETE |  |  |
| 3 | 1.2 | **PROGRAMME MANAGEMENT** |  | 1089d | 2022-10-31 A | 2026-12-31 | 44% | 609.27d | 2022-10-31 | 2026-12-31 | 1089d | 2022-10-31 | 2026-12-31 | 31998d |  |  | N/A | N/A | 5.0 | N/A |  |  |  |  |
| 4 | 1.2.1 | **Programme Management** |  | 1089d | 2022-10-31 A | 2026-12-31 | 43% | 616d | 2022-10-31 | 2026-12-31 | 1089d | 2022-10-31 | 2026-12-31 | 31998d |  |  | N/A | N/A | 5.0 | N/A |  |  | M10 |  |
| 5 | 1.2.1.1 | Sprint-based prioritisation planning and execution |  | 1089d | 2022-10-31 A | 2026-12-31 | 43% | 616d | 2022-10-31 | 2026-12-31 | 1089d | 2022-10-31 | 2026-12-31 | 31998d | finish no earlier than 2026-12-31 |  | PMO | CPT | 5.0 | N/A | Green | GREEN |  |  |
| 6 | 1.2.1.2 | Programme governance secretariat |  | 1089d | 2022-10-31 A | 2026-12-31 | 43% | 616d | 2022-10-31 | 2026-12-31 | 1089d | 2022-10-31 | 2026-12-31 | 31998d |  |  | PMO | CPT | 5.0 | N/A | Green | GREEN |  |  |
| 7 | 1.2.1.3 | RAID management and reporting |  | 1089d | 2022-10-31 A | 2026-12-31 | 43% | 616d | 2022-10-31 | 2026-12-31 | 1089d | 2022-10-31 | 2026-12-31 | 31998d |  |  | PMO | CPT | 5.0 | N/A | Green | GREEN |  |  |
| 8 | 1.2.1.4 | Tracking against Programme outcomes and KPIs |  | 1089d | 2022-10-31 A | 2026-12-31 | 43% | 616d | 2022-10-31 | 2026-12-31 | 1089d | 2022-10-31 | 2026-12-31 | 31998d |  |  | PMO | CPT | 5.0 | N/A | Green | GREEN |  |  |
| 9 | 1.2.1.5 | Change control and reporting |  | 1089d | 2022-10-31 A | 2026-12-31 | 43% | 616d | 2022-10-31 | 2026-12-31 | 1089d | 2022-10-31 | 2026-12-31 | 31998d |  |  | PMO | CPT | 5.0 | N/A | Green | GREEN |  |  |
| 10 | 1.2.1.6 | Ongoing identification of lessons learned relating to the PMO and implementation of improvements |  | 1089d | 2022-10-31 A | 2026-12-31 | 43% | 616d | 2022-10-31 | 2026-12-31 | 1089d | 2022-10-31 | 2026-12-31 | 31998d |  |  | PMO | CPT | 5.0 | N/A | Green | GREEN |  |  |
| 11 | 1.2.2 | **Programme Internal Assurance Reviews** |  | 1089d | 2022-10-31 A | 2026-12-31 | 43% | 616d | 2022-10-31 | 2026-12-31 | 1089d | 2022-10-31 | 2026-12-31 | 31998d |  |  | N/A | N/A | 5.0 | N/A |  |  | M9 | D18A - Quarterly Assurance Report |
| 12 | 1.2.2.1 | Programme Internal Assurance Reviews |  | 1089d | 2022-10-31 A | 2026-12-31 | 43% | 616d | 2022-10-31 | 2026-12-31 | 1089d | 2022-10-31 | 2026-12-31 | 31998d |  |  | CPT | PMO | 5.0 | N/A | Green | GREEN |  | D18A - Quarterly Assurance Report |
| 13 | 1.2.3 | **Engagement with PPs** |  | 1089d | 2022-10-31 A | 2026-12-31 | 43% | 615.89d | 2022-10-31 | 2026-12-31 | 1089d | 2022-10-31 | 2026-12-31 | 31998d |  |  | N/A | N/A | 5.0 | N/A |  |  | M5,M6 |  |
| 14 | 1.2.3.1 | Ongoing PP liaison activities |  | 1089d | 2022-10-31 A | 2026-12-31 | 43% | 616d | 2022-10-31 | 2026-12-31 | 1089d | 2022-10-31 | 2026-12-31 | 31998d |  |  | PPC | CPT | 5.0 | N/A | Green | GREEN |  |  |
| 15 | 1.2.3.2 | Milestone and Control Point objective setting |  | 1089d | 2022-10-31 A | 2026-12-31 | 43% | 616d | 2022-10-31 | 2026-12-31 | 1089d | 2022-10-31 | 2026-12-31 | 31998d |  |  | PPC | CPT | 5.0 | N/A | Green | GREEN |  |  |
| 16 | 1.2.3.3 | Reporting |  | 1089d | 2022-10-31 A | 2026-12-31 | 43% | 616d | 2022-10-31 | 2026-12-31 | 1089d | 2022-10-31 | 2026-12-31 | 31998d |  |  | PPC |  | 5.0 | N/A | Green | GREEN |  |  |
| 17 | 1.2.3.4 | **PP Engagement Events** |  | 1089d | 2022-10-31 A | 2026-12-31 | 43% | 616d | 2022-10-31 | 2026-12-31 | 1089d | 2022-10-31 | 2026-12-31 | 31998d |  |  | N/A | N/A | 5.0 | N/A |  |  |  |  |
| 18 | 1.2.3.4.1 | Bilateral meetings |  | 1089d | 2022-10-31 A | 2026-12-31 | 43% | 616d | 2022-10-31 | 2026-12-31 | 1089d | 2022-10-31 | 2026-12-31 | 31998d |  |  | PPC | CPT | 5.0 | N/A | Green | GREEN |  |  |
| 19 | 1.2.3.4.2 | Monthly webinars |  | 1089d | 2022-10-31 A | 2026-12-31 | 43% | 616d | 2022-10-31 | 2026-12-31 | 1089d | 2022-10-31 | 2026-12-31 | 31998d |  |  | PPC | CPT | 5.0 | N/A | Green | GREEN |  |  |
| 20 | 1.2.3.4.3 | Open days |  | 1089d | 2022-10-31 A | 2026-12-31 | 43% | 616d | 2022-10-31 | 2026-12-31 | 1089d | 2022-10-31 | 2026-12-31 | 31998d |  |  | PPC | CPT | 5.0 | N/A | Green | GREEN |  |  |
| 21 | 1.2.3.5 | **PP Communications** |  | 1088d | 2022-10-31 A | 2026-12-30 | 43% | 615d | 2022-10-31 | 2026-12-30 | 1088d | 2022-10-31 | 2026-12-30 | 31999d |  |  | N/A | N/A | 5.0 | N/A |  |  |  |  |
| 22 | 1.2.3.5.1 | The Clock updates (weekly) |  | 1088d | 2022-10-31 A | 2026-12-30 | 43% | 615d | 2022-10-31 | 2026-12-30 | 1088d | 2022-10-31 | 2026-12-30 | 31999d |  |  | PPC |  | 5.0 | N/A | Green | GREEN |  |  |
| 23 | 1.2.3.5.2 | Maintain and update content on public-facing Portal (and ongoing feedback reviews to identify and implement Portal improvements) |  | 1088d | 2022-10-31 A | 2026-12-30 | 43% | 615d | 2022-10-31 | 2026-12-30 | 1088d | 2022-10-31 | 2026-12-30 | 31999d |  |  | PPC |  | 5.0 | N/A | Green | GREEN |  |  |
| 24 | 1.2.4 | **Code Change Support / Other Programme Alignment** |  | 1089d | 2022-10-31 A | 2026-12-31 | 43% | 616d | 2022-10-31 | 2026-12-31 | 1089d | 2022-10-31 | 2026-12-31 | 31998d |  |  | N/A | N/A | 5.0 | N/A |  |  | M6 | D17 - Code Change Report & Recommendations |
| 25 | 1.2.4.1 | Support DCC/BEIS on SEC change |  | 1089d | 2022-10-31 A | 2026-12-31 | 43% | 616d | 2022-10-31 | 2026-12-31 | 1089d | 2022-10-31 | 2026-12-31 | 31998d |  |  | CPT |  | 5.0 | N/A | Green | GREEN |  |  |
| 26 | 1.2.4.2 | Support on Smart Meters Act changes |  | 1089d | 2022-10-31 A | 2026-12-31 | 43% | 616d | 2022-10-31 | 2026-12-31 | 1089d | 2022-10-31 | 2026-12-31 | 31998d |  |  | CPT |  | 5.0 | N/A | Green | GREEN |  |  |
| 27 | 1.2.4.3 | Support DCC/RECCo on CSS change |  | 1089d | 2022-10-31 A | 2026-12-31 | 43% | 616d | 2022-10-31 | 2026-12-31 | 1089d | 2022-10-31 | 2026-12-31 | 31998d |  |  | CPT |  | 5.0 | N/A | Green | GREEN |  |  |
| 28 | 1.2.4.4 | Support Elexon on BSC change |  | 1089d | 2022-10-31 A | 2026-12-31 | 43% | 616d | 2022-10-31 | 2026-12-31 | 1089d | 2022-10-31 | 2026-12-31 | 31998d |  |  | CPT |  | 5.0 | N/A | Green | GREEN |  |  |
| 29 | 1.2.4.5 | Support code change inside & outside CCIAG |  | 1089d | 2022-10-31 A | 2026-12-31 | 43% | 616d | 2022-10-31 | 2026-12-31 | 1089d | 2022-10-31 | 2026-12-31 | 31998d |  |  | CPT |  | 5.0 | N/A | Green | GREEN |  |  |
| 30 | 1.2.4.6 | Support code change inside & outside CCAG |  | 1089d | 2022-10-31 A | 2026-12-31 | 43% | 616d | 2022-10-31 | 2026-12-31 | 1089d | 2022-10-31 | 2026-12-31 | 31998d |  |  | CPT |  | 5.0 | N/A | Green | GREEN |  |  |

| ID | WBS | Task | Type | Duration | Start | Finish | Predecessors | Complete | Remaining | Baseline start | Baseline finish | Baseline duration | Baseline 1 start | Baseline 1 finish | Total slack | Constraint | Baseline cost | Responsible | Involved | Task Status | Update Version | MHHS Resource Name | Sched Status | RAG | Milestone ID | Text29 | Tier | Text3 | MHHS Programme Phase | Artefact ID |
| --- | --- | --- | --- | --- | --- | --- | --- | --- | --- | --- | --- | --- | --- | --- | --- | --- | --- | --- | --- | --- | --- | --- | --- | --- | --- | --- | --- | --- | --- | --- |
| 31 | 1.2.5 | **Programme Replan Baseline** |  | 163d | 2022-10-31 A | 2023-06-14 A |  | 100% |  | 2022-10-31 | 2023-06-14 | 163d | 2022-10-31 | 2023-06-14 |  |  |  | N/A | N/A | M5+ | 5.0 | N/A |  |  |  |  |  |  |  |  |
| 32 | 1.2.5.1 | Round 3 consultation preparation |  | 32d | 2022-10-31 A | 2022-12-13 A |  | 100% |  | 2022-10-31 | 2022-12-13 | 32d | 2022-10-31 | 2022-12-13 |  |  |  | PMO | CPT |  | 5.0 | N/A | Complete | COMPLETE |  |  |  |  |  |  |
| 33 | 1.2.5.2 | PSG decision to launch Round 3 consultation | milestone | 0d | 2022-12-07 A | 2022-12-07 A | 32FS-5d | 100% |  | 2022-12-07 | 2022-12-07 | 0d | 2022-12-07 | 2022-12-07 |  |  |  | PMO | PPC |  | 5.0 | N/A | Complete | COMPLETE |  |  |  |  |  |  |
| 34 | 1.2.5.3 | Round 3 consultation (incl. walkthroughs and Q&A) |  | 35d | 2022-12-14 A | 2023-01-31 A | 33FS+5d | 100% |  | 2022-12-14 | 2023-01-31 | 35d | 2022-12-14 | 2023-01-31 |  |  |  | PP | PMO, PPC,IPA |  | 5.0 | N/A | Complete | COMPLETE |  |  |  |  |  |  |
| 35 | 1.2.5.4 | Review and uplift of foundational testing documents to align with replan approach |  | 92d | 2022-12-14 A | 2023-04-20 A | 34SS | 100% |  | 2022-12-14 | 2023-04-20 | 92d | 2022-12-14 | 2023-04-20 |  |  |  | SI Test | CPT |  | 5.0 | N/A | Complete | COMPLETE |  |  |  |  |  |  |
| 36 | 1.2.5.5 | Round 3 consultation responses analysis (incl. identification of SIT volunteers) |  | 10d | 2023-02-01 A | 2023-02-14 A | 34 | 100% |  | 2023-02-01 | 2023-02-14 | 10d | 2023-02-01 | 2023-02-14 |  |  |  | PMO | CPT |  | 5.0 | N/A | Complete | COMPLETE |  |  |  |  |  |  |
| 37 | 1.2.5.6 | Replan re-drafting and supporting artefact updates (incl. engagement with Ofgem) |  | 26d | 2023-02-15 A | 2023-03-22 A | 36 | 100% |  | 2023-02-15 | 2023-03-22 | 26d | 2023-02-15 | 2023-03-22 |  |  |  | PMO | CPT,IPA,Ofgem |  | 5.0 | N/A | Complete | COMPLETE |  |  |  |  |  |  |
| 38 | 1.2.5.7 | Draft Replan Change Request |  | 31d | 2023-02-15 A | 2023-03-29 A | 36 | 100% |  | 2023-02-15 | 2023-03-29 | 31d | 2023-02-15 | 2023-03-29 |  |  |  | PMO | CPT |  | 5.0 | N/A | Complete | COMPLETE |  |  |  |  |  |  |
| 39 | 1.2.5.8 | PSG decision to issue CR for industry impact assessment | milestone | 0d | 2023-04-05 A | 2023-04-05 A | 38FS+5d | 100% |  | 2023-04-05 | 2023-04-05 | 0d | 2023-04-05 | 2023-04-05 |  |  |  | PMO | CPT |  | 5.0 | N/A | Complete | COMPLETE |  |  |  |  |  |  |
| 40 | 1.2.5.9 | Industry impact assessment |  | 10d | 2023-04-06 A | 2023-04-19 A | 39 | 100% |  | 2023-04-06 | 2023-04-19 | 10d | 2023-04-06 | 2023-04-19 |  |  |  | PP | PMO,PPC |  | 5.0 | N/A | Complete | COMPLETE |  |  |  |  |  |  |
| 41 | 1.2.5.10 | Replan playbacks (to assist PPs in impact assessment) |  | 5d | 2023-04-11 A | 2023-04-17 A | 40SS+3d | 100% |  | 2023-04-11 | 2023-04-17 | 5d | 2023-04-11 | 2023-04-17 |  |  |  | CPT | PPC,PP |  | 5.0 | N/A | Complete | COMPLETE |  |  |  |  |  |  |
| 42 | 1.2.5.11 | Industry impact assessment responses analysis |  | 5d | 2023-04-20 A | 2023-04-26 A | 40 | 100% |  | 2023-04-20 | 2023-04-26 | 5d | 2023-04-20 | 2023-04-26 |  |  |  | PMO | CPT |  | 5.0 | N/A | Complete | COMPLETE |  |  |  |  |  |  |
| 43 | 1.2.5.12 | Extraordinary PSG decision to agree baseline recommendation | milestone | 0d | 2023-05-03 A | 2023-05-03 A | 42FS+5d | 100% |  | 2023-05-03 | 2023-05-03 | 0d | 2023-05-03 | 2023-05-03 |  |  |  | CPT | PMO,PP |  | 5.0 | N/A | Complete | COMPLETE |  |  |  |  |  |  |
| 44 | 1.2.5.13 | Plan Rebaselined (subject to Ofgem decision) | milestone | 0d | 2023-06-08 A | 2023-06-08 A | 43FS+25d | 100% |  | 2023-06-08 | 2023-06-08 | 0d? | 2023-06-07 | 2023-06-07 |  | start no earlier than 2023-06-08 | -0 | CPT | PMO,PP |  | 5.0 | N/A | Complete | COMPLETE | T1-PM-1000 | PSG | T1 |  |  |  |
| 45 | 1.2.5.14 | Programme Replan playbacks and drop-in sessions |  | 5d | 2023-06-08 A | 2023-06-14 A | 44 | 100% |  | 2023-06-08 | 2023-06-14 | 5d | 2023-06-08 | 2023-06-14 |  |  |  | PMO | PPC, PP |  | 5.0 | N/A | Complete | COMPLETE |  |  |  |  |  |  |
| 46 | 1.3 | **DESIGN, BUILD & TEST (PIT)** |  | 1101d? | 2022-10-31 A | 2027-01-18 |  | 80% | 215.94d? | 2022-10-31 | 2027-01-18 | 1101d | 2022-10-31 | 2027-01-18 | 31986d |  | -0 | N/A | N/A |  |  | N/A |  |  |  |  |  | 1 May 2022 - 31 Jul 2023 | Design, Build & Test (PIT) |  |
| 47 | 1.3.1 | **Design Baseline & Enduring PP Support** |  | 1101d | 2022-10-31 A | 2027-01-18 |  | 71% | 319.69d | 2022-10-31 | 2027-01-18 | 1101d | 2022-10-31 | 2027-01-18 | 31986d |  | -0 | N/A | N/A |  | 5.0 | N/A |  |  |  |  |  |  | Design, Build & Test (PIT) |  |
| 48 | 1.3.1.1 | Physical design baselined (M5) | milestone | 0d | 2022-10-31 A | 2022-10-31 A |  | 100% |  | 2022-10-31 | 2022-10-31 | 0d | 2022-10-31 | 2022-10-31 |  |  |  | SRO Design | SI Design,PP,IPA |  | 5.0 | Paul Pettitt | Complete | COMPLETE | T1-DB-1000 | PSG | T1 |  | Design, Build & Test (PIT) | MHHS-ART001 |
| 49 | 1.3.1.2 | **M5 Design Work-Off Plan Implementation & Approval** |  | 79d | 2022-10-31 A | 2023-02-16 A |  | 100% |  | 2022-10-31 | 2023-02-16 | 79d | 2022-10-31 | 2023-02-16 |  |  |  | N/A | N/A |  | 5.0 | N/A |  |  |  |  |  |  | Design, Build & Test (PIT) |  |
| 50 | 1.3.1.2.1 | Implementation of M5 design Work-Off Plan |  | 74d | 2022-10-31 A | 2023-02-09 A | 48 | 100% |  | 2022-10-31 | 2023-02-09 | 74d | 2022-10-31 | 2023-02-09 |  |  |  | SI Design | PP |  | 5.0 | Paul Pettitt | Complete | COMPLETE |  |  |  |  | Design, Build & Test (PIT) |  |
| 51 | 1.3.1.2.2 | M5 design Work-Off Plan completion approved | milestone | 0d | 2023-02-16 A | 2023-02-16 A | 50FS+5d | 100% |  | 2023-02-16 | 2023-02-16 | 0d | 2023-02-16 | 2023-02-16 |  |  |  | SI Design | PP |  | 5.0 | Paul Pettitt | Complete | COMPLETE | T3-DB-0014 | DAG | T3 |  | Design, Build & Test (PIT) |  |
| 52 | 1.3.1.3 | **Enduring PP Design Support** |  | 1089d | 2022-10-31 A | 2026-12-31 A |  | 100% |  | 2022-10-31 | 2026-12-31 | 1089d | 2022-10-31 | 2026-12-31 |  |  |  | N/A | N/A |  | 5.0 | N/A |  |  |  |  |  |  | Design, Build & Test (PIT) |  |
| 53 | 1.3.1.3.1 | Design playbacks and drop-in sessions |  | 45d | 2022-10-31 A | 2022-12-30 A | 48 | 100% |  | 2022-10-31 | 2022-12-30 | 45d | 2022-10-31 | 2022-12-30 |  |  |  | SI Design | PMO,PPC, SRO Design |  | 5.0 | Paul Pettitt | Complete | COMPLETE |  |  |  |  | Design, Build & Test (PIT) |  |
| 54 | 1.3.1.3.2 | Support participants on E2E MHHS Design |  | 1089d | 2022-10-31 A | 2026-12-31 A | 48 | 100% |  | 2022-10-31 | 2026-12-31 | 1089d | 2022-10-31 | 2026-12-31 |  |  |  | SI Design | PP |  | 5.0 | Paul Pettitt | Complete | COMPLETE |  |  |  |  | Design, Build & Test (PIT) |  |
| 55 | 1.3.1.3.3 | DIP Onboarding Support |  | 70d | 2022-11-14 A | 2023-02-17 A |  | 100% |  | 2022-11-14 | 2023-02-17 | 70d | 2022-11-14 | 2023-02-17 |  | must start on 2022-11-14 |  | SI Design | SRO Design |  | 5.0 | Paul Pettitt | Complete | COMPLETE |  |  |  |  | Design, Build & Test (PIT) |  |
| 56 | 1.3.1.3.4 | iServer Launch | milestone | 0d | 2023-02-16 A | 2023-02-16 A | 51 | 100% |  | 2023-02-16 | 2023-02-16 | 0d | 2023-02-16 | 2023-02-16 |  |  |  | SI Design | PP |  | 5.0 | Paul Pettitt | Complete | COMPLETE |  |  |  |  | Design, Build & Test (PIT) |  |

| ID | WBS | Task | Type | Duration | Start | Finish | Predecessors | Complete | Remaining | Baseline start | Baseline finish | Baseline duration | Baseline 1 start | Baseline 1 finish | Total slack | Constraint | Baseline cost | Responsible | Involved | Update Version | MHHS Resource Name | MHHS Programme Phase | Sched Status | RAG | Milestone ID | Text29 | Tier |
| --- | --- | --- | --- | --- | --- | --- | --- | --- | --- | --- | --- | --- | --- | --- | --- | --- | --- | --- | --- | --- | --- | --- | --- | --- | --- | --- | --- |
| 57 | 1.3.1.4 | **Establish Design Change Management Processes** |  | 1101d | 2022-10-31 A | 2027-01-18 |  | 36% | 706.22d | 2022-10-31 | 2027-01-18 | 1101d | 2022-10-31 | 2027-01-18 | 31986d |  |  | N/A | N/A | 5.0 | N/A | Design, Build & Test (PIT) |  |  |  |  |  |
| 58 | 1.3.1.4.1 | Internal review of internal change management processes |  | 35d | 2022-10-31 A | 2022-12-16 A |  | 100% |  | 2022-10-31 | 2022-12-16 | 35d | 2022-10-31 | 2022-12-16 |  |  |  | SRO | SI Design | 5.0 | Paul Pettitt | Design, Build & Test (PIT) | Complete | COMPLETE |  |  |  |
| 59 | 1.3.1.4.2 | SRO approval of internal change management processes | milestone | 0d | 2022-12-16 A | 2022-12-16 A | 58FF | 100% |  | 2022-12-16 | 2022-12-16 | 0d | 2022-12-16 | 2022-12-16 |  |  |  | SRO | SI Design | 5.0 | Paul Pettitt | Design, Build & Test (PIT) | Complete | COMPLETE |  |  |  |
| 60 | 1.3.1.4.3 | Change Process Webinar | milestone | 0d | 2023-01-16 A | 2023-01-16 A |  | 100% |  | 2023-01-16 | 2023-01-16 | 0d | 2023-01-16 | 2023-01-16 |  | must start on 2023-01-16 |  | SI Design | PP | 5.0 | Paul Pettitt | Design, Build & Test (PIT) | Complete | COMPLETE |  |  |  |
| 61 | 1.3.1.4.4 | Enduring change management process approved | milestone | 0d | 2023-02-16 A | 2023-02-16 A | 51FF | 100% |  | 2023-02-16 | 2023-02-16 | 0d | 2023-02-16 | 2023-02-16 |  |  |  | SI Design | PP | 5.0 | Paul Pettitt | Design, Build & Test (PIT) | Complete | COMPLETE | T3-DB-0016 | DAG | T3 |
| 62 | 1.3.1.4.5 | Maintain E2E MHHS Design (post-M5 design change management processes operational) |  | 1022d | 2023-02-17 A | 2027-01-18 | 61 | 34% | 678d | 2023-02-17 | 2027-01-18 | 1022d | 2023-02-17 | 2027-01-18 | 31986d |  |  | SI Design | PP | 5.0 | Paul Pettitt | Design, Build & Test (PIT) | Green | GREEN |  |  |  |
| 63 | 1.3.1.5 | **Design Authority Mobilisation** |  | 29d | 2022-12-14 A | 2023-01-23 A |  | 100% |  | 2022-12-14 | 2023-01-23 | 29d | 2022-12-14 | 2023-01-23 |  |  |  | N/A | N/A | 5.0 | N/A | Design, Build & Test (PIT) |  |  |  |  |  |
| 64 | 1.3.1.5.1 | Design Authority ToR approved | milestone | 0d | 2022-12-14 A | 2022-12-14 A |  | 100% |  | 2022-12-14 | 2022-12-14 | 0d | 2022-12-14 | 2022-12-14 |  | must start on 2022-12-14 |  | SI Design | PP | 5.0 | Paul Pettitt | Design, Build & Test (PIT) | Complete | COMPLETE | T3-DB-0010 | DAG | T3 |
| 65 | 1.3.1.5.2 | Inaugural Design Authority | milestone | 0d | 2023-01-23 A | 2023-01-23 A | 64FS+29d | 100% |  | 2023-01-23 | 2023-01-23 | 0d | 2023-01-23 | 2023-01-23 |  |  |  | SI Design | PP | 5.0 | Paul Pettitt | Design, Build & Test (PIT) | Complete | COMPLETE |  |  |  |
| 66 | 1.3.1.6 | **Network Operation Services Adaptor Procurement** |  | 0d | 2023-05-23 A | 2023-05-23 A |  | 100% |  | 2023-05-23 | 2023-05-23 | 0d | 2023-02-01 | 2025-03-14 |  |  | -0 | N/A | N/A | 5.0 | N/A | Design, Build & Test (PIT) |  |  |  |  |  |
| 67 | 1.3.1.6.1 | All SIT LDSOs have procured their adapter providers | milestone | 0d | 2023-05-23 A | 2023-05-23 A | 545SS | 100% |  | 2023-05-23 | 2023-05-23 | 0d | 2023-05-23 | 2023-05-23 |  |  |  | SI Design | PP | 5.0 | Paul Pettitt | Design, Build & Test (PIT) | Complete | COMPLETE | T3-DB-0020 | DAG | T3 |
| 68 | 1.3.2 | **PP Mobilisation** |  | 67d | 2022-10-31 A | 2023-01-31 A |  | 100% |  | 2022-10-31 | 2023-01-31 | 67d | 2022-10-31 | 2023-01-31 |  |  |  | N/A | N/A | 5.0 | N/A | Design, Build & Test (PIT) |  |  |  |  |  |
| 69 | 1.3.2.1 | Set up governance |  | 67d | 2022-10-31 A | 2023-01-31 A |  | 100% |  | 2022-10-31 | 2023-01-31 | 67d | 2022-10-31 | 2023-01-31 |  |  |  | PP |  | 5.0 | PP | Design, Build & Test (PIT) | Complete | COMPLETE |  |  |  |
| 70 | 1.3.2.2 | Set up reporting |  | 67d | 2022-10-31 A | 2023-01-31 A |  | 100% |  | 2022-10-31 | 2023-01-31 | 67d | 2022-10-31 | 2023-01-31 |  |  |  | PP |  | 5.0 | PP | Design, Build & Test (PIT) | Complete | COMPLETE |  |  |  |
| 71 | 1.3.2.3 | Obtain funding |  | 67d | 2022-10-31 A | 2023-01-31 A |  | 100% |  | 2022-10-31 | 2023-01-31 | 67d | 2022-10-31 | 2023-01-31 |  |  |  | PP |  | 5.0 | PP | Design, Build & Test (PIT) | Complete | COMPLETE |  |  |  |
| 72 | 1.3.2.4 | Earmark resources |  | 67d | 2022-10-31 A | 2023-01-31 A |  | 100% |  | 2022-10-31 | 2023-01-31 | 67d | 2022-10-31 | 2023-01-31 |  |  |  | PP |  | 5.0 | PP | Design, Build & Test (PIT) | Complete | COMPLETE |  |  |  |
| 73 | 1.3.2.5 | Mobilise initial team |  | 67d | 2022-10-31 A | 2023-01-31 A |  | 100% |  | 2022-10-31 | 2023-01-31 | 67d | 2022-10-31 | 2023-01-31 |  |  |  | PP |  | 5.0 | PP | Design, Build & Test (PIT) | Complete | COMPLETE |  |  |  |
| 74 | 1.3.3 | **PIT Stub Specification and Delivery** |  | 435d | 2022-10-31 A | 2024-06-28 A |  | 100% |  | 2022-10-31 | 2024-06-21 | 430d | 2022-10-31 | 2023-05-31 |  |  | -0 | N/A | N/A | 5.0 | N/A | Design, Build & Test (PIT) |  |  |  |  |  |
| 75 | 1.3.3.1 | **DIP Simulator** |  | 108d | 2022-10-31 A | 2023-03-29 A |  | 100% |  | 2022-10-31 | 2023-03-29 | 108d | 2022-10-31 | 2023-03-29 |  |  |  | N/A | N/A | 5.0 | N/A | Design, Build & Test (PIT) |  |  |  |  |  |
| 76 | 1.3.3.1.1 | Build & Test |  | 95d | 2022-10-31 A | 2023-03-10 A | 48 | 100% |  | 2022-10-31 | 2023-03-10 | 95d | 2022-10-31 | 2023-03-10 |  |  |  | SI DevOps |  | 5.0 | Rebecca Farooq | Design, Build & Test (PIT) | Complete | COMPLETE |  |  |  |
| 77 | 1.3.3.1.2 | UAT |  | 85d | 2022-11-14 A | 2023-03-10 A | 76SS+10d | 100% |  | 2022-11-14 | 2023-03-10 | 85d | 2022-11-14 | 2023-03-10 |  |  |  | SI Test |  | 5.0 | Rebecca Farooq | Design, Build & Test (PIT) | Complete | COMPLETE |  |  |  |
| 78 | 1.3.3.1.3 | Beta test |  | 95d | 2022-10-31 A | 2023-03-10 A | 76SS | 100% |  | 2022-10-31 | 2023-03-10 | 95d | 2022-10-31 | 2023-03-10 |  |  |  | PP | SI Test | 5.0 | Rebecca Farooq | Design, Build & Test (PIT) | Complete | COMPLETE |  |  |  |
| 79 | 1.3.3.1.4 | Prepare for release |  | 18d | 2023-03-06 A | 2023-03-29 A | 78FS-5d | 100% |  | 2023-03-06 | 2023-03-29 | 18d | 2023-03-06 | 2023-03-29 |  |  |  | SI DevOps |  | 5.0 | Rebecca Farooq | Design, Build & Test (PIT) | Complete | COMPLETE |  |  |  |
| 80 | 1.3.3.1.5 | DIP Simulator released | milestone | 0d | 2023-03-29 A | 2023-03-29 A | 79FF | 100% |  | 2023-03-29 | 2023-03-29 | 0d | 2023-03-29 | 2023-03-29 |  | start no earlier than 2023-01-30 |  | SI DevOps |  | 5.0 | Rebecca Farooq | Design, Build & Test (PIT) | Complete | COMPLETE | T3-DB-0018 | SITAG | T3 |

| ID | WBS | Task | Type | Duration | Start | Finish | Predecessors | Complete | Remaining | Baseline start | Baseline finish | Baseline duration | Baseline 1 start | Baseline 1 finish | Total slack | Constraint | Baseline cost | Responsible | Involved | Update Version | MHHS Resource Name | MHHS Programme Phase | Sched Status | RAG | Milestone ID | Text29 | Tier |
| --- | --- | --- | --- | --- | --- | --- | --- | --- | --- | --- | --- | --- | --- | --- | --- | --- | --- | --- | --- | --- | --- | --- | --- | --- | --- | --- | --- |
| 81 | 1.3.3.2 | **DIP Simulator Uplifts** |  | 257d | 2023-07-06 A | 2024-06-28 A |  | 100% |  | 2023-07-06 | 2024-06-21 | 252d |  |  |  |  | -0 | N/A | N/A | 5.1 | N/A | Design, Build & Test (PIT) |  |  |  |  |  |
| 82 | 1.3.3.2.1 | DIP Simulator uplifted to align with design releases - design/build/test |  | 27d | 2023-07-06 A | 2023-08-11 A | 118 | 100% |  | 2023-07-06 | 2023-08-11 | 27d |  |  |  |  |  | SI DevOps |  | 5.1 | Rebecca Farooq | Design, Build & Test (PIT) | Complete | COMPLETE |  |  |  |
| 83 | 1.3.3.2.2 | DIP Simulator uplifted to align with Interim Release 2 | milestone | 0d | 2023-08-11 A | 2023-08-11 A | 82 | 100% |  | 2023-08-11 | 2023-08-11 | 0d |  |  |  |  |  | SI DevOps |  | 5.1 | Rebecca Farooq | Design, Build & Test (PIT) | Complete | COMPLETE | T3-DB-0035 | SITAG | T3 |
| 84 | 1.3.3.2.3 | DIP Simulator uplifted to align with design releases - design/build/test |  | 20d | 2023-10-09 A | 2023-11-03 A | 127FS+2d | 100% |  | 2023-10-09 | 2023-11-03 | 20d |  |  |  |  |  | SI DevOps |  | 5.3 | Rebecca Farooq | Design, Build & Test (PIT) | Complete | COMPLETE |  |  |  |
| 85 | 1.3.3.2.4 | DIP Simulator uplifted to align with Interim Release 5 | milestone | 0d | 2023-11-03 A | 2023-11-03 A | 84 | 100% |  | 2023-11-03 | 2023-11-03 | 0d |  |  |  |  |  | SI DevOps |  | 5.11 | Rebecca Farooq | Design, Build & Test (PIT) | Complete | COMPLETE | T3-DB-0039 | SITAG | T3 |
| 86 | 1.3.3.2.5 | DIP Simulator uplifted to align with design releases - design/build/test |  | 37d | 2024-02-01 A | 2024-03-22 A | 135 | 100% |  | 2024-02-01 | 2024-03-22 | 37d |  |  |  |  |  | SI DevOps | PP,SRO,Testing | 5.14 | Matthew Bray | Design, Build & Test (PIT) | Complete | COMPLETE |  |  |  |
| 87 | 1.3.3.2.6 | DIP Simulator uplifted to align with Interim Release 7 | milestone | 0d | 2024-03-22 A | 2024-03-22 A | 86 | 100% |  | 2024-03-22 | 2024-03-22 | 0d |  |  |  |  |  | SI DevOps | PP,SRO,Testing | 5.14 | Matthew Bray | Design, Build & Test (PIT) | Complete | COMPLETE | T3-DB-0182 | SITAG | T3 |
| 88 | 1.3.3.2.7 | DIP Simulator uplifted to align with design releases - design/build/test |  | 57d | 2024-04-04 A | 2024-06-21 A | 139 | 100% |  | 2024-04-04 | 2024-06-21 | 57d |  |  |  |  |  | SI DevOps | PP,SRO,Testing | 5.14 | Matthew Bray | Design, Build & Test (PIT) | Complete | COMPLETE |  |  |  |
| 89 | 1.3.3.2.8 | DIP Simulator uplifted to align with Interim Release 8 | milestone | 0d | 2024-06-28 A | 2024-06-28 A | 88FS+5d | 100% |  | 2024-06-21 | 2024-06-21 | 0d |  |  |  |  |  | SI DevOps | PP,SRO,Testing | 5.28 | Matthew Bray | Design, Build & Test (PIT) | Complete | COMPLETE | T3-DB-0183 | SITAG | T3 |
| 90 | 1.3.3.3 | **Data Generator** |  | 130d | 2022-12-01 A | 2023-05-31 A |  | 100% |  | 2022-12-01 | 2023-05-31 | 130d | 2022-12-01 | 2023-05-31 |  |  |  | N/A | N/A | 5.0 | N/A | Design, Build & Test (PIT) |  |  |  |  |  |
| 91 | 1.3.3.3.1 | Design | manual | 15d | 2022-12-01 A | 2022-12-21 A |  | 100% |  | 2022-12-01 | 2022-12-21 | 15d | 2022-12-01 | 2022-12-21 |  |  |  | SI DevOps |  | 5.0 | Rebecca Farooq | Design, Build & Test (PIT) | Complete | COMPLETE |  |  |  |
| 92 | 1.3.3.3.2 | Build & Test |  | 50d | 2023-02-16 A | 2023-04-26 A | 91FS+40d | 100% |  | 2023-02-16 | 2023-04-26 | 50d | 2023-02-16 | 2023-04-26 |  |  |  | SI DevOps |  | 5.0 | Rebecca Farooq | Design, Build & Test (PIT) | Complete | COMPLETE |  |  |  |
| 93 | 1.3.3.3.3 | UAT |  | 10d | 2023-04-27 A | 2023-05-10 A | 92 | 100% |  | 2023-04-27 | 2023-05-10 | 10d | 2023-04-27 | 2023-05-10 |  |  |  | SI Test |  | 5.0 | Rebecca Farooq | Design, Build & Test (PIT) | Complete | COMPLETE |  |  |  |
| 94 | 1.3.3.3.4 | Beta test |  | 45d | 2023-03-30 A | 2023-05-31 A | 92FS-20d, 96FF | 100% |  | 2023-03-30 | 2023-05-31 | 45d | 2023-03-30 | 2023-05-31 |  |  |  | PP | SI Test | 5.0 | Rebecca Farooq | Design, Build & Test (PIT) | Complete | COMPLETE |  |  |  |
| 95 | 1.3.3.3.5 | Prepare for release |  | 24d | 2023-04-27 A | 2023-05-30 A | 93SS | 100% |  | 2023-04-27 | 2023-05-30 | 24d | 2023-04-27 | 2023-05-30 |  |  |  | SI DevOps |  | 5.0 | Rebecca Farooq | Design, Build & Test (PIT) | Complete | COMPLETE |  |  |  |
| 96 | 1.3.3.3.6 | Data Generator released | milestone | 0d | 2023-05-31 A | 2023-05-31 A | 95FS+1d | 100% |  | 2023-05-31 | 2023-05-31 | 0d | 2023-05-31 | 2023-05-31 |  |  |  | SI DevOps |  | 5.0 | Rebecca Farooq | Design, Build & Test (PIT) | Complete | COMPLETE | T3-DB-0022 | SITAG | T3 |
| 97 | 1.3.4 | **Design Artefact Releases** |  | 433d? | 2023-02-22 A | 2024-10-18 |  | 92% | 33.14d? | 2023-02-22 | 2024-08-30 | 398d | 2023-02-22 | 2023-09-29 | 31798d |  | -0 | N/A | N/A | 5.0 | N/A | Design, Build & Test (PIT) |  |  |  |  |  |
| 98 | 1.3.4.1 | **Interim release 1** |  | 79d | 2023-02-22 A | 2023-06-12 A |  | 100% |  | 2023-02-22 | 2023-06-12 | 79d | 2023-02-22 | 2023-06-28 |  |  |  | N/A | N/A | 5.0 | N/A | Design, Build & Test (PIT) |  |  |  |  |  |
| 99 | 1.3.4.1.1 | Prioritise DINs and CR |  | 1d | 2023-02-22 A | 2023-02-22 A |  | 100% |  | 2023-02-22 | 2023-02-22 | 1d | 2023-02-22 | 2023-02-22 |  | must start on 2023-02-22 |  | SI Design |  | 5.0 | Paul Pettitt | Design, Build & Test (PIT) | Complete | COMPLETE |  |  |  |
| 100 | 1.3.4.1.2 | **Industry input session** |  | 7d | 2023-02-23 A | 2023-03-03 A |  | 100% |  | 2023-02-23 | 2023-03-03 | 7d | 2023-02-23 | 2023-03-03 |  |  |  | N/A | N/A | 5.0 | N/A | Design, Build & Test (PIT) |  |  |  |  |  |
| 101 | 1.3.4.1.2.1 | Raise a CR covering prioritized assessment cluster |  | 1d | 2023-02-23 A | 2023-02-23 A | 99 | 100% |  | 2023-02-23 | 2023-02-23 | 1d | 2023-02-23 | 2023-02-23 |  |  |  | SI Design |  | 5.0 | Paul Pettitt | Design, Build & Test (PIT) | Complete | COMPLETE |  |  |  |
| 102 | 1.3.4.1.2.2 | Organize Industry Input session to go through significant items to reach consensus |  | 1d | 2023-02-23 A | 2023-02-23 A | 101SS | 100% |  | 2023-02-23 | 2023-02-23 | 1d | 2023-02-23 | 2023-02-23 |  |  |  | SI Design | PP | 5.0 | Paul Pettitt,Berlinda Kugara | Design, Build & Test (PIT) | Complete | COMPLETE |  |  |  |
| 103 | 1.3.4.1.2.3 | Conduct Meeting |  | 1d | 2023-03-03 A | 2023-03-03 A | 102FS+5d | 100% |  | 2023-03-03 | 2023-03-03 | 1d | 2023-03-03 | 2023-03-03 |  |  |  | SI Design | PP | 5.0 | Paul Pettitt,Berlinda Kugara | Design, Build & Test (PIT) | Complete | COMPLETE |  |  |  |
| 104 | 1.3.4.1.3 | Update baselined artefacts |  | 10d | 2023-03-24 A | 2023-04-06 A |  | 100% |  | 2023-03-24 | 2023-04-06 | 10d | 2023-03-24 | 2023-04-06 |  |  |  | SI Design |  | 5.0 | Paul Pettitt | Design, Build & Test (PIT) | Complete | COMPLETE |  |  |  |

Notes:
- 85: Amber as S&E couldn't view design docs, & assess scope changes. Required workload likely more than 2 sprints (original estimate). Additional MS work & CIT testing support has stretched capacity further. Delivery could be delayed. / Action: 26/7/23 - forecast changed from 15/12/23 - 3/11/23 - Changed from Interim Release 6 to 5. Updated in milestone register
- 87: 11/12- Add new milestone to reflect confirmation of Interim Release Delivery dates. 20/12 - Approved at TMAG on 20/12
- 89: 20/6: Date missed because a decision was taken and agreed with SRO to bundle IR8 and IR8.1, meaning a later combined release date of 28/6. No PP impact as PIT for SIT Cycle 3 will be baselined against IR8.1

| ID | WBS | Task | Type | Duration | Start | Finish | Predecessors | Complete | Baseline start | Baseline finish | Baseline duration | Baseline 1 start | Baseline 1 finish | Constraint | Baseline cost | Responsible | Involved | Update Version | MHHS Resource Name | MHHS Programme Phase | Sched Status | RAG | Milestone ID | Text29 | Tier | Action |
| --- | --- | --- | --- | --- | --- | --- | --- | --- | --- | --- | --- | --- | --- | --- | --- | --- | --- | --- | --- | --- | --- | --- | --- | --- | --- | --- |
| 105 | 1.3.4.1.4 | **Participant review and impact assess changes** |  | 18d | 2023-04-14 A | 2023-05-09 A |  | 100% | 2023-04-14 | 2023-05-09 | 18d | 2023-04-14 | 2023-05-09 |  |  | N/A | N/A | 5.0 | N/A | Design, Build & Test (PIT) |  |  |  |  |  |  |
| 106 | 1.3.4.1.4.1 | Issue Redline Version of documents |  | 1d | 2023-04-14 A | 2023-04-14 A | 104FS+5d | 100% | 2023-04-14 | 2023-04-14 | 1d | 2023-04-14 | 2023-04-14 |  |  | SI Design |  | 5.0 | Paul Pettitt | Design, Build & Test (PIT) | Complete | COMPLETE |  |  |  |  |
| 107 | 1.3.4.1.4.2 | Participants provide review comments to common log |  | 17d | 2023-04-17 A | 2023-05-09 A | 106 | 100% | 2023-04-17 | 2023-05-09 | 17d | 2023-04-17 | 2023-05-09 |  |  | PP |  | 5.0 | Paul Pettitt | Design, Build & Test (PIT) | Complete | COMPLETE |  |  |  |  |
| 108 | 1.3.4.1.5 | **Assurance review** |  | 19d | 2023-05-10 A | 2023-06-05 A |  | 100% | 2023-05-10 | 2023-06-05 | 19d | 2023-05-10 | 2023-06-05 |  |  | N/A | N/A | 5.0 | N/A | Design, Build & Test (PIT) |  |  |  |  |  |  |
| 109 | 1.3.4.1.5.1 | SI Design Review and Respond to Comments |  | 5d | 2023-05-10 A | 2023-05-16 A | 107 | 100% | 2023-05-10 | 2023-05-16 | 5d | 2023-05-10 | 2023-05-16 |  |  | SI Design |  | 5.0 | Paul Pettitt | Design, Build & Test (PIT) | Complete | COMPLETE |  |  |  |  |
| 110 | 1.3.4.1.5.2 | Prep for Assurance Review Meeting |  | 7d | 2023-05-17 A | 2023-05-25 A | 109 | 100% | 2023-05-17 | 2023-05-25 | 7d | 2023-05-17 | 2023-05-25 |  |  | SI Design |  | 5.0 | Paul Pettitt | Design, Build & Test (PIT) | Complete | COMPLETE |  |  |  |  |
| 111 | 1.3.4.1.5.3 | Conduct Assurance Review Meeting |  | 1d | 2023-05-26 A | 2023-05-26 A | 110 | 100% | 2023-05-26 | 2023-05-26 | 1d | 2023-05-26 | 2023-05-26 |  |  | SI Design |  | 5.0 | Paul Pettitt | Design, Build & Test (PIT) | Complete | COMPLETE |  |  |  |  |
| 112 | 1.3.4.1.5.4 | Update Artefacts following Assurance Review |  | 6d | 2023-05-29 A | 2023-06-05 A | 111 | 100% | 2023-05-29 | 2023-06-05 | 6d | 2023-05-29 | 2023-06-05 |  |  | SI Design |  | 5.0 | Paul Pettitt | Design, Build & Test (PIT) | Complete | COMPLETE |  |  |  |  |
| 113 | 1.3.4.1.6 | PSG Approval of interim release plan |  | 1d | 2023-06-08 A | 2023-06-08 A |  | 100% | 2023-06-08 | 2023-06-08 | 1d |  |  | must start on 2023-06-08 |  | PP | SI Design | 5.1 | Paul Pettitt | Design, Build & Test (PIT) | Complete | COMPLETE |  |  |  |  |
| 114 | 1.3.4.1.7 | Publish updated baselined artefacts | milestone | 0d | 2023-06-06 A | 2023-06-12 A | 112 | 100% | 2023-06-06 | 2023-06-12 | 5d | 2023-06-15 | 2023-06-21 |  |  | SI Design |  | 5.0 | Paul Pettitt | Design, Build & Test (PIT) | Complete | COMPLETE |  |  |  |  |
| 115 | 1.3.4.1.8 | Interim release 1 Go live | milestone | 0d | 2023-06-12 A | 2023-06-12 A | 114 | 100% | 2023-06-12 | 2023-06-12 | 0d | 2023-06-28 | 2023-06-28 |  |  | SI Design |  | 5.0 | Paul Pettitt | Design, Build & Test (PIT) | Complete | COMPLETE | T3-DB-0095 | DAG | T3 |  |
| 116 | 1.3.4.2 | **Interim release 2** |  | 27d | 2023-05-30 A | 2023-07-05 A |  | 100% | 2023-05-30 | 2023-07-05 | 27d | 2023-05-24 | 2023-07-28 |  |  | N/A | N/A | 5.0 | N/A | Design, Build & Test (PIT) |  |  |  |  |  |  |
| 117 | 1.3.4.2.1 | Update baselined artefacts |  | 27d | 2023-05-30 A | 2023-07-05 A |  | 100% | 2023-05-30 | 2023-07-05 | 27d |  |  | must start on 2023-05-30 |  | SI Design | PP | 5.1 | Paul Pettitt | Design, Build & Test (PIT) | Complete | COMPLETE |  |  |  |  |
| 118 | 1.3.4.2.2 | Interim release 2 Go live | milestone | 0d | 2023-07-05 A | 2023-07-05 A | 117 | 100% | 2023-07-05 | 2023-07-05 | 0d | 2023-07-28 | 2023-07-28 |  |  | SI Design |  | 5.0 | Paul Pettitt | Design, Build & Test (PIT) | Complete | COMPLETE | T3-DB-0096 | DAG | T3 |  |
| 119 | 1.3.4.3 | **Interim release 3** |  | 35d | 2023-06-15 A | 2023-08-02 A |  | 100% | 2023-06-15 | 2023-08-02 | 35d | 2023-06-29 | 2023-09-29 |  |  | N/A | N/A | 5.0 | N/A | Design, Build & Test (PIT) |  |  |  |  |  |  |
| 120 | 1.3.4.3.1 | Update baselined artefacts |  | 35d | 2023-06-15 A | 2023-08-02 A |  | 100% | 2023-06-15 | 2023-08-02 | 35d |  |  | must start on 2023-06-15 |  | SI Design | PP | 5.1 | Paul Pettitt | Design, Build & Test (PIT) | Complete | COMPLETE |  |  |  |  |
| 121 | 1.3.4.3.2 | Interim release 3 Go live | milestone | 0d | 2023-08-02 A | 2023-08-02 A | 120 | 100% | 2023-08-02 | 2023-08-02 | 0d | 2023-09-29 | 2023-09-29 |  |  | SI Design |  | 5.0 | Paul Pettitt | Design, Build & Test (PIT) | Complete | COMPLETE | T3-DB-0097 | DAG | T3 |  |
| 122 | 1.3.4.4 | **Interim release 4** |  | 36d | 2023-07-12 A | 2023-08-30 A |  | 100% | 2023-07-12 | 2023-08-30 | 36d |  |  |  |  | N/A | N/A | 5.1 | N/A | Design, Build & Test (PIT) |  |  |  |  |  |  |
| 123 | 1.3.4.4.1 | Update baselined artefacts |  | 36d | 2023-07-12 A | 2023-08-30 A |  | 100% | 2023-07-12 | 2023-08-30 | 36d |  |  | must start on 2023-07-12 |  | SI Design | PP | 5.1 | Paul Pettitt | Design, Build & Test (PIT) | Complete | COMPLETE |  |  |  |  |
| 124 | 1.3.4.4.2 | Interim release 4 Go live | milestone | 0d | 2023-08-30 A | 2023-08-30 A | 123 | 100% | 2023-08-30 | 2023-08-30 | 0d |  |  |  |  | SI Design |  | 5.1 | Paul Pettitt | Design, Build & Test (PIT) | Complete | COMPLETE | T3-DB-0081 | DAG | T3 |  |
| 125 | 1.3.4.5 | **Interim release 5** |  | 147d | 2023-08-17 A | 2024-03-08 A |  | 100% | 2023-08-17 | 2024-03-08 | 147d |  |  |  | -0 | N/A | N/A | 5.1 | N/A | Design, Build & Test (PIT) |  |  |  |  |  |  |
| 126 | 1.3.4.5.1 | Update baselined artefacts |  | 35d | 2023-08-17 A | 2023-10-04 A |  | 100% | 2023-08-17 | 2023-10-04 | 35d |  |  | must start on 2023-08-17 |  | SI Design | PP | 5.1 | Paul Pettitt | Design, Build & Test (PIT) | Complete | COMPLETE |  |  |  |  |
| 127 | 1.3.4.5.2 | Interim release 5 Go live | milestone | 0d | 2023-10-04 A | 2023-10-04 A | 126 | 100% | 2023-10-04 | 2023-10-04 | 0d |  |  |  |  | SI Design |  | 5.1 | Paul Pettitt | Design, Build & Test (PIT) | Complete | COMPLETE | T3-DB-0083 | DAG | T3 | 11/8 - successor is SIT functional (starts in march) |
| 128 | 1.3.4.5.3 | Interim Release 5 Deployed to SIT |  | 10d | 2024-02-26 A | 2024-03-08 A | 127FS+102d | 100% | 2024-02-26 | 2024-03-08 | 10d |  |  |  |  | SI Testing | PP | 5.16 |  |  | Complete | COMPLETE |  |  |  |  |

| ID | WBS | Task | Type | Duration | Start | Finish | Predecessors | Complete | Remaining | Baseline start | Baseline finish | Baseline duration | Baseline 1 start | Baseline 1 finish | Total slack | Free slack | Constraint | Baseline cost | Responsible | Involved | Update Version | MHHS Resource Name | MHHS Programme Phase | Sched Status | RAG | Milestone ID | Text29 | Tier | Action | Task Status |
| --- | --- | --- | --- | --- | --- | --- | --- | --- | --- | --- | --- | --- | --- | --- | --- | --- | --- | --- | --- | --- | --- | --- | --- | --- | --- | --- | --- | --- | --- | --- |
| 129 | 1.3.4.6 | **Interim release 6** |  | 192d | 2023-09-14 A | 2024-06-07 A |  | 100% |  | 2023-09-14 | 2024-06-07 | 192d |  |  |  |  |  | -0 | N/A | N/A | 5.1 | N/A | Design, Build & Test (PIT) |  |  |  |  |  |  |  |
| 130 | 1.3.4.6.1 | Update baselined artefacts |  | 35d | 2023-09-14 A | 2023-11-01 A |  | 100% |  | 2023-09-14 | 2023-10-27 | 32d |  |  |  |  | must start on 2023-09-14 |  | SI Design | PP | 5.1 | Paul Pettitt | Design, Build & Test (PIT) | Complete | COMPLETE |  |  |  |  |  |
| 131 | 1.3.4.6.2 | Interim release 6 Go live | milestone | 0d | 2023-11-01 A | 2023-11-01 A | 130 | 100% |  | 2023-10-27 | 2023-10-27 | 0d |  |  |  |  |  |  | SI Design |  | 5.11 | Paul Pettitt | Design, Build & Test (PIT) | Complete | COMPLETE | T3-DB-0085 | DAG | T3 |  |  |
| 132 | 1.3.4.6.3 | Interim Release 6 Deployed to SIT |  | 10d | 2024-05-27 A | 2024-06-07 A | 131FS+147d | 100% |  | 2024-05-27 | 2024-06-07 | 10d |  |  |  |  |  |  | SI Testing | PP | 5.16 |  |  | Complete | COMPLETE |  |  |  |  |  |
| 133 | 1.3.4.7 | **Interim release 7** |  | 168d | 2023-10-18 A | 2024-06-07 A |  | 100% |  | 2023-10-18 | 2024-06-07 | 168d |  |  |  |  |  | -0 | N/A | N/A | 5.5 | N/A | Design, Build & Test (PIT) |  |  |  |  |  |  |  |
| 134 | 1.3.4.7.1 | Update baselined artefacts |  | 76d | 2023-10-18 A | 2024-01-31 A |  | 100% |  | 2023-10-18 | 2024-01-31 | 76d |  |  |  |  | start no earlier than 2023-10-18 |  | SI Design | PP | 5.5 | Paul Pettitt | Design, Build & Test (PIT) | Complete | COMPLETE |  |  |  |  |  |
| 135 | 1.3.4.7.2 | Interim release 7 Go live | milestone | 0d | 2024-01-31 A | 2024-01-31 A | 134 | 100% |  | 2024-01-31 | 2024-01-31 | 0d |  |  |  |  |  |  | SI Design | PP | 5.14 | Paul Pettitt | Design, Build & Test (PIT) | Complete | COMPLETE | T3-DB-0098 | DAG | T3 | 4/8 - add as t3 milestones. Awaiting approval at TMAG |  |
| 136 | 1.3.4.7.3 | Interim Release 7 Deployed to SIT |  | 10d | 2024-05-27 A | 2024-06-07 A | 135FS+82d | 100% |  | 2024-05-27 | 2024-06-07 | 10d |  |  |  |  |  |  | SI Testing | PP | 5.16 |  |  | Complete | COMPLETE |  |  |  |  |  |
| 137 | 1.3.4.8 | **Interim release 8** |  | 178d? | 2024-02-14 A | 2024-10-18 |  | 55% | 80.91d? | 2024-02-14 | 2024-08-30 | 143d |  |  | 31798d |  |  | -0 | N/A | N/A | 5.5 | N/A | Design, Build & Test (PIT) |  |  |  |  |  |  |  |
| 138 | 1.3.4.8.1 | Update baselined artefacts |  | 36d | 2024-02-14 A | 2024-04-03 A |  | 100% |  | 2024-02-14 | 2024-04-03 | 36d |  |  |  |  | start no earlier than 2024-02-14 |  | SI Design | PP | 5.5 | Paul Pettitt | Design, Build & Test (PIT) | Complete | COMPLETE |  |  |  |  |  |
| 139 | 1.3.4.8.2 | Interim release 8 Go live | milestone | 0d | 2024-04-03 A | 2024-04-03 A | 138 | 100% |  | 2024-04-03 | 2024-04-03 | 0d |  |  |  |  | start no earlier than 2024-01-10 |  | SI Design | PP | 5.14 | Paul Pettitt | Design, Build & Test (PIT) | Complete | COMPLETE | T3-DB-0099 | DAG | T3 | 4/8 - add as t3 milestones. Awaiting approval at TMAG |  |
| 140 | 1.3.4.8.3 | **Interim Release 8.3 - Maintenance Window** |  | 20d? | 2024-09-23 | 2024-10-18 |  |  |  |  |  |  |  |  | 27d |  |  |  |  |  | 6.0 |  |  | Overdue Start | green |  |  |  |  | -686.67 |
| 141 | 1.3.4.8.3.1 | Interim Release 8 Deployed to SIT A |  | 20d | 2024-09-23 | 2024-10-18 | 139FS+122d |  |  | 2024-08-19 | 2024-08-30 | 10d |  |  | 27d | 0d |  |  | SI Testing | PP | 5.16 | Roger Robar |  | Red | RED |  |  |  |  | 3.33 |
| 142 | 1.3.4.8.3.2 | Interim Release 8 Deployed to SIT B |  | 10d? | 2024-09-23 | 2024-10-04 | 141SS |  |  |  |  |  |  |  | 31808d | 0d |  |  |  |  |  |  |  | No BL | GREEN |  |  |  |  | 3.33 |
| 143 | 1.3.5 | **Queries Support / Knowledgebase & Tool Roll-Out (Systems)** |  | 325d | 2023-01-03 A | 2024-04-01 A |  | 100% |  | 2023-01-03 | 2024-04-01 | 325d | 2023-01-03 | 2024-04-01 |  |  |  |  | N/A | N/A | 5.0 | N/A | Design, Build & Test (PIT) |  |  |  |  |  |  |  |
| 144 | 1.3.5.1 | **Query Management** |  | 325d | 2023-01-03 A | 2024-04-01 A |  | 100% |  | 2023-01-03 | 2024-04-01 | 325d | 2023-01-03 | 2024-04-01 |  |  |  |  | N/A | N/A | 5.0 | N/A | Design, Build & Test (PIT) |  |  |  |  |  |  |  |
| 145 | 1.3.5.1.1 | Respond to Participant Queries |  | 325d | 2023-01-03 A | 2024-04-01 A |  | 100% |  | 2023-01-03 | 2024-04-01 | 325d | 2023-01-03 | 2024-04-01 |  |  | must start on 2023-01-03 |  | SI Design | PP | 5.0 | Paul Pettitt | Design, Build & Test (PIT) | Complete | COMPLETE |  |  |  | 11/8 - runs out to end of the programme |  |
| 146 | 1.3.5.1.2 | Respond to Programme Queries |  | 325d | 2023-01-03 A | 2024-04-01 A | 145SS | 100% |  | 2023-01-03 | 2024-04-01 | 325d | 2023-01-03 | 2024-04-01 |  |  |  |  | SI Design | PP | 5.0 | Paul Pettitt | Design, Build & Test (PIT) | Complete | COMPLETE |  |  |  | 11/8 - runs out to end of the programme |  |
| 147 | 1.3.5.2 | **Query Support tooling (FreshDesk)** |  | 23d | 2023-06-01 A | 2023-07-03 A |  | 100% |  | 2023-06-01 | 2023-07-03 | 23d | 2023-06-01 | 2023-07-03 |  |  |  |  | N/A | N/A | 5.0 | N/A | Design, Build & Test (PIT) |  |  |  |  |  |  |  |
| 148 | 1.3.5.2.1 | Migrate to Standalone Freshdesk |  | 10d | 2023-06-01 A | 2023-06-14 A |  | 100% |  | 2023-06-01 | 2023-06-14 | 10d | 2023-06-01 | 2023-06-14 |  |  | must start on 2023-06-01 |  | SI Design |  | 5.0 | Paul Pettitt | Design, Build & Test (PIT) | Complete | COMPLETE |  |  |  |  |  |
| 149 | 1.3.5.2.2 | Develop reporting dashboard |  | 5d | 2023-06-15 A | 2023-06-21 A | 148 | 100% |  | 2023-06-15 | 2023-06-21 | 5d | 2023-06-15 | 2023-06-21 |  |  |  |  | SI Design |  | 5.0 | Paul Pettitt | Design, Build & Test (PIT) | Complete | COMPLETE |  |  |  |  |  |
| 150 | 1.3.5.2.3 | Issue to SRO for Review |  | 5d | 2023-06-22 A | 2023-06-28 A | 149 | 100% |  | 2023-06-22 | 2023-06-28 | 5d | 2023-06-22 | 2023-06-28 |  |  |  |  | SI Design |  | 5.0 | Paul Pettitt | Design, Build & Test (PIT) | Complete | COMPLETE |  |  |  |  |  |
| 151 | 1.3.5.2.4 | Update following review |  | 2d | 2023-06-29 A | 2023-06-30 A | 150 | 100% |  | 2023-06-29 | 2023-06-30 | 2d | 2023-06-29 | 2023-06-30 |  |  |  |  | SI Design |  | 5.0 | Paul Pettitt | Design, Build & Test (PIT) | Complete | COMPLETE |  |  |  |  |  |
| 152 | 1.3.5.2.5 | Sign off |  | 1d | 2023-07-03 A | 2023-07-03 A | 151 | 100% |  | 2023-07-03 | 2023-07-03 | 1d | 2023-07-03 | 2023-07-03 |  |  |  |  | SI Design |  | 5.0 | Paul Pettitt | Design, Build & Test (PIT) | Complete | COMPLETE |  |  |  |  |  |

Notes:
- 134: 4/8 - Added in as per PPs advice
- 135: 27/11- Red because forecast date has changed to align with Testing Release Management. Discussed with no objections at FTIG on 23/11. To be taken to Dec DAG for noting
- 138: 4/8 - Added in as per PPs advice
- 139: 27/11- Amber because forecast date has changed to align with Testing Release Management. Discussed with no objections at FTIG on 23/11. To be taken to Dec DAG for noting

| ID | WBS | Task | Type | Duration | Start | Finish | Predecessors | Complete | Remaining | Baseline start | Baseline finish | Baseline duration | Baseline 1 start | Baseline 1 finish | Total slack | Baseline cost | Responsible | Involved | Update Version | MHHS Resource Name | MHHS Programme Phase | Sched Status | RAG | Task Status | Milestone ID | Text29 | Tier |
| --- | --- | --- | --- | --- | --- | --- | --- | --- | --- | --- | --- | --- | --- | --- | --- | --- | --- | --- | --- | --- | --- | --- | --- | --- | --- | --- | --- |
| 153 | 1.3.5.3 | **KnowledgeBase Development** |  | 72d | 2023-06-01 A | 2023-09-08 A |  | 100% |  | 2023-06-01 | 2023-09-08 | 72d | 2023-06-01 | 2023-09-08 |  |  | N/A | N/A | 5.0 | N/A | Design, Build & Test (PIT) |  |  |  |  |  |  |
| 154 | 1.3.5.3.1 | Define Scope of KB |  | 1d | 2023-06-01 A | 2023-06-01 A | 148SS | 100% |  | 2023-06-01 | 2023-06-01 | 1d | 2023-06-01 | 2023-06-01 |  |  | SI Design |  | 5.0 | Paul Pettitt | Design, Build & Test (PIT) | Complete | COMPLETE |  |  |  |  |
| 155 | 1.3.5.3.2 | Capture Existing KB artefacts |  | 20d | 2023-06-02 A | 2023-06-29 A | 154 | 100% |  | 2023-06-02 | 2023-06-29 | 20d | 2023-06-02 | 2023-06-29 |  |  | SI Design |  | 5.0 | Paul Pettitt | Design, Build & Test (PIT) | Complete | COMPLETE |  |  |  |  |
| 156 | 1.3.5.3.3 | Tag artefacts |  | 5d | 2023-06-30 A | 2023-07-06 A | 155 | 100% |  | 2023-06-30 | 2023-07-06 | 5d | 2023-06-30 | 2023-07-06 |  |  | SI Design |  | 5.0 | Paul Pettitt | Design, Build & Test (PIT) | Complete | COMPLETE |  |  |  |  |
| 157 | 1.3.5.3.4 | Develop Participant Interfaces |  | 20d | 2023-07-07 A | 2023-08-03 A | 156 | 100% |  | 2023-07-07 | 2023-08-03 | 20d | 2023-07-07 | 2023-08-03 |  |  | SI Design |  | 5.0 | Paul Pettitt | Design, Build & Test (PIT) | Complete | COMPLETE |  |  |  |  |
| 158 | 1.3.5.3.5 | Promote to Collaboration Portal |  | 21d | 2023-08-04 A | 2023-09-01 A | 157 | 100% |  | 2023-08-04 | 2023-09-01 | 21d | 2023-08-04 | 2023-09-01 |  |  | SI Design |  | 5.0 | Paul Pettitt | Design, Build & Test (PIT) | Complete | COMPLETE |  |  |  |  |
| 159 | 1.3.5.3.6 | Link into FreshDesk |  | 5d | 2023-09-04 A | 2023-09-08 A | 158 | 100% |  | 2023-09-04 | 2023-09-08 | 5d | 2023-09-04 | 2023-09-08 |  |  | SI Design |  | 5.0 | Paul Pettitt | Design, Build & Test (PIT) | Complete | COMPLETE |  |  |  |  |
| 160 | 1.3.6 | **PP Design, Build & Test (DBT)** |  | 560d | 2022-10-31 A | 2024-12-20 |  | 96% | 21.45d | 2022-10-31 | 2024-09-20 | 495d | 2022-10-31 | 2026-02-16 | 31868d | -0 | N/A | N/A | 5.0 | N/A | Design, Build & Test (PIT) |  |  |  |  |  |  |
| 161 | 1.3.6.1 | **PP Impact Assessment, Planning & Procurement** |  | 110d | 2022-10-31 A | 2023-03-31 A |  | 100% |  | 2022-10-31 | 2023-03-31 | 110d | 2022-10-31 | 2023-03-31 |  |  | N/A | N/A | 5.0 | N/A | Design, Build & Test (PIT) |  |  |  |  |  |  |
| 162 | 1.3.6.1.1 | **PP Impact Assessment** |  | 67d | 2022-10-31 A | 2023-01-31 A |  | 100% |  | 2022-10-31 | 2023-01-31 | 67d | 2022-10-31 | 2023-01-31 |  |  | N/A | N/A | 5.0 | N/A | Design, Build & Test (PIT) |  |  |  |  |  |  |
| 163 | 1.3.6.1.1.1 | Develop heatmap for impact of MHHS |  | 67d | 2022-10-31 A | 2023-01-31 A | 48 | 100% |  | 2022-10-31 | 2023-01-31 | 67d | 2022-10-31 | 2023-01-31 |  |  | PP |  | 5.0 | PP | Design, Build & Test (PIT) | Complete | COMPLETE |  |  |  |  |
| 164 | 1.3.6.1.1.2 | Develop detailed impact assessment |  | 67d | 2022-10-31 A | 2023-01-31 A | 48 | 100% |  | 2022-10-31 | 2023-01-31 | 67d | 2022-10-31 | 2023-01-31 |  |  | PP |  | 5.0 | PP | Design, Build & Test (PIT) | Complete | COMPLETE |  |  |  |  |
| 165 | 1.3.6.1.2 | **PP Planning** |  | 67d | 2022-10-31 A | 2023-01-31 A |  | 100% |  | 2022-10-31 | 2023-01-31 | 67d | 2022-10-31 | 2023-01-31 |  |  | N/A | N/A | 5.0 | N/A | Design, Build & Test (PIT) |  |  |  |  |  |  |
| 166 | 1.3.6.1.2.1 | Develop detailed short-term plan |  | 23d | 2022-10-31 A | 2022-11-30 A | 48 | 100% |  | 2022-10-31 | 2022-11-30 | 23d | 2022-10-31 | 2022-11-30 |  |  | PP |  | 5.0 | PP | Design, Build & Test (PIT) | Complete | COMPLETE |  |  |  |  |
| 167 | 1.3.6.1.2.2 | Develop overall project plan for implementation |  | 67d | 2022-10-31 A | 2023-01-31 A | 48 | 100% |  | 2022-10-31 | 2023-01-31 | 67d | 2022-10-31 | 2023-01-31 |  |  | PP |  | 5.0 | PP | Design, Build & Test (PIT) | Complete | COMPLETE |  |  |  |  |
| 168 | 1.3.6.1.2.3 | Develop procurement plan |  | 67d | 2022-10-31 A | 2023-01-31 A | 48 | 100% |  | 2022-10-31 | 2023-01-31 | 67d | 2022-10-31 | 2023-01-31 |  |  | PP |  | 5.0 | PP | Design, Build & Test (PIT) | Complete | COMPLETE |  |  |  |  |
| 169 | 1.3.6.1.3 | **PP Software/Service Procurement** |  | 110d | 2022-10-31 A | 2023-03-31 A |  | 100% |  | 2022-10-31 | 2023-03-31 | 110d | 2022-10-31 | 2023-03-31 |  |  | N/A | N/A | 5.0 | N/A | Design, Build & Test (PIT) |  |  |  |  |  |  |
| 170 | 1.3.6.1.3.1 | Run tender process |  | 67d | 2022-10-31 A | 2023-01-31 A | 48 | 100% |  | 2022-10-31 | 2023-01-31 | 67d | 2022-10-31 | 2023-01-31 |  |  | PP |  | 5.0 | PP | Design, Build & Test (PIT) | Complete | COMPLETE |  |  |  |  |
| 171 | 1.3.6.1.3.2 | Select provider & sign commercials |  | 43d | 2023-02-01 A | 2023-03-31 A | 170 | 100% |  | 2023-02-01 | 2023-03-31 | 43d | 2023-02-01 | 2023-03-31 |  |  | PP |  | 5.0 | PP | Design, Build & Test (PIT) | Complete | COMPLETE |  |  |  |  |
| 172 | 1.3.6.2 | **Central Systems DBT** |  | 325d | 2022-10-31 A | 2024-01-26 A |  | 100% |  | 2022-10-31 | 2024-02-23 | 345d | 2022-10-31 | 2024-05-13 |  | -0 | N/A | N/A | 5.0 | N/A | Design, Build & Test (PIT) |  |  | -316.67 |  |  |  |
| 173 | 1.3.6.2.1 | **Elexon Central Systems DBT CIT (Entering at Interval 1)** |  | 248d | 2022-10-31 A | 2023-10-11 A |  | 100% |  | 2022-10-31 | 2023-10-12 | 249d | 2022-10-31 | 2023-09-29 |  | -0 | N/A | N/A | 5.0 | N/A | Design, Build & Test (PIT) |  |  |  |  |  |  |
| 174 | 1.3.6.2.1.1 | **Design and Build** |  | 235d | 2022-10-31 A | 2023-09-22 A |  | 100% |  | 2022-10-31 | 2023-09-29 | 240d | 2022-10-31 | 2023-09-29 |  |  | N/A | N/A | 5.0 | N/A | Design, Build & Test (PIT) |  |  | -259.67 |  |  |  |
| 175 | 1.3.6.2.1.1.1 | Helix Design and Build |  | 235d | 2022-10-31 A | 2023-09-22 A | 2 | 100% |  | 2022-10-31 | 2023-09-29 | 240d | 2022-10-31 | 2023-09-29 |  |  | PP | SI Test | 5.0 |  | Design, Build & Test (PIT) | Complete | COMPLETE |  |  |  |  |
| 176 | 1.3.6.2.1.2 | **Test Approach & Plan** |  | 235d | 2022-10-31 A | 2023-09-22 A |  | 100% |  | 2022-10-31 | 2023-09-22 | 235d | 2022-10-31 | 2023-07-21 |  | -0 | N/A | N/A | 5.0 | N/A | Design, Build & Test (PIT) |  |  |  |  |  |  |
| 177 | 1.3.6.2.1.2.1 | Develop Test Approach & Plan |  | 180d | 2022-10-31 A | 2023-07-07 A |  | 100% |  | 2022-10-31 | 2023-07-07 | 180d | 2022-10-31 | 2023-07-07 |  |  | PP | SI Test | 5.0 |  | Design, Build & Test (PIT) | Complete | COMPLETE |  |  |  |  |
| 178 | 1.3.6.2.1.2.2 | Elexon Central Systems Test Approach & Plan (PIT) submitted to Programme for assurance | milestone | 0d | 2023-07-13 A | 2023-07-13 A | 177FF+4d | 100% |  | 2023-07-13 | 2023-07-13 | 0d | 2023-07-07 | 2023-07-07 |  |  | PP | SI Test | 5.0 |  | Design, Build & Test (PIT) | Complete | COMPLETE |  | T3-DB-0029 | SITAG | T3 |
| 179 | 1.3.6.2.1.2.3 | Elexon Central Systems Test Approach & Plan (PIT) V2 resubmitted to Programme for assurance | milestone, manual | 0d | 2023-07-27 A | 2023-07-27 A | 178FS+9d | 100% |  | 2023-07-27 | 2023-07-27 | 0d |  |  |  |  | PP | SI Test | 5.4 |  | Design, Build & Test (PIT) | Complete | COMPLETE |  |  |  |  |
| 180 | 1.3.6.2.1.2.4 | Elexon Central Systems Test Approach & Plan (PIT) V3 resubmitted to Programme for assurance | milestone | 0d | 2023-08-18 A | 2023-08-18 A | 179FS+17d | 100% |  | 2023-08-18 | 2023-08-18 | 0d |  |  |  |  | PP | SI Test | 5.4 |  | Design, Build & Test (PIT) | Complete | COMPLETE |  |  |  |  |
| 181 | 1.3.6.2.1.2.5 | Elexon Central Systems Test approach and plan MHHS Review Completed | milestone | 0d | 2023-09-22 A | 2023-09-22 A | 180FS+25d | 100% |  | 2023-09-22 | 2023-09-22 | 0d | 2023-07-10 | 2023-07-21 |  |  | SI Test | PP | 5.8 |  | Design, Build & Test (PIT) | Complete | COMPLETE |  | T3-DB-0106 | SITAG | T3 |

Notes:
- 181: 1/9 - to be raised as new T3 at TMAG. Approved at TMAG on 20/9

| ID | WBS | Task | Type | Duration | Start | Finish | Predecessors | Complete | Baseline start | Baseline finish | Baseline duration | Baseline 1 start | Baseline 1 finish | Constraint | Baseline cost | Responsible | Involved | Update Version | MHHS Resource Name | MHHS Programme Phase | Sched Status | RAG | Artefact ID | Milestone ID | Text29 | Tier |
| --- | --- | --- | --- | --- | --- | --- | --- | --- | --- | --- | --- | --- | --- | --- | --- | --- | --- | --- | --- | --- | --- | --- | --- | --- | --- | --- |
| 182 | 1.3.6.2.1.3 | **Test Readiness Report** |  | 16d | 2023-07-28 A | 2023-08-18 A |  | 100% | 2023-08-03 | 2023-10-12 | 51d | 2023-07-21 | 2023-09-29 |  |  | N/A | N/A | 5.0 | N/A | Design, Build & Test (PIT) |  |  |  |  |  |  |
| 183 | 1.3.6.2.1.3.1 | Test readiness reporting |  | 16d | 2023-07-28 A | 2023-08-18 A | 178FS+10d | 100% | 2023-08-03 | 2023-10-12 | 51d | 2023-07-21 | 2023-09-29 |  |  | PP | 109 | 5.0 |  | Design, Build & Test (PIT) | Complete | COMPLETE |  |  |  |  |
| 184 | 1.3.6.2.1.4 | **Requirements to test Traceability Matrix (RTTM)** |  | 35d | 2023-08-04 A | 2023-09-22 A |  | 100% | 2023-08-04 | 2023-09-22 | 35d | 2022-10-31 | 2023-08-18 |  | -0 | N/A | N/A | 5.0 | N/A | Design, Build & Test (PIT) |  |  |  |  |  |  |
| 185 | 1.3.6.2.1.4.1 | Elexon Central Systems RTTM submitted to Programme for assurance | milestone | 0d | 2023-08-04 A | 2023-08-04 A | 178 | 100% | 2023-08-04 | 2023-08-04 | 0d | 2023-08-04 | 2023-08-04 | start no earlier than 2023-04-28 |  | PP | SI Test | 5.0 |  | Design, Build & Test (PIT) | Complete | COMPLETE | MHHS-ART009 | T3-DB-0030 | SITAG | T3 |
| 186 | 1.3.6.2.1.4.2 | Elexon Central Systems RTTM MHHS Review Completed | milestone | 0d | 2023-09-22 A | 2023-09-22 A | 185FS+35d | 100% | 2023-09-22 | 2023-09-22 | 0d | 2023-08-07 | 2023-08-18 |  |  | SI Test | PP | 5.8 |  | Design, Build & Test (PIT) | Complete | COMPLETE |  | T3-DB-0107 | SITAG | T3 |
| 187 | 1.3.6.2.1.5 | **Test Scenarios** |  | 35d | 2023-08-04 A | 2023-09-22 A |  | 100% | 2023-08-04 | 2023-09-22 | 35d | 2022-10-31 | 2023-08-18 |  | -0 | N/A | N/A | 5.0 | N/A | Design, Build & Test (PIT) |  |  |  |  |  |  |
| 188 | 1.3.6.2.1.5.1 | Elexon Central Systems test scenarios submitted to Programme for assurance | milestone | 0d | 2023-08-04 A | 2023-08-04 A | 178 | 100% | 2023-08-04 | 2023-08-04 | 0d | 2023-08-04 | 2023-08-04 |  |  | PP | SI Test | 5.0 |  | Design, Build & Test (PIT) | Complete | COMPLETE |  | T3-DB-0032 | SITAG | T3 |
| 189 | 1.3.6.2.1.5.2 | Elexon Central Systems Test scenarios MHHS Review Completed | milestone | 0d | 2023-09-22 A | 2023-09-22 A | 188FS+35d | 100% | 2023-09-22 | 2023-09-22 | 0d | 2023-08-07 | 2023-08-18 |  |  | SI Test | PP | 5.8 |  | Design, Build & Test (PIT) | Complete | COMPLETE |  | T3-DB-0108 | SITAG | T3 |
| 190 | 1.3.6.2.1.6 | **PIT Execution** |  | 38d | 2023-08-21 A | 2023-10-11 A |  | 100% | 2022-10-31 | 2023-10-11 | 248d | 2022-10-31 | 2023-09-29 |  | -0 | N/A | N/A | 5.0 | N/A | Design, Build & Test (PIT) |  |  |  |  |  |  |
| 191 | 1.3.6.2.1.6.1 | PIT Test Execution Progress Report |  | 18d | 2023-09-04 A | 2023-09-27 A | 183FS+10d | 100% | 2022-10-31 | 2023-09-22 | 235d | 2022-10-31 | 2023-09-22 |  |  | PP | SI Test | 5.1 |  | Design, Build & Test (PIT) | Complete | COMPLETE |  |  |  |  |
| 192 | 1.3.6.2.1.6.2 | Elexon Central Systems PIT Execution |  | 28d | 2023-08-21 A | 2023-09-27 A | 183 | 100% | 2022-11-08 | 2023-10-09 | 240d | 2022-10-31 | 2023-09-29 |  |  | PP | SI Test | 5.1 |  | Design, Build & Test (PIT) | Complete | COMPLETE |  |  |  |  |
| 193 | 1.3.6.2.1.6.3 | Elexon Central Systems PIT Completion Report submitted to Programme for assurance | milestone | 0d | 2023-09-27 A | 2023-09-27 A | 192 | 100% | 2023-09-27 | 2023-09-27 | 0d | 2024-01-05 | 2024-01-05 |  |  | PP | SI Test | 5.8 |  | Design, Build & Test (PIT) | Complete | COMPLETE |  | T3-DB-0109 | SITAG | T3 |
| 194 | 1.3.6.2.1.6.4 | Elexon Central Systems PIT Completion Report MHHS Review Completed | milestone | 0d | 2023-10-11 A | 2023-10-11 A | 186, 189, 191, 193FS+10d, 181 | 100% | 2023-10-11 | 2023-10-11 | 0d |  |  |  |  | SI Test | PP | 5.8 |  | Design, Build & Test (PIT) | Complete | COMPLETE |  | T3-DB-0110 | SITAG | T3 |
| 195 | 1.3.6.2.2 | **DIP DBT CIT (Entering at Interval 1)** |  | 221d | 2023-01-02 A | 2023-11-06 A |  | 100% | 2022-10-31 | 2023-11-06 | 266d | 2022-10-31 | 2023-09-29 |  | -0 | N/A | N/A | 5.0 | N/A | Design, Build & Test (PIT) |  |  |  |  |  |  |
| 196 | 1.3.6.2.2.1 | Design |  | 80d | 2023-01-02 A | 2023-04-21 A |  | 100% | 2023-01-02 | 2023-04-21 | 80d | 2023-01-02 | 2023-04-21 | must start on 2023-01-02 |  | PP | SI Design | 5.0 |  | Design, Build & Test (PIT) | Complete | COMPLETE |  |  |  |  |
| 197 | 1.3.6.2.2.2 | Build |  | 155d | 2023-01-09 A | 2023-08-11 A | 196SS+5d | 100% | 2023-01-09 | 2023-08-11 | 155d | 2023-01-09 | 2023-08-11 |  |  | PP |  | 5.5 |  | Design, Build & Test (PIT) | Complete | COMPLETE |  |  |  |  |
| 198 | 1.3.6.2.2.3 | **Test Approach & Plan** |  | 9d | 2023-07-07 A | 2023-07-20 A |  | 100% | 2022-10-31 | 2023-07-21 | 190d | 2022-10-31 | 2023-07-21 |  |  | N/A | N/A | 5.0 | N/A | Design, Build & Test (PIT) |  |  |  |  |  |  |
| 199 | 1.3.6.2.2.3.1 | DIP Test Approach & Plan (PIT) submitted to Programme for assurance | milestone | 0d | 2023-07-07 A | 2023-07-07 A |  | 100% | 2023-07-07 | 2023-07-07 | 0d | 2023-07-07 | 2023-07-07 |  |  | PP | SI Test | 5.0 |  | Design, Build & Test (PIT) | Complete | COMPLETE | MHHS-ART073 | T3-DB-0026 | SITAG | T3 |
| 200 | 1.3.6.2.2.3.2 | DIP Test Approach & Plan (PIT) MHHS Review Completed | milestone | 0d | 2023-07-20 A | 2023-07-20 A | 199FS+9d | 100% | 2023-07-10 | 2023-07-21 | 10d | 2023-07-10 | 2023-07-21 |  |  | SI Test | PP | 5.0 |  | Design, Build & Test (PIT) | Complete | COMPLETE |  |  |  |  |
| 201 | 1.3.6.2.2.4 | **PIT Test Readiness Report** |  | 31d | 2023-07-21 A | 2023-09-01 A |  | 100% | 2023-07-21 | 2023-09-29 | 51d | 2023-07-21 | 2023-09-29 |  |  | N/A | N/A | 5.0 | N/A | Design, Build & Test (PIT) |  |  |  |  |  |  |
| 202 | 1.3.6.2.2.4.1 | Test readiness reporting |  | 31d | 2023-07-21 A | 2023-09-01 A | 199FS+9d | 100% | 2023-07-21 | 2023-09-29 | 51d | 2023-07-21 | 2023-09-29 |  |  | SI Test | 109 | 5.0 |  | Design, Build & Test (PIT) | Complete | COMPLETE |  |  |  |  |
| 203 | 1.3.6.2.2.5 | **Requirements to test Traceability Matrix (RTTM)** |  | 18d | 2023-08-04 A | 2023-08-30 A |  | 100% | 2022-10-31 | 2023-08-18 | 210d | 2022-10-31 | 2023-08-18 |  |  | N/A | N/A | 5.0 | N/A | Design, Build & Test (PIT) |  |  |  |  |  |  |
| 204 | 1.3.6.2.2.5.1 | DIP RTTM submitted to Programme for assurance | milestone | 0d | 2023-08-04 A | 2023-08-04 A | 199FS+15d | 100% | 2023-08-04 | 2023-08-04 | 0d | 2023-08-04 | 2023-08-04 |  |  | PP | SI Test | 5.6 |  | Design, Build & Test (PIT) | Complete | COMPLETE | MHHS-ART009 | T3-DB-0034 | SITAG | T3 |
| 205 | 1.3.6.2.2.5.2 | DIP RTTM MHHS Review Completed | milestone | 0d | 2023-08-30 A | 2023-08-30 A | 204FS+18d | 100% | 2023-08-07 | 2023-08-18 | 10d | 2023-08-07 | 2023-08-18 |  |  | SI Test | PP | 5.0 |  | Design, Build & Test (PIT) | Complete | COMPLETE |  |  |  |  |

Notes:
- 186: 1/9 - to be raised as new T3 at TMAG. Approved at TMAG on 20/9
- 189: 1/9 - to be raised as new T3 at TMAG. Approved at TMAG on 20/9
- 193: 1/9 - to be raised as new T3 at TMAG. Approved at TMAG on 20/9
- 194: 1/9 - to be raised as new T3 at TMAG. Approved at TMAG on 20/9
- 202: Action: 14/8 - Query from RG - IS this an SI Test deliverable or expected to be a DIP deliverable if so be more specific
- 204: RG confirmed Submitted on 10/8/23

| ID | WBS | Task | Type | Duration | Start | Finish | Predecessors | Complete | Baseline start | Baseline finish | Baseline duration | Baseline 1 start | Baseline 1 finish | Constraint | Baseline cost | Responsible | Involved | Update Version | MHHS Resource Name | MHHS Programme Phase | Sched Status | RAG | Milestone ID | Text29 | Tier |
| --- | --- | --- | --- | --- | --- | --- | --- | --- | --- | --- | --- | --- | --- | --- | --- | --- | --- | --- | --- | --- | --- | --- | --- | --- | --- |
| 206 | 1.3.6.2.2.6 | **Test Scenarios** |  | 22d | 2023-07-31 A | 2023-08-30 A |  | 100% | 2022-10-31 | 2023-08-14 | 206d | 2022-10-31 | 2023-08-18 |  |  | N/A | N/A | 5.0 | N/A | Design, Build & Test (PIT) |  |  |  |  |  |
| 207 | 1.3.6.2.2.6.1 | DIP PIT test scenarios submitted to Programme for assurance | milestone | 0d | 2023-07-31 A | 2023-07-31 A | 199FS+15d | 100% | 2023-07-31 | 2023-07-31 | 0d | 2023-08-04 | 2023-08-04 |  |  | PP | SI Test | 5.0 |  | Design, Build & Test (PIT) | Complete | COMPLETE | T3-DB-0036 | SITAG | T3 |
| 208 | 1.3.6.2.2.6.2 | DIP Test scenarios MHHS Review Completed | milestone | 0d | 2023-08-30 A | 2023-08-30 A | 207FS+22d | 100% | 2023-08-01 | 2023-08-14 | 10d | 2023-08-07 | 2023-08-18 |  |  | SI Test | PP | 5.0 |  | Design, Build & Test (PIT) | Complete | COMPLETE |  |  |  |
| 209 | 1.3.6.2.2.7 | **PIT execution** |  | 50d | 2023-08-29 A | 2023-11-06 A |  | 100% | 2023-09-01 | 2023-11-06 | 47d | 2022-10-31 | 2023-09-29 |  | -0 | N/A | N/A | 5.0 | N/A | Design, Build & Test (PIT) |  |  |  |  |  |
| 210 | 1.3.6.2.2.7.1 | PIT Test Execution Progress Report |  | 37d | 2023-09-01 A | 2023-10-23 A | 211FF, 202 | 100% | 2023-09-01 | 2023-10-23 | 37d | 2022-10-31 | 2023-09-22 | start no earlier than 2023-08-29 |  | PP | SI Test | 5.6 |  | Design, Build & Test (PIT) | Complete | COMPLETE |  |  |  |
| 211 | 1.3.6.2.2.7.2 | PIT Execution (Interim Release 1) |  | 30d | 2023-08-29 A | 2023-10-09 A |  | 100% | 2023-09-06 | 2023-10-09 | 24d | 2022-10-31 | 2023-09-29 | start no earlier than 2023-08-29 |  | PP | SI Test | 5.6 |  | Design, Build & Test (PIT) | Complete | COMPLETE |  |  |  |
| 212 | 1.3.6.2.2.7.3 | PIT Execution (Interim Release 2) |  | 10d | 2023-10-10 A | 2023-10-23 A | 211 | 100% | 2023-10-10 | 2023-10-23 | 10d |  |  |  |  | PP | SI Test | 5.6 |  | Design, Build & Test (PIT) | Complete | COMPLETE |  |  |  |
| 213 | 1.3.6.2.2.7.4 | DIP PIT Completion Report (Interim Release 1) submitted to Programme for assurance | milestone | 0d | 2023-10-09 A | 2023-10-09 A | 211 | 100% | 2023-10-09 | 2023-10-09 | 0d | 2024-01-05 | 2024-01-05 |  |  | PP | SI Test | 5.8 |  | Design, Build & Test (PIT) | Complete | COMPLETE | T3-DB-0111 | SITAG | T3 |
| 214 | 1.3.6.2.2.7.5 | DIP PIT Completion Report (Interim Release 1) MHHS Review Completed | milestone | 0d | 2023-10-23 A | 2023-10-23 A | 213FS+10d | 100% | 2023-10-23 | 2023-10-23 | 0d |  |  |  |  | SI Test | SI Test | 5.10 |  | Design, Build & Test (PIT) | Complete | COMPLETE | T3-DB-0112 | SITAG | T3 |
| 215 | 1.3.6.2.2.7.6 | DIP PIT Completion Report (Interim Release 2) submitted to Programme for assurance | milestone | 0d | 2023-10-23 A | 2023-10-23 A | 212, 210 | 100% | 2023-10-23 | 2023-10-23 | 0d | 2024-01-05 | 2024-01-05 |  |  | PP | SI Test | 5.10 |  | Design, Build & Test (PIT) | Complete | COMPLETE | T3-DB-0113 | SITAG | T3 |
| 216 | 1.3.6.2.2.7.7 | DIP PIT Completion Report (Interim Release 2) MHHS Review Completed | milestone | 0d | 2023-11-06 A | 2023-11-06 A | 215FS+10d | 100% | 2023-11-06 | 2023-11-06 | 0d |  |  |  |  | SI Test | SI Test | 5.14 |  | Design, Build & Test (PIT) | Complete | COMPLETE | T3-DB-0114 | SITAG | T3 |
| 217 | 1.3.6.2.3 | **DCC (DSP) DBT SIT Functional (Entering at SIT Functional)** |  | 325d | 2022-10-31 A | 2024-01-26 A |  | 100% | 2022-10-31 | 2024-02-23 | 345d | 2022-10-31 | 2024-01-05 |  | -0 | N/A | N/A | 5.18 | N/A | Design, Build & Test (PIT) |  |  |  |  |  |
| 218 | 1.3.6.2.3.1 | Design |  | 67d | 2022-10-31 A | 2023-01-31 A |  | 100% | 2022-10-31 | 2023-01-31 | 67d | 2022-10-31 | 2023-01-31 |  |  | PP | SI Design | 5.18 |  | Design, Build & Test (PIT) | Complete | COMPLETE |  |  |  |
| 219 | 1.3.6.2.3.2 | **Test Approach & Plan** |  | 20d | 2023-11-17 A | 2023-12-15 A |  | 100% | 2023-11-17 | 2023-12-15 | 20d | 2022-10-31 | 2023-10-27 |  | -0 | N/A | N/A | 5.18 | N/A | Design, Build & Test (PIT) |  |  |  |  |  |
| 220 | 1.3.6.2.3.2.1 | DCC Test Approach & Plan (PIT) submitted to Programme for assurance | milestone | 0d | 2023-11-17 A | 2023-11-17 A | 218FS+208d | 100% | 2023-11-17 | 2023-11-17 | 0d | 2023-10-13 | 2023-10-13 |  |  | PP | SI Test | 5.18 |  | Design, Build & Test (PIT) | Complete | COMPLETE | T3-DB-0068 | SITAG | T3 |
| 221 | 1.3.6.2.3.2.2 | DCC Test Approach & Plan (PIT) MHHS Review Completed | milestone | 0d | 2023-12-15 A | 2023-12-15 A | 220FS+20d | 100% | 2023-12-15 | 2023-12-15 | 0d | 2023-10-16 | 2023-10-27 |  |  | SI Test | PP | 5.18 |  | Design, Build & Test (PIT) | Complete | COMPLETE | T3-DB-0115 | SITAG | T3 |
| 222 | 1.3.6.2.3.3 | **Test Readiness Report** |  | 22d | 2023-12-04 A | 2024-01-02 A |  | 100% | 2023-10-27 | 2024-01-05 | 51d | 2023-10-27 | 2024-01-05 |  |  | N/A | N/A | 5.18 | N/A | Design, Build & Test (PIT) |  |  |  |  |  |
| 223 | 1.3.6.2.3.3.1 | Test readiness reporting |  | 22d | 2023-12-04 A | 2024-01-02 A | 220FS+10d | 100% | 2023-10-27 | 2024-01-05 | 51d | 2023-10-27 | 2024-01-05 |  |  | PP | 109 | 5.18 |  | Design, Build & Test (PIT) | Complete | COMPLETE |  |  |  |
| 224 | 1.3.6.2.3.4 | **Requirements to test Traceability Matrix (RTTM)** |  | 30d | 2023-12-15 A | 2024-01-26 A |  | 100% | 2023-12-15 | 2024-01-26 | 30d | 2022-10-31 | 2023-11-24 |  | -0 | N/A | N/A | 5.18 | N/A | Design, Build & Test (PIT) |  |  |  |  |  |
| 225 | 1.3.6.2.3.4.1 | DCC RTTM submitted to Programme for assurance | milestone | 0d | 2023-12-15 A | 2023-12-15 A | 220FS+20d | 100% | 2023-12-15 | 2023-12-15 | 0d | 2023-11-10 | 2023-11-10 | start no earlier than 2023-04-28 |  | PP | SI Test | 5.18 |  | Design, Build & Test (PIT) | Complete | COMPLETE | T3-DB-0074 | SITAG | T3 |
| 226 | 1.3.6.2.3.4.2 | DCC RTTM MHHS Review Completed | milestone | 0d | 2024-01-26 A | 2024-01-26 A | 225FS+30d | 100% | 2024-01-26 | 2024-01-26 | 0d | 2023-11-13 | 2023-11-24 |  |  | SI Test | PP | 5.18 |  | Design, Build & Test (PIT) | Complete | COMPLETE | T3-DB-0116 | SITAG | T3 |
| 227 | 1.3.6.2.3.5 | **Test Scenarios** |  | 30d | 2023-12-15 A | 2024-01-26 A |  | 100% | 2023-12-15 | 2024-01-26 | 30d | 2022-10-31 | 2023-11-24 |  | -0 | N/A | N/A | 5.18 | N/A | Design, Build & Test (PIT) |  |  |  |  |  |
| 228 | 1.3.6.2.3.5.1 | DCC test scenarios submitted to Programme for assurance | milestone | 0d | 2023-12-15 A | 2023-12-15 A | 220FS+20d | 100% | 2023-12-15 | 2023-12-15 | 0d | 2023-11-10 | 2023-11-10 |  |  | PP | SI Test | 5.18 |  | Design, Build & Test (PIT) | Complete | COMPLETE | T3-DB-0078 | SITAG | T3 |
| 229 | 1.3.6.2.3.5.2 | DCC Test Scenarios MHHS Review Completed | milestone | 0d | 2024-01-26 A | 2024-01-26 A | 228FS+30d | 100% | 2024-01-26 | 2024-01-26 | 0d | 2023-11-13 | 2023-11-24 |  |  | SI Test | PP | 5.18 |  | Design, Build & Test (PIT) | Complete | COMPLETE | T3-DB-0117 | SITAG | T3 |

Notes:
- 210: 21/8 - due to complete 9/10 - advised by RG
- 211: 21/8 - due to complete 9/10 - advised by RG
- 212: 21/8 - new line added date are 9/10 - 23/10 - advised by RG.
- 213: 1/9 - to be raised as new T3 at TMAG. Approved at TMAG on 20/9. 9/10 - RG - After discussions with DM it was decided a completion report for IR1 wasn't required as we are entering IR2 ahead of schedule & draft completion report already submitted & assured
- 214: 1/9 - to be raised as new T3 at TMAG. Approved at TMAG on 20/9
- 215: 1/9 - to be raised as new T3 at TMAG. Approved at TMAG on 20/9
- 216: 7/11- Red because further clarity around remaining open low severity defect work off plan requested. No impact. Completed on 8/12 / Guidance: 6/10 - LC - Successor should be SIT Component Integration Testing 1 Preparation Complete but not linked as DIP test completion plus 10 day review breaks logic. Decision will be made to proceed without a conclusion of the report review
- 220: 21/11- Red because not received. Currently no impact. 30/1 - Completed on 26/1
- 221: 1/9 - to be raised as new T3 at TMAG DCC no longer in CIT, new dates relate to SIT Functional. Approved at TMAG on 20/9. 19/12 - Red because not received
- 225: 19/12- Red because not received. 30/1 - Completed on 26/1
- 226: 23/1- Amber because of potential late delivery of RTTM. No impact. No action. 30/1 - Completed on 26/1
- 228: 5/12- Red because of late delivery of PIT approach and plan. No impact. No action. 30/1 - Completed on 26/1
- 229: 23/1- Amber because of potential late delivery of test scenarios. No impact. No action. 30/1 - Completed on 26/1

| ID | WBS | Task | Type | Duration | Start | Finish | Predecessors | Complete | Baseline start | Baseline finish | Baseline duration | Baseline 1 start | Baseline 1 finish | Constraint | Baseline cost | Responsible | Involved | Update Version | MHHS Resource Name | MHHS Programme Phase | Sched Status | RAG | Milestone ID | Text29 | Tier | Artefact ID |
| --- | --- | --- | --- | --- | --- | --- | --- | --- | --- | --- | --- | --- | --- | --- | --- | --- | --- | --- | --- | --- | --- | --- | --- | --- | --- | --- |
| 230 | 1.3.6.2.4 | **RECCo (EES) DBT CIT (Entering at Interval 6)** |  | 71d | 2023-10-13 A | 2024-01-19 A |  | 100% | 2022-10-31 | 2024-01-19 | 320d | 2022-10-31 | 2024-01-05 |  | -0 | N/A | N/A | 5.0 | N/A | Design, Build & Test (PIT) |  |  |  |  |  |  |
| 231 | 1.3.6.2.4.1 | **Test Approach & Plan** |  | 20d | 2023-10-13 A | 2023-11-09 A |  | 100% | 2023-10-13 | 2023-11-09 | 20d | 2022-10-31 | 2023-10-27 |  | -0 | N/A | N/A | 5.0 | N/A | Design, Build & Test (PIT) |  |  |  |  |  |  |
| 232 | 1.3.6.2.4.1.1 | EES Test Approach & Plan (PIT) submitted to Programme for assurance | milestone | 0d | 2023-10-13 A | 2023-10-13 A |  | 100% | 2023-10-13 | 2023-10-13 | 0d | 2023-10-13 | 2023-10-13 | start no earlier than 2023-10-13 |  | PP | SI Test | 5.8 |  | Design, Build & Test (PIT) | Complete | COMPLETE | T3-DB-0066 | SITAG | T3 |  |
| 233 | 1.3.6.2.4.1.2 | EES Test approach and plan (PIT) MHHS Review Completed | milestone | 0d | 2023-11-09 A | 2023-11-09 A | 232FS+20d | 100% | 2023-11-09 | 2023-11-09 | 0d | 2023-10-16 | 2023-10-27 |  |  | SI Test | PP | 5.8 |  | Design, Build & Test (PIT) | Complete | COMPLETE | T3-DB-0119 | SITAG | T3 |  |
| 234 | 1.3.6.2.4.2 | **Test Readiness Report** |  | 10d | 2023-10-27 A | 2023-11-09 A |  | 100% | 2023-10-27 | 2024-01-05 | 51d | 2023-10-27 | 2024-01-05 |  |  | N/A | N/A | 5.0 | N/A | Design, Build & Test (PIT) |  |  |  |  |  |  |
| 235 | 1.3.6.2.4.2.1 | Test readiness reporting |  | 10d | 2023-10-27 A | 2023-11-09 A | 232FS+10d | 100% | 2023-10-27 | 2024-01-05 | 51d | 2023-10-27 | 2024-01-05 |  |  | PP | 109 | 5.0 |  | Design, Build & Test (PIT) | Complete | COMPLETE |  |  |  |  |
| 236 | 1.3.6.2.4.3 | **Requirements to test Traceability Matrix (RTTM)** |  | 20d | 2023-11-02 A | 2023-11-30 A |  | 100% | 2023-11-02 | 2023-11-30 | 20d | 2022-10-31 | 2023-11-24 |  | -0 | N/A | N/A | 5.0 | N/A | Design, Build & Test (PIT) |  |  |  |  |  |  |
| 237 | 1.3.6.2.4.3.1 | EES RTTM submitted to Programme for assurance | milestone | 0d | 2023-11-02 A | 2023-11-02 A | 232FS+15d | 100% | 2023-11-02 | 2023-11-02 | 0d | 2023-11-10 | 2023-11-10 |  |  | PP | SI Test | 5.8 |  | Design, Build & Test (PIT) | Complete | COMPLETE | T3-DB-0072 | SITAG | T3 | MHHS-ART009 |
| 238 | 1.3.6.2.4.3.2 | EES RTTM MHHS Review Completed | milestone | 0d | 2023-11-30 A | 2023-11-30 A | 237FS+20d | 100% | 2023-11-30 | 2023-11-30 | 0d | 2023-11-13 | 2023-11-24 |  |  | SI Test | PP | 5.14 |  | Design, Build & Test (PIT) | Complete | COMPLETE | T3-DB-0120 | SITAG | T3 |  |
| 239 | 1.3.6.2.4.4 | **Test Scenarios** |  | 20d | 2023-11-02 A | 2023-11-30 A |  | 100% | 2023-11-02 | 2023-11-30 | 20d | 2022-10-31 | 2023-11-24 |  | -0 | N/A | N/A | 5.0 | N/A | Design, Build & Test (PIT) |  |  |  |  |  |  |
| 240 | 1.3.6.2.4.4.1 | EES test scenarios submitted to Programme for assurance | milestone | 0d | 2023-11-02 A | 2023-11-02 A | 232FS+15d | 100% | 2023-11-02 | 2023-11-02 | 0d | 2023-11-10 | 2023-11-10 |  |  | PP | SI Test | 5.8 |  | Design, Build & Test (PIT) | Complete | COMPLETE | T3-DB-0031 | SITAG | T3 |  |
| 241 | 1.3.6.2.4.4.2 | EES Test scenarios MHHS Review Completed | milestone | 0d | 2023-11-30 A | 2023-11-30 A | 240FS+20d | 100% | 2023-11-30 | 2023-11-30 | 0d | 2023-11-13 | 2023-11-24 |  |  | SI Test | PP | 5.14 |  | Design, Build & Test (PIT) | Complete | COMPLETE | T3-DB-0121 | SITAG | T3 |  |
| 242 | 1.3.6.2.4.5 | **PIT execution** |  | 51d | 2023-11-10 A | 2024-01-19 A |  | 100% | 2022-10-31 | 2024-01-19 | 320d | 2022-10-31 | 2024-01-05 |  | -0 | N/A | N/A | 5.0 | N/A | Design, Build & Test (PIT) |  |  |  |  |  |  |
| 243 | 1.3.6.2.4.5.1 | PIT Test Execution Progress Report |  | 41d | 2023-11-10 A | 2024-01-05 A | 235 | 100% | 2023-11-10 | 2024-01-05 | 41d | 2022-10-31 | 2023-12-29 |  |  | PP | SI Test | 5.0 |  | Design, Build & Test (PIT) | Complete | COMPLETE |  |  |  |  |
| 244 | 1.3.6.2.4.5.2 | PIT Execution |  | 41d | 2023-11-10 A | 2024-01-05 A | 240FS+5d | 100% | 2022-10-31 | 2024-01-05 | 310d | 2022-10-31 | 2024-01-05 |  |  | PP | SI Test | 5.0 |  | Design, Build & Test (PIT) | Complete | COMPLETE |  |  |  |  |
| 245 | 1.3.6.2.4.5.3 | EES PIT Completion Report submitted to Programme for assurance | milestone | 0d | 2024-01-05 A | 2024-01-05 A | 243, 244 | 100% | 2024-01-05 | 2024-01-05 | 0d | 2024-01-05 | 2024-01-05 |  |  | PP | SI Test | 5.14 |  | Design, Build & Test (PIT) | Complete | COMPLETE | T3-DB-0122 | SITAG | T3 |  |
| 246 | 1.3.6.2.4.5.4 | EES PIT Completion Report MHHS Review Completed | milestone | 0d | 2024-01-19 A | 2024-01-19 A | 233, 238, 241, 245FS+10d | 100% | 2024-01-19 | 2024-01-19 | 0d |  |  |  |  | SI Test | PP | 5.14 |  | Design, Build & Test (PIT) | Complete | COMPLETE | T3-DB-0123 | SITAG | T3 |  |
| 247 | 1.3.6.2.5 | **Registration Services DBT CIT (Entering at Interval 2)** |  | 70d | 2023-07-28 A | 2023-11-03 A |  | 100% | 2023-07-28 | 2023-11-03 | 70d | 2022-10-31 | 2024-02-28 |  | -0 | N/A | N/A | 5.0 | N/A | Design, Build & Test (PIT) |  |  |  |  |  |  |
| 248 | 1.3.6.2.5.1 | **Test Approach & Plan** |  | 40d | 2023-07-28 A | 2023-09-22 A |  | 100% | 2023-07-28 | 2023-09-22 | 40d | 2022-10-31 | 2023-08-11 |  | -0 | N/A | N/A | 5.0 | N/A | Design, Build & Test (PIT) |  |  |  |  |  |  |
| 249 | 1.3.6.2.5.1.1 | Registration Services Test Approach & Plan (PIT) submitted to Programme for assurance | milestone | 0d | 2023-07-28 A | 2023-07-28 A |  | 100% | 2023-07-28 | 2023-07-28 | 0d | 2023-07-28 | 2023-07-28 |  |  | PP | SI Test | 5.0 |  | Design, Build & Test (PIT) | Complete | COMPLETE | T3-DB-0028 | SITAG | T3 | MHHS-ART073 |
| 250 | 1.3.6.2.5.1.2 | Registration Services Test approach and plan MHHS Review Completed | milestone | 0d | 2023-09-22 A | 2023-09-22 A | 249FS+40d | 100% | 2023-09-22 | 2023-09-22 | 0d | 2023-07-31 | 2023-08-11 |  |  | SI Test | PP | 5.8 |  | Design, Build & Test (PIT) | Complete | COMPLETE | T3-DB-0124 | SITAG | T3 |  |
| 251 | 1.3.6.2.5.2 | **Test Readiness Report** |  | 20d | 2023-08-14 A | 2023-09-08 A |  | 100% | 2023-08-11 | 2023-10-20 | 51d | 2023-08-11 | 2023-10-20 |  |  | N/A | N/A | 5.0 | N/A | Design, Build & Test (PIT) |  |  |  |  |  |  |
| 252 | 1.3.6.2.5.2.1 | Test readiness reporting |  | 20d | 2023-08-14 A | 2023-09-08 A | 249FS+10d | 100% | 2023-08-11 | 2023-10-20 | 51d | 2023-08-11 | 2023-10-20 |  |  | PP | 109 | 5.0 |  | Design, Build & Test (PIT) | Complete | COMPLETE |  |  |  |  |
| 253 | 1.3.6.2.5.3 | **Requirements to test Traceability Matrix (RTTM)** |  | 20d | 2023-09-01 A | 2023-09-29 A |  | 100% | 2023-09-01 | 2023-09-29 | 20d | 2022-10-31 | 2023-09-15 |  | -0 | N/A | N/A | 5.0 | N/A | Design, Build & Test (PIT) |  |  |  |  |  |  |
| 254 | 1.3.6.2.5.3.1 | Registration Services RTTM submitted to Programme for assurance | milestone | 0d | 2023-09-01 A | 2023-09-01 A | 249FS+15d | 100% | 2023-09-01 | 2023-09-01 | 0d | 2023-09-01 | 2023-09-01 | start no earlier than 2023-04-28 |  | PP | SI Test | 5.6 |  | Design, Build & Test (PIT) | Complete | COMPLETE | T3-DB-0042 | SITAG | T3 | MHHS-ART009 |
| 255 | 1.3.6.2.5.3.2 | Registration Services RTTM MHHS Review Completed | milestone | 0d | 2023-09-29 A | 2023-09-29 A | 254FS+20d | 100% | 2023-09-29 | 2023-09-29 | 0d | 2023-09-04 | 2023-09-15 |  |  | SI Test | PP | 5.8 |  | Design, Build & Test (PIT) | Complete | COMPLETE | T3-DB-0125 | SITAG | T3 |  |

Notes:
- 230: Assumption that Migration/Reverse Migration DBT is not applicable to RECCo.
- 232: 12/9 - TMAG for name change. Approved at TMAG on 20/9. 17/10 - Red because document not yet received. No impact currently. Issuance from RECCo requested
- 233: 1/9 - to be raised as new T3 at TMAG. Approved at TMAG on 20/9. 17/10 - Amber because Late delivery of document plus earlier intervals backlog. Currently no impact
- 237: 7/11 - Red because not submitted. No impact. No action
- 238: 5/12- Red because Assurance conducted. Comments issued and awaiting response. No impact. No action. Completed on 15/12
- 240: 7/11 - Red because not submitted. No impact. No action
- 241: 5/12- Red because Assurance conducted. Comments issued and awaiting response. No impact. No action. Completed on 15/12
- 245: 1/9 - to be raised as new T3 at TMAG. Approved at TMAG on 20/9. 19/12 - Completed on 15/12
- 246: 1/9 - to be raised as new T3 at TMAG. Approved at TMAG on 20/9. 19/12 - Completed on 15/12
- 250: 1/9 - to be raised as new T3 at TMAG. Approved at TMAG on 20/9
- 255: 1/9 - to be raised as new T3 at TMAG. Approved at TMAG on 20/9. 4/10 - Red because small number of comments still to be resolved, will be completed no later than 3/11 ahead of Interval 2 Readiness Assessment

| ID | WBS | Task | Type | Duration | Start | Finish | Predecessors | Complete | Remaining | Baseline start | Baseline finish | Baseline duration | Baseline 1 start | Baseline 1 finish | Total slack | Constraint | Baseline cost | Responsible | Involved | Update Version | MHHS Resource Name | MHHS Programme Phase | Sched Status | RAG | Milestone ID | Text29 | Tier |
| --- | --- | --- | --- | --- | --- | --- | --- | --- | --- | --- | --- | --- | --- | --- | --- | --- | --- | --- | --- | --- | --- | --- | --- | --- | --- | --- | --- |
| 256 | 1.3.6.2.5.4 | **Test Scenarios** |  | 20d | 2023-09-01 A | 2023-09-29 A |  | 100% |  | 2023-09-01 | 2023-09-29 | 20d | 2022-10-31 | 2023-09-15 |  |  | -0 | N/A | N/A | 5.0 | N/A | Design, Build & Test (PIT) |  |  |  |  |  |
| 257 | 1.3.6.2.5.4.1 | Registration Services test scenarios submitted to Programme for assurance | milestone | 0d | 2023-09-01 A | 2023-09-01 A | 249FS+15d | 100% |  | 2023-09-01 | 2023-09-01 | 0d | 2023-09-01 | 2023-09-01 |  |  |  | PP | SI Test | 5.6 |  | Design, Build & Test (PIT) | Complete | COMPLETE | T3-DB-0044 | SITAG | T3 |
| 258 | 1.3.6.2.5.4.2 | Registration Services Test scenarios MHHS Review Completed | milestone | 0d | 2023-09-29 A | 2023-09-29 A | 257FS+20d | 100% |  | 2023-09-29 | 2023-09-29 | 0d | 2023-09-04 | 2023-09-15 |  |  |  | SI Test | PP | 5.8 |  | Design, Build & Test (PIT) | Complete | COMPLETE | T3-DB-0126 | SITAG | T3 |
| 259 | 1.3.6.2.5.5 | **PIT execution** |  | 40d | 2023-09-11 A | 2023-11-03 A |  | 100% |  | 2023-09-11 | 2023-11-03 | 40d | 2023-01-02 | 2023-10-20 |  |  | -0 | N/A | N/A | 5.0 | N/A | Design, Build & Test (PIT) |  |  |  |  |  |
| 260 | 1.3.6.2.5.5.1 | PIT Test Execution Progress Report |  | 33d | 2023-09-11 A | 2023-10-25 A | 252 | 100% |  | 2023-09-11 | 2023-10-20 | 30d | 2023-01-02 | 2023-10-13 |  |  |  | PP | SI Test | 5.0 |  | Design, Build & Test (PIT) | Complete | COMPLETE |  |  |  |
| 261 | 1.3.6.2.5.5.2 | PIT Execution |  | 30d | 2023-09-11 A | 2023-10-20 A | 257FS+5d | 100% |  | 2023-09-11 | 2023-10-20 | 30d | 2023-01-16 | 2023-10-20 |  |  |  | PP | SI Test | 5.0 |  | Design, Build & Test (PIT) | Complete | COMPLETE |  |  |  |
| 262 | 1.3.6.2.5.5.3 | Registration Services PIT (CIT interval 2) Completion Report submitted to Programme for assurance | milestone | 0d | 2023-10-25 A | 2023-10-25 A | 260, 261 | 100% |  | 2023-10-20 | 2023-10-20 | 0d | 2024-01-05 | 2024-01-05 |  |  |  | PP | SI Test | 5.10 |  | Design, Build & Test (PIT) | Complete | COMPLETE | T3-DB-0127 | SITAG | T3 |
| 263 | 1.3.6.2.5.5.4 | Registration Services PIT (CIT interval 2) Completion Report MHHS Review Completed | milestone | 0d | 2023-11-03 A | 2023-11-03 A | 250, 255, 258, 262FS+7d | 100% |  | 2023-11-03 | 2023-11-03 | 0d |  |  |  |  |  | SI Test | PP | 5.11 |  | Design, Build & Test (PIT) | Complete | COMPLETE | T3-DB-0128 | SITAG | T3 |
| 264 | 1.3.6.3 | **SIT Participants DBT** |  | 356d | 2023-08-11 A | 2024-12-20 |  | 89% | 38.14d | 2022-10-31 | 2024-09-20 | 495d | 2022-10-31 | 2025-03-14 | 31868d |  | -0 | N/A | N/A | 5.0 | N/A | Design, Build & Test (PIT) |  |  |  |  |  |
| 265 | 1.3.6.3.1 | **All Data Services DBT CIT (Entering at Interval 3)** |  | 71d | 2023-08-11 A | 2023-11-17 A |  | 100% |  | 2022-10-31 | 2023-11-17 | 275d | 2022-10-31 | 2023-11-03 |  |  | -0 | N/A | N/A | 5.0 | N/A | Design, Build & Test (PIT) |  |  |  |  |  |
| 266 | 1.3.6.3.1.1 | **Test Approach & Plan** |  | 30d | 2023-08-11 A | 2023-09-21 A |  | 100% |  | 2023-08-11 | 2023-09-21 | 29d | 2022-10-31 | 2023-08-25 |  |  | -0 | N/A | N/A | 5.0 | N/A | Design, Build & Test (PIT) |  |  |  |  |  |
| 267 | 1.3.6.3.1.1.1 | All Data Services Test Approach & Plans (PIT) submitted to Programme for assurance | milestone | 0d | 2023-08-11 A | 2023-08-11 A |  | 100% |  | 2023-08-11 | 2023-08-11 | 0d | 2023-08-11 | 2023-08-11 |  | start no earlier than 2023-08-11 |  | PP | SI Test | 5.0 |  | Design, Build & Test (PIT) | Complete | COMPLETE | T3-DB-0038 | SITAG | T3 |
| 268 | 1.3.6.3.1.1.2 | All Data Services Test approach and plans MHHS Review Completed | milestone | 0d | 2023-09-21 A | 2023-09-21 A | 267FS+30d | 100% |  | 2023-09-21 | 2023-09-21 | 0d | 2023-08-14 | 2023-08-25 |  |  |  | SI Test | PP | 5.11 |  | Design, Build & Test (PIT) | Complete | COMPLETE | T3-DB-0129 | SITAG | T3 |
| 269 | 1.3.6.3.1.2 | **Test Readiness Report** |  | 11d | 2023-08-25 A | 2023-09-08 A |  | 100% |  | 2023-08-25 | 2023-09-08 | 11d | 2023-08-25 | 2023-11-03 |  |  | -0 | N/A | N/A | 5.0 | N/A | Design, Build & Test (PIT) |  |  |  |  |  |
| 270 | 1.3.6.3.1.2.1 | Test readiness reporting |  | 11d | 2023-08-25 A | 2023-09-08 A | 267FS+10d | 100% |  | 2023-08-25 | 2023-09-08 | 11d | 2023-08-25 | 2023-11-03 |  |  |  | PP | 109 | 5.0 |  | Design, Build & Test (PIT) | Complete | COMPLETE |  |  |  |
| 271 | 1.3.6.3.1.3 | **Requirements to test Traceability Matrix (RTTM)** |  | 7d | 2023-09-20 A | 2023-09-29 A |  | 100% |  | 2023-09-22 | 2023-09-29 | 5d | 2022-10-31 | 2023-10-06 |  |  | -0 | N/A | N/A | 5.0 | N/A | Design, Build & Test (PIT) |  |  |  |  |  |
| 272 | 1.3.6.3.1.3.1 | All Data Services RTTMs submitted to Programme for assurance | milestone | 0d | 2023-09-20 A | 2023-09-20 A | 267FS+29d | 100% |  | 2023-09-22 | 2023-09-22 | 0d | 2023-09-22 | 2023-09-22 |  |  |  | PP | SI Test | 5.7 |  | Design, Build & Test (PIT) | Complete | COMPLETE | T3-DB-0058 | SITAG | T3 |
| 273 | 1.3.6.3.1.3.2 | All Data Services RTTMs MHHS Review Completed | milestone | 0d | 2023-09-29 A | 2023-09-29 A | 272FS+7d | 100% |  | 2023-09-29 | 2023-09-29 | 0d | 2023-09-25 | 2023-10-06 |  |  |  | SI Test | PP | 5.8 |  | Design, Build & Test (PIT) | Complete | COMPLETE | T3-DB-0130 | SITAG | T3 |
| 274 | 1.3.6.3.1.4 | **Test Scenarios** |  | 6d | 2023-09-20 A | 2023-09-28 A |  | 100% |  | 2023-09-22 | 2023-09-28 | 4d | 2022-10-31 | 2023-10-06 |  |  | -0 | N/A | N/A | 5.0 | N/A | Design, Build & Test (PIT) |  |  |  |  |  |
| 275 | 1.3.6.3.1.4.1 | All Data Services test scenarios' submitted to Programme for assurance | milestone | 0d | 2023-09-20 A | 2023-09-20 A | 267FS+29d | 100% |  | 2023-09-22 | 2023-09-22 | 0d | 2023-09-22 | 2023-09-22 |  |  |  | PP | SI Test | 5.7 |  | Design, Build & Test (PIT) | Complete | COMPLETE | T3-DB-0056 | SITAG | T3 |
| 276 | 1.3.6.3.1.4.2 | All Data Services Test scenarios' MHHS Review Completed | milestone | 0d | 2023-09-28 A | 2023-09-28 A | 275FS+6d | 100% |  | 2023-09-28 | 2023-09-28 | 0d | 2023-09-25 | 2023-10-06 |  |  |  | SI Test | PP | 5.11 |  | Design, Build & Test (PIT) | Complete | COMPLETE | T3-DB-0131 | SITAG | T3 |
| 277 | 1.3.6.3.1.5 | **PIT execution** |  | 50d | 2023-09-11 A | 2023-11-17 A |  | 100% |  | 2022-10-31 | 2023-11-17 | 275d | 2022-10-31 | 2023-11-03 |  |  | -0 | N/A | N/A | 5.0 | N/A | Design, Build & Test (PIT) |  |  |  |  |  |
| 278 | 1.3.6.3.1.5.1 | PIT Test Execution Progress Report |  | 40d | 2023-09-11 A | 2023-11-03 A | 270 | 100% |  | 2022-10-31 | 2023-10-27 | 260d | 2022-10-31 | 2023-10-27 |  |  |  | PP | SI Test | 5.0 |  | Design, Build & Test (PIT) | Complete | COMPLETE |  |  |  |
| 279 | 1.3.6.3.1.5.2 | PIT Execution |  | 27d | 2023-09-28 A | 2023-11-03 A | 275FS+5d | 100% |  | 2022-10-31 | 2023-11-03 | 265d | 2022-10-31 | 2023-11-03 |  |  |  | PP | SI Test | 5.0 |  | Design, Build & Test (PIT) | Complete | COMPLETE |  |  |  |
| 280 | 1.3.6.3.1.5.3 | All Data Services PIT Completion Reports submitted to Programme for assurance | milestone | 0d | 2023-11-03 A | 2023-11-03 A | 278, 279 | 100% |  | 2023-11-03 | 2023-11-03 | 0d | 2024-01-05 | 2024-01-05 |  |  |  | PP | SI Test | 5.11 |  | Design, Build & Test (PIT) | Complete | COMPLETE | T3-DB-0132 | SITAG | T3 |
| 281 | 1.3.6.3.1.5.4 | All Data Services PIT Completion Reports MHHS Review Completed | milestone | 0d | 2023-11-17 A | 2023-11-17 A | 268, 273, 276, 280FS+10d | 100% |  | 2023-11-17 | 2023-11-17 | 0d |  |  |  |  |  | SI Test | PP | 5.13 |  | Design, Build & Test (PIT) | Complete | COMPLETE | T3-DB-0133 | SITAG | T3 |

Notes:
- 258: 1/9 - to be raised as new T3 at TMAG
- 261: 17/10 - Amber because St Clements assessment. No impact. Being monitored
- 262: 1/9 - to be raised as new T3 at TMAG. Approved at TMAG on 20/9. 24/10 - Red because 3 day delay to SCS PIT completion. No impact to CIT Interval 2.
- 263: 1/9 - to be raised as new T3 at TMAG. Approved at TMAG on 20/9. 17/10 - Amber because St Clements assessment. No impact. Being monitored
- 268: 1/9 - to be raised as new T3 at TMAG. Approved at TMAG on 20/9. Red due to high volume to be reviewed. Date change under consideration. Review will be completed no later than 17/11 ahead of Interval 3 Readiness Assessment
- 273: 1/9 - to be raised as new T3 at TMAG Approved at TMAG on 20/9. Red due to high volume to be reviewed. Date change under consideration. Review will be completed no later than 17/11 ahead of Interval 3 Readiness Assessment
- 276: 1/9 - to be raised as new T3 at TMAG. Approved at TMAG on 20/9. Red due to high volume to be reviewed. Date change under consideration. Review will be completed no later than 17/11 ahead of Interval 3 Readiness Assessment
- 278: 10/10 - LC - red because date in the past, not all participants have provided reports. No impact. No action
- 279: 10/10 - LC - red because date in the past, acceptable for some participants to have not started PIT yet
- 280: 1/9 - to be raised as new T3 at TMAG. Approved at TMAG on 20/9
- 281: 1/9 - to be raised as new T3 at TMAG. Approved at TMAG on 20/9. 21/11-Red because 1 report remains outstanding due to close 22/11. Completed on 22/11

| ID | WBS | Task | Type | Duration | Start | Finish | Predecessors | Complete | Remaining | Baseline start | Baseline finish | Baseline duration | Baseline 1 start | Baseline 1 finish | Total slack | Constraint | Baseline cost | Responsible | Involved | Update Version | MHHS Resource Name | MHHS Programme Phase | Sched Status | RAG | Milestone ID | Text29 | Tier | Artefact ID |
| --- | --- | --- | --- | --- | --- | --- | --- | --- | --- | --- | --- | --- | --- | --- | --- | --- | --- | --- | --- | --- | --- | --- | --- | --- | --- | --- | --- | --- |
| 282 | 1.3.6.3.2 | **All Metering Services DBT CIT (Entering at Interval 4)** |  | 70d | 2023-08-25 A | 2023-12-01 A |  | 100% |  | 2022-10-31 | 2023-12-01 | 285d | 2022-10-31 | 2023-11-17 |  |  | -0 | N/A | N/A | 5.0 | N/A | Design, Build & Test (PIT) |  |  |  |  |  |  |
| 283 | 1.3.6.3.2.1 | **Test Approach & Plan** |  | 40d | 2023-08-25 A | 2023-10-20 A |  | 100% |  | 2023-08-25 | 2023-10-20 | 40d | 2022-10-31 | 2023-09-08 |  |  | -0 | N/A | N/A | 5.0 | N/A | Design, Build & Test (PIT) |  |  |  |  |  |  |
| 284 | 1.3.6.3.2.1.1 | All Metering Services Test Approach & Plans (PIT) submitted to Programme for assurance | milestone | 0d | 2023-08-25 A | 2023-08-25 A |  | 100% |  | 2023-08-25 | 2023-08-25 | 0d | 2023-08-25 | 2023-08-25 |  |  |  | PP | SI Test | 5.6 |  | Design, Build & Test (PIT) | Complete | COMPLETE | T3-DB-0040 | SITAG | T3 |  |
| 285 | 1.3.6.3.2.1.2 | All Metering Services Test approach and plans MHHS Review Completed | milestone | 0d | 2023-10-20 A | 2023-10-20 A | 284FS+40d | 100% |  | 2023-10-20 | 2023-10-20 | 0d | 2023-08-28 | 2023-09-08 |  |  |  | SI Test | PP | 5.8 |  | Design, Build & Test (PIT) | Complete | COMPLETE | T3-DB-0134 | SITAG | T3 |  |
| 286 | 1.3.6.3.2.2 | **Test Readiness Report** |  | 11d | 2023-09-11 A | 2023-09-25 A |  | 100% |  | 2023-09-08 | 2023-11-17 | 51d | 2023-09-08 | 2023-11-17 |  |  |  | N/A | N/A | 5.0 | N/A | Design, Build & Test (PIT) |  |  |  |  |  |  |
| 287 | 1.3.6.3.2.2.1 | Test readiness reporting |  | 11d | 2023-09-11 A | 2023-09-25 A | 284FS+10d | 100% |  | 2023-09-08 | 2023-11-17 | 51d | 2023-09-08 | 2023-11-17 |  |  |  | PP | 109 | 5.0 |  | Design, Build & Test (PIT) | Complete | COMPLETE |  |  |  |  |
| 288 | 1.3.6.3.2.3 | **Requirements to test Traceability Matrix (RTTM)** |  | 30d | 2023-09-15 A | 2023-10-27 A |  | 100% |  | 2023-09-15 | 2023-10-27 | 30d | 2022-10-31 | 2023-09-29 |  |  | -0 | N/A | N/A | 5.0 | N/A | Design, Build & Test (PIT) |  |  |  |  |  |  |
| 289 | 1.3.6.3.2.3.1 | All Metering Services RTTMs submitted to Programme for assurance | milestone | 0d | 2023-09-15 A | 2023-09-15 A | 284FS+15d | 100% |  | 2023-09-15 | 2023-09-15 | 0d | 2023-09-15 | 2023-09-15 |  |  |  | PP | SI Test | 5.8 |  | Design, Build & Test (PIT) | Complete | COMPLETE | T3-DB-0048 | SITAG | T3 | MHHS-ART009 |
| 290 | 1.3.6.3.2.3.2 | All Metering Services MHHS Reviews Completed | milestone | 0d | 2023-10-27 A | 2023-10-27 A | 289FS+30d | 100% |  | 2023-10-27 | 2023-10-27 | 0d | 2023-09-18 | 2023-09-29 |  |  |  | SI Test | PP | 5.13 |  | Design, Build & Test (PIT) | Complete | COMPLETE | T3-DB-0135 | SITAG | T3 |  |
| 291 | 1.3.6.3.2.4 | **Test Scenarios** |  | 30d | 2023-09-15 A | 2023-10-27 A |  | 100% |  | 2023-09-15 | 2023-10-27 | 30d | 2022-10-31 | 2023-09-29 |  |  | -0 | N/A | N/A | 5.0 | N/A | Design, Build & Test (PIT) |  |  |  |  |  |  |
| 292 | 1.3.6.3.2.4.1 | All Metering Services test scenarios' submitted to Programme for assurance | milestone | 0d | 2023-09-15 A | 2023-09-15 A | 284FS+15d | 100% |  | 2023-09-15 | 2023-09-15 | 0d | 2023-09-15 | 2023-09-15 |  |  |  | PP | SI Test | 5.8 |  | Design, Build & Test (PIT) | Complete | COMPLETE | T3-DB-0050 | SITAG | T3 |  |
| 293 | 1.3.6.3.2.4.2 | All Metering Services Test scenarios' MHHS Review Completed | milestone | 0d | 2023-10-27 A | 2023-10-27 A | 292FS+30d | 100% |  | 2023-10-27 | 2023-10-27 | 0d | 2023-09-18 | 2023-09-29 |  |  |  | SI Test | PP | 5.13 |  | Design, Build & Test (PIT) | Complete | COMPLETE | T3-DB-0136 | SITAG | T3 |  |
| 294 | 1.3.6.3.2.5 | **PIT execution** |  | 50d | 2023-09-25 A | 2023-12-01 A |  | 100% |  | 2022-10-31 | 2023-12-01 | 285d | 2022-10-31 | 2023-11-17 |  |  | -0 | N/A | N/A | 5.0 | N/A | Design, Build & Test (PIT) |  |  |  |  |  |  |
| 295 | 1.3.6.3.2.5.1 | PIT Test Execution Progress Report |  | 39d | 2023-09-26 A | 2023-11-17 A | 287 | 100% |  | 2023-09-26 | 2023-11-17 | 39d | 2022-10-31 | 2023-11-10 |  |  |  | PP | SI Test | 5.0 |  | Design, Build & Test (PIT) | Complete | COMPLETE |  |  |  |  |
| 296 | 1.3.6.3.2.5.2 | PIT Execution |  | 40d | 2023-09-25 A | 2023-11-17 A | 292FS+5d | 100% |  | 2022-10-31 | 2023-11-17 | 275d | 2022-10-31 | 2023-11-17 |  |  |  | PP | SI Test | 5.0 |  | Design, Build & Test (PIT) | Complete | COMPLETE |  |  |  |  |
| 297 | 1.3.6.3.2.5.3 | All Metering Services PIT Completion Reports submitted to Programme for assurance | milestone | 0d | 2023-11-17 A | 2023-11-17 A | 295, 296 | 100% |  | 2023-11-17 | 2023-11-17 | 0d | 2024-01-05 | 2024-01-05 |  |  |  | PP | SI Test | 5.13 |  | Design, Build & Test (PIT) | Complete | COMPLETE | T3-DB-0137 | SITAG | T3 |  |
| 298 | 1.3.6.3.2.5.4 | All Metering Services PIT Completion Reports MHHS Review Completed | milestone | 0d | 2023-12-01 A | 2023-12-01 A | 285, 290, 293, 297FS+10d | 100% |  | 2023-12-01 | 2023-12-01 | 0d |  |  |  |  |  | SI Test | PP | 5.13 |  | Design, Build & Test (PIT) | Complete | COMPLETE | T3-DB-0138 | SITAG | T3 |  |
| 299 | 1.3.6.3.3 | **All SIT Programme Participants PIT (SIT Functional)** |  | 286d | 2023-11-17 A | 2024-12-20 |  | 77% | 66.09d | 2022-12-30 | 2024-09-20 | 451d | 2022-12-30 | 2024-02-16 | 31868d |  | -0 | N/A | N/A | 5.0 | N/A | Design, Build & Test (PIT) |  |  |  |  |  |  |
| 300 | 1.3.6.3.3.1 | **Test Approach & Plans** |  | 40d | 2023-11-17 A | 2024-01-11 A |  | 100% |  | 2023-11-17 | 2024-01-11 | 40d | 2022-12-30 | 2023-11-30 |  |  | -0 | N/A | N/A | 5.2 | N/A | Design, Build & Test (PIT) |  |  |  |  |  |  |
| 301 | 1.3.6.3.3.1.1 | SIT Functional PIT Test Approach & Plan (PIT) submitted to Programme for assurance | milestone | 0d | 2023-11-17 A | 2023-11-17 A |  | 100% |  | 2023-11-17 | 2023-11-17 | 0d | 2023-11-16 | 2023-11-16 |  | start no earlier than 2023-11-17 |  | PP | SI Test | 5.16 |  | Design, Build & Test (PIT) | Complete | COMPLETE | T3-DB-0093 | SITAG | T3 |  |
| 302 | 1.3.6.3.3.1.2 | All SIT Functional Test approach and plans MHHS Reviews Completed | milestone | 0d | 2024-01-11 A | 2024-01-11 A | 301FS+40d | 100% |  | 2024-01-11 | 2024-01-11 | 0d | 2023-11-17 | 2023-11-30 |  |  |  | SI Test | PP | 5.8 |  | Design, Build & Test (PIT) | Complete | COMPLETE | T3-DB-0139 | SITAG | T3 |  |
| 303 | 1.3.6.3.3.2 | **Test Readiness Reports** |  | 11d | 2023-12-01 A | 2023-12-15 A |  | 100% |  | 2023-12-01 | 2024-02-09 | 51d | 2023-11-30 | 2024-02-08 |  |  |  | N/A | N/A | 5.2 | N/A | Design, Build & Test (PIT) |  |  |  |  |  |  |
| 304 | 1.3.6.3.3.2.1 | Test readiness reporting |  | 11d | 2023-12-01 A | 2023-12-15 A | 301FS+10d | 100% |  | 2023-12-01 | 2023-12-15 | 51d | 2023-11-30 | 2024-02-08 |  |  |  | PP | 109 | 5.2 |  | Design, Build & Test (PIT) | Complete | COMPLETE |  |  |  |  |
| 305 | 1.3.6.3.3.3 | **Requirements to test Traceability Matrices (RTTM)** |  | 30d | 2023-12-07 A | 2024-01-18 A |  | 100% |  | 2023-12-07 | 2024-01-18 | 30d | 2023-01-06 | 2024-01-05 |  |  | -0 | N/A | N/A | 5.2 | N/A | Design, Build & Test (PIT) |  |  |  |  |  |  |
| 306 | 1.3.6.3.3.3.1 | SIT Functional PIT RTTM submitted to Programme for assurance | milestone | 0d | 2023-12-07 A | 2023-12-07 A | 301FS+15d | 100% |  | 2023-12-07 | 2023-12-07 | 0d | 2023-12-14 | 2023-12-14 |  |  |  | PP | SI Test | 5.14 |  | Design, Build & Test (PIT) | Complete | COMPLETE | T3-DB-0091 | SITAG | T3 |  |
| 307 | 1.3.6.3.3.3.2 | All SIT Functional RTTMs MHHS Reviews Completed | milestone | 0d | 2024-01-18 A | 2024-01-18 A | 306FS+30d | 100% |  | 2024-01-18 | 2024-01-18 | 0d | 2023-12-15 | 2024-01-05 |  |  |  | SI Test | PP | 5.14 |  | Design, Build & Test (PIT) | Complete | COMPLETE | T3-DB-0140 | SITAG | T3 |  |

Notes:
- 285: 7/10 - Red due to high volume to be reviewed. Date change under consideration. Review will be completed no later than 04/12 ahead of Interval 4 Readiness Assessment
- 289: 13/9 - name change at TMAG. Red because 9/10 received. Approved at TMAG on 20/9
- 290: 1/9 - to be raised as new T3 at TMAG. Approved at TMAG on 20/9. 17/10 - Red because assurance reviews open comments remain outstanding. Final reviews will be completed no later than 4/12 ahead of Interval 4 Readiness Report
- 292: 13/9 - name change at TMAG Red because 9/10 . Approved at TMAG on 20/9
- 293: 1/9 - to be raised as new T3 at TMAG. Approved at TMAG on 20/9. 17/10 - Red because assurance reviews open comments remain outstanding. Final reviews will be completed no later than 4/12 ahead of Interval 4 Readiness Report
- 297: 1/9 - to be raised as new T3 at TMAG. Approved at TMAG on 20/9. 21/11-Red because not all test completion reports received. No impact. No action
- 298: 1/9 - to be raised as new T3 at TMAG. Approved at TMAG on 20/9.28/11 - Amber because late delivery of some completion reports impairing ability to conclude on time. Expediting reviews ahead of RA 4
- 301: 12/9 - name change to TMAG. Approved at TMAG on 20/9. 5/12-Red because not all test approach and plans received. Escalated at FTIG and PSG. Completed 4/1/24
- 302: 1/9 - to be raised as new T3 at TMAG. Approved at TMAG on 20/9. 16/1- All remaining / late artefacts now received and reviewed by Programme with feedback provided to PPs. Awaiting PPs final feedback. Approved complete at SITAG on 21/2/24
- 306: 12/9 - name and date change to TMAG. Approved at TMAG on 20/9. 20/02 - 1 PP artefact not yet received. Escalated at FTIG
- 307: 1/9 - to be raised as new T3 at TMAG. Approved at TMAG on 20/9. 23/01 - Late due to late delivery of PP artefacts for review

| ID | WBS | Task | Type | Duration | Start | Finish | Predecessors | Complete | Baseline start | Baseline finish | Baseline duration | Baseline 1 start | Baseline 1 finish | Constraint | Baseline cost | Responsible | Involved | Update Version | MHHS Resource Name | MHHS Programme Phase | Sched Status | RAG | Milestone ID | Text29 | Tier |
| --- | --- | --- | --- | --- | --- | --- | --- | --- | --- | --- | --- | --- | --- | --- | --- | --- | --- | --- | --- | --- | --- | --- | --- | --- | --- |
| 308 | 1.3.6.3.3.4 | **Test Scenarios** |  | 30d | 2023-12-07 A | 2024-01-18 A |  | 100% | 2023-12-07 | 2024-01-18 | 30d | 2023-01-06 | 2024-01-05 |  | -0 | N/A | N/A | 5.2 | N/A | Design, Build & Test (PIT) |  |  |  |  |  |
| 309 | 1.3.6.3.3.4.1 | SIT Functional PIT test scenarios submitted to Programme for assurance | milestone | 0d | 2023-12-07 A | 2023-12-07 A | 301FS+15d | 100% | 2023-12-07 | 2023-12-07 | 0d | 2023-12-14 | 2023-12-14 |  |  | PP | SI Test | 5.14 |  | Design, Build & Test (PIT) | Complete | COMPLETE | T3-DB-0089 | SITAG | T3 |
| 310 | 1.3.6.3.3.4.2 | All SIT Functional Test scenarios' MHHS Reviews Completed | milestone | 0d | 2024-01-18 A | 2024-01-18 A | 309FS+30d | 100% | 2024-01-18 | 2024-01-18 | 0d | 2023-12-15 | 2024-01-05 |  |  | SI Test | PP | 5.14 |  | Design, Build & Test (PIT) | Complete | COMPLETE | T3-DB-0141 | SITAG | T3 |
| 311 | 1.3.6.3.3.5 | **PIT execution** |  | 51d | 2023-12-15 A | 2024-02-23 A |  | 100% | 2022-12-30 | 2024-02-23 | 301d | 2022-12-30 | 2024-02-09 |  | -0 | N/A | N/A | 5.0 | N/A | Design, Build & Test (PIT) |  |  |  |  |  |
| 312 | 1.3.6.3.3.5.1 | PIT Test Execution Progress Reports |  | 40d | 2023-12-18 A | 2024-02-09 A | 304 | 100% | 2023-12-18 | 2024-02-09 | 40d | 2022-12-30 | 2024-02-01 |  |  | PP | SI Test | 5.0 |  | Design, Build & Test (PIT) | Complete | COMPLETE |  |  |  |
| 313 | 1.3.6.3.3.5.2 | PIT Execution |  | 41d | 2023-12-15 A | 2024-02-09 A | 309FS+5d | 100% | 2022-12-30 | 2024-02-09 | 290d | 2022-12-30 | 2024-02-09 |  |  | PP | SI Test | 5.0 |  | Design, Build & Test (PIT) | Complete | COMPLETE |  |  |  |
| 314 | 1.3.6.3.3.5.3 | All SIT Functional PIT Completion Reports submitted to Programme for Assurance | milestone | 0d | 2024-02-09 A | 2024-02-09 A | 312, 313 | 100% | 2024-02-09 | 2024-02-09 | 0d | 2024-01-05 | 2024-01-05 |  |  | PP | SI Test | 5.19 |  | Design, Build & Test (PIT) | Complete | COMPLETE | T3-DB-0087 | SITAG | T3 |
| 315 | 1.3.6.3.3.5.4 | All SIT Functional PIT Completion Reports MHHS Review Completed | milestone | 0d | 2024-02-23 A | 2024-02-23 A | 302, 307, 310, 314FS+10d | 100% | 2024-02-23 | 2024-02-23 | 0d |  |  |  |  | SI Test | PP | 5.19 |  | Design, Build & Test (PIT) | Complete | COMPLETE | T3-DB-0142 | SITAG | T3 |
| 316 | 1.3.6.3.3.6 | **All SIT Programme Participants PIT (SIT Migration)** |  | 71d | 2024-02-16 A | 2024-05-24 A |  | 100% | 2023-03-31 | 2024-05-24 | 301d |  |  |  | -0 | N/A | N/A | 5.1 | N/A | Design, Build & Test (PIT) |  |  |  |  |  |
| 317 | 1.3.6.3.3.6.1 | **Test Approach & Plans** |  | 40d | 2024-02-16 A | 2024-04-11 A |  | 100% | 2024-02-16 | 2024-04-11 | 40d |  |  |  | -0 | N/A | N/A | 5.2 | N/A | Design, Build & Test (PIT) |  |  |  |  |  |
| 318 | 1.3.6.3.3.6.1.1 | All SIT Migration PIT Test Approach & Plans submitted to Programme for assurance | milestone | 0d | 2024-02-16 A | 2024-02-16 A |  | 100% | 2024-02-16 | 2024-02-16 | 0d |  |  | start no earlier than 2024-02-16 |  | PP | SI Test | 5.8 |  | Design, Build & Test (PIT) | Complete | COMPLETE | T3-DB-0143 | SITAG | T3 |
| 319 | 1.3.6.3.3.6.1.2 | All SIT Migration PIT Test approach and plans MHHS Reviews Completed | milestone | 0d | 2024-04-11 A | 2024-04-11 A | 318FS+40d | 100% | 2024-04-11 | 2024-04-11 | 0d |  |  |  |  | SI Test | PP | 5.23 |  | Design, Build & Test (PIT) | Complete | COMPLETE | T3-DB-0144 | SITAG | T3 |
| 320 | 1.3.6.3.3.6.2 | **Test Readiness Reports** |  | 11d | 2024-03-01 A | 2024-03-15 A |  | 100% | 2024-03-01 | 2024-05-10 | 51d |  |  |  |  | N/A | N/A | 5.2 | N/A | Design, Build & Test (PIT) |  |  |  |  |  |
| 321 | 1.3.6.3.3.6.2.1 | Test readiness reporting |  | 11d | 2024-03-01 A | 2024-03-15 A | 318FS+10d | 100% | 2024-03-01 | 2024-05-10 | 51d |  |  |  |  | PP | 109 | 5.2 |  | Design, Build & Test (PIT) | Complete | COMPLETE |  |  |  |
| 322 | 1.3.6.3.3.6.3 | **Requirements to test Traceability Matrices (RTTM)** |  | 30d | 2024-03-07 A | 2024-04-18 A |  | 100% | 2024-03-07 | 2024-04-18 | 30d |  |  |  | -0 | N/A | N/A | 5.2 | N/A | Design, Build & Test (PIT) |  |  |  |  |  |
| 323 | 1.3.6.3.3.6.3.1 | All SIT Migration PIT RTTMs submitted to Programme for assurance | milestone | 0d | 2024-03-07 A | 2024-03-07 A | 318FS+15d | 100% | 2024-03-07 | 2024-03-07 | 0d |  |  |  |  | PP | SI Test | 5.23 |  | Design, Build & Test (PIT) | Complete | COMPLETE | T3-DB-0145 | SITAG | T3 |
| 324 | 1.3.6.3.3.6.3.2 | All SIT Migration RTTMs MHHS Reviews Completed | milestone | 0d | 2024-04-18 A | 2024-04-18 A | 323FS+30d | 100% | 2024-04-18 | 2024-04-18 | 0d |  |  |  |  | SI Test | PP | 5.25 |  | Design, Build & Test (PIT) | Complete | COMPLETE | T3-DB-0146 | SITAG | T3 |
| 325 | 1.3.6.3.3.6.4 | **Test Scenarios** |  | 30d | 2024-03-07 A | 2024-04-18 A |  | 100% | 2024-03-07 | 2024-04-18 | 30d |  |  |  | -0 | N/A | N/A | 5.2 | N/A | Design, Build & Test (PIT) |  |  |  |  |  |
| 326 | 1.3.6.3.3.6.4.1 | All SIT Migration PIT test scenarios submitted to Programme for assurance | milestone | 0d | 2024-03-07 A | 2024-03-07 A | 318FS+15d | 100% | 2024-03-07 | 2024-03-07 | 0d |  |  |  |  | PP | SI Test | 5.23 |  | Design, Build & Test (PIT) | Complete | COMPLETE | T3-DB-0147 | SITAG | T3 |
| 327 | 1.3.6.3.3.6.4.2 | All SIT Migration Test scenarios MHHS Reviews Completed | milestone | 0d | 2024-04-18 A | 2024-04-18 A | 326FS+30d | 100% | 2024-04-18 | 2024-04-18 | 0d |  |  |  |  | SI Test | PP | 5.25 |  | Design, Build & Test (PIT) | Complete | COMPLETE | T3-DB-0148 | SITAG | T3 |
| 328 | 1.3.6.3.3.6.5 | **PIT execution** |  | 51d | 2024-03-15 A | 2024-05-24 A |  | 100% | 2023-03-31 | 2024-05-24 | 301d |  |  |  | -0 | N/A | N/A | 5.1 | N/A | Design, Build & Test (PIT) |  |  |  |  |  |
| 329 | 1.3.6.3.3.6.5.1 | PIT Test Execution Progress Reports |  | 40d | 2024-03-18 A | 2024-05-10 A | 321 | 100% | 2024-03-18 | 2024-05-10 | 40d |  |  |  |  | PP | SI Test | 5.1 |  | Design, Build & Test (PIT) | Complete | COMPLETE |  |  |  |
| 330 | 1.3.6.3.3.6.5.2 | PIT Execution |  | 41d | 2024-03-15 A | 2024-05-10 A | 326FS+5d | 100% | 2023-03-31 | 2024-05-10 | 290d |  |  |  |  | PP | SI Test | 5.1 |  | Design, Build & Test (PIT) | Complete | COMPLETE |  |  |  |
| 331 | 1.3.6.3.3.6.5.3 | All SIT Migration PIT Completion Reports submitted to Programme for assurance | milestone | 0d | 2024-05-10 A | 2024-05-10 A | 329, 330 | 100% | 2024-05-10 | 2024-05-10 | 0d | 2024-01-05 | 2024-01-05 |  |  | PP | SI Test | 5.8 |  | Design, Build & Test (PIT) | Complete | COMPLETE | T3-DB-0149 | SITAG | T3 |
| 332 | 1.3.6.3.3.6.5.4 | All SIT Migration PIT Completion Reports MHHS Review Completed | milestone | 0d | 2024-05-24 A | 2024-05-24 A | 319, 324, 327, 331FS+10d | 100% | 2024-05-24 | 2024-05-24 | 0d |  |  |  |  | SI Test | PP | 5.8 |  | Design, Build & Test (PIT) | Complete | COMPLETE | T3-DB-0150 | SITAG | T3 |

Notes:
- 309: 12/9 - name and date change to TMAG. Approved at TMAG on 20/9. 20/02 - 2 PP artefacts not yet received. Escalated at FTIG
- 310: 1/9 - to be raised as new T3 at TMAG. Approved at TMAG on 20/9. 12/12 - Late due to late delivery of PP artefacts for review
- 312: 16/4: completed 12/4
- 313: 16/4: completed 12/4
- 314: 1/9 - name change at TMAG. Approved at TMAG on 20/9. 20/2 - 23 reports received. The majority of late deliveries have been discussed and agreed with the Programme.5/3 - Approved 1/3 SITAG with work off
- 315: 1/9 - to be raised as new T3 at TMAG. Approved at TMAG on 20/9. 27/2 - Target date missed due to late delivery of some reports. 5/3 - Approved 1/3 SITAG with work off
- 318: 1/9 - to be raised as new T3 at TMAG. Approved at TMAG on 20/9.. 19/3 - 33/35 received
- 319: 1/9 - to be raised as new T3 at TMAG. Approved at TMAG on 20/9. 26/3: At risk because of late delivery of PIT test approach and plans by PPs. 16/4: All received. All but 1 reviewed
- 323: 1/9 - to be raised as new T3 at TMAG. Approved at TMAG on 20/9. 22/04: 33/34 received. Remainder to be chased
- 324: 1/9 - to be raised as new T3 at TMAG. Approved at TMAG on 20/9. 26/3: At risk because of late delivery of RTTMs by PPs 30/4: Late because of late delivery or RTTMS 33/34 reviewed
- 326: 1/9 - to be raised as new T3 at TMAG. Approved at TMAG on 20/9. 22/04: 31/34 received. Remainder to be chased
- 327: 1/9 - to be raised as new T3 at TMAG. Approved at TMAG on 20/9. 26/3: At risk because of late delivery of PIT test scenarios by PPs. 30/4: Late because of late delivery or Test scenarios. 33/34 reviewed
- 331: Sufficient PIT completion reports on track, some are known to be late. 11/6: 29/33 received. Small number of PPs will be PIT complete late, but before SIT migration. 1 PP will be post SIT Migration start. 11/6: eSITAG approved on 3/6 subject to Work-off
- 332: 1/9 - to be raised as new T3 at TMAG. Approved at TMAG on 20/9. 14/5: Won't deliver to forecast because of late delivery of by some PPs of PIT completion report. 11/6: eSITAG approved on 3/6 subject to Work-off

| ID | WBS | Task | Type | Duration | Start | Finish | Predecessors | Complete | Remaining | Baseline start | Baseline finish | Baseline duration | Baseline 1 start | Baseline 1 finish | Total slack | Free slack | Constraint | Baseline cost | Responsible | Involved | Update Version | MHHS Resource Name | MHHS Programme Phase | Sched Status | RAG | Milestone ID | Text29 | Tier | Guidance | Task Status | Notes (2) |
| --- | --- | --- | --- | --- | --- | --- | --- | --- | --- | --- | --- | --- | --- | --- | --- | --- | --- | --- | --- | --- | --- | --- | --- | --- | --- | --- | --- | --- | --- | --- | --- |
| 333 | 1.3.6.3.3.7 | **All SIT Programme Participants PIT (SIT Non Functional)** |  | 116d | 2024-07-12 A | 2024-12-20 |  | 64% | 42.28d | 2023-06-23 | 2024-08-16 | 301d |  |  | 31868d |  |  | -0 | N/A | N/A | 5.1 | N/A | Design, Build & Test (PIT) |  |  |  |  |  |  |  |  |
| 334 | 1.3.6.3.3.7.1 | **Test Approach & Plan** |  | 39d | 2024-09-27 A | 2024-11-21 |  |  | 39d | 2024-05-10 | 2024-07-04 | 40d |  |  | 0d |  |  | -0 | N/A | N/A | 5.2 | N/A | Design, Build & Test (PIT) |  |  |  |  |  |  |  |  |
| 335 | 1.3.6.3.3.7.1.1 | SIT Non-Functional PIT Test Approach & Plan (PIT) submitted to Programme for assurance | milestone | 0d | 2024-09-27 A | 2024-09-27 |  | 75% | 0d | 2024-05-10 | 2024-05-10 | 0d |  |  | 0d |  | start no earlier than 2024-05-10 |  | PP | SI Test | 5.30 | Roger Robar | Design, Build & Test (PIT) | Red | RED | T3-DB-0151 | SITAG | T3 |  |  |  |
| 336 | 1.3.6.3.3.7.1.2 | SIT Non-Functional Test approach and plan MHHS Review Completed | milestone | 0d | 2024-11-21 A | 2024-11-21 A | 335FS+40d | 100% |  | 2024-07-04 | 2024-07-04 | 0d |  |  |  |  |  |  | SI Test | PP | 5.30 | Roger Robar | Design, Build & Test (PIT) | Complete | COMPLETE | T3-DB-0152 | SITAG | T3 | 6/9/24: Approved at esitag on 26/7/24 |  |  |
| 337 | 1.3.6.3.3.7.2 | **Test Readiness Report** |  | 13d | 2024-10-04 A | 2024-10-22 |  | 85% | 2d | 2024-05-24 | 2024-08-02 | 51d |  |  | 0d |  |  |  | N/A | N/A | 5.2 | N/A | Design, Build & Test (PIT) |  |  |  |  |  |  |  |  |
| 338 | 1.3.6.3.3.7.2.1 | Test readiness reporting |  | 13d | 2024-10-04 A | 2024-10-22 | 335FS+10d | 85% | 2d | 2024-05-24 | 2024-08-02 | 51d |  |  | 0d |  |  |  | PP | 109 | 5.2 |  | Design, Build & Test (PIT) | Red | RED |  |  |  |  |  |  |
| 339 | 1.3.6.3.3.7.3 | **Requirements to test Traceability Matrix (RTTM)** |  | 20d | 2024-11-01 | 2024-11-29 |  |  |  | 2024-05-30 | 2024-07-11 | 30d |  |  | 31883d |  |  | -0 | N/A | N/A | 5.2 | N/A | Design, Build & Test (PIT) |  |  |  |  |  |  |  |  |
| 340 | 1.3.6.3.3.7.3.1 | SIT Non-Functional PIT RTTM submitted to Programme for assurance | milestone | 0d | 2024-11-01 | 2024-11-01 | 335FS+26d |  |  | 2024-05-30 | 2024-05-30 | 0d |  |  | 31883d | 0d |  |  | PP | SI Test | 5.8 | Roger Robar | Design, Build & Test (PIT) | Red | RED | T3-DB-0153 | SITAG | T3 |  | 42.71 |  |
| 341 | 1.3.6.3.3.7.3.2 | SIT Non-Functional RTTM MHHS Review Completed | milestone | 0d | 2024-11-29 | 2024-11-29 | 340FS+20d |  |  | 2024-07-11 | 2024-07-11 | 0d |  |  | 31883d | 15d | start no earlier than 2024-11-29 |  | SI Test | PP | 5.8 | Roger Robar | Design, Build & Test (PIT) | Red | RED | T3-DB-0154 | SITAG | T3 |  | 70.71 |  |
| 342 | 1.3.6.3.3.7.4 | **Test Scenarios** |  | 20d | 2024-11-01 | 2024-11-29 |  |  |  | 2024-05-30 | 2024-07-11 | 30d |  |  | 0d |  |  | -0 | N/A | N/A | 5.2 | N/A | Design, Build & Test (PIT) |  |  |  |  |  |  |  |  |
| 343 | 1.3.6.3.3.7.4.1 | SIT Non-Functional PIT test scenarios submitted to Programme for assurance | milestone | 0d | 2024-11-01 | 2024-11-01 | 335FS+26d |  |  | 2024-05-30 | 2024-05-30 | 0d |  |  | 0d |  |  |  | PP | SI Test | 5.8 | Roger Robar | Design, Build & Test (PIT) | Red | RED | T3-DB-0155 | SITAG | T3 |  | 42.71 |  |
| 344 | 1.3.6.3.3.7.4.2 | SIT Non-Functional Test scenarios MHHS Review Completed | milestone | 0d | 2024-11-29 | 2024-11-29 | 343FS+20d |  |  | 2024-07-11 | 2024-07-11 | 0d |  |  | 31883d | 15d |  |  | SI Test | PP | 5.8 | Roger Robar | Design, Build & Test (PIT) | Red | RED | T3-DB-0156 | SITAG | T3 |  | 70.71 |  |
| 345 | 1.3.6.3.3.7.5 | **PIT execution** |  | 116d | 2024-07-12 A | 2024-12-20 |  | 61% | 45.66d | 2023-06-23 | 2024-08-16 | 301d |  |  | 31868d |  |  | -0 | N/A | N/A | 5.1 | N/A | Design, Build & Test (PIT) |  |  |  |  |  |  |  |  |
| 346 | 1.3.6.3.3.7.5.1 | PIT Test Execution Progress Report |  | 50d | 2024-07-15 A | 2024-11-21 | 338 | 56% | 22d | 2024-06-10 | 2024-08-01 | 39d |  |  | 31874d | 6d | finish no earlier than 2024-11-21 |  | PP | SI Test | 5.1 | Roger Robar | Design, Build & Test (PIT) | Red | RED |  |  |  |  |  |  |
| 347 | 1.3.6.3.3.7.5.2 | PIT Execution |  | 44d | 2024-07-12 A | 2024-11-29 | 343FS+5d | 66% | 15d | 2023-06-23 | 2024-08-02 | 290d |  |  | 31868d | 0d | finish no earlier than 2024-11-29 |  | PP | SI Test | 5.1 | Roger Robar | Design, Build & Test (PIT) | Red | RED |  |  |  |  |  |  |
| 348 | 1.3.6.3.3.7.5.3 | SIT Non-Functional PIT Completion Report submitted to Programme for assurance | milestone | 0d | 2024-11-29 | 2024-11-29 | 346, 347 |  |  | 2024-08-02 | 2024-08-02 | 0d | 2024-01-05 | 2024-01-05 | 31868d | 0d |  |  | PP | SI Test | 5.10 | Roger Robar | Design, Build & Test (PIT) | Red | RED | T3-DB-0157 | SITAG | T3 |  | 70.71 |  |
| 349 | 1.3.6.3.3.7.5.4 | SIT Non-Functional PIT Completion Report MHHS Review Completed | milestone | 0d | 2024-12-20 | 2024-12-20 | 336, 341, 344, 348FS+15d |  |  | 2024-08-16 | 2024-08-16 | 0d |  |  | 31868d | 90d |  |  | SI Test | PP | 5.8 | Roger Robar | Design, Build & Test (PIT) | Red | RED | T3-DB-0158 | SITAG | T3 |  | 91.71 |  |
| 350 | 1.3.6.3.3.8 | **All SIT Programme Participants PIT (SIT Operational)** |  | 116d | 2024-07-12 A | 2024-12-20 |  | 46% | 62.41d | 2024-06-14 | 2024-09-20 | 71d |  |  | 31835d |  |  | -0 | N/A | N/A | 5.1 | N/A | Design, Build & Test (PIT) |  |  |  |  |  |  |  |  |
| 351 | 1.3.6.3.3.8.1 | **Test Approach & Plan** |  | 40d | 2024-09-27 | 2024-11-21 |  |  |  | 2024-06-14 | 2024-08-08 | 40d |  |  | 0d |  |  | -0 | N/A | N/A | 5.2 | N/A | Design, Build & Test (PIT) |  |  |  |  |  |  |  |  |
| 352 | 1.3.6.3.3.8.1.1 | SIT Operational PIT Test Approach & Plan (PIT) submitted to Programme for assurance | milestone | 0d | 2024-09-27 | 2024-09-27 |  |  |  | 2024-06-14 | 2024-06-14 | 0d |  |  | 0d |  | start no earlier than 2024-09-27 |  | PP | SI Test | 5.8 | Roger Robar | Design, Build & Test (PIT) | Red | RED | T3-DB-0159 | SITAG | T3 |  | 7.33 |  |
| 353 | 1.3.6.3.3.8.1.2 | SIT Operational Test approach and plan MHHS Review Completed | milestone | 0d | 2024-11-21 | 2024-11-21 | 352FS+40d |  |  | 2024-08-08 | 2024-08-08 | 0d |  |  | 31856d | 21d |  |  | SI Test | PP | 5.8 | Roger Robar | Design, Build & Test (PIT) | Red | RED | T3-DB-0160 | SITAG | T3 |  | 62.71 |  |
| 354 | 1.3.6.3.3.8.2 | **Test Readiness Report** |  | 13d | 2024-10-04 A | 2024-10-22 |  | 42% | 7.5d | 2024-06-28 | 2024-09-06 | 51d |  |  | 0d |  |  |  | N/A | N/A | 5.2 | N/A | Design, Build & Test (PIT) |  |  |  |  |  |  |  |  |
| 355 | 1.3.6.3.3.8.2.1 | Test readiness reporting |  | 13d | 2024-10-04 A | 2024-10-22 | 352FS+10d | 42% | 7.5d | 2024-06-28 | 2024-09-06 | 51d |  |  | 0d |  |  |  | PP | 109 | 5.2 |  | Design, Build & Test (PIT) | Red | RED |  |  |  |  |  |  |
| 356 | 1.3.6.3.3.8.3 | **Requirements to test Traceability Matrix (RTTM)** |  | 20d | 2024-11-01 | 2024-11-29 |  |  |  | 2024-07-04 | 2024-08-15 | 30d |  |  | 31850d |  |  | -0 | N/A | N/A | 5.2 | N/A | Design, Build & Test (PIT) |  |  |  |  |  |  |  |  |
| 357 | 1.3.6.3.3.8.3.1 | SIT Operational PIT RTTM submitted to Programme for assurance | milestone | 0d | 2024-11-01 | 2024-11-01 | 352FS+26d |  |  | 2024-07-04 | 2024-07-04 | 0d |  |  | 31850d | 0d |  |  | PP | SI Test | 5.8 | Roger Robar | Design, Build & Test (PIT) | Red | RED | T3-DB-0161 | SITAG | T3 |  | 42.71 | dependent on the PPs |
| 358 | 1.3.6.3.3.8.3.2 | SIT Operational RTTM MHHS Review Completed | milestone | 0d | 2024-11-29 | 2024-11-29 | 357FS+20d |  |  | 2024-08-15 | 2024-08-15 | 0d |  |  | 31850d | 15d |  |  | SI Test | PP | 5.8 | Roger Robar | Design, Build & Test (PIT) | Red | RED | T3-DB-0162 | SITAG | T3 |  | 70.71 |  |

Notes:
- 335: 34/34 plans have been submitted to the Programme. Because of the delay to all plans being submitted there is an increased risk to completion of SIT Non-Functional PIT. Re-forecasting the completion date isnt possible as delivery is dependent on the PPs
- 336: 14/34 test approaches completed. Late because the completion of the review is dependant on the delivery of all of the SIT Non-Functional Test Approach and Plans from the PPs. This increases the risk to SIT Non-Functional PIT completion
- 340: 33/34 RTTMs have been submitted to the Programme. Because of the delay to all RTTMs being submitted there is an increased risk to completion of SIT Non-Functional PIT. Re-forecasting the completion date isnt possible as delivery is dependent on the PPs. Engagement taking place for remaining PPs.
- 341: 18/34 reviewed. As per T3-DB-0153, Status red until remaining RTTMs submitted and reviewed.
- 343: 29/34 test scenarios have been submitted to the Programme. Because of the delay to all test scenarios being submitted there is an increased risk to completion of SIT Non-Functional PIT. Re-forecasting the completion date isnt possible as delivery is dependent on the PPs. Engagement taking place for remaining PPs
- 344: 16/34 scenarios have been completed. Date missed because the completion of the review is dependent on the delivery of all of the SIT Non-Functional Test Scenarios from the PPs. This increases the risk to SIT Non-Functional PIT completion
- 348: 18/34 SIT Non-Functional PIT RTTMs have been submitted to the Programme. Because of the delay to all RTTMs being submitted there is an increased risk to completion of SIT Operational PIT. Re-forecasting the completion date isnt possible as delivery is dependent on the PPs. Engagement taking place for remaining PPs.
- 349: 3/34 reviewed. As per T3-DB-0157. Status red until remaining PIT Test Approach and Plans submitted and reviewed.
- 352: 32/34 test approach and plans have been submitted to the Programme. Because of the delay to all Test Approach and plans being submitted there is an increased risk to completion of SIT Operational PIT. Re-forecasting the completion date isnt possible as delivery is dependent~on the PPs. Engagement taking place for remaining PPs
- 353: 19/34 reviewed. As per T3-DB-0159, Status red until remaining PIT Test Approach and Plans submitted and reviewed.
- 357: 23/34 SIT Operational PIT RTTMs have been submitted to the Programme. Because of the delay to all RTTMs being submitted there is an increased risk to completion of SIT Operational PIT. Re-forecasting the completion date isnt possible as delivery is dependent on the PPs. Engagement taking place for remaining PPs.
- 358: 13/34 reviewed. As per T3-DB-0161. Status red until remaining PIT Test Approach and Plans submitted and reviewed.

| ID | WBS | Task | Type | Duration | Start | Finish | Predecessors | Complete | Remaining | Baseline start | Baseline finish | Baseline duration | Baseline 1 start | Baseline 1 finish | Total slack | Free slack | Constraint | Baseline cost | Responsible | Involved | Update Version | MHHS Resource Name | MHHS Programme Phase | Task Status | Sched Status | RAG | Notes (2) | Milestone ID | Text29 | Tier | Artefact ID |
| --- | --- | --- | --- | --- | --- | --- | --- | --- | --- | --- | --- | --- | --- | --- | --- | --- | --- | --- | --- | --- | --- | --- | --- | --- | --- | --- | --- | --- | --- | --- | --- |
| 359 | 1.3.6.3.3.8.4 | **Test Scenarios** |  | 20d | 2024-11-01 | 2024-11-29 |  |  |  | 2024-07-04 | 2024-08-15 | 30d |  |  | 0d |  |  | -0 | N/A | N/A | 5.2 | N/A | Design, Build & Test (PIT) |  |  |  |  |  |  |  |  |
| 360 | 1.3.6.3.3.8.4.1 | SIT Operational PIT test scenarios submitted to Programme for assurance | milestone | 0d | 2024-11-01 | 2024-11-01 | 352FS+26d |  |  | 2024-07-04 | 2024-07-04 | 0d |  |  | 0d |  |  |  | PP | SI Test | 5.8 | Roger Robar | Design, Build & Test (PIT) | 42.71 | Red | RED | date isn’t possible as delivery is dependent on the PPs | T3-DB-0163 | SITAG | T3 |  |
| 361 | 1.3.6.3.3.8.4.2 | SIT Operational Test scenarios MHHS Review Completed | milestone | 0d | 2024-11-29 | 2024-11-29 | 360FS+20d |  |  | 2024-08-15 | 2024-08-15 | 0d |  |  | 31850d | 15d |  |  | SI Test | PP | 5.8 | Roger Robar | Design, Build & Test (PIT) | 70.71 | Red | RED |  | T3-DB-0164 | SITAG | T3 |  |
| 362 | 1.3.6.3.3.8.5 | **PIT execution** |  | 116d | 2024-07-12 A | 2024-12-20 |  | 47% | 61.67d | 2024-07-12 | 2024-09-20 | 51d |  |  | 31835d |  |  | -0 | N/A | N/A | 5.1 | N/A | Design, Build & Test (PIT) |  |  |  |  |  |  |  |  |
| 363 | 1.3.6.3.3.8.5.1 | PIT Test Execution Progress Report |  | 40d | 2024-07-15 A | 2024-11-21 | 355 | 45% | 22d | 2024-07-15 | 2024-09-06 | 40d |  |  | 31841d | 6d |  |  | PP | SI Test | 5.1 | Roger Robar | Design, Build & Test (PIT) |  | Red | RED |  |  |  |  |  |
| 364 | 1.3.6.3.3.8.5.2 | PIT Execution |  | 39d | 2024-07-12 A | 2024-11-29 | 360 | 49% | 20d | 2024-07-12 | 2024-09-06 | 41d |  |  | 31835d | 0d |  |  | PP | SI Test | 5.1 | Roger Robar | Design, Build & Test (PIT) |  | Red | RED |  |  |  |  |  |
| 365 | 1.3.6.3.3.8.5.3 | SIT Operational PIT Completion Report submitted to Programme for assurance | milestone | 0d | 2024-11-29 | 2024-11-29 | 363, 364 |  |  | 2024-09-06 | 2024-09-06 | 0d | 2024-01-05 | 2024-01-05 | 31835d | 0d |  |  | PP | SI Test | 5.10 | Roger Robar | Design, Build & Test (PIT) | 70.71 | Red | RED |  | T3-DB-0165 | SITAG | T3 |  |
| 366 | 1.3.6.3.3.8.5.4 | SIT Operational PIT Completion Report MHHS Review Completed | milestone | 0d | 2024-12-20 | 2024-12-20 | 353, 358, 361, 365FS+15d |  |  | 2024-09-20 | 2024-09-20 | 0d |  |  | 31835d | 20d |  |  | SI Test | PP | 5.8 | Roger Robar | Design, Build & Test (PIT) | 91.71 | Red | RED |  | T3-DB-0166 | SITAG | T3 |  |
| 367 | 1.3.6.3.4 | **All Suppliers DBT CIT (Entering at Interval 5)** |  | 71d | 2023-09-15 A | 2023-12-22 A |  | 100% |  | 2022-10-31 | 2023-12-22 | 300d | 2022-10-31 | 2025-03-14 |  |  |  | -0 | N/A | N/A | 5.0 | N/A | Design, Build & Test (PIT) |  |  |  |  |  |  |  |  |
| 368 | 1.3.6.3.4.1 | **Test Approach & Plan** |  | 20d | 2023-09-15 A | 2023-10-12 A |  | 100% |  | 2023-09-15 | 2023-10-12 | 19d | 2022-10-31 | 2023-09-29 |  |  |  | -0 | N/A | N/A | 5.0 | N/A | Design, Build & Test (PIT) |  |  |  |  |  |  |  |  |
| 369 | 1.3.6.3.4.1.1 | All SIT Suppliers Test Approach & Plans (PIT) submitted to Programme for assurance | milestone | 0d | 2023-09-15 A | 2023-09-15 A |  | 100% |  | 2023-09-15 | 2023-09-15 | 0d | 2023-09-15 | 2023-09-15 |  |  | start no earlier than 2023-09-15 |  | PP | SI Test | 5.8 |  | Design, Build & Test (PIT) |  | Complete | COMPLETE |  | T3-DB-0046 | SITAG | T3 |  |
| 370 | 1.3.6.3.4.1.2 | All SIT Suppliers Test Approach & Plans MHHS Review Completed | milestone | 0d | 2023-10-12 A | 2023-10-12 A | 369FS+20d | 100% |  | 2023-10-12 | 2023-10-12 | 0d | 2023-09-18 | 2023-09-29 |  |  |  |  | SI Test | PP | 5.8 |  | Design, Build & Test (PIT) |  | Complete | COMPLETE |  | T3-DB-0167 | SITAG | T3 |  |
| 371 | 1.3.6.3.4.2 | **Test Readiness Report** |  | 11d | 2023-09-29 A | 2023-10-13 A |  | 100% |  | 2023-09-29 | 2023-12-08 | 51d | 2023-09-29 | 2023-12-08 |  |  |  |  | N/A | N/A | 5.0 | N/A | Design, Build & Test (PIT) |  |  |  |  |  |  |  |  |
| 372 | 1.3.6.3.4.2.1 | Test readiness reporting |  | 11d | 2023-09-29 A | 2023-10-13 A | 369FS+10d | 100% |  | 2023-09-29 | 2023-12-08 | 51d | 2023-09-29 | 2023-12-08 |  |  |  |  | PP | 109 | 5.0 |  | Design, Build & Test (PIT) |  | Complete | COMPLETE |  |  |  |  |  |
| 373 | 1.3.6.3.4.3 | **Requirements to test Traceability Matrix (RTTM)** |  | 20d | 2023-10-06 A | 2023-11-03 A |  | 100% |  | 2023-10-06 | 2023-11-03 | 21d | 2022-10-31 | 2023-10-20 |  |  |  | -0 | N/A | N/A | 5.0 | N/A | Design, Build & Test (PIT) |  |  |  |  |  |  |  |  |
| 374 | 1.3.6.3.4.3.1 | All SIT Suppliers RTTMs submitted to Programme for assurance | milestone | 0d | 2023-10-06 A | 2023-10-06 A | 369FS+16d | 100% |  | 2023-10-06 | 2023-10-06 | 1d | 2023-10-06 | 2023-10-06 |  |  |  |  | PP | SI Test | 5.8 |  | Design, Build & Test (PIT) |  | Complete | COMPLETE |  | T3-DB-0064 | SITAG | T3 | MHHS-ART009 |
| 375 | 1.3.6.3.4.3.2 | All SIT Suppliers RTTMs MHHS Review Completed | milestone | 0d | 2023-11-03 A | 2023-11-03 A | 374FS+20d | 100% |  | 2023-11-03 | 2023-11-03 | 0d | 2023-10-09 | 2023-10-20 |  |  |  |  | SI Test | PP | 5.14 |  | Design, Build & Test (PIT) |  | Complete | COMPLETE |  | T3-DB-0168 | SITAG | T3 |  |
| 376 | 1.3.6.3.4.4 | **Test Scenarios** |  | 20d | 2023-10-05 A | 2023-11-02 A |  | 100% |  | 2023-10-05 | 2023-11-02 | 20d | 2022-10-31 | 2023-10-20 |  |  |  | -0 | N/A | N/A | 5.0 | N/A | Design, Build & Test (PIT) |  |  |  |  |  |  |  |  |
| 377 | 1.3.6.3.4.4.1 | All SIT Suppliers test scenarios' submitted to Programme for assurance | milestone | 0d | 2023-10-05 A | 2023-10-05 A | 369FS+15d | 100% |  | 2023-10-05 | 2023-10-05 | 0d | 2023-10-06 | 2023-10-06 |  |  |  |  | PP | SI Test | 5.8 |  | Design, Build & Test (PIT) |  | Complete | COMPLETE |  | T3-DB-0037 | SITAG | T3 |  |
| 378 | 1.3.6.3.4.4.2 | All SIT Suppliers Test scenarios' MHHS Review Completed | milestone | 0d | 2023-11-02 A | 2023-11-02 A | 377FS+20d | 100% |  | 2023-11-02 | 2023-11-02 | 0d | 2023-10-09 | 2023-10-20 |  |  |  |  | SI Test | PP | 5.14 |  | Design, Build & Test (PIT) |  | Complete | COMPLETE |  | T3-DB-0169 | SITAG | T3 |  |
| 379 | 1.3.6.3.4.5 | **PIT execution** |  | 51d | 2023-10-13 A | 2023-12-22 A |  | 100% |  | 2022-10-31 | 2023-12-22 | 300d | 2022-10-31 | 2023-12-08 |  |  |  | -0 | N/A | N/A | 5.0 | N/A | Design, Build & Test (PIT) |  |  |  |  |  |  |  |  |
| 380 | 1.3.6.3.4.5.1 | PIT Test Execution Progress Report |  | 40d | 2023-10-16 A | 2023-12-08 A | 377FS+5d, 372 | 100% |  | 2023-10-16 | 2023-12-08 | 40d | 2022-10-31 | 2023-12-01 |  |  |  |  | PP | SI Test | 5.0 |  | Design, Build & Test (PIT) |  | Complete | COMPLETE |  |  |  |  |  |
| 381 | 1.3.6.3.4.5.2 | PIT Execution |  | 41d | 2023-10-13 A | 2023-12-08 A | 377FS+5d | 100% |  | 2022-10-31 | 2023-12-08 | 290d | 2022-10-31 | 2023-12-08 |  |  |  |  | PP | SI Test | 5.0 |  | Design, Build & Test (PIT) |  | Complete | COMPLETE |  |  |  |  |  |
| 382 | 1.3.6.3.4.5.3 | All SIT Suppliers PIT Completion Reports submitted to Programme for assurance | milestone | 0d | 2023-12-08 A | 2023-12-08 A | 381, 380 | 100% |  | 2023-12-08 | 2023-12-08 | 0d | 2024-01-05 | 2024-01-05 |  |  |  |  | PP | SI Test | 5.14 |  | Design, Build & Test (PIT) |  | Complete | COMPLETE |  | T3-DB-0170 | SITAG | T3 |  |
| 383 | 1.3.6.3.4.5.4 | All SIT Suppliers PIT Completion Reports MHHS Review Completed | milestone | 0d | 2023-12-22 A | 2023-12-22 A | 382FS+10d, 370, 375, 378 | 100% |  | 2023-12-22 | 2023-12-22 | 0d |  |  |  |  |  |  | SI Test | PP | 5.14 |  | Design, Build & Test (PIT) |  | Complete | COMPLETE |  | T3-DB-0171 | SITAG | T3 |  |

Notes:
- 360: 22/34 SIT Operational PIT test scenarios have been submitted to the Programme. Because of the delay to all SIT Operational PIT test scenarios being submitted there is increased risk to the completion of SIT Operational PIT. Re-forecasting the completion date isnt possible as delivery is dependent on the PPs. Engagement taking place for remaining PPs
- 361: 13/34 reviewed. As per T3-DB-0163. Status red until remaining PIT Test Approach and Plans submitted and reviewed.
- 365: 19/08/24 - Date at risk because of potential delay to submissions for SIT Operational PIT completion reports. Impact may be a delay to the start of SIT Operational Testing. Bilaterals scheduled for week commencing 19/8.
- 366: Date at risk because of potential delay to submissions for SIT Operational PIT completion reports. Impact may be a delay to the start of SIT Operational Testing. Continue engagement with PPs
- 369: 12/9 - TMAG for name change Red because 7/9 received. Approved at TMAG on 20/9
- 370: 7/11 - Red due to high volume to be reviewed. Date change under consideration. Initial reviews complete. Final review will be completed no later than 08/01/24 ahead of Interval 5 Readiness Assessment
- 374: 12/9 - TMAG for name change. Approved at TMAG on 20/9. 10/10 - Red because small number of RTTMs still outstanding
- 375: 17/10 - Red because open comments still outstanding. Assurance reviews complete. Review will be completed no later than 08/01/24 ahead of Interval 5 Readiness Report . Completed on 14/12
- 377: 12/9 - TMAG for name change. Approved at TMAG on 20/9. 10/10 - Red because small number of Test Scenarios still outstanding
- 378: 1/9 - to be raised as new T3 at TMAG. Approved at TMAG on 20/9. 17/10 - Red due to high volume and backlog to be reviewed. Review will be completed no later than 08/01/24 ahead of Interval 5 Readiness Report. Completed 14/12
- 382: 1/9 - to be raised as new T3 at TMAG. Approved at TMAG on 20/9. 12/12 - Red because not all received. No impact as of yet. No action. Completed 12/12
- 383: 1/9 - to be raised as new T3 at TMAG. Approved at TMAG on 20/9. 12/12 - Amber because not all artefacts received. No impact. No action. Completed 15/12

| ID | WBS | Task | Type | Duration | Start | Finish | Predecessors | Complete | Actual start | Actual finish | Baseline start | Baseline finish | Baseline duration | Baseline 1 start | Baseline 1 finish | Constraint | Baseline cost | Responsible | Involved | Update Version | MHHS Resource Name | MHHS Programme Phase | Sched Status | RAG | Milestone ID | Text29 | Tier | Artefact ID |
| --- | --- | --- | --- | --- | --- | --- | --- | --- | --- | --- | --- | --- | --- | --- | --- | --- | --- | --- | --- | --- | --- | --- | --- | --- | --- | --- | --- | --- |
| 384 | 1.3.6.3.5 | **All LDSO Network Operations DBT CIT (Entering at Interval 5)** |  | 71d | 2023-09-15 A | 2023-12-22 A |  | 100% |  |  | 2022-10-31 | 2024-01-05 | 310d | 2022-10-31 | 2025-03-14 |  | -0 | N/A | N/A | 5.0 | N/A | Design, Build & Test (PIT) |  |  |  |  |  |  |
| 385 | 1.3.6.3.5.1 | **Test Approach & Plan** |  | 71d | 2023-09-15 A | 2023-12-22 A |  | 100% |  |  | 2022-10-31 | 2024-01-05 | 310d | 2022-10-31 | 2023-08-11 |  | -0 | N/A | N/A | 5.0 | N/A | Design, Build & Test (PIT) |  |  |  |  |  |  |
| 386 | 1.3.6.3.5.1.1 | All Network Operation Test Approach & Plans (PIT) submitted to Programme for assurance | milestone | 0d | 2023-09-15 A | 2023-09-15 A |  | 100% |  |  | 2023-09-15 | 2023-09-15 | 0d | 2023-07-28 | 2023-07-28 | start no earlier than 2023-09-15 |  | PP | SI Test | 5.8 |  | Design, Build & Test (PIT) | Complete | COMPLETE | T3-DB-0054 | SITAG | T3 |  |
| 387 | 1.3.6.3.5.1.2 | All Network Operation Test Approach & Plans MHHS Review Completed | milestone | 0d | 2023-10-12 A | 2023-10-12 A | 386FS+20d | 100% |  |  | 2023-10-12 | 2023-10-12 | 0d | 2023-07-31 | 2023-08-11 |  |  | SI Test | PP | 5.8 |  | Design, Build & Test (PIT) | Complete | COMPLETE | T3-DB-0172 | SITAG | T3 |  |
| 388 | 1.3.6.3.5.1.3 | **Test Readiness Report** |  | 11d | 2023-09-29 A | 2023-10-13 A |  | 100% |  |  | 2023-08-11 | 2023-10-20 | 51d | 2023-08-11 | 2023-10-20 |  |  | N/A | N/A | 5.0 | N/A | Design, Build & Test (PIT) |  |  |  |  |  |  |
| 389 | 1.3.6.3.5.1.3.1 | Test readiness reporting |  | 11d | 2023-09-29 A | 2023-10-13 A | 386FS+10d | 100% |  |  | 2023-08-11 | 2023-10-20 | 51d | 2023-08-11 | 2023-10-20 |  |  | PP | 109 | 5.0 |  | Design, Build & Test (PIT) | Complete | COMPLETE |  |  |  |  |
| 390 | 1.3.6.3.5.1.4 | **Requirements to test Traceability Matrix (RTTM)** |  | 20d | 2023-10-05 A | 2023-11-02 A |  | 100% |  |  | 2023-10-05 | 2023-11-02 | 20d | 2022-10-31 | 2023-09-15 |  | -0 | N/A | N/A | 5.0 | N/A | Design, Build & Test (PIT) |  |  |  |  |  |  |
| 391 | 1.3.6.3.5.1.4.1 | All Network Operation RTTMs submitted to Programme for assurance | milestone | 0d | 2023-10-05 A | 2023-10-05 A | 386FS+15d | 100% |  |  | 2023-10-05 | 2023-10-05 | 0d | 2023-09-01 | 2023-09-01 | start no earlier than 2023-04-28 |  | PP | SI Test | 5.8 |  | Design, Build & Test (PIT) | Complete | COMPLETE | T3-DB-0062 | SITAG | T3 | MHHS-ART009 |
| 392 | 1.3.6.3.5.1.4.2 | All Network Operation RTTMs MHHS Review Completed | milestone | 0d | 2023-11-02 A | 2023-11-02 A | 391FS+20d | 100% |  |  | 2023-11-02 | 2023-11-02 | 0d | 2023-09-04 | 2023-09-15 |  |  | SI Test | PP | 5.14 |  | Design, Build & Test (PIT) | Complete | COMPLETE | T3-DB-0173 | SITAG | T3 |  |
| 393 | 1.3.6.3.5.1.5 | **Test Scenarios** |  | 20d | 2023-10-05 A | 2023-11-02 A |  | 100% |  |  | 2023-10-05 | 2023-11-02 | 20d | 2022-10-31 | 2023-09-15 |  | -0 | N/A | N/A | 5.0 | N/A | Design, Build & Test (PIT) |  |  |  |  |  |  |
| 394 | 1.3.6.3.5.1.5.1 | All Network Operation test scenarios' submitted to Programme for assurance | milestone | 0d | 2023-10-05 A | 2023-10-05 A | 386FS+15d | 100% |  |  | 2023-10-05 | 2023-10-05 | 0d | 2023-09-01 | 2023-09-01 |  |  | PP | SI Test | 5.8 |  | Design, Build & Test (PIT) | Complete | COMPLETE | T3-DB-0011 | SITAG | T3 |  |
| 395 | 1.3.6.3.5.1.5.2 | All Network Operation test scenarios' MHHS Review Completed | milestone | 0d | 2023-11-02 A | 2023-11-02 A | 394FS+20d | 100% |  |  | 2023-11-02 | 2023-11-02 | 0d | 2023-09-04 | 2023-09-15 |  |  | SI Test | PP | 5.14 |  | Design, Build & Test (PIT) | Complete | COMPLETE | T3-DB-0174 | SITAG | T3 |  |
| 396 | 1.3.6.3.5.1.6 | **PIT execution** |  | 51d | 2023-10-13 A | 2023-12-22 A |  | 100% |  |  | 2022-10-31 | 2024-01-05 | 310d | 2022-10-31 | 2024-01-05 |  | -0 | N/A | N/A | 5.0 | N/A | Design, Build & Test (PIT) |  |  |  |  |  |  |
| 397 | 1.3.6.3.5.1.6.1 | PIT Test Execution Progress Report |  | 40d | 2023-10-16 A | 2023-12-08 A | 394FS+5d, 389 | 100% |  |  | 2022-10-31 | 2023-12-29 | 305d | 2022-10-31 | 2023-12-29 |  |  | PP | SI Test | 5.0 |  | Design, Build & Test (PIT) | Complete | COMPLETE |  |  |  |  |
| 398 | 1.3.6.3.5.1.6.2 | PIT Execution |  | 41d | 2023-10-13 A | 2023-12-08 A | 394FS+5d | 100% |  |  | 2022-10-31 | 2024-01-05 | 310d | 2022-10-31 | 2024-01-05 |  |  | PP | SI Test | 5.0 |  | Design, Build & Test (PIT) | Complete | COMPLETE |  |  |  |  |
| 399 | 1.3.6.3.5.1.6.3 | All Network Operation PIT (CIT interval 5) Completion Reports submitted to Programme for assurance | milestone | 0d | 2023-12-08 A | 2023-12-08 A | 398, 397 | 100% |  |  | 2023-12-08 | 2023-12-08 | 0d | 2024-01-05 | 2024-01-05 |  |  | PP | SI Test | 5.0 |  | Design, Build & Test (PIT) | Complete | COMPLETE | T3-DB-0175 | SITAG | T3 |  |
| 400 | 1.3.6.3.5.1.6.4 | All Network Operation PIT (CIT interval 5) Completion Reports MHHS Review Completed | milestone | 0d | 2023-12-22 A | 2023-12-22 A | 399FS+10d, 387, 392, 395 | 100% |  |  | 2023-12-22 | 2023-12-22 | 0d |  |  |  |  | SI Test | PP | 5.15 |  | Design, Build & Test (PIT) | Complete | COMPLETE | T3-DB-0176 | SITAG | T3 |  |
| 401 | 1.3.6.3.6 | **All UMSO DBT CIT (Entering at Interval 6)** |  | 81d | 2023-09-29 | 2024-01-19 A |  | 100% | 2023-10-13 |  | 2022-10-31 | 2024-01-19 | 320d | 2022-10-31 | 2024-05-13 |  | -0 | N/A | N/A | 5.0 | N/A | Design, Build & Test (PIT) |  |  |  |  |  |  |
| 402 | 1.3.6.3.6.1 | **Test Approach & Plan** |  | 20d | 2023-10-13 A | 2023-11-09 A |  | 100% |  |  | 2023-09-15 | 2023-11-09 | 40d | 2022-10-31 | 2023-09-29 |  | -0 | N/A | N/A | 5.0 | N/A | Design, Build & Test (PIT) |  |  |  |  |  |  |
| 403 | 1.3.6.3.6.1.1 | All UMSO Test Approach & Plans (PIT) submitted to Programme for assurance | milestone | 0d | 2023-10-13 A | 2023-10-13 A |  | 100% |  |  | 2023-09-15 | 2023-09-15 | 0d | 2023-09-15 | 2023-09-15 | start no earlier than 2023-10-13 |  | PP | SI Test | 5.11 |  | Design, Build & Test (PIT) | Complete | COMPLETE | T3-DB-0052 | SITAG | T3 |  |
| 404 | 1.3.6.3.6.1.2 | All UMSO Test Approach & Plans MHHS Review Completed | milestone | 0d | 2023-11-09 A | 2023-11-09 A | 403FS+20d | 100% |  |  | 2023-11-09 | 2023-11-09 | 0d | 2023-09-18 | 2023-09-29 |  |  | SI Test | PP | 5.10 |  | Design, Build & Test (PIT) | Complete | COMPLETE | T3-DB-0177 | SITAG | T3 |  |
| 405 | 1.3.6.3.6.2 | **Test Readiness Report** |  | 11d | 2023-09-29 | 2023-10-13 |  | 100% | 2023-10-27 | 2023-11-10 | 2023-10-27 | 2023-11-10 | 11d | 2023-09-29 | 2023-12-08 |  | -0 | N/A | N/A | 5.0 | N/A | Design, Build & Test (PIT) |  |  |  |  |  |  |
| 406 | 1.3.6.3.6.2.1 | Test readiness reporting |  | 11d | 2023-10-27 A | 2023-11-10 A | 403FS+10d | 100% |  |  | 2023-10-27 | 2023-11-10 | 11d | 2023-09-29 | 2023-12-08 |  |  | PP | 109 | 5.0 |  | Design, Build & Test (PIT) | Complete | COMPLETE |  |  |  |  |
| 407 | 1.3.6.3.6.3 | **Requirements to test Traceability Matrix (RTTM)** |  | 20d | 2023-10-05 | 2023-11-01 |  | 100% | 2023-11-02 | 2023-11-30 | 2023-11-02 | 2023-11-30 | 20d | 2022-10-31 | 2023-10-20 |  | -0 | N/A | N/A | 5.0 | N/A | Design, Build & Test (PIT) |  |  |  |  |  |  |
| 408 | 1.3.6.3.6.3.1 | All UMSO RTTMs submitted to Programme for assurance | milestone | 0d | 2023-11-02 A | 2023-11-02 A | 403FS+15d | 100% |  |  | 2023-11-02 | 2023-11-02 | 0d | 2023-10-06 | 2023-10-06 |  |  | PP | SI Test | 5.12 |  | Design, Build & Test (PIT) | Complete | COMPLETE | T3-DB-0060 | SITAG | T3 | MHHS-ART009 |
| 409 | 1.3.6.3.6.3.2 | All UMSO RTTMs MHHS Review Completed | milestone | 0d | 2023-11-30 A | 2023-11-30 A | 408FS+20d | 100% |  |  | 2023-11-30 | 2023-11-30 | 0d | 2023-10-09 | 2023-10-20 |  |  | SI Test | PP | 5.12 |  | Design, Build & Test (PIT) | Complete | COMPLETE | T3-DB-0178 | SITAG | T3 |  |

Notes:
- 386: 12/9 - TMAG for name and date change Red because only received 1/2 test approach and plans. Approved at TMAG on 20/9
- 387: 11/9 - to be raised as new T3 at TMAG. Approved at TMAG on 20/9. Red due to high volume to be reviewed. Date change under consideration. Review will be completed no later than 08/01/24 ahead of Interval 5 Readiness Assessment
- 391: 12/9 - TMAG for name and date change Approved at TMAG on 20/9. 10/10 - Red because 50% of RTTMs outstanding
- 392: 17/10 - Red because open comments still outstanding. Assurance reviews complete. Review will be completed no later than 08/01/24 ahead of Interval 5 Readiness Report . 19/12 - completed 14/12
- 394: 12/9 - TMAG for name and date change. Approved at TMAG on 20/9. 17/10 - Red because currently 50% have been received. Date change under consideration.
- 395: 17/10 - Red because open comments still outstanding. Assurance reviews complete. Review will be completed no later than 08/01/24 ahead of Interval 5 Readiness Assessment . 19/12 - completed 14/12
- 399: 11/9 - to be raised as new T3 at TMAG. Approved at TMAG on 20/9. 19/12 - completed 14/12
- 400: 11/9 - to be raised as new T3 at TMAG. Approved at TMAG on 20/9. 12/12 - Amber because all reviews complete, clarifications are requested
- 403: 12/9 - TMAG for name and date change. Approved at TMAG on 20/9. 17/10 - Red because not all received. Currently no impact. Issuance request sent. Complete 1/11
- 404: To go to TMAG for date change. Approved for date change at TMAG on 23/10/23. 7/11-Amber because of high volume and backlog to be reviewed. Review will be completed no later than 22/01/24 ahead of Interval 6 Readiness Assessment
- 408: 4/10 - Red because baseline date incorrect. To go to TMAG for date change. Approved for date change at TMAG on 23/10/23. 14/11-Red because up to 50% not received. No impact. No action
- 409: 1/9 - to be raised as new T3 at TMAG. Approved at TMAG on 20/9. 4/10 - Red because baseline date incorrect. To go to TMAG for date change. Approved for date change at TMAG on 23/10/23

| ID | WBS | Task | Type | Duration | Start | Finish | Predecessors | Complete | Remaining | Actual start | Actual finish | Baseline start | Baseline finish | Baseline duration | Baseline 1 start | Baseline 1 finish | Total slack | Constraint | Baseline cost | Responsible | Involved | Update Version | MHHS Resource Name | MHHS Programme Phase | Sched Status | RAG | Milestone ID | Text29 | Tier | Task Status |
| --- | --- | --- | --- | --- | --- | --- | --- | --- | --- | --- | --- | --- | --- | --- | --- | --- | --- | --- | --- | --- | --- | --- | --- | --- | --- | --- | --- | --- | --- | --- |
| 410 | 1.3.6.3.6.4 | **Test Scenarios** |  | 20d | 2023-10-05 | 2023-11-01 |  | 100% |  | 2023-11-02 | 2023-11-30 | 2023-11-02 | 2023-11-30 | 20d | 2022-10-31 | 2023-10-20 |  |  | -0 | N/A | N/A | 5.0 | N/A | Design, Build & Test (PIT) |  |  |  |  |  |  |
| 411 | 1.3.6.3.6.4.1 | All UMSO test scenarios' submitted to Programme for assurance | milestone | 0d | 2023-11-02 A | 2023-11-02 A | 403FS+15d | 100% |  |  |  | 2023-11-02 | 2023-11-02 | 0d | 2023-10-06 | 2023-10-06 |  |  |  | PP | SI Test | 5.12 |  | Design, Build & Test (PIT) | Complete | COMPLETE | T3-DB-0025 | SITAG | T3 |  |
| 412 | 1.3.6.3.6.4.2 | All UMSO Test scenarios' MHHS Review Completed | milestone | 0d | 2023-11-30 A | 2023-11-30 A | 411FS+20d | 100% |  |  |  | 2023-11-30 | 2023-11-30 | 0d | 2023-10-09 | 2023-10-20 |  |  |  | SI Test | PP | 5.10 |  | Design, Build & Test (PIT) | Complete | COMPLETE | T3-DB-0179 | SITAG | T3 |  |
| 413 | 1.3.6.3.6.5 | **PIT execution** |  | 51d | 2023-11-10 A | 2024-01-19 A |  | 100% |  |  |  | 2022-10-31 | 2024-01-19 | 320d | 2022-10-31 | 2023-12-08 |  |  | -0 | N/A | N/A | 5.0 | N/A | Design, Build & Test (PIT) |  |  |  |  |  |  |
| 414 | 1.3.6.3.6.5.1 | PIT Test Execution Progress Report |  | 40d | 2023-11-13 A | 2024-01-05 A | 411FS+5d, 406 | 100% |  |  |  | 2023-11-13 | 2024-01-05 | 40d | 2022-10-31 | 2023-12-01 |  |  |  | PP | SI Test | 5.0 |  | Design, Build & Test (PIT) | Complete | COMPLETE |  |  |  |  |
| 415 | 1.3.6.3.6.5.2 | PIT Execution |  | 40d | 2023-11-10 A | 2024-01-04 A | 411FS+5d | 100% |  |  |  | 2022-10-31 | 2024-01-05 | 290d | 2022-10-31 | 2023-12-08 |  |  |  | PP | SI Test | 5.0 |  | Design, Build & Test (PIT) | Complete | COMPLETE |  |  |  |  |
| 416 | 1.3.6.3.6.5.3 | All UMSO PIT (CIT interval 6) Completion Reports submitted to Programme for assurance | milestone | 0d | 2024-01-05 A | 2024-01-05 A | 415, 414 | 100% |  |  |  | 2024-01-05 | 2024-01-05 | 0d | 2024-01-05 | 2024-01-05 |  |  |  | PP | SI Test | 5.10 |  | Design, Build & Test (PIT) | Complete | COMPLETE | T3-DB-0180 | SITAG | T3 |  |
| 417 | 1.3.6.3.6.5.4 | All UMSO PIT (CIT interval 6) Completion Reports MHHS Review Completed | milestone | 0d | 2024-01-19 A | 2024-01-19 A | 404, 409, 412, 416FS+10d | 100% |  |  |  | 2024-01-19 | 2024-01-19 | 0d |  |  |  |  |  | SI Test | PP | 5.10 |  | Design, Build & Test (PIT) | Complete | COMPLETE | T3-DB-0181 | SITAG | T3 |  |
| 418 | 1.3.7 | **DBT Monitoring and Assurance** |  | 842d | 2022-10-31 A | 2026-01-20 |  | 64% | 301d |  |  | 2022-10-31 | 2026-01-20 | 842d | 2022-10-31 | 2026-01-19 | 32245d |  |  | N/A | N/A | 5.0 | N/A | Design, Build & Test (PIT) |  |  |  |  |  |  |
| 419 | 1.3.7.1 | **Planning and DBT Progress Monitoring of PPs** |  | 696d | 2022-10-31 A | 2025-06-30 |  | 67% | 233d |  |  | 2022-10-31 | 2025-06-30 | 696d | 2022-10-31 | 2025-06-30 | 32391d |  |  | N/A | N/A | 5.0 | N/A | Design, Build & Test (PIT) |  |  |  |  |  | M9 |
| 420 | 1.3.7.1.1 | Monitor Non-SIT PPs Planning and DBT1 progress (to inform confirmation of Qualification Testing Tranche participants milestones) |  | 696d | 2022-10-31 A | 2025-06-30 | 166SS | 67% | 233d |  |  | 2022-10-31 | 2025-06-30 | 696d | 2022-10-31 | 2025-06-30 | 32391d |  |  | Code Bodies | SI Test,PPC | 5.0 | Roger Robar | Design, Build & Test (PIT) | Green | GREEN |  |  |  |  |
| 421 | 1.3.7.2 | **DBT Progress Monitoring of Consequential Change** |  | 774d | 2023-02-02 A | 2026-01-20 |  | 51% | 379d |  |  | 2023-02-02 | 2026-01-20 | 774d | 2023-02-01 | 2026-01-19 | 32245d |  |  | N/A | N/A | 5.0 | N/A | Design, Build & Test (PIT) |  |  |  |  |  | M9 |
| 422 | 1.3.7.2.1 | Monitor & report data cleanse progress |  | 774d | 2023-02-02 A | 2026-01-20 |  | 51% | 379d |  |  | 2023-02-02 | 2026-01-20 | 774d | 2023-02-01 | 2026-01-19 | 32245d |  |  | SI Test | PPC | 5.0 | Matthew Breen | Design, Build & Test (PIT) | Green | GREEN |  |  |  |  |
| 423 | 1.3.7.3 | **Design Assurance** |  | 713d | 2022-11-14 A | 2025-08-06 |  | 71% | 206.27d |  |  | 2022-11-14 | 2025-08-06 | 713d | 2022-11-14 | 2025-08-06 | 32364d |  |  | N/A | N/A | 5.0 | N/A | Design, Build & Test (PIT) |  |  |  |  |  | M9 |
| 424 | 1.3.7.3.1 | **Design Assurance Readiness Assessment Preparation** |  | 39d | 2023-02-28 A | 2023-04-21 A |  | 100% |  |  |  | 2023-02-28 | 2023-04-21 | 39d | 2023-02-28 | 2023-04-21 |  |  |  | N/A | N/A | 5.0 | N/A | Design, Build & Test (PIT) |  |  |  |  |  |  |
| 425 | 1.3.7.3.1.1 | Set up FTIG |  | 15d | 2023-04-03 A | 2023-04-21 A |  | 100% |  |  |  | 2023-04-03 | 2023-04-21 | 15d | 2023-04-03 | 2023-04-21 |  | must start on 2023-04-03 |  | SI Design |  | 5.0 | Paul Pettitt | Design, Build & Test (PIT) | Complete | COMPLETE |  |  |  |  |
| 426 | 1.3.7.3.1.2 | Produce Draft Questions |  | 10d | 2023-02-28 A | 2023-03-13 A |  | 100% |  |  |  | 2023-02-28 | 2023-03-13 | 10d | 2023-02-28 | 2023-03-13 |  | must start on 2023-02-28 |  | SI Design |  | 5.0 | Paul Pettitt | Design, Build & Test (PIT) | Complete | COMPLETE |  |  |  |  |
| 427 | 1.3.7.3.1.3 | Pilot with SRO |  | 1d | 2023-03-14 A | 2023-03-14 A | 426 | 100% |  |  |  | 2023-03-14 | 2023-03-14 | 1d | 2023-03-14 | 2023-03-14 |  |  |  | SI Design |  | 5.0 | Paul Pettitt | Design, Build & Test (PIT) | Complete | COMPLETE |  |  |  |  |
| 428 | 1.3.7.3.1.4 | Finalise questions |  | 10d | 2023-03-15 A | 2023-03-28 A | 427 | 100% |  |  |  | 2023-03-15 | 2023-03-28 | 10d | 2023-03-15 | 2023-03-28 |  |  |  | SI Design |  | 5.0 | Paul Pettitt | Design, Build & Test (PIT) | Complete | COMPLETE |  |  |  |  |
| 429 | 1.3.7.3.1.5 | Prepare on-line RA tooling |  | 10d | 2023-03-29 A | 2023-04-11 A | 428 | 100% |  |  |  | 2023-03-29 | 2023-04-11 | 10d | 2023-03-29 | 2023-04-11 |  |  |  | SI Design |  | 5.0 | Paul Pettitt | Design, Build & Test (PIT) | Complete | COMPLETE |  |  |  |  |
| 430 | 1.3.7.3.1.6 | Prepare webinar content |  | 5d | 2023-03-20 A | 2023-03-24 A | 426FS+4d | 100% |  |  |  | 2023-03-20 | 2023-03-24 | 5d | 2023-03-20 | 2023-03-24 |  |  |  | SI Design |  | 5.0 | Paul Pettitt | Design, Build & Test (PIT) | Complete | COMPLETE |  |  |  |  |
| 431 | 1.3.7.3.1.7 | Conduct webinar |  | 1d | 2023-03-30 A | 2023-03-30 A | 430FS+3d | 100% |  |  |  | 2023-03-30 | 2023-03-30 | 1d | 2023-03-30 | 2023-03-30 |  |  |  | SI Design | PP | 5.0 | Paul Pettitt | Design, Build & Test (PIT) | Complete | COMPLETE |  |  |  |  |
| 432 | 1.3.7.3.2 | **Participant Design Assurance Approach** |  | 43d | 2022-11-14 A | 2023-01-11 A |  | 100% |  |  |  | 2022-11-14 | 2023-01-11 | 43d | 2022-11-14 | 2023-01-11 |  |  |  | N/A | N/A | 5.0 | N/A | Design, Build & Test (PIT) |  |  |  |  |  |  |
| 433 | 1.3.7.3.2.1 | Develop document |  | 20d | 2022-11-14 A | 2022-12-09 A | 48FS+10d | 100% |  |  |  | 2022-11-14 | 2022-12-09 | 20d | 2022-11-14 | 2022-12-09 |  | start no earlier than 2022-11-14 |  | SI Design | PP | 5.0 | Paul Pettitt | Design, Build & Test (PIT) | Complete | COMPLETE |  |  |  |  |
| 434 | 1.3.7.3.2.2 | Review document |  | 18d | 2022-12-12 A | 2023-01-04 A | 433 | 100% |  |  |  | 2022-12-12 | 2023-01-04 | 18d | 2022-12-12 | 2023-01-04 |  |  |  | PP | SI Design,IPA | 5.0 | Paul Pettitt | Design, Build & Test (PIT) | Complete | COMPLETE |  |  |  |  |
| 435 | 1.3.7.3.2.3 | Participant Design Assurance Approach approved | milestone | 0d | 2023-01-11 A | 2023-01-11 A | 434FF+5d | 100% |  |  |  | 2023-01-11 | 2023-01-11 | 0d | 2023-01-11 | 2023-01-11 |  |  |  | SI Design | PP | 5.0 | Paul Pettitt | Design, Build & Test (PIT) | Complete | COMPLETE | T3-DB-0012 | DAG | T3 |  |

Notes:
- 411: Approved at TMAG on 20/9. 4/10 - Red because baseline date incorrect. To go to TMAG for date change. Approved for date change at TMAG on 23/10/23. 7/11-Red because not received. Expected 10/11. No impact No action
- 412: 1/9 - to be raised as new T3 at TMAG. Approved at TMAG on 20/9. 5/12 - Assurance review conducted, but outstanding comments to be addressed
- 416: . 4/10 - Red because baseline date incorrect. To go to TMAG for date change. Approved for date change at TMAG on 23/10/23. 16/1 - Not all completion reports yet received. Completed on 21/2
- 417: Red because baseline date incorrect. To go to TMAG for date change. Approved for date change at TMAG on 23/10/23. 16/01 - Late due to late delivery of PP artefacts for review. Completed on 21/2
- 420: 15/9 - hold in plan until qualification sections updated
- 422: 15/9 - query with John Wiggins where this sits

| ID | WBS | Task | Type | Duration | Start | Finish | Predecessors | Complete | Remaining | Baseline start | Baseline finish | Baseline duration | Baseline 1 start | Baseline 1 finish | Total slack | Constraint | Responsible | Involved | Update Version | MHHS Resource Name | MHHS Programme Phase | Sched Status | RAG | Artefact ID | Milestone ID | Text29 | Tier | Task Status |
| --- | --- | --- | --- | --- | --- | --- | --- | --- | --- | --- | --- | --- | --- | --- | --- | --- | --- | --- | --- | --- | --- | --- | --- | --- | --- | --- | --- | --- |
| 436 | 1.3.7.3.3 | **Phase 1 - SIT Volunteers (Core Providers)** |  | 145d | 2023-04-10 A | 2023-10-27 A |  | 100% |  | 2023-04-10 | 2023-10-27 | 145d | 2023-04-10 | 2023-10-27 |  |  | N/A | N/A | 5.0 | N/A | Design, Build & Test (PIT) |  |  |  |  |  |  |  |
| 437 | 1.3.7.3.3.1 | Send on-line questionnaire to core capability providers and current SIT volunteers (from Round 3 consultation) |  | 1d | 2023-04-10 A | 2023-04-10 A |  | 100% |  | 2023-04-10 | 2023-04-10 | 1d | 2023-04-10 | 2023-04-10 |  | must start on 2023-04-10 | SI Design | PP | 5.0 | Paul Pettitt | Design, Build & Test (PIT) | Complete | COMPLETE |  |  |  |  |  |
| 438 | 1.3.7.3.3.2 | Participants Provide Responses to questionnaires |  | 15d | 2023-04-11 A | 2023-05-01 A | 437 | 100% |  | 2023-04-11 | 2023-05-01 | 15d | 2023-04-11 | 2023-05-01 |  |  | PP |  | 5.0 | Paul Pettitt | Design, Build & Test (PIT) | Complete | COMPLETE |  |  |  |  |  |
| 439 | 1.3.7.3.3.3 | Assess on-line responses and provided evidence |  | 5d | 2023-05-02 A | 2023-05-08 A | 438 | 100% |  | 2023-05-02 | 2023-05-08 | 5d | 2023-05-02 | 2023-05-08 |  |  | SI Design |  | 5.0 | Paul Pettitt | Design, Build & Test (PIT) | Complete | COMPLETE |  |  |  |  |  |
| 440 | 1.3.7.3.3.4 | Bi-lateral meeting with each responder, to walk and navigate through provided materials |  | 31d | 2023-05-09 A | 2023-06-20 A | 439 | 100% |  | 2023-05-09 | 2023-06-20 | 31d | 2023-05-09 | 2023-06-20 |  |  | SI Design | PP | 5.0 | Paul Pettitt | Design, Build & Test (PIT) | Complete | COMPLETE |  |  |  |  |  |
| 441 | 1.3.7.3.3.5 | Plan for, create and execute deep dive assurance interviews based on agreed priorities (participants, design areas) |  | 62d | 2023-06-07 A | 2023-08-31 A | 440FS-10d | 100% |  | 2023-06-07 | 2023-08-31 | 62d | 2023-06-07 | 2023-08-01 |  |  | SI Design |  | 5.2 | Paul Pettitt | Design, Build & Test (PIT) | Complete | COMPLETE |  |  |  |  |  |
| 442 | 1.3.7.3.3.6 | SI endorsement of participants’ design – assurance reports |  | 43d | 2023-08-02 A | 2023-09-29 A | 441FS-22d | 100% |  | 2023-08-02 | 2023-09-29 | 43d | 2023-08-02 | 2023-08-15 |  |  | SI Design |  | 5.2 | Paul Pettitt | Design, Build & Test (PIT) | Complete | COMPLETE |  |  |  |  |  |
| 443 | 1.3.7.3.3.7 | Post-assurance review of recommendations take-up by assured participants |  | 44d | 2023-08-29 A | 2023-10-27 A | 442SS+19d | 100% |  | 2023-10-02 | 2023-10-27 | 20d | 2023-08-16 | 2023-10-27 |  |  | SI Design |  | 5.2 | Paul Pettitt | Design, Build & Test (PIT) | Complete | COMPLETE |  |  |  |  |  |
| 444 | 1.3.7.3.3.8 | Phase 1 - SIT Volunteers (Core Providers) complete | milestone | 0d | 2023-10-27 A | 2023-10-27 A | 443 | 100% |  | 2023-10-27 | 2023-10-27 | 0d | 2023-10-27 | 2023-10-27 |  |  | SI Design |  | 5.11 | Paul Pettitt | Design, Build & Test (PIT) | Complete | COMPLETE | MHHS-ART002 | T2-DB-0100 | DAG | T2 |  |
| 445 | 1.3.7.3.4 | **Phase 2 - SIT all other participants** |  | 143d | 2023-05-08 A | 2023-11-22 A |  | 100% |  | 2023-05-08 | 2023-11-22 | 143d | 2023-05-08 | 2023-11-22 |  |  | N/A | N/A | 5.0 | N/A | Design, Build & Test (PIT) |  |  |  |  |  |  |  |
| 446 | 1.3.7.3.4.1 | Send on-line questionnaire to core capability providers and current SIT volunteers (from Round 3 consultation) |  | 1d | 2023-05-08 A | 2023-05-08 A |  | 100% |  | 2023-05-08 | 2023-05-08 | 1d | 2023-05-08 | 2023-05-08 |  | must start on 2023-05-08 | SI Design | PP | 5.0 | Paul Pettitt | Design, Build & Test (PIT) | Complete | COMPLETE |  |  |  |  |  |
| 447 | 1.3.7.3.4.2 | Participants Provide Responses to questionnaires |  | 15d | 2023-05-09 A | 2023-05-29 A | 446 | 100% |  | 2023-05-09 | 2023-05-29 | 15d | 2023-05-09 | 2023-05-29 |  |  | PP |  | 5.0 | Paul Pettitt | Design, Build & Test (PIT) | Complete | COMPLETE |  |  |  |  |  |
| 448 | 1.3.7.3.4.3 | Assess on-line responses and provided evidence |  | 5d | 2023-05-30 A | 2023-06-05 A | 447 | 100% |  | 2023-05-30 | 2023-06-05 | 5d | 2023-05-30 | 2023-06-05 |  |  | SI Design |  | 5.0 | Paul Pettitt | Design, Build & Test (PIT) | Complete | COMPLETE |  |  |  |  |  |
| 449 | 1.3.7.3.4.4 | Bi-lateral meeting with each responder, to walk and navigate through provided materials |  | 84d | 2023-06-06 A | 2023-09-29 A | 448 | 100% |  | 2023-06-06 | 2023-09-29 | 84d | 2023-06-06 | 2023-07-18 |  |  | SI Design | PP | 5.2 | Paul Pettitt | Design, Build & Test (PIT) | Complete | COMPLETE |  |  |  |  |  |
| 450 | 1.3.7.3.4.5 | Plan for, create and execute deep dive assurance interviews based on agreed priorities (participants, design areas) |  | 69d | 2023-06-27 A | 2023-09-29 A | 449SS+15d | 100% |  | 2023-06-27 | 2023-09-29 | 69d | 2023-07-05 | 2023-08-29 |  |  | SI Design |  | 5.2 | Paul Pettitt | Design, Build & Test (PIT) | Complete | COMPLETE |  |  |  |  |  |
| 451 | 1.3.7.3.4.6 | SI endorsement of participants’ design – assurance reports |  | 54d | 2023-07-18 A | 2023-09-29 A | 450SS+15d | 100% |  | 2023-07-18 | 2023-09-29 | 54d | 2023-08-30 | 2023-09-12 |  |  | SI Design |  | 5.2 | Paul Pettitt | Design, Build & Test (PIT) | Complete | COMPLETE |  |  |  |  |  |
| 452 | 1.3.7.3.4.7 | Post-assurance review of recommendations take-up by assured participants |  | 73d | 2023-08-14 A | 2023-11-22 A | 451SS+19d | 100% |  | 2023-10-02 | 2023-11-22 | 38d | 2023-09-13 | 2023-11-22 |  |  | SI Design |  | 5.2 | Paul Pettitt | Design, Build & Test (PIT) | Complete | COMPLETE |  |  |  |  |  |
| 453 | 1.3.7.3.4.8 | SIT PPs design assurance (excl Migration/Reverse Migration) complete | milestone | 0d | 2023-11-22 A | 2023-11-22 A | 452 | 100% |  | 2023-11-22 | 2023-11-22 | 0d | 2023-11-22 | 2023-11-22 |  |  | SI Design |  | 5.11 | Paul Pettitt | Design, Build & Test (PIT) | Complete | COMPLETE | MHHS-ART002 | T2-DB-0200 | DAG | T2 |  |
| 454 | 1.3.7.3.5 | **Non-SIT PPs design assurance** |  | 445d | 2023-11-23 A | 2025-08-06 |  | 33% | 300d | 2023-11-23 | 2025-08-06 | 445d | 2023-11-23 | 2025-08-06 | 32364d |  | N/A | N/A | 5.0 | N/A | Design, Build & Test (PIT) |  |  |  |  |  |  |  |
| 455 | 1.3.7.3.5.1 | Non-SIT PPs design assurance (risk-based sample) |  | 445d | 2023-11-23 A | 2025-08-06 | 453 | 33% | 300d | 2023-11-23 | 2025-08-06 | 445d | 2023-11-23 | 2025-08-06 | 32364d |  | SI Design | PPC | 5.0 | Paul Pettitt | Design, Build & Test (PIT) | Green | GREEN |  |  |  |  |  |
| 456 | 1.3.7.4 | **Test Assurance** |  | 629d | 2023-02-01 A | 2025-06-30 |  | 63% | 233d | 2022-10-31 | 2025-06-30 | 696d | 2022-10-31 | 2025-06-30 | 32391d |  | N/A | N/A | 5.0 | N/A | Design, Build & Test (PIT) |  |  |  |  |  |  | M9 |
| 457 | 1.3.7.4.1 | Non-SIT PPs test assurance |  | 629d | 2023-02-01 A | 2025-06-30 |  | 63% | 233d | 2023-02-01 | 2025-06-30 | 629d | 2023-02-01 | 2025-06-30 | 32391d |  | Code Bodies | PP,PPC,SI Test | 5.0 | Roger Robar | Design, Build & Test (PIT) | Green | GREEN |  |  |  |  |  |
| 458 | 1.3.7.5 | **Pre-Qualification Guidance (PIT Guidance)** |  | 67d | 2022-10-31 A | 2023-01-31 A |  | 100% |  | 2022-10-31 | 2023-01-31 | 67d | 2022-10-31 | 2023-01-31 |  |  | N/A | N/A | 5.0 | N/A | Design, Build & Test (PIT) |  |  |  |  |  |  |  |
| 459 | 1.3.7.5.1 | Develop document (incl. collaboration with code bodies, as required) |  | 56d | 2022-10-31 A | 2023-01-16 A |  | 100% |  | 2022-10-31 | 2023-01-16 | 56d | 2022-10-31 | 2023-01-16 |  |  | SI Test | Code Bodies | 5.0 |  | Design, Build & Test (PIT) | Complete | COMPLETE |  |  |  |  |  |
| 460 | 1.3.7.5.2 | Review, update and agree Pre-Qualification Guidance internally |  | 11d | 2023-01-17 A | 2023-01-31 A | 459 | 100% |  | 2023-01-17 | 2023-01-31 | 11d | 2023-01-17 | 2023-01-31 |  |  | SRO Function | IPA,SI Test | 5.0 |  | Design, Build & Test (PIT) | Complete | COMPLETE |  |  |  |  |  |

Notes:
- 444: 16/10 Awaiting the issuing of backlog reports. But no significant design impacts identified. No impact to commencing SIT
- 452: 6/11 - last report sent out 27/10
- 453: 6/11 - last report sent out 27/10
- 457: 15/9 - keep in plan until qualification reviewed

| ID | WBS | Task | Type | Duration | Start | Finish | Predecessors | Complete | Remaining | Baseline start | Baseline finish | Baseline duration | Baseline 1 start | Baseline 1 finish | Total slack | Constraint | Baseline cost | Responsible | Involved | Update Version | MHHS Resource Name | MHHS Programme Phase | Sched Status | RAG | Text3 | Task Status | Artefact ID | Milestone ID | Text29 | Tier |
| --- | --- | --- | --- | --- | --- | --- | --- | --- | --- | --- | --- | --- | --- | --- | --- | --- | --- | --- | --- | --- | --- | --- | --- | --- | --- | --- | --- | --- | --- | --- |
| 461 | 1.3.7.6 | **External Programme Dependency Management** |  | 0d | 2022-11-03 A | 2022-11-03 A |  | 100% |  | 2022-11-03 | 2022-11-03 | 0d | 2022-11-03 | 2022-11-03 |  |  |  | N/A | N/A | 5.0 | N/A | Design, Build & Test (PIT) |  |  |  |  |  |  |  |  |
| 462 | 1.3.7.6.1 | **SLC47** |  | 0d | 2022-11-03 A | 2022-11-03 A |  | 100% |  | 2022-11-03 | 2022-11-03 | 0d | 2022-11-03 | 2022-11-03 |  |  |  | N/A | N/A | 5.0 | N/A | Design, Build & Test (PIT) |  |  |  |  |  |  |  |  |
| 463 | 1.3.7.6.1.1 | SLC47 implementation date | milestone | 0d | 2022-11-03 A | 2022-11-03 A |  | 100% |  | 2022-11-03 | 2022-11-03 | 0d | 2022-11-03 | 2022-11-03 |  | start no earlier than 2022-11-03 |  | Ofgem |  | 5.0 |  | Design, Build & Test (PIT) | Complete | COMPLETE |  |  |  |  |  |  |
| 464 | 1.4 | **SYSTEMS INTEGRATION TESTING (SIT)** |  | 1125d? | 2022-10-31 A | 2027-02-19 |  | 60% | 447.54d? | 2022-10-31 | 2026-01-19 | 841d | 2022-10-31 | 2026-01-19 | 31962d |  | -0 | N/A | N/A |  | N/A | Systems Integration Testing (SIT) |  |  | 1 Aug 2023 - 30 Sep 2024 |  |  |  |  |  |
| 465 | 1.4.1 | **SIT Preparation** |  | 650d? | 2022-10-31 A | 2025-04-25 |  | 80% | 129.42d? | 2022-10-31 | 2025-03-03 | 611d | 2022-10-31 | 2025-03-10 | 32437d |  | -0 | N/A | N/A | 5.0 | N/A | Systems Integration Testing (SIT) |  |  |  |  |  |  |  |  |
| 466 | 1.4.1.1 | **Test Artefact Development** |  | 472d | 2022-10-31 A | 2024-08-21 |  | 99% | 2.69d | 2022-10-31 | 2024-08-21 | 472d | 2022-10-31 | 2023-09-01 | 32615d |  | -0 | N/A | N/A | 5.0 | N/A | Systems Integration Testing (SIT) |  |  |  | M9 |  |  |  |  |
| 467 | 1.4.1.1.1 | **Environment Approach & Plan** |  | 460d | 2022-11-16 A | 2024-08-21 A |  | 100% |  | 2022-11-16 | 2024-08-21 | 460d | 2022-11-16 | 2023-06-30 |  |  | -0 | N/A | N/A | 5.0 | N/A | Systems Integration Testing (SIT) |  |  |  |  |  |  |  |  |
| 468 | 1.4.1.1.1.1 | Environment Approach & Plan approved | milestone | 0d | 2022-11-16 A | 2022-11-16 A |  | 100% |  | 2022-11-16 | 2022-11-16 | 0d | 2022-11-16 | 2022-11-16 |  | start no earlier than 2022-11-16 |  | SI Test | PP | 5.0 | Simon Berry | Systems Integration Testing (SIT) | Complete | COMPLETE |  |  | MHHS-ART139 | T3-TE-0010 | SITAG | T3 |
| 469 | 1.4.1.1.1.2 | Environment Approach & Plan - Work Off |  | 157d | 2022-11-17 A | 2023-06-23 A | 468FS+1d | 100% |  | 2022-11-17 | 2023-06-23 | 157d | 2022-11-17 | 2023-06-23 |  |  |  | SI Test | PP | 5.0 | Simon Berry | Systems Integration Testing (SIT) | Complete | COMPLETE |  |  |  |  |  |  |
| 470 | 1.4.1.1.1.3 | Environment Approach & Plan - Work Off Approved | milestone | 0d | 2023-08-16 A | 2023-08-16 A | 469FS+5d | 100% |  | 2023-08-16 | 2023-08-16 | 0d | 2023-06-30 | 2023-06-30 |  | start no earlier than 2023-08-16 |  | SI Test | PP | 5.0 | Simon Berry | Systems Integration Testing (SIT) | Complete | COMPLETE |  |  | MHHS-ART139 | T3-TE-0068 | SITAG | T3 |
| 471 | 1.4.1.1.1.4 | Environment Approach and Plan - SIT Functional | milestone | 0d | 2023-11-20 A | 2023-11-20 A |  | 100% |  | 2023-11-15 | 2023-11-15 | 0d |  |  |  | start no earlier than 2023-11-20 |  | SI Test | PP | 5.12 | Simon Berry | Systems Integration Testing (SIT) | Complete | COMPLETE |  |  | MHHS-DEL 618 | T3-TE-0090 | SITAG | T3 |
| 472 | 1.4.1.1.1.5 | Define Approach to Simulator for Non-SIT LDSO | milestone | 0d | 2023-11-15 A | 2023-11-15 A |  | 100% |  | 2023-11-15 | 2023-11-15 | 0d |  |  |  | start no earlier than 2023-11-15 |  | SI Test | PP | 5.12 | Simon Berry |  | Complete | COMPLETE |  |  |  |  |  |  |
| 473 | 1.4.1.1.1.6 | Environment Approach and Plan - Non SIT LDSO Testing | milestone | 0d | 2024-04-17 A | 2024-04-17 A |  | 100% |  | 2024-04-17 | 2024-04-17 | 0d |  |  |  | start no earlier than 2024-04-17 |  | SI Test | PP | 5.22 | Simon Berry | Systems Integration Testing (SIT) | Complete | COMPLETE |  |  | MHHS-DEL 619 | T3-TE-0091 | SITAG/QAG | T3 |
| 474 | 1.4.1.1.1.7 | Environment Approach and Plan - S and A Testing | milestone | 0d | 2024-07-17 A | 2024-07-17 A |  | 100% |  | 2024-07-17 | 2024-07-17 | 0d |  |  |  | start no earlier than 2024-07-17 |  | SI Test | PP | 5.27 | Simon Berry | Systems Integration Testing (SIT) | Complete | COMPLETE |  |  | MHHS-DEL 619 | T3-TE-0120 | SITAG/QAG | T3 |
| 475 | 1.4.1.1.1.8 | Environment Approach and Plan - SIT Non Functional | milestone | 0d | 2024-06-19 A | 2024-06-19 A |  | 100% |  | 2024-06-19 | 2024-06-19 | 0d |  |  |  | start no earlier than 2024-06-19 |  | SI Test | PP | 5.27 | Simon Berry | Systems Integration Testing (SIT) | Complete | COMPLETE |  |  | MHHS-DEL 620 | T3-TE-0092 | SITAG | T3 |
| 476 | 1.4.1.1.1.9 | Environment Approach and Plan - Sandbox | milestone | 0d | 2024-08-21 A | 2024-08-21 A |  | 100% |  | 2024-08-21 | 2024-08-21 | 0d |  |  |  | start no earlier than 2024-08-21 |  | SI Test | PP | 5.27 | Simon Berry | Systems Integration Testing (SIT) | Complete | COMPLETE |  |  | MHHS-DEL 621 | T3-TE-0093 | SITAG/QAG | T3 |
| 477 | 1.4.1.1.2 | **Overarching Test Scope (for all stages)** |  | 65d | 2022-10-31 A | 2023-01-27 A |  | 100% |  | 2022-10-31 | 2023-06-30 | 175d | 2022-10-31 | 2023-06-30 |  |  |  | N/A | N/A | 5.0 | N/A | Systems Integration Testing (SIT) |  |  |  |  |  |  |  |  |
| 478 | 1.4.1.1.2.1 | **Overarching Test Scope (excl. Migration/Reverse Migration, NFT and Ops components)** |  | 65d | 2022-10-31 A | 2023-01-27 A |  | 100% |  | 2022-10-31 | 2023-01-27 | 65d | 2022-10-31 | 2023-01-27 |  |  |  | N/A | N/A | 5.0 | N/A | Systems Integration Testing (SIT) |  |  |  |  |  |  |  |  |
| 479 | 1.4.1.1.2.1.1 | Develop document (excl Migration/Reverse Migration, NFT and Ops components) |  | 55d | 2022-10-31 A | 2023-01-13 A | 48 | 100% |  | 2022-10-31 | 2023-01-13 | 55d | 2022-10-31 | 2023-01-13 |  |  |  | SI Test |  | 5.0 |  | Systems Integration Testing (SIT) | Complete | COMPLETE |  |  |  |  |  |  |
| 480 | 1.4.1.1.2.1.2 | Review, update & agree document (excl Migration/Reverse Migration, NFT and Ops components) |  | 10d | 2023-01-16 A | 2023-01-27 A | 479 | 100% |  | 2023-01-16 | 2023-01-27 | 10d | 2023-01-16 | 2023-01-27 |  |  |  | SI Test | IPA,Code Bodies,PP | 5.0 |  | Systems Integration Testing (SIT) | Complete | COMPLETE |  |  |  |  |  |  |
| 481 | 1.4.1.1.3 | **Configuration and Release Management Approach & Plan** |  | 164d | 2022-11-01 A | 2023-06-16 A |  | 100% |  | 2022-11-01 | 2023-06-16 | 164d | 2022-11-01 | 2023-04-28 |  |  |  | N/A | N/A | 5.0 | N/A | Systems Integration Testing (SIT) |  |  |  | M9 |  |  |  |  |
| 482 | 1.4.1.1.3.1 | Develop document |  | 69d | 2022-11-01 A | 2023-06-16 A |  | 100% |  | 2022-11-01 | 2023-06-16 | 69d | 2022-11-01 | 2023-01-31 |  | start no earlier than 2022-11-01 |  | SI Test |  | 5.0 | Simon Berry | Systems Integration Testing (SIT) | Complete | COMPLETE |  |  |  |  |  |  |
| 483 | 1.4.1.1.3.2 | Review, update and agree Configuration and Release Management Approach & Plan internally |  | 63d | 2023-02-01 A | 2023-04-28 A | 482 | 100% |  | 2023-02-01 | 2023-04-28 | 63d | 2023-02-01 | 2023-04-28 |  |  |  | SRO Function | IPA,SI Test | 5.0 | Simon Berry | Systems Integration Testing (SIT) | Complete | COMPLETE |  |  |  |  |  |  |
| 484 | 1.4.1.1.4 | **Test Data Overarching Approach & Plan** |  | 179d | 2022-11-14 A | 2023-07-20 A |  | 100% |  | 2022-11-14 | 2023-07-20 | 179d | 2022-11-14 | 2023-05-18 |  |  |  | N/A | N/A | 5.0 | N/A | Systems Integration Testing (SIT) |  |  |  | M9 |  |  |  |  |
| 485 | 1.4.1.1.4.1 | Develop document |  | 20d | 2022-11-14 A | 2022-12-09 A |  | 100% |  | 2022-11-14 | 2022-12-09 | 20d | 2022-11-14 | 2022-12-09 |  | start no earlier than 2022-11-14 |  | SI Test | PP | 5.0 | Cesar Lopes | Systems Integration Testing (SIT) | Complete | COMPLETE |  |  |  |  |  |  |
| 486 | 1.4.1.1.4.2 | Document review and update |  | 155d | 2022-12-12 A | 2023-07-14 A | 485 | 100% |  | 2022-12-12 | 2023-07-14 | 155d | 2022-12-12 | 2023-05-17 |  |  |  | PP | SI Test,IPA | 5.0 | Cesar Lopes | Systems Integration Testing (SIT) | Complete | COMPLETE |  |  |  |  |  |  |
| 487 | 1.4.1.1.4.3 | Test Data Overarching Approach & Plan approved by TMAG | milestone | 0d | 2023-07-19 A | 2023-07-19 A | 486FS+3d | 100% |  | 2023-07-19 | 2023-07-19 | 0d | 2023-05-17 | 2023-05-17 |  |  |  | SRO Test | PP,IPA,Code Bodies | 5.0 | Cesar Lopes | Systems Integration Testing (SIT) | Complete | COMPLETE |  |  |  | T3-TE-0072 | SITAG | T3 |
| 488 | 1.4.1.1.4.4 | Document publication final version |  | 1d | 2023-07-20 A | 2023-07-20 A | 487 | 100% |  | 2023-07-20 | 2023-07-20 | 1d | 2023-05-18 | 2023-05-18 |  |  |  | SI Test |  | 5.0 | Cesar Lopes | Systems Integration Testing (SIT) | Complete | COMPLETE |  |  |  |  |  |  |

Notes:
- 465: Action: 11/3: Ask Simon B for the link (line 1312) dip onboarding to non sit ldso
- 467: Action: 16/8 - add to milestone register. Build out detail further
- 468: Action: 25/7 - Simon to provide update
- 469: Action: 25/7 - Simon to provide update
- 470: Action: 25/7 - Simon to provide update
- 471: The LDSO element is on hold whilst discussions are being held between Programme and Code Bodies re: LDSO testing. When concluded, that update will be re-planned by agreement with TMAG. 20/11- Approved at TMAG / Action: 16/8 - add to milestone register. Build out detail further
- 473: 25/03: To go to Apr QAG for name change as Non-SIT LDSO and S and A will deliver on different timelines so '& S and A' will be removed. 17/4: Approved for name change at SITAG on 17/4/24. / Action: 16/8 - add to milestone register. Build out detail further
- 474: . 25/03: New milestone to go to Apr QAG as Non-SIT LDSO and S and A will deliver on different timelines so need to create a new milestone for S and A. 17/4: Approved as new milestone at SITAG on 17/4/24. 19/6: Approved at SITAG on 19/6 / Action: 16/8 - add to milestone register. Build out detail further
- 475: 26/3/24: To go to April SITAG for date change approval. Because of dependency on NF test approach and plan. Currently under PP review 17/4: Approved date change at SITAG on 17/4/24. 19/6: Approved at SITAG on 19/6 / Action: 16/8 - add to milestone register. Build out detail further
- 476: Name change to remove 'qualification and' to reflect sandbox only scope. Name and date change approved at QAG on 21/3/24. 19/6: Approved at SITAG on 19/6 / Action: 16/8 - add to milestone register. Build out detail further
- 481: Action: 1280 DIP available for Onboarding (need to add a link - non sit ldso)

| ID | WBS | Task | Type | Duration | Start | Finish | Predecessors | Complete | Remaining | Baseline start | Baseline finish | Baseline duration | Baseline 1 start | Baseline 1 finish | Total slack | Constraint | Baseline cost | Responsible | Involved | Update Version | MHHS Resource Name | MHHS Programme Phase | Sched Status | RAG | Task Status |
| --- | --- | --- | --- | --- | --- | --- | --- | --- | --- | --- | --- | --- | --- | --- | --- | --- | --- | --- | --- | --- | --- | --- | --- | --- | --- |
| 489 | 1.4.1.1.5 | **Interface Code of Connection (dates subject to DIP Service Provider's plan)** |  | 48d | 2023-03-01 A | 2023-05-05 A |  | 100% |  | 2023-03-01 | 2023-05-05 | 48d | 2023-03-01 | 2023-05-05 |  |  |  | N/A | N/A | 5.0 | N/A | Systems Integration Testing (SIT) |  |  |  |
| 490 | 1.4.1.1.5.1 | Develop Interface Code of Connection with DIP Service Provider |  | 43d | 2023-03-01 A | 2023-04-28 A |  | 100% |  | 2023-03-01 | 2023-04-28 | 43d | 2023-03-01 | 2023-04-28 |  | must start on 2023-03-01 |  | DIP Provider | SI Test | 5.0 |  | Systems Integration Testing (SIT) | Complete | COMPLETE |  |
| 491 | 1.4.1.1.5.2 | Interface Code of Connection approved at SDWG | milestone | 0d | 2023-05-05 A | 2023-05-05 A | 490FS+5d | 100% |  | 2023-05-05 | 2023-05-05 | 0d | 2023-05-05 | 2023-05-05 |  |  |  | SI Test | PP | 5.0 |  | Systems Integration Testing (SIT) | Complete | COMPLETE |  |
| 492 | 1.4.1.1.6 | **Test Traceability** |  | 165d | 2023-06-01 A | 2024-01-17 |  | 98% | 2.71d | 2023-06-01 | 2024-01-17 | 165d | 2023-06-01 | 2023-09-01 | 32769d |  | -0 | N/A | N/A | 5.0 | N/A | Systems Integration Testing (SIT) |  |  |  |
| 493 | 1.4.1.1.6.1 | RTM containing Method Statement Implied Requirements into Azure DevOps |  | 22d | 2023-06-01 A | 2023-06-30 A |  | 100% |  | 2023-06-01 | 2023-06-30 | 22d | 2023-06-01 | 2023-06-30 |  | must start on 2023-06-01 |  | SI Test |  | 5.0 |  | Systems Integration Testing (SIT) | Complete | COMPLETE |  |
| 494 | 1.4.1.1.6.2 | RTM Containing Interface Catalogue Implied Requirements |  | 27d | 2023-06-01 A | 2023-07-07 A |  | 100% |  | 2023-06-01 | 2023-07-07 | 27d | 2023-06-01 | 2023-07-07 |  | must start on 2023-06-01 |  | SI Test |  | 5.0 |  | Systems Integration Testing (SIT) | Complete | COMPLETE |  |
| 495 | 1.4.1.1.6.3 | SIT CIT Full Traceability & Coverage complete |  | 118d | 2023-07-10 A | 2023-12-20 A | 494, 493 | 100% |  | 2023-07-10 | 2023-12-08 | 110d | 2023-07-10 | 2023-07-28 |  |  |  | SI Test |  | 5.0 |  | Systems Integration Testing (SIT) | Complete | COMPLETE |  |
| 496 | 1.4.1.1.6.4 | SIT Functional Full Traceability & Coverage complete |  | 138d | 2023-07-10 A | 2024-01-17 | 494, 493 | 96% | 5d | 2023-07-10 | 2024-01-17 | 138d | 2023-07-10 | 2023-09-01 | 32769d |  |  | SI Test |  | 5.0 | Roger Robar | Systems Integration Testing (SIT) | Overdue | RED |  |
| 497 | 1.4.1.2 | **Test Tool Development** |  | 256d? | 2022-10-31 A | 2023-10-23 |  | 95% | 12.04d? | 2022-10-31 | 2023-06-30 | 175d | 2022-10-31 | 2023-06-30 | 32831d |  |  | N/A | N/A | 5.0 | N/A | Systems Integration Testing (SIT) |  |  |  |
| 498 | 1.4.1.2.1 | **Test Management Tool** |  | 256d | 2022-10-31 A | 2023-10-23 A |  | 100% |  | 2022-10-31 | 2023-06-30 | 175d | 2022-10-31 | 2023-06-30 |  |  |  | N/A | N/A | 5.0 | N/A | Systems Integration Testing (SIT) |  |  |  |
| 499 | 1.4.1.2.1.1 | **Test Management Tool Implementation** |  | 256d | 2022-10-31 A | 2023-10-23 A |  | 100% |  | 2022-10-31 | 2023-06-30 | 175d | 2022-10-31 | 2023-06-30 |  |  |  | N/A | N/A | 5.0 | N/A | Systems Integration Testing (SIT) |  |  |  |
| 500 | 1.4.1.2.1.1.1 | Requirements identification |  | 40d | 2022-10-31 A | 2022-12-23 A |  | 100% |  | 2022-10-31 | 2022-12-23 | 40d | 2022-10-31 | 2022-12-23 |  |  |  | SI DevOps | SI Test | 5.0 | Simon Berry | Systems Integration Testing (SIT) | Complete | COMPLETE |  |
| 501 | 1.4.1.2.1.1.2 | Development |  | 125d | 2023-01-02 A | 2023-06-23 A | 500FS+5d | 100% |  | 2023-01-02 | 2023-06-23 | 125d | 2023-01-02 | 2023-06-23 |  |  |  | SI DevOps | SI Test | 5.0 | Simon Berry | Systems Integration Testing (SIT) | Complete | COMPLETE |  |
| 502 | 1.4.1.2.1.1.3 | Testing |  | 125d | 2023-01-02 A | 2023-06-23 A | 501FF | 100% |  | 2023-01-02 | 2023-06-23 | 125d | 2023-01-02 | 2023-06-23 |  |  |  | SI DevOps | SI Test | 5.0 | Simon Berry | Systems Integration Testing (SIT) | Complete | COMPLETE |  |
| 503 | 1.4.1.2.1.1.4 | Accept tool | milestone | 0d | 2023-06-23 A | 2023-06-23 A | 502FF | 100% |  | 2023-06-23 | 2023-06-23 | 0d | 2023-06-23 | 2023-06-23 |  |  |  | SI DevOps | SI Test | 5.0 | Simon Berry | Systems Integration Testing (SIT) | Complete | COMPLETE |  |
| 504 | 1.4.1.2.1.1.5 | Implementation |  | 1d | 2023-10-23 A | 2023-10-23 A | 503FS+85d | 100% |  | 2023-06-30 | 2023-06-30 | 1d | 2023-06-30 | 2023-06-30 |  |  |  | SI DevOps | PPC | 5.0 | Simon Berry | Systems Integration Testing (SIT) | Complete | COMPLETE |  |
| 505 | 1.4.1.2.1.2 | **Test Management Tool User Guide** |  | 115d | 2023-01-02 A | 2023-06-09 A |  | 100% |  | 2023-01-02 | 2023-06-09 | 115d | 2023-01-02 | 2023-06-09 |  |  |  | N/A | N/A | 5.0 | N/A | Systems Integration Testing (SIT) |  |  |  |
| 506 | 1.4.1.2.1.2.1 | Develop document |  | 100d | 2023-01-02 A | 2023-05-19 A | 501SS, 502SS | 100% |  | 2023-01-02 | 2023-05-19 | 100d | 2023-01-02 | 2023-05-19 |  | start no earlier than 2023-01-02 |  | SI DevOps |  | 5.0 |  | Systems Integration Testing (SIT) | Complete | COMPLETE |  |
| 507 | 1.4.1.2.1.2.2 | Review, update and agree Test Management Tool User Guide internally |  | 15d | 2023-05-22 A | 2023-06-09 A | 506 | 100% |  | 2023-05-22 | 2023-06-09 | 15d | 2023-05-22 | 2023-06-09 |  |  |  | SRO Function | SI DevOps,SI Test,IPA,PPC | 5.0 |  | Systems Integration Testing (SIT) | Complete | COMPLETE |  |
| 508 | 1.4.1.2.1.3 | **Test Management Tool Configuration Guide** |  | 60d | 2023-01-02 A | 2023-03-24 A |  | 100% |  | 2023-01-02 | 2023-03-24 | 60d | 2023-01-02 | 2023-03-24 |  |  |  | N/A | N/A | 5.0 | N/A | Systems Integration Testing (SIT) |  |  |  |
| 509 | 1.4.1.2.1.3.1 | Develop document |  | 45d | 2023-01-02 A | 2023-03-03 A | 500 | 100% |  | 2023-01-02 | 2023-03-03 | 45d | 2023-01-02 | 2023-03-03 |  | start no earlier than 2023-01-02 |  | SI DevOps | SI Test,IPA | 5.0 |  | Systems Integration Testing (SIT) | Complete | COMPLETE |  |
| 510 | 1.4.1.2.1.3.2 | Review, update and agree Test Management Tool Configuration Guide internally |  | 15d | 2023-03-06 A | 2023-03-24 A | 509 | 100% |  | 2023-03-06 | 2023-03-24 | 15d | 2023-03-06 | 2023-03-24 |  |  |  | SRO Function | SI DevOps,SI Test,IPA | 5.0 |  | Systems Integration Testing (SIT) | Complete | COMPLETE |  |
| 511 | 1.4.1.2.2 | **Secure Volunteer SIT Participants** |  | 163d? | 2023-01-31 | 2023-09-14 |  |  |  |  |  |  |  |  | 32858d |  |  |  |  | 6.0 |  |  | Overdue Start | RED | -680.67 |
| 512 | 1.4.1.2.2.1 | PPs decide whether to volunteer to participate in SIT and inform Programme of decision via Round 3 Replan consultation |  | 1d? | 2023-01-31 | 2023-01-31 |  |  |  |  |  |  |  |  | 33020d | finish no earlier than 2023-01-31 |  |  |  | 6.0 |  |  | Overdue Start | RED | -597.67 |
| 513 | 1.4.1.2.2.2 | Assurance of SIT volunteers' plans (submitted via Round 3 Replan Consultation) |  | 1d? | 2023-02-14 | 2023-02-14 |  |  |  |  |  |  |  |  | 33010d | finish no earlier than 2023-02-14 |  |  |  | 6.0 |  |  | Overdue Start | RED | -583.67 |
| 514 | 1.4.1.2.2.3 | SIT Participant Volunteers Identified |  | 1d? | 2023-02-14 | 2023-02-14 |  |  |  |  |  |  |  |  | 33010d | start no earlier than 2023-02-14 |  |  |  | 6.0 |  |  | Overdue Start | RED | -583.67 |
| 515 | 1.4.1.2.2.4 | Engagement with SIT volunteers |  | 1d? | 2023-05-23 | 2023-05-23 |  |  |  |  |  |  |  |  | 32940d | finish no earlier than 2023-05-23 |  |  |  | 6.0 |  |  | Overdue Start | RED | -485.67 |
| 516 | 1.4.1.2.2.5 | SIT Participants Agreed |  | 1d? | 2023-05-23 | 2023-05-23 |  |  |  |  |  |  |  |  | 32940d | start no earlier than 2023-05-23 |  |  |  | 6.0 |  |  | Overdue Start | RED | -485.67 |

Notes:
- 496: Stays red till delivery plan agreed at SITAG

| ID | WBS | Task | Type | Duration | Start | Finish | Predecessors | Complete | Baseline start | Baseline finish | Baseline duration | Baseline 1 start | Baseline 1 finish | Total slack | Constraint | Task Status | Update Version | Sched Status | RAG | Responsible | Involved | MHHS Resource Name | MHHS Programme Phase | Milestone ID | Text29 | Tier |
| --- | --- | --- | --- | --- | --- | --- | --- | --- | --- | --- | --- | --- | --- | --- | --- | --- | --- | --- | --- | --- | --- | --- | --- | --- | --- | --- |
| 517 | 1.4.1.2.2.6 | **Data Protection Impact Assessment (DPIA)** |  | 11d? | 2023-06-30 | 2023-07-14 |  |  |  |  |  |  |  | 32902d |  | -680.67 | 6.0 | Overdue Start | RED |  |  |  |  |  |  |  |
| 518 | 1.4.1.2.2.6.1 | Conduct DPIA on Overall Test Data Approach |  | 1d? | 2023-06-30 | 2023-06-30 |  |  |  |  |  |  |  | 32912d | finish no earlier than 2023-06-30 | -447.67 | 6.0 | Overdue Start | RED |  |  |  |  |  |  |  |
| 519 | 1.4.1.2.2.6.2 | Revise Overarching Test Data Approach& plan for DPIA (if required), including engagement with DWG |  | 1d? | 2023-07-13 | 2023-07-13 |  |  |  |  |  |  |  | 32903d | finish no earlier than 2023-07-13 | -434.67 | 6.0 | Overdue Start | RED |  |  |  |  |  |  |  |
| 520 | 1.4.1.2.2.6.3 | Review (internal), update and approve revised Overarching Test Data Approach& Plan (if required) |  | 1d? | 2023-07-14 | 2023-07-14 |  |  |  |  |  |  |  | 32902d | start no earlier than 2023-07-14 | -433.67 | 6.0 | Overdue Start | RED |  |  |  |  |  |  |  |
| 521 | 1.4.1.2.2.7 | **Data Sharing Agreements** |  | 30d? | 2023-08-04 | 2023-09-14 |  |  |  |  |  |  |  | 32858d |  | -680.67 | 6.0 | Overdue Start | RED |  |  |  |  |  |  |  |
| 522 | 1.4.1.2.2.7.1 | Produce Data Sharing Agreement for Industry Review |  | 1d? | 2023-08-04 | 2023-08-04 |  |  |  |  |  |  |  | 32887d | finish no earlier than 2023-08-04 | -412.67 | 6.0 | Overdue Start | RED |  |  |  |  |  |  |  |
| 523 | 1.4.1.2.2.7.2 | Manage Participant Queries and Contract Agreement Execution |  | 1d? | 2023-09-14 | 2023-09-14 |  |  |  |  |  |  |  | 32858d | finish no earlier than 2023-09-14 | -371.67 | 6.0 | Overdue Start | RED |  |  |  |  |  |  |  |
| 524 | 1.4.1.2.2.7.3 | Data Sharing Agreements Complete |  | 1d? | 2023-09-14 | 2023-09-14 |  |  |  |  |  |  |  | 32858d | start no earlier than 2023-09-14 | -371.67 | 6.0 | Overdue Start | RED |  |  |  |  |  |  |  |
| 525 | 1.4.1.2.2.8 | **Production Data Cut & Data Obfuscation** |  | 55d? | 2023-06-19 | 2023-09-01 |  |  |  |  |  |  |  | 32867d |  | -680.67 | 6.0 | Overdue Start | RED |  |  |  |  |  |  |  |
| 526 | 1.4.1.2.2.8.1 | **SI Data Cut Preparation& Infrastructure** |  | 45d? | 2023-06-19 | 2023-08-18 |  |  |  |  |  |  |  | 32877d |  | -680.67 | 6.0 | Overdue Start | RED |  |  |  |  |  |  |  |
| 527 | 1.4.1.2.2.8.1.1 | SI Data Cut Planning activities (incl. pre-cut and post-cut cleansing and population approach) |  | 1d? | 2023-06-19 | 2023-06-19 |  |  |  |  |  |  |  | 32921d | finish no earlier than 2023-06-19 | -458.67 | 6.0 | Overdue Start | RED |  |  |  |  |  |  |  |
| 528 | 1.4.1.2.2.8.1.2 | Set up SI database and transmission structure |  | 1d? | 2023-08-17 | 2023-08-17 |  |  |  |  |  |  |  | 32878d | finish no earlier than 2023-08-17 | -399.67 | 6.0 | Overdue Start | RED |  |  |  |  |  |  |  |
| 529 | 1.4.1.2.2.8.1.3 | Mechanism for transfer of data in place |  | 1d? | 2023-08-18 | 2023-08-18 |  |  |  |  |  |  |  | 32877d | start no earlier than 2023-08-18 | -398.67 | 6.0 | Overdue Start | RED |  |  |  |  |  |  |  |
| 530 | 1.4.1.2.2.8.1.4 | SI Data Cut Preparation& Infrastructure Complete |  | 1d? | 2023-08-18 | 2023-08-18 |  |  |  |  |  |  |  | 32877d | start no earlier than 2023-08-18 | -398.67 | 6.0 | Overdue Start | RED |  |  |  |  |  |  |  |
| 531 | 1.4.1.2.2.8.2 | **Production Data Cut** |  | 55d? | 2023-06-19 | 2023-09-01 |  |  |  |  |  |  |  | 32867d |  | -680.67 | 6.0 | Overdue Start | RED |  |  |  |  |  |  |  |
| 532 | 1.4.1.2.2.8.2.1 | Notification of Production Data Cut issued to relevant participants |  | 1d? | 2023-06-19 | 2023-06-19 |  |  |  |  |  |  |  | 32921d | start no earlier than 2023-06-19 | -458.67 | 6.0 | Overdue Start | RED |  |  |  |  |  |  |  |
| 533 | 1.4.1.2.2.8.2.2 | Coordinate relevant participants taking data cut from production systems |  | 1d? | 2023-08-11 | 2023-08-11 |  |  |  |  |  |  |  | 32882d | finish no earlier than 2023-08-11 | -405.67 | 6.0 | Overdue Start | RED |  |  |  |  |  |  |  |
| 534 | 1.4.1.2.2.8.2.3 | Production data cut GONG decision |  | 1d? | 2023-08-16 | 2023-08-16 |  |  |  |  |  |  |  | 32879d | start no earlier than 2023-08-16 | -400.67 | 6.0 | Overdue Start | RED |  |  |  |  |  |  |  |
| 535 | 1.4.1.2.2.8.2.4 | Relevant participants take data cut from production systems (Saturday 19 August) |  | 1d? | 2023-08-21 | 2023-08-21 |  |  |  |  |  |  |  | 32876d | start no earlier than 2023-08-21 | -395.67 | 6.0 | Overdue Start | RED |  |  |  |  |  |  |  |
| 536 | 1.4.1.2.2.8.2.5 | EES transmit request data to SI |  | 1d? | 2023-08-25 | 2023-08-25 |  |  |  |  |  |  |  | 32872d | finish no earlier than 2023-08-25 | -391.67 | 6.0 | Overdue Start | RED |  |  |  |  |  |  |  |
| 537 | 1.4.1.2.2.8.2.6 | Check data alignment and integrity of data cut |  | 1d? | 2023-09-01 | 2023-09-01 |  |  |  |  |  |  |  | 32867d | finish no earlier than 2023-09-01 | -384.67 | 6.0 | Overdue Start | RED |  |  |  |  |  |  |  |
| 538 | 1.4.1.2.2.8.2.7 | Data cut from relevant participants' production systems completed (Saturday 19 August) |  | 1d? | 2023-08-21 | 2023-08-21 |  |  |  |  |  |  |  | 32876d | start no earlier than 2023-08-21 | -395.67 | 6.0 | Overdue Start | RED |  |  |  |  |  |  |  |
| 539 | 1.4.1.2.2.8.2.8 | Production Data Cut Complete |  | 1d? | 2023-08-21 | 2023-08-21 |  |  |  |  |  |  |  | 32876d | start no earlier than 2023-08-21 | -395.67 | 6.0 | Overdue Start | RED |  |  |  |  |  |  |  |
| 540 | 1.4.1.3 | **SIT Participation** |  | 147d | 2022-10-31 A | 2023-05-23 A |  | 100% | 2022-10-31 | 2023-05-23 | 147d | 2022-10-31 | 2023-05-23 |  |  |  | 5.0 |  |  | N/A | N/A | N/A | Systems Integration Testing (SIT) |  |  |  |
| 541 | 1.4.1.3.1 | PPs decide whether to volunteer to participate in SIT and inform Programme of decision via Round 3 Replan consultation |  | 67d | 2022-10-31 A | 2023-01-31 A | 34FF | 100% | 2022-10-31 | 2023-01-31 | 67d | 2022-10-31 | 2023-01-31 |  |  |  | 5.0 | Complete | COMPLETE | PP | SI Test,PMO |  | Systems Integration Testing (SIT) |  |  |  |
| 542 | 1.4.1.3.2 | Assurance of SIT volunteers' plans (submitted via Round 3 Replan Consultation) |  | 10d | 2023-02-01 A | 2023-02-14 A | 541, 34 | 100% | 2023-02-01 | 2023-02-14 | 10d | 2023-02-01 | 2023-02-14 |  |  |  | 5.0 | Complete | COMPLETE | SI Test | PP |  | Systems Integration Testing (SIT) |  |  |  |
| 543 | 1.4.1.3.3 | SIT Participant Volunteers Identified | milestone | 0d | 2023-02-14 A | 2023-02-14 A | 542FF | 100% | 2023-02-14 | 2023-02-14 | 0d | 2023-02-14 | 2023-02-14 |  |  |  | 5.0 | Complete | COMPLETE | SI Test | PP |  | Systems Integration Testing (SIT) | T2-TE-0100 | SITAG | T2 |
| 544 | 1.4.1.3.4 | Engagement with SIT volunteers |  | 147d | 2022-10-31 A | 2023-05-23 A |  | 100% | 2022-10-31 | 2023-05-23 | 147d | 2022-10-31 | 2023-05-23 |  |  |  | 5.0 | Complete | COMPLETE | SI Test | PP |  | Systems Integration Testing (SIT) |  |  |  |
| 545 | 1.4.1.3.5 | SIT Participants Agreed | milestone | 0d | 2023-05-23 A | 2023-05-23 A | 544, 579FS-74d | 100% | 2023-05-23 | 2023-05-23 | 0d | 2023-05-23 | 2023-05-23 |  |  |  | 5.0 | Complete | COMPLETE | SI Test | PP |  | Systems Integration Testing (SIT) | T2-TE-0150 | SITAG | T2 |

| ID | WBS | Task | Type | Duration | Start | Finish | Predecessors | Complete | Remaining | Baseline start | Baseline finish | Baseline duration | Baseline 1 start | Baseline 1 finish | Total slack | Constraint | Baseline cost | Responsible | Involved | Update Version | MHHS Resource Name | MHHS Programme Phase | Sched Status | RAG | Artefact ID | Milestone ID | Text29 | Tier | Task Status | Guidance |
| --- | --- | --- | --- | --- | --- | --- | --- | --- | --- | --- | --- | --- | --- | --- | --- | --- | --- | --- | --- | --- | --- | --- | --- | --- | --- | --- | --- | --- | --- | --- |
| 546 | 1.4.1.4 | **SIT Stage-Specific Preparation** |  | 650d? | 2022-10-31 A | 2025-04-25 |  | 75% | 159.74d? | 2022-10-31 | 2025-03-03 | 611d | 2022-10-31 | 2025-03-10 | 32437d |  | -0 | N/A | N/A | 5.0 | N/A | Systems Integration Testing (SIT) |  |  |  |  |  |  |  |  |
| 547 | 1.4.1.4.1 | **SIT Component Integration Preparation** |  | 320d | 2022-10-31 A | 2024-01-19 A |  | 100% |  | 2022-10-31 | 2024-01-22 | 321d | 2022-10-31 | 2024-01-22 |  |  | -0 | N/A | N/A | 5.0 | N/A | Systems Integration Testing (SIT) |  |  |  |  |  |  |  |  |
| 548 | 1.4.1.4.1.1 | **Test Approach & Plan** |  | 188d | 2022-10-31 A | 2023-07-19 A |  | 100% |  | 2022-10-31 | 2023-07-19 | 188d | 2022-10-31 | 2023-07-19 |  |  |  | N/A | N/A | 5.0 | N/A | Systems Integration Testing (SIT) |  |  |  |  |  |  |  |  |
| 549 | 1.4.1.4.1.1.1 | Develop document with SITWG |  | 159d | 2022-10-31 A | 2023-06-08 A |  | 100% |  | 2022-10-31 | 2023-06-08 | 159d | 2022-10-31 | 2023-05-12 |  |  |  | SI Test |  | 5.0 |  | Systems Integration Testing (SIT) | Complete | COMPLETE |  |  |  |  |  |  |
| 550 | 1.4.1.4.1.1.2 | Industry consultation |  | 10d | 2023-06-09 A | 2023-06-22 A | 549 | 100% |  | 2023-06-09 | 2023-06-22 | 10d |  |  |  |  |  | PP |  | 5.1 |  | Systems Integration Testing (SIT) | Complete | COMPLETE |  |  |  |  |  |  |
| 551 | 1.4.1.4.1.1.3 | Artefact review (via TMAG) and updates |  | 19d | 2023-06-23 A | 2023-07-19 A | 550 | 100% |  | 2023-06-23 | 2023-07-19 | 19d | 2023-06-09 | 2023-07-06 |  | finish no earlier than 2023-07-06 |  | SI Test | PP,IPA,Code Bodies | 5.0 |  | Systems Integration Testing (SIT) | Complete | COMPLETE |  |  |  |  |  |  |
| 552 | 1.4.1.4.1.1.4 | SIT Component Integration Testing Test Approach & Plan approved | milestone | 0d | 2023-07-19 A | 2023-07-19 A | 551 | 100% |  | 2023-07-19 | 2023-07-19 | 0d | 2023-07-19 | 2023-07-19 |  | finish no earlier than 2023-07-19 |  | SI Test | PP | 5.0 |  | Systems Integration Testing (SIT) | Complete | COMPLETE | MHHS-ART073 | T3-TE-0012 | SITAG | T3 |  |  |
| 553 | 1.4.1.4.1.2 | **Test Data Approach & Plan** |  | 29d | 2023-06-09 A | 2023-07-19 A |  | 100% |  | 2023-06-09 | 2023-07-19 | 29d | 2023-06-09 | 2023-07-19 |  |  |  | N/A | N/A | 5.0 | N/A | Systems Integration Testing (SIT) |  |  |  |  |  |  |  |  |
| 554 | 1.4.1.4.1.2.1 | Industry consultation |  | 10d | 2023-06-09 A | 2023-06-22 A | 550SS | 100% |  | 2023-06-09 | 2023-06-22 | 10d |  |  |  |  |  | PP |  | 5.1 | Cesar Lopes | Systems Integration Testing (SIT) | Complete | COMPLETE |  |  |  |  |  |  |
| 555 | 1.4.1.4.1.2.2 | Artefact review (via TMAG) and updates |  | 19d | 2023-06-23 A | 2023-07-19 A | 554 | 100% |  | 2023-06-23 | 2023-07-19 | 19d | 2023-06-09 | 2023-07-06 |  |  |  | SI Test | PP | 5.0 | Cesar Lopes | Systems Integration Testing (SIT) | Complete | COMPLETE |  |  |  |  |  |  |
| 556 | 1.4.1.4.1.2.3 | SIT Component Integration Testing Test Data Approach & Plan approved | milestone | 0d | 2023-07-19 A | 2023-07-19 A | 555 | 100% |  | 2023-07-19 | 2023-07-19 | 0d | 2023-07-19 | 2023-07-19 |  |  |  | SI Test | IPA | 5.0 | Cesar Lopes | Systems Integration Testing (SIT) | Complete | COMPLETE |  |  |  |  |  |  |
| 557 | 1.4.1.4.1.3 | **Test scenarios** |  | 173d | 2023-01-02 A | 2023-08-30 A |  | 100% |  | 2023-01-02 | 2023-08-30 | 173d | 2023-01-02 | 2023-06-02 |  |  |  | N/A | N/A | 5.0 | N/A | Systems Integration Testing (SIT) |  |  |  |  |  |  |  |  |
| 558 | 1.4.1.4.1.3.1 | Development of test scenarios | milestone | 0d | 2023-01-02 A | 2023-04-28 A | 549SS+45d | 100% |  | 2023-01-02 | 2023-04-28 | 85d | 2023-01-02 | 2023-04-28 |  |  |  | SI Test | PP, Code Bodies | 5.0 |  | Systems Integration Testing (SIT) | Complete | COMPLETE |  |  |  |  |  |  |
| 559 | 1.4.1.4.1.3.2 | Review test scenarios with SIT Working Group |  | 11d | 2023-02-01 A | 2023-08-09 A | 558SS+22d | 100% |  | 2023-02-01 | 2023-08-09 | 136d | 2023-02-01 | 2023-05-26 |  |  |  | SI Test | PP, Code Bodies, IPA | 5.0 |  | Systems Integration Testing (SIT) | Complete | COMPLETE |  |  |  |  |  |  |
| 560 | 1.4.1.4.1.3.3 | SIT Component Integration Testing Test scenarios approved | milestone | 0d | 2023-08-30 A | 2023-08-30 A | 559FS+15d | 100% |  | 2023-08-30 | 2023-08-30 | 0d | 2023-06-02 | 2023-06-02 |  |  |  | SI Test | PP | 5.6 |  | Systems Integration Testing (SIT) | Complete | COMPLETE | MHHS-ART148 | T3-TE-0014 | SITAG | T3 |  |  |
| 561 | 1.4.1.4.1.4 | **Test cases** |  | 160d | 2023-05-01 A | 2023-12-08 A |  | 100% |  | 2023-05-01 | 2023-12-08 | 160d | 2023-05-01 | 2023-09-01 |  |  |  | N/A | N/A | 5.6 | N/A | Systems Integration Testing (SIT) |  |  |  |  |  |  |  |  |
| 562 | 1.4.1.4.1.4.1 | **SI Test cases** |  | 160d | 2023-05-01 A | 2023-12-08 A |  | 100% |  | 2023-05-01 | 2023-12-08 | 160d | 2023-05-01 | 2023-09-01 |  |  |  | N/A | N/A | 5.6 | N/A | Systems Integration Testing (SIT) |  |  |  |  |  |  |  |  |
| 563 | 1.4.1.4.1.4.1.1 | **Batch 1 (CIT Intervals 1 and 2)** |  | 110d | 2023-05-01 A | 2023-09-29 A |  | 100% |  | 2023-05-01 | 2023-09-29 | 110d |  |  |  |  |  | N/A | N/A | 5.6 | N/A | Systems Integration Testing (SIT) |  |  |  |  |  |  | -290.67 |  |
| 564 | 1.4.1.4.1.4.1.1.1 | Develop Test cases |  | 100d | 2023-05-01 A | 2023-09-15 A | 558 | 100% |  | 2023-05-01 | 2023-09-15 | 100d | 2023-05-01 | 2023-07-28 |  |  |  | SI Test |  | 5.6 |  | Systems Integration Testing (SIT) | Complete | COMPLETE |  |  |  |  |  |  |
| 565 | 1.4.1.4.1.4.1.1.2 | Review Test cases with SIT Working Group |  | 9d | 2023-09-18 A | 2023-09-28 A | 564 | 100% |  | 2023-09-18 | 2023-09-28 | 9d | 2023-05-26 | 2023-08-25 |  |  |  | SI Test | PP,IPA | 5.6 |  | Systems Integration Testing (SIT) | Complete | COMPLETE |  |  |  |  |  |  |
| 566 | 1.4.1.4.1.4.1.1.3 | SIT Component Integration Testing Test cases Batch 1 (CIT Intervals 1 and 2) approved at ETMAG | milestone | 0d | 2023-09-29 A | 2023-09-29 A | 565FS+1d | 100% |  | 2023-09-29 | 2023-09-29 | 0d | 2023-09-01 | 2023-09-01 |  |  |  | SI Test | PP | 5.6 |  | Systems Integration Testing (SIT) | Complete | COMPLETE | MHHS-ART073 | T3-TE-0069 | SITAG | T3 |  | 18/8 - needs to finish on 29/9 for ETWAG |
| 567 | 1.4.1.4.1.4.1.2 | **Batch 2 (CIT Intervals 3 and 4)** |  | 25d | 2023-10-02 A | 2023-11-03 A |  | 100% |  | 2023-10-02 | 2023-11-03 | 25d |  |  |  |  |  | N/A | N/A | 5.6 | N/A | Systems Integration Testing (SIT) |  |  |  |  |  |  | -290.67 |  |
| 568 | 1.4.1.4.1.4.1.2.1 | Develop Test cases |  | 15d | 2023-10-02 A | 2023-10-20 A | 566 | 100% |  | 2023-10-02 | 2023-10-20 | 15d | 2023-05-01 | 2023-07-28 |  |  |  | SI Test |  | 5.6 |  | Systems Integration Testing (SIT) | Complete | COMPLETE |  |  |  |  |  |  |
| 569 | 1.4.1.4.1.4.1.2.2 | Review Test cases with SIT Working Group |  | 9d | 2023-10-23 A | 2023-11-02 A | 568 | 100% |  | 2023-10-23 | 2023-11-02 | 9d | 2023-05-26 | 2023-08-25 |  |  |  | SI Test | PP,IPA | 5.6 |  | Systems Integration Testing (SIT) | Complete | COMPLETE |  |  |  |  |  |  |
| 570 | 1.4.1.4.1.4.1.2.3 | SIT Component Integration Testing Test cases Batch 2 (CIT Intervals 3 and 4) approved at ETMAG | milestone | 0d | 2023-11-03 A | 2023-11-03 A | 569FS+1d | 100% |  | 2023-11-03 | 2023-11-03 | 0d | 2023-09-01 | 2023-09-01 |  |  |  | SI Test | PP | 5.11 |  | Systems Integration Testing (SIT) | Complete | COMPLETE |  | T3-TE-0104 | SITAG | T3 |  | 18/8 - needs to finish on 3/11 for ETWAG |

Notes:
- 560: 17/8 - to go to ETMAG on 30/8
- 561: 18/8 - added in with LC to reflect his ppt slide
- 562: 18/8 - added in with LC to reflect his ppt slide
- 563: 18/8 - added in with LC to reflect his ppt slide
- 564: 18/8 - added in with LC to reflect his ppt slide
- 565: 18/8 - added in with LC to reflect his ppt slide
- 566: 18/8 - added in with LC to reflect his ppt slide / Action: 18/8 - needs to finish on 29/9 for ETWAG. Update Milestone register after approval
- 567: 18/8 - added in with LC to reflect his ppt slide
- 568: 18/8 - added in with LC to reflect his ppt slide
- 569: 18/8 - added in with LC to reflect his ppt slide
- 570: 18/8 - added in with LC to reflect his ppt slide / Action: 18/8 - needs to finish on 29/9 for ETWAG

| ID | WBS | Task | Type | Duration | Start | Finish | Predecessors | Complete | Baseline start | Baseline finish | Baseline duration | Baseline 1 start | Baseline 1 finish | Constraint | Baseline cost | Responsible | Involved | Task Status | Update Version | MHHS Resource Name | MHHS Programme Phase | Sched Status | RAG | Milestone ID | Text29 | Tier | Artefact ID | Action |
| --- | --- | --- | --- | --- | --- | --- | --- | --- | --- | --- | --- | --- | --- | --- | --- | --- | --- | --- | --- | --- | --- | --- | --- | --- | --- | --- | --- | --- |
| 571 | 1.4.1.4.1.4.1.3 | **Batch 3 (CIT Intervals 5 and 6)** |  | 25d | 2023-11-03 A | 2023-12-08 A |  | 100% | 2023-11-03 | 2023-12-08 | 25d |  |  |  |  | N/A | N/A | -290.67 | 5.6 | N/A | Systems Integration Testing (SIT) |  |  |  |  |  |  |  |
| 572 | 1.4.1.4.1.4.1.3.1 | Develop Test cases |  | 15d | 2023-11-03 A | 2023-11-24 A | 570 | 100% | 2023-11-03 | 2023-11-24 | 15d | 2023-05-01 | 2023-07-28 |  |  | SI Test |  |  | 5.6 |  | Systems Integration Testing (SIT) | Complete | COMPLETE |  |  |  |  |  |
| 573 | 1.4.1.4.1.4.1.3.2 | Review Test cases with SIT Working Group |  | 9d | 2023-11-27 A | 2023-12-07 A | 572 | 100% | 2023-11-27 | 2023-12-07 | 9d | 2023-05-26 | 2023-08-25 |  |  | SI Test | PP,IPA |  | 5.6 |  | Systems Integration Testing (SIT) | Complete | COMPLETE |  |  |  |  |  |
| 574 | 1.4.1.4.1.4.1.3.3 | SIT Component Integration Testing Test cases Batch 3 (CIT Intervals 5 and 6) approved at ETMAG | milestone | 0d | 2023-12-08 A | 2023-12-08 A | 573FS+1d | 100% | 2023-12-08 | 2023-12-08 | 0d | 2023-09-01 | 2023-09-01 |  |  | SI Test | PP |  | 5.14 |  | Systems Integration Testing (SIT) | Complete | COMPLETE | T3-TE-0105 | SITAG | T3 |  |  |
| 575 | 1.4.1.4.1.5 | **CIT Interval 1 Preparation** |  | 283d | 2022-11-16 A | 2023-12-15 A |  | 100% | 2022-11-16 | 2023-12-08 | 278d | 2022-11-16 | 2023-10-23 |  | -0 | N/A | N/A |  | 5.6 | N/A | Systems Integration Testing (SIT) |  |  |  |  |  |  |  |
| 576 | 1.4.1.4.1.5.1 | **Environments (SIT A)** |  | 246d | 2022-11-16 A | 2023-10-25 A |  | 100% | 2022-11-16 | 2023-10-16 | 239d | 2022-11-16 | 2023-10-06 |  |  | N/A | N/A |  | 5.0 | N/A | Systems Integration Testing (SIT) |  |  |  |  |  |  |  |
| 577 | 1.4.1.4.1.5.1.1 | PPs register PKI Officers and request PKI certificates |  | 5d | 2023-10-09 A | 2023-10-13 A |  | 100% | 2023-10-09 | 2023-10-13 | 5d | 2023-08-28 | 2023-09-01 | start no earlier than 2023-10-09 |  | PP | DIP Provider |  | 5.5 | Simon Berry | Systems Integration Testing (SIT) | Complete | COMPLETE |  |  |  |  |  |
| 578 | 1.4.1.4.1.5.1.2 | PPs register PKI Officers and request PKI certificates Complete - Interval 1 | milestone | 0d | 2023-10-25 A | 2023-10-25 A | 577FS+8d | 100% | 2023-10-13 | 2023-10-13 | 0d |  |  |  |  | PP | DIP Provider |  | 5.10 | Simon Berry | Systems Integration Testing (SIT) | Complete | COMPLETE | T3-TE-0094 | SITAG | T3 |  |  |
| 579 | 1.4.1.4.1.5.1.3 | PP SIT A environment preparation (incl. security certificates and security compliance) |  | 238d | 2022-11-16 A | 2023-10-13 A | 468 | 100% | 2022-11-16 | 2023-09-01 | 208d | 2022-11-16 | 2023-09-01 |  |  | PP | SI Test |  | 5.8 | Simon Berry | Systems Integration Testing (SIT) | Complete | COMPLETE |  |  |  |  |  |
| 580 | 1.4.1.4.1.5.1.4 | SI coordinate SIT Participants' SIT A environment preparation |  | 238d | 2022-11-16 A | 2023-10-13 A | 579SS | 100% | 2022-11-16 | 2023-09-01 | 208d | 2022-11-16 | 2023-09-01 |  |  | SI Test | PP |  | 5.8 | Simon Berry | Systems Integration Testing (SIT) | Complete | COMPLETE |  |  |  |  |  |
| 581 | 1.4.1.4.1.5.1.5 | PP submit self-declaration of environment preparation complete (incl. security certificates and security compliance) to Programme for assurance | milestone | 0d | 2023-10-13 A | 2023-10-13 A | 579FF | 100% | 2023-09-01 | 2023-09-01 | 0d | 2023-09-01 | 2023-09-01 | start no earlier than 2023-10-13 |  | PP | SI Test |  | 5.8 | Simon Berry | Systems Integration Testing (SIT) | Complete | COMPLETE |  |  |  |  |  |
| 582 | 1.4.1.4.1.5.1.6 | SI assure PPs' self-declaration of environment preparation complete (incl. security certificates and security compliance) |  | 5d | 2023-10-16 A | 2023-10-20 A | 581FF+5d | 100% | 2023-09-04 | 2023-09-08 | 5d | 2023-09-04 | 2023-09-08 |  |  | SI Test | PP |  | 5.8 | Simon Berry | Systems Integration Testing (SIT) | Complete | COMPLETE |  |  |  |  |  |
| 583 | 1.4.1.4.1.5.1.7 | SIT Participants' SIT A environments ready to start connectivity proving CIT Interval 1 | milestone | 0d | 2023-09-01 A | 2023-09-01 A | 581SS | 100% | 2023-09-01 | 2023-09-01 | 0d | 2023-09-01 | 2023-09-01 |  |  | PP | PP,IPA |  | 5.6 | Simon Berry | Systems Integration Testing (SIT) | Complete | COMPLETE | T3-TE-0019 | SITAG | T3 | MHHS-ART139 |  |
| 584 | 1.4.1.4.1.5.1.8 | PP SIT A environment connectivity proving |  | 10d | 2023-09-04 A | 2023-09-15 A | 583 | 100% | 2023-09-12 | 2023-10-09 | 20d | 2023-09-04 | 2023-09-29 |  |  | PP | SI Test |  | 5.8 | Simon Berry | Systems Integration Testing (SIT) | Complete | COMPLETE |  |  |  |  |  |
| 585 | 1.4.1.4.1.5.1.9 | SI coordinate SIT Participants' SIT A environment connectivity proving |  | 10d | 2023-09-04 A | 2023-09-15 A | 584SS | 100% | 2023-09-12 | 2023-10-09 | 20d | 2023-09-04 | 2023-09-29 |  |  | SI Test | PP |  | 5.8 | Simon Berry | Systems Integration Testing (SIT) | Complete | COMPLETE |  |  |  |  |  |
| 586 | 1.4.1.4.1.5.1.10 | PP deployment of MHHS solution code to SIT A environments |  | 10d | 2023-09-25 A | 2023-10-06 A | 627FF | 100% | 2023-09-26 | 2023-10-09 | 10d | 2023-09-18 | 2023-09-29 |  |  | PP | SI Test |  | 5.0 | Simon Berry | Systems Integration Testing (SIT) | Complete | COMPLETE |  |  |  |  |  |
| 587 | 1.4.1.4.1.5.1.11 | SI coordinate deployment of MHHS solution code to SIT Participants' SIT A environments |  | 10d | 2023-09-25 A | 2023-10-06 A | 627FF | 100% | 2023-09-26 | 2023-10-09 | 10d | 2023-09-18 | 2023-09-29 |  |  | SI Test | PP |  | 5.0 | Simon Berry | Systems Integration Testing (SIT) | Complete | COMPLETE |  |  |  |  |  |
| 588 | 1.4.1.4.1.5.1.12 | PP submit evidence of SIT A environment connectivity proving and code deployment completion to Programme for assurance |  | 30d | 2023-09-04 A | 2023-10-13 A | 584SS | 100% | 2023-09-12 | 2023-10-09 | 20d | 2023-09-04 | 2023-09-29 |  |  | PP | SI Test |  | 5.8 | Simon Berry | Systems Integration Testing (SIT) | Complete | COMPLETE |  |  |  |  |  |
| 589 | 1.4.1.4.1.5.1.13 | SI assurance of SIT Participants' SIT A environment connectivity proving and code deployment completion |  | 25d | 2023-09-18 A | 2023-10-20 A | 588FF+5d | 100% | 2023-09-12 | 2023-10-16 | 25d | 2023-09-04 | 2023-10-06 |  |  | SI Test | PP |  | 5.8 | Simon Berry | Systems Integration Testing (SIT) | Complete | COMPLETE |  |  |  |  |  |
| 590 | 1.4.1.4.1.5.2 | **Test Data - ISD Creation** |  | 9d | 2023-08-22 A | 2023-09-01 A |  | 100% | 2023-08-22 | 2023-09-01 | 9d |  |  |  |  | N/A | N/A | -275.67 | 5.5 | N/A | Systems Integration Testing (SIT) |  |  |  |  |  |  |  |
| 591 | 1.4.1.4.1.5.2.1 | Set-up Market Participants and DIP ID Data |  | 8d | 2023-08-22 A | 2023-08-31 A |  | 100% | 2023-08-22 | 2023-08-31 | 8d |  |  |  |  | SI Test Data | SI Test, DIP, Helix |  | 5.5 | Cesar Lopes | Systems Integration Testing (SIT) | Complete | COMPLETE |  |  |  |  |  |
| 592 | 1.4.1.4.1.5.2.2 | Distribute ISD Data to Participants |  | 1d | 2023-09-01 A | 2023-09-01 A | 591 | 100% | 2023-09-01 | 2023-09-01 | 1d |  |  |  |  | SI Test Data | SI Test, DIP, Helix |  | 5.5 | Cesar Lopes | Systems Integration Testing (SIT) | Complete | COMPLETE |  |  |  |  |  |
| 593 | 1.4.1.4.1.5.2.3 | Test Data - ISD Creation Complete | milestone | 0d | 2023-09-01 A | 2023-09-01 A | 592 | 100% | 2023-09-01 | 2023-09-01 | 0d |  |  |  |  | SI Test Data | SI Test, DIP, Helix |  | 5.5 | Cesar Lopes | Systems Integration Testing (SIT) | Complete | COMPLETE | T3-TE-0083 | SITAG | T3 |  | 3/8 - add as t3 milestones. Awaiting approval at TMAG |
| 594 | 1.4.1.4.1.5.3 | **Test Data - SFTP Onboarding** |  | 70d | 2023-08-21 A | 2023-11-24 A |  | 100% | 2023-08-21 | 2023-11-24 | 70d |  |  |  | -0 | N/A | N/A | -275.67 | 5.5 | N/A | Systems Integration Testing (SIT) |  |  |  |  |  |  |  |
| 595 | 1.4.1.4.1.5.3.1 | Create Containers and Keys for Participants |  | 3d | 2023-08-21 A | 2023-08-23 A |  | 100% | 2023-08-21 | 2023-08-23 | 3d |  |  |  |  | SI Test Data | SI Test |  | 5.5 | Cesar Lopes | Systems Integration Testing (SIT) | Complete | COMPLETE |  |  |  |  |  |
| 596 | 1.4.1.4.1.5.3.2 | Share SFTP Access with Participants |  | 5d | 2023-08-24 A | 2023-08-30 A | 595 | 100% | 2023-08-24 | 2023-08-30 | 5d |  |  |  |  | SI Test Data | SI Test, PP |  | 5.5 | Cesar Lopes | Systems Integration Testing (SIT) | Complete | COMPLETE |  |  |  |  |  |
| 597 | 1.4.1.4.1.5.3.3 | Test SFTP Connectivity |  | 5d | 2023-08-31 A | 2023-09-06 A | 596 | 100% | 2023-08-31 | 2023-09-06 | 5d |  |  |  |  | SI Test Data | SI Test, PP |  | 5.5 | Cesar Lopes | Systems Integration Testing (SIT) | Complete | COMPLETE |  |  |  |  |  |
| 598 | 1.4.1.4.1.5.3.4 | Test Data - SFTP Onboarding Complete | milestone | 0d | 2023-11-24 A | 2023-11-24 A | 597FS+57d | 100% | 2023-11-24 | 2023-11-24 | 0d |  |  |  |  | SI Test Data | SI Test, PP |  | 5.13 | Cesar Lopes | Systems Integration Testing (SIT) | Complete | COMPLETE | T3-TE-0084 | SITAG | T3 |  |  |

Notes:
- 571: 18/8 - added in with LC to reflect his ppt slide
- 572: 18/8 - added in with LC to reflect his ppt slide
- 573: 18/8 - added in with LC to reflect his ppt slide
- 574: 18/8 - added in with LC to reflect his ppt slide. 28/11 - Red because TMAG date has moved from 8/12 to 20/12 due to reduction in Dec TMAGs. No impact. No action. 20/12 - Approved at TMAG on 20/12 / Guidance: 28/11 - Red because TMAG date has moved from 8/12 to 20/12 due to reduction in Dec TMAGs. No impact. No action
- 578: 16/8- new milestones added in and date change. Approved at TMAG on 16/8. 18/10 - Red because there is an issue that is preventing the issue of PKI certificates. ~Avanade are working with GlobalSign to resolve.~A fix is in the process of being tested
- 590: 3/8 - JW and CL meeting - added in to give e more clarity around work being undertaken
- 591: 3/8 - JW and CL meeting - added in to give e more clarity around work being undertaken
- 592: 3/8 - JW and CL meeting - added in to give e more clarity around work being undertaken
- 593: 3/8 - JW and CL meeting - added in to give more clarity around work being undertaken
- 594: 3/8 - JW and CL meeting - added in to give more clarity around work being undertaken
- 595: 3/8 - JW and CL meeting - added in to give more clarity around work being undertaken
- 596: 3/8 - JW and CL meeting - added in to give more clarity around work being undertaken
- 597: 3/8 - JW and CL meeting - added in to give more clarity around work being undertaken
- 598: Approved at TMAG on 20/9. 26/9 - RP - Red because we have changed the approach to SFTP onboarding to be phased by interval. To go to TMAG for date change approval. Approved for date change at TMAG on 23/10/23

| ID | WBS | Task | Type | Duration | Start | Finish | Predecessors | Complete | Baseline start | Baseline finish | Baseline duration | Baseline 1 start | Baseline 1 finish | Baseline cost | Responsible | Involved | Task Status | Update Version | MHHS Resource Name | MHHS Programme Phase | Sched Status | RAG | Milestone ID | Text29 | Tier | Artefact ID |
| --- | --- | --- | --- | --- | --- | --- | --- | --- | --- | --- | --- | --- | --- | --- | --- | --- | --- | --- | --- | --- | --- | --- | --- | --- | --- | --- |
| 599 | 1.4.1.4.1.5.4 | **Test Data - Provide Sample Files** |  | 10d | 2023-08-21 A | 2023-09-01 A |  | 100% | 2023-08-21 | 2023-09-01 | 10d |  |  |  | N/A | N/A | -275.67 | 5.5 | N/A | Systems Integration Testing (SIT) |  |  |  |  |  |  |
| 600 | 1.4.1.4.1.5.4.1 | Generate Sample Files off IF Messages |  | 8d | 2023-08-21 A | 2023-08-30 A |  | 100% | 2023-08-21 | 2023-08-30 | 8d |  |  |  | SI Test Data | SI Test |  | 5.5 | Cesar Lopes | Systems Integration Testing (SIT) | Complete | COMPLETE |  |  |  |  |
| 601 | 1.4.1.4.1.5.4.2 | Transmit Sample Files off IF Messages to Participants (More detail needs to be planned for a POC) |  | 2d | 2023-08-31 A | 2023-09-01 A | 600 | 100% | 2023-08-31 | 2023-09-01 | 2d |  |  |  | SI Test Data | SI Test |  | 5.5 | Cesar Lopes | Systems Integration Testing (SIT) | Complete | COMPLETE |  |  |  |  |
| 602 | 1.4.1.4.1.5.4.3 | Test Data - Provide Sample Files Complete | milestone | 0d | 2023-09-01 A | 2023-09-01 A | 601 | 100% | 2023-09-01 | 2023-09-01 | 0d |  |  |  | SI Test Data | SI Test |  | 5.5 | Cesar Lopes | Systems Integration Testing (SIT) | Complete | COMPLETE | T3-TE-0085 | SITAG | T3 |  |
| 603 | 1.4.1.4.1.5.5 | **Test Data - Detailed SIT Data Load Guidance** |  | 65d | 2023-09-07 A | 2023-12-06 A |  | 100% | 2023-09-07 | 2023-12-01 | 62d |  |  | -0 | N/A | N/A | -275.67 | 5.5 | N/A | Systems Integration Testing (SIT) |  |  |  |  |  |  |
| 604 | 1.4.1.4.1.5.5.1 | Document Guidance |  | 21d | 2023-09-07 A | 2023-10-05 A | 602FS+3d | 100% | 2023-09-07 | 2023-09-28 | 16d |  |  |  | SI Test Data | SI Test |  | 5.9 | Cesar Lopes | Systems Integration Testing (SIT) | Complete | COMPLETE |  |  |  |  |
| 605 | 1.4.1.4.1.5.5.2 | Provide Guidance to PPs |  | 1d | 2023-10-06 A | 2023-10-06 A | 604 | 100% | 2023-09-29 | 2023-09-29 | 1d |  |  |  | SI Test Data | SI Test |  | 5.9 | Cesar Lopes | Systems Integration Testing (SIT) | Complete | COMPLETE |  |  |  |  |
| 606 | 1.4.1.4.1.5.5.3 | Test Data - Detailed SIT Functional Data Load Guidance Complete | milestone | 0d | 2023-12-06 A | 2023-12-06 A | 605FS+43d | 100% | 2023-12-01 | 2023-12-01 | 0d |  |  |  | SI Test Data | SI Test |  | 5.13 | Richard Puddephatt | Systems Integration Testing (SIT) | Complete | COMPLETE | T3-TE-0095 | SITAG | T3 | MHHS-DEL 1545 |
| 607 | 1.4.1.4.1.5.6 | **Test Data - Population of Data Items for Testing Guidance - Draft** |  | 80d | 2023-08-17 A | 2023-12-06 A |  | 100% | 2023-08-17 | 2023-12-01 | 77d |  |  | -0 | N/A | N/A | -275.67 | 5.5 | N/A | Systems Integration Testing (SIT) |  |  |  |  |  |  |
| 608 | 1.4.1.4.1.5.6.1 | Document Guidance - Draft |  | 11d | 2023-08-17 A | 2023-08-31 A | 797 | 100% | 2023-08-17 | 2023-08-31 | 11d |  |  |  | SI Test Data | SI Test |  | 5.6 | Cesar Lopes | Systems Integration Testing (SIT) | Complete | COMPLETE |  |  |  |  |
| 609 | 1.4.1.4.1.5.6.2 | Provide Guidance to PPs - Draft |  | 1d | 2023-09-01 A | 2023-09-01 A | 608 | 100% | 2023-09-01 | 2023-09-01 | 1d |  |  |  | SI Test Data | SI Test |  | 5.6 | Cesar Lopes | Systems Integration Testing (SIT) | Complete | COMPLETE |  |  |  |  |
| 610 | 1.4.1.4.1.5.6.3 | Test Data - Population of Data Items for Testing Guidance - Draft Complete | milestone | 0d | 2023-12-06 A | 2023-12-06 A | 609FS+68d | 100% | 2023-12-01 | 2023-12-01 | 0d |  |  |  | SI Test Data | SI Test |  | 5.13 | Richard Puddephatt | Systems Integration Testing (SIT) | Complete | COMPLETE | T3-TE-0096 | SITAG | T3 | MHHS-DEL 816 |
| 611 | 1.4.1.4.1.5.7 | **Test Data - Population of Data Items for Testing Guidance - Final** |  | 87d | 2023-08-17 A | 2023-12-15 A |  | 100% | 2023-10-09 | 2023-12-08 | 45d |  |  |  | N/A | N/A | -275.67 | 5.5 | N/A | Systems Integration Testing (SIT) |  |  |  |  |  |  |
| 612 | 1.4.1.4.1.5.7.1 | Update Document Guidance With PPS Feedback |  | 81d | 2023-08-17 A | 2023-12-07 A | 608SS | 100% | 2023-10-09 | 2023-12-07 | 44d |  |  |  | SI Test Data | SI Test |  | 5.5 | Richard Puddephatt | Systems Integration Testing (SIT) | Complete | COMPLETE |  |  |  |  |
| 613 | 1.4.1.4.1.5.7.2 | Provide Final Guidance to PPs |  | 1d | 2023-12-08 A | 2023-12-08 A | 612 | 100% | 2023-12-08 | 2023-12-08 | 1d |  |  |  | SI Test Data | SI Test |  | 5.5 | Richard Puddephatt | Systems Integration Testing (SIT) | Complete | COMPLETE |  |  |  |  |
| 614 | 1.4.1.4.1.5.7.3 | Test Data - Population of Data Items for Testing Guidance - Final Complete | milestone | 0d | 2023-12-15 A | 2023-12-15 A | 613FS+5d | 100% | 2023-12-08 | 2023-12-08 | 0d |  |  |  | SI Test Data | SI Test |  | 5.14 | Richard Puddephatt | Systems Integration Testing (SIT) | Complete | COMPLETE | T3-TE-0097 | SITAG | T3 | MHHS-DEL 816 |
| 615 | 1.4.1.4.1.5.8 | **Test Data (SIT A) Interval 1** |  | 40d | 2023-09-04 A | 2023-10-27 A |  | 100% | 2023-09-04 | 2023-09-29 | 20d | 2023-09-04 | 2023-09-29 |  | N/A | N/A |  | 5.0 | N/A | Systems Integration Testing (SIT) |  |  |  |  |  |  |
| 616 | 1.4.1.4.1.5.8.1 | Run data allocation |  | 4d | 2023-09-04 A | 2023-09-07 A | 556, 593 | 100% | 2023-09-04 | 2023-09-07 | 4d | 2023-09-04 | 2023-09-07 |  | SI Test |  |  | 5.0 | Cesar Lopes | Systems Integration Testing (SIT) | Complete | COMPLETE |  |  |  |  |
| 617 | 1.4.1.4.1.5.8.2 | Cleanse, anonymise and populate data post cut |  | 4d | 2023-09-08 A | 2023-09-13 A | 616 | 100% | 2023-09-08 | 2023-09-13 | 4d | 2023-09-08 | 2023-09-13 |  | SI Test |  |  | 5.0 | Cesar Lopes | Systems Integration Testing (SIT) | Complete | COMPLETE |  |  |  |  |
| 618 | 1.4.1.4.1.5.8.3 | Transmit data sets to PPs |  | 3d | 2023-09-15 A | 2023-09-19 A | 617 | 100% | 2023-09-15 | 2023-09-15 | 1d | 2023-09-14 | 2023-09-15 |  | SI Test |  |  | 5.0 | Cesar Lopes | Systems Integration Testing (SIT) | Complete | COMPLETE |  |  |  |  |
| 619 | 1.4.1.4.1.5.8.4 | PP - Load test data to test environments |  | 7d | 2023-09-20 A | 2023-09-28 A | 618, 602 | 100% | 2023-09-18 | 2023-09-22 | 5d | 2023-09-18 | 2023-09-22 |  | PP |  |  | 5.0 | Cesar Lopes | Systems Integration Testing (SIT) | Complete | COMPLETE |  |  |  |  |
| 620 | 1.4.1.4.1.5.8.5 | PP Check data integrity on test environment |  | 1d | 2023-09-29 A | 2023-09-29 A | 619 | 100% | 2023-09-25 | 2023-09-29 | 5d | 2023-09-25 | 2023-09-29 |  | PP |  |  | 5.0 | Cesar Lopes | Systems Integration Testing (SIT) | Complete | COMPLETE |  |  |  |  |
| 621 | 1.4.1.4.1.5.8.6 | PP submit self-declaration to Programme to confirm loading & verification of test data | milestone | 0d | 2023-09-29 A | 2023-09-29 A | 620FF | 100% | 2023-09-29 | 2023-09-29 | 0d | 2023-09-29 | 2023-09-29 |  | PP | SI Test |  | 5.0 | Cesar Lopes | Systems Integration Testing (SIT) | Complete | COMPLETE |  |  |  |  |
| 622 | 1.4.1.4.1.5.8.7 | Test Data (SIT A) Interval 1 Complete | milestone | 0d | 2023-10-27 A | 2023-10-27 A | 621FS+20d | 100% | 2023-09-29 | 2023-09-29 | 0d |  |  |  | SI Test | PP |  | 5.10 | Cesar Lopes | Systems Integration Testing (SIT) | Complete | COMPLETE | T3-TE-0073 | SITAG | T3 | MHHS-ART148/169 |

Notes:
- 599: 3/8 - JW and CL meeting - added in to give more clarity around work being undertaken
- 600: 3/8 - JW and CL meeting - added in to give more clarity around work being undertaken
- 601: 3/8 - JW and CL meeting - added in to give more clarity around work being undertaken
- 602: 3/8 - JW and CL meeting - added in to give more clarity around work being undertaken / Action: 3/8 - add as t3 milestones. Awaiting approval at TMAG
- 603: 3/8 - JW and CL meeting - added in to give more clarity around work being undertaken
- 604: 3/8 - JW and CL meeting - added in to give more clarity around work being undertaken
- 605: 3/8 - JW and CL meeting - added in to give more clarity around work being undertaken
- 606: 28/11- Red because of slow start to CIT Interval 3, doc timelines may need to be extended. Currently no impact on final doc. Aim to update the doc incrementally
- 607: 3/8 - JW and CL meeting - added in to give more clarity around work being undertaken
- 608: 3/8 - JW and CL meeting - added in to give more clarity around work being undertaken
- 609: 3/8 - JW and CL meeting - added in to give more clarity around work being undertaken
- 610: 28/11- Red because of slow start to CIT Interval 3, doc timelines may need to be extended. Currently no impact on final doc. Aim to update the doc incrementally
- 611: 3/8 - JW and CL meeting - added in to give more clarity around work being undertaken
- 612: 3/8 - JW and CL meeting - added in to give more clarity around work being undertaken
- 613: 3/8 - JW and CL meeting - added in to give more clarity around work being undertaken
- 614: 15/8 - JW and CL meeting - added in to give more clarity around work being undertaken. 12/12 - Red because we needed to provide the SRO 5 more working days to review. No impact. No action
- 622: 28/7: CH: added in to be aT3 milestone. 10/10 - RP - Red because Avanade plan to load Test Data on week commencing 23/10, this is the earliest it can be planned due to latest code being required (M9 dependant) / Action: 28/7: CH: Needs to be set-up as a reporting milestone. 31/7: Check with Cesar if has been approved so can be baselined

| ID | WBS | Task | Type | Duration | Start | Finish | Predecessors | Complete | Baseline start | Baseline finish | Baseline duration | Baseline 1 start | Baseline 1 finish | Constraint | Baseline cost | Responsible | Involved | Update Version | MHHS Resource Name | MHHS Programme Phase | Sched Status | RAG | Artefact ID | Milestone ID | Text29 | Tier |
| --- | --- | --- | --- | --- | --- | --- | --- | --- | --- | --- | --- | --- | --- | --- | --- | --- | --- | --- | --- | --- | --- | --- | --- | --- | --- | --- |
| 623 | 1.4.1.4.1.5.9 | **Other Preparation** |  | 45d | 2023-07-03 A | 2023-09-01 A |  | 100% | 2023-07-03 | 2023-09-01 | 45d | 2023-07-03 | 2023-09-01 |  |  | N/A | N/A | 5.0 | N/A | Systems Integration Testing (SIT) |  |  |  |  |  |  |
| 624 | 1.4.1.4.1.5.9.1 | Onboarding of Test Participants to Test Management Tool (Azure DevOps) |  | 45d | 2023-07-03 A | 2023-09-01 A | 583SF | 100% | 2023-07-03 | 2023-09-01 | 45d | 2023-07-03 | 2023-09-01 |  |  | SI Test | PP | 5.0 |  | Systems Integration Testing (SIT) | Complete | COMPLETE |  |  |  |  |
| 625 | 1.4.1.4.1.5.9.2 | Test Management Tool onboarding |  | 45d | 2023-07-03 A | 2023-09-01 A | 583SF | 100% | 2023-07-03 | 2023-09-01 | 45d | 2023-07-03 | 2023-09-01 |  |  | PP | SI Test | 5.0 |  | Systems Integration Testing (SIT) | Complete | COMPLETE |  |  |  |  |
| 626 | 1.4.1.4.1.5.10 | **SIT Component Integration Test Readiness Report** |  | 28d | 2023-09-14 A | 2023-10-23 A |  | 100% | 2023-10-09 | 2023-10-20 | 9d | 2023-09-11 | 2023-10-20 |  |  | N/A | N/A | 5.6 | N/A | Systems Integration Testing (SIT) |  |  |  |  |  |  |
| 627 | 1.4.1.4.1.5.10.1 | PP submit Test Readiness Report to Programme for assurance | milestone | 0d | 2023-10-20 A | 2023-10-20 A | 625, 566, 622 | 100% | 2023-10-09 | 2023-10-09 | 0d | 2023-09-29 | 2023-09-29 | start no earlier than 2023-10-09 |  | PP | SI Test | 5.6 |  | Systems Integration Testing (SIT) | Complete | COMPLETE |  |  |  |  |
| 628 | 1.4.1.4.1.5.10.2 | SI assure Test Participants' Test Readiness Reports |  | 1d | 2023-10-23 A | 2023-10-23 A | 627SS | 100% | 2023-10-10 | 2023-10-16 | 5d | 2023-10-02 | 2023-10-06 |  |  | SI Test | PP,IPA | 5.6 |  | Systems Integration Testing (SIT) | Complete | COMPLETE |  |  |  |  |
| 629 | 1.4.1.4.1.5.10.3 | SI develop Overarching SIT Component Integration Test Readiness Report |  | 23d | 2023-09-14 A | 2023-10-16 A | 552FS+40d | 100% | 2023-10-10 | 2023-10-13 | 4d | 2023-09-11 | 2023-10-06 |  |  | SI Test |  | 5.6 |  | Systems Integration Testing (SIT) | Complete | COMPLETE |  |  |  |  |
| 630 | 1.4.1.4.1.5.10.4 | Artefact review (via TMAG) and updates |  | 4d | 2023-10-17 A | 2023-10-20 A | 629 | 100% | 2023-10-16 | 2023-10-20 | 5d | 2023-10-09 | 2023-10-20 |  |  | SI Test | PP,IPA | 5.6 |  | Systems Integration Testing (SIT) | Complete | COMPLETE |  |  |  |  |
| 631 | 1.4.1.4.1.5.11 | SIT Component Integration Testing 1 Preparation Complete (incl. approval of SI SIT Component Integration Test Readiness Report) | milestone | 0d | 2023-10-27 A | 2023-10-27 A | 630FS+1d, 627, 583, 625, 622, 200, 205, 194, 214, 215, 628 | 100% | 2023-10-23 | 2023-10-23 | 0d | 2023-10-23 | 2023-10-23 |  |  | SI Test | PP,IPA | 5.11 |  | Systems Integration Testing (SIT) | Complete | COMPLETE | MHHS-ART071 | T2-TE-0250 | SITAG | T2 |
| 632 | 1.4.1.4.1.6 | **CIT Interval 2 Preparation** |  | 103d | 2023-07-03 A | 2023-11-22 A |  | 100% | 2023-07-03 | 2023-11-10 | 95d | 2022-11-16 | 2023-11-06 |  | -0 | N/A | N/A | 5.0 | N/A | Systems Integration Testing (SIT) |  |  |  |  |  |  |
| 633 | 1.4.1.4.1.6.1 | **Environments (SIT A)** |  | 43d | 2023-09-22 A | 2023-11-22 A |  | 100% | 2023-09-22 | 2023-11-10 | 35d | 2022-11-16 | 2023-10-27 |  | -0 | N/A | N/A | 5.0 | N/A | Systems Integration Testing (SIT) |  |  |  |  |  |  |
| 634 | 1.4.1.4.1.6.1.1 | SIT Participants' SIT A environments ready to start connectivity proving CIT Interval 2 | milestone | 0d | 2023-09-22 A | 2023-09-22 A |  | 100% | 2023-09-22 | 2023-09-22 | 0d | 2023-09-22 | 2023-09-22 |  |  | PP | PP,IPA | 5.6 | Simon Berry | Systems Integration Testing (SIT) | Complete | COMPLETE | MHHS-ART139 | T3-TE-0020 | SITAG | T3 |
| 635 | 1.4.1.4.1.6.1.2 | Programme Participants Ready to Start Connectivity Proving | milestone | 0d | 2023-09-22 A | 2023-09-22 A |  | 100% | 2023-09-22 | 2023-09-22 | 0d |  |  | finish no earlier than 2023-09-22 |  | PP |  | 5.10 | Simon Berry | Systems Integration Testing (SIT) | Complete | COMPLETE |  |  |  |  |
| 636 | 1.4.1.4.1.6.1.3 | Internal Connectivity Proving Phase |  | 10d | 2023-09-25 A | 2023-10-06 A | 635 | 100% | 2023-09-25 | 2023-10-06 | 10d |  |  |  |  | PP |  | 5.10 | Simon Berry | Systems Integration Testing (SIT) | Complete | COMPLETE |  |  |  |  |
| 637 | 1.4.1.4.1.6.1.4 | Internal Connectivity Proving Phase Complete | milestone | 0d | 2023-10-06 A | 2023-10-06 A | 636 | 100% | 2023-10-06 | 2023-10-06 | 0d |  |  | start no earlier than 2023-10-06 |  | PP |  | 5.10 | Simon Berry | Systems Integration Testing (SIT) | Complete | COMPLETE |  |  |  |  |
| 638 | 1.4.1.4.1.6.1.5 | DIP Onboarding Activity (1. PKI Officers and Certificates, 2. Set-up Validation, 3. End Point Creation, 4. Controlled Smoke Test ) |  | 28d | 2023-10-16 A | 2023-11-22 A | 637FS+5d | 100% | 2023-10-16 | 2023-11-10 | 20d |  |  |  |  | PP |  | 5.10 | Simon Berry | Systems Integration Testing (SIT) | Complete | COMPLETE |  |  |  |  |
| 639 | 1.4.1.4.1.6.1.6 | DIP Onboarding Complete | milestone | 0d | 2023-11-22 A | 2023-11-22 A | 638 | 100% | 2023-11-10 | 2023-11-10 | 0d |  |  |  |  | PP |  | 5.10 | Simon Berry | Systems Integration Testing (SIT) | Complete | COMPLETE |  |  |  |  |
| 640 | 1.4.1.4.1.6.1.7 | PPs Register PKI Officers and request PKI certificates Complete - Interval 2 | milestone | 0d | 2023-11-22 A | 2023-11-22 A | 639 | 100% | 2023-10-20 | 2023-10-20 | 0d |  |  |  |  | PP | DIP Provider | 5.15 | Simon Berry | Systems Integration Testing (SIT) | Complete | COMPLETE |  | T3-TE-0098 | SITAG | T3 |
| 641 | 1.4.1.4.1.6.1.8 | PP Code Deployment | milestone | 0d | 2023-10-20 A | 2023-10-20 A |  | 100% | 2023-10-20 | 2023-10-20 | 0d |  |  | start no earlier than 2023-10-20 |  | PP |  | 5.10 | Simon Berry | Systems Integration Testing (SIT) | Complete | COMPLETE |  |  |  |  |
| 642 | 1.4.1.4.1.6.2 | **Test Data (SIT A) Interval 2** |  | 43d | 2023-09-20 A | 2023-11-17 A |  | 100% | 2023-09-18 | 2023-10-20 | 25d | 2023-09-18 | 2023-10-20 |  |  | N/A | N/A | 5.0 | N/A | Systems Integration Testing (SIT) |  |  |  |  |  |  |
| 643 | 1.4.1.4.1.6.2.1 | Run data allocation |  | 7d | 2023-09-20 A | 2023-09-28 A | 619SS | 100% | 2023-09-18 | 2023-09-22 | 5d | 2023-09-18 | 2023-09-22 |  |  | SI Test |  | 5.0 | Cesar Lopes | Systems Integration Testing (SIT) | Complete | COMPLETE |  |  |  |  |
| 644 | 1.4.1.4.1.6.2.2 | Cleanse and populate data post cut |  | 2d | 2023-09-29 A | 2023-10-02 A | 643 | 100% | 2023-09-25 | 2023-09-29 | 5d | 2023-09-25 | 2023-09-29 |  |  | SI Test |  | 5.0 | Cesar Lopes | Systems Integration Testing (SIT) | Complete | COMPLETE |  |  |  |  |
| 645 | 1.4.1.4.1.6.2.3 | Transmit data sets to PPs |  | 1d | 2023-10-03 A | 2023-10-03 A | 644 | 100% | 2023-10-02 | 2023-10-03 | 2d | 2023-10-02 | 2023-10-03 |  |  | SI Test |  | 5.0 | Cesar Lopes | Systems Integration Testing (SIT) | Complete | COMPLETE |  |  |  |  |
| 646 | 1.4.1.4.1.6.2.4 | PP - Load test data to test environments |  | 33d | 2023-10-04 A | 2023-11-17 A | 645 | 100% | 2023-10-04 | 2023-10-13 | 8d | 2023-10-04 | 2023-10-13 |  |  | PP |  | 5.0 | Cesar Lopes | Systems Integration Testing (SIT) | Complete | COMPLETE |  |  |  |  |
| 647 | 1.4.1.4.1.6.2.5 | PP Check data integrity on test environment |  | 15d | 2023-10-23 A | 2023-11-17 A | 646FF | 100% | 2023-10-16 | 2023-10-20 | 5d | 2023-10-16 | 2023-10-20 |  |  | PP |  | 5.0 | Cesar Lopes | Systems Integration Testing (SIT) | Complete | COMPLETE |  |  |  |  |
| 648 | 1.4.1.4.1.6.2.6 | PP submit self-declaration to Programme to confirm loading & verification of test data | milestone | 0d | 2023-11-17 A | 2023-11-17 A | 647FF | 100% | 2023-10-20 | 2023-10-20 | 0d | 2023-10-20 | 2023-10-20 |  |  | PP | SI Test | 5.0 | Cesar Lopes | Systems Integration Testing (SIT) | Complete | COMPLETE |  |  |  |  |
| 649 | 1.4.1.4.1.6.2.7 | Test Data (SIT A) Interval 2 Complete | milestone | 0d | 2023-11-17 A | 2023-11-17 A | 648 | 100% | 2023-10-20 | 2023-10-20 | 0d |  |  |  |  | SI Test | PP | 5.12 | Cesar Lopes | Systems Integration Testing (SIT) | Complete | COMPLETE | MHHS-ART148/169 | T3-TE-0074 | SITAG | T3 |

Notes:
- 626: Action: 21/8 - Rework with Lee
- 627: 18/8 - dates changed to reflect PIT Execution date changes advised by RG
- 628: 18/8 - dates changed to reflect PIT Execution date changes advised by RG / Action: 21/8 - Rework with Lee
- 629: 18/8 - dates changed to reflect PIT Execution date changes advised by RG / Action: 21/8 - Rework with Lee
- 630: 18/8 - dates changed to reflect PIT Execution date changes advised by RG / Action: 21/8 - Rework with Lee
- 631: Red because prep now dependant on an agreed work-off plan.
- 640: 5/12- Red because only 1 PP has successfully registered their PKI Officers; received their PKI certificates; set-up validation compete; end point creation complete; and completed controlled smoke test. The other PP is currently in Step 4 of E2E onboarding
- 649: 28/7: CH: added in to be aT3 milestone. 15/11 - Red because of Data Customisation requirement for St. Clements and additional DIP message requirement. Impact is CIT able to start on selected MPANS remaining MPANS to be fixed by 16/11 / Action: 28/7: CH: Needs to be set-up as a reporting milestone. 31/7: Check with Cesar if has been approved so can be baselined

| ID | WBS | Task | Type | Duration | Start | Finish | Predecessors | Complete | Baseline start | Baseline finish | Baseline duration | Baseline 1 start | Baseline 1 finish | Constraint | Baseline cost | Responsible | Involved | Update Version | MHHS Resource Name | MHHS Programme Phase | Sched Status | RAG | Artefact ID | Milestone ID | Text29 | Tier | Action |
| --- | --- | --- | --- | --- | --- | --- | --- | --- | --- | --- | --- | --- | --- | --- | --- | --- | --- | --- | --- | --- | --- | --- | --- | --- | --- | --- | --- |
| 650 | 1.4.1.4.1.6.3 | **Other Preparation** |  | 87d | 2023-07-03 A | 2023-10-31 A |  | 100% | 2023-07-03 | 2023-10-31 | 87d | 2023-07-03 | 2023-09-22 |  | -0 | N/A | N/A | 5.0 | N/A | Systems Integration Testing (SIT) |  |  |  |  |  |  |  |
| 651 | 1.4.1.4.1.6.3.1 | Onboarding of Test Participants to Test Management Tool (Azure DevOps) |  | 60d | 2023-07-03 A | 2023-09-22 A | 634SF | 100% | 2023-07-03 | 2023-09-22 | 60d | 2023-07-03 | 2023-09-22 |  |  | SI Test | PP | 5.0 |  | Systems Integration Testing (SIT) | Complete | COMPLETE |  |  |  |  |  |
| 652 | 1.4.1.4.1.6.3.2 | Test Management Tool onboarding |  | 27d | 2023-09-25 A | 2023-10-31 A | 651 | 100% | 2023-09-25 | 2023-10-31 | 27d | 2023-07-03 | 2023-09-22 |  |  | PP | SI Test | 5.0 | Simon Berry | Systems Integration Testing (SIT) | Complete | COMPLETE |  |  |  |  |  |
| 653 | 1.4.1.4.1.6.4 | **SIT Component Integration Test Readiness Report** |  | 25d | 2023-10-02 A | 2023-11-03 A |  | 100% | 2023-10-02 | 2023-11-03 | 25d | 2023-10-02 | 2023-11-03 |  |  | N/A | N/A | 5.0 | N/A | Systems Integration Testing (SIT) |  |  |  |  |  |  |  |
| 654 | 1.4.1.4.1.6.4.1 | PP submit Test Readiness Report to Programme for assurance | milestone | 0d | 2023-10-25 A | 2023-10-25 A | 566FS+18d | 100% | 2023-10-20 | 2023-10-20 | 0d | 2023-10-20 | 2023-10-20 |  |  | PP | SI Test | 5.0 |  | Systems Integration Testing (SIT) | Complete | COMPLETE |  |  |  |  |  |
| 655 | 1.4.1.4.1.6.4.2 | SI assure Test Participants' Test Readiness Reports |  | 2d | 2023-10-26 A | 2023-10-27 A | 654 | 100% | 2023-10-23 | 2023-10-27 | 5d | 2023-10-23 | 2023-10-27 |  |  | SI Test | PP,IPA | 5.0 |  | Systems Integration Testing (SIT) | Complete | COMPLETE |  |  |  |  |  |
| 656 | 1.4.1.4.1.6.4.3 | SI develop Overarching SIT Component Integration Test Readiness Report |  | 20d | 2023-10-02 A | 2023-10-27 A | 655FF | 100% | 2023-10-02 | 2023-10-27 | 20d | 2023-10-02 | 2023-10-27 |  |  | SI Test |  | 5.0 |  | Systems Integration Testing (SIT) | Complete | COMPLETE |  |  |  |  |  |
| 657 | 1.4.1.4.1.6.4.4 | Artefact review (via TMAG) and updates |  | 5d | 2023-10-30 A | 2023-11-03 A | 656 | 100% | 2023-10-30 | 2023-11-03 | 5d | 2023-10-30 | 2023-11-03 |  |  | SI Test | PP,IPA | 5.0 |  | Systems Integration Testing (SIT) | Complete | COMPLETE |  |  |  |  |  |
| 658 | 1.4.1.4.1.6.5 | SIT Component Integration Testing 2 Preparation Complete (incl. approval of SI SIT Component Integration Test Readiness Report) | milestone | 0d | 2023-11-06 A | 2023-11-06 A | 652, 657FS+1d, 634, 263 | 100% | 2023-11-06 | 2023-11-06 | 0d | 2023-11-06 | 2023-11-06 |  |  | SI Test | PP,IPA | 5.11 |  | Systems Integration Testing (SIT) | Complete | COMPLETE | MHHS-ART071 | T2-TE-0300 | SITAG | T2 |  |
| 659 | 1.4.1.4.1.7 | **CIT Interval 3 Preparation** |  | 54d | 2023-10-03 A | 2023-12-15 A |  | 100% | 2023-07-17 | 2023-11-20 | 91d | 2022-11-16 | 2023-11-20 |  | -0 | N/A | N/A | 5.0 | N/A | Systems Integration Testing (SIT) |  |  |  |  |  |  |  |
| 660 | 1.4.1.4.1.7.1 | **PIT Test Completion Report (incl. evidence)** |  | 26d | 2023-10-13 A | 2023-11-17 A |  | 100% | 2023-10-13 | 2023-11-10 | 21d | 2023-10-13 | 2023-11-10 |  |  | N/A | N/A | 5.0 | N/A | Systems Integration Testing (SIT) |  |  |  |  |  |  |  |
| 661 | 1.4.1.4.1.7.1.1 | Submit draft PIT Test Completion Report (incl. evidence) and submit to Programme for assurance |  | 11d | 2023-10-13 A | 2023-10-27 A |  | 100% | 2023-10-13 | 2023-10-13 | 1d | 2023-10-13 | 2023-10-13 | must start on 2023-10-13 |  | PP | SI Test | 5.0 |  | Systems Integration Testing (SIT) | Complete | COMPLETE |  |  |  |  |  |
| 662 | 1.4.1.4.1.7.1.2 | Finalise PIT Test Completion Report (incl. evidence) |  | 5d | 2023-10-30 A | 2023-11-03 A | 661 | 100% | 2023-10-16 | 2023-11-03 | 15d | 2023-10-16 | 2023-11-03 |  |  | PP | SI Test | 5.0 |  | Systems Integration Testing (SIT) | Complete | COMPLETE |  |  |  |  |  |
| 663 | 1.4.1.4.1.7.1.3 | PP PIT Completion Report (excl. Migration/Reverse Migration) submitted to Programme for assurance CIT Interval 3 | milestone | 0d | 2023-11-03 A | 2023-11-03 A | 662, 80, 96 | 100% | 2023-11-03 | 2023-11-03 | 0d | 2023-11-03 | 2023-11-03 |  |  | PP | SI Test | 5.11 |  | Systems Integration Testing (SIT) | Complete | COMPLETE |  | T3-DB-0017 | SITAG | T3 |  |
| 664 | 1.4.1.4.1.7.1.4 | PP Final PIT Completion Reports assured by SI |  | 10d | 2023-11-06 A | 2023-11-17 A | 663 | 100% | 2023-11-06 | 2023-11-10 | 5d | 2023-11-06 | 2023-11-10 |  |  | SI Test | PP | 5.0 |  | Systems Integration Testing (SIT) | Complete | COMPLETE |  |  |  |  |  |
| 665 | 1.4.1.4.1.7.2 | **Environments (SIT A)** |  | 51d | 2023-10-06 A | 2023-12-15 A |  | 100% | 2023-10-06 | 2023-11-10 | 26d | 2022-11-16 | 2023-11-10 |  | -0 | N/A | N/A | 5.0 | N/A | Systems Integration Testing (SIT) |  |  |  |  |  |  |  |
| 666 | 1.4.1.4.1.7.2.1 | Programme Participants Ready to Start Connectivity Proving | milestone | 0d | 2023-10-06 A | 2023-10-06 A |  | 100% | 2023-10-06 | 2023-10-06 | 0d |  |  | start no earlier than 2023-10-06 |  | PP | PP.SI Test | 5.10 | Simon Berry | Systems Integration Testing (SIT) | Complete | COMPLETE |  |  |  |  |  |
| 667 | 1.4.1.4.1.7.2.2 | SIT Participants' SIT A environments ready to start connectivity proving CIT Interval 3 | milestone | 0d | 2023-10-06 A | 2023-10-06 A | 666 | 100% | 2023-10-06 | 2023-10-06 | 0d | 2023-10-06 | 2023-10-06 |  |  | PP | PP,SI Test | 5.10 | Simon Berry | Systems Integration Testing (SIT) | Complete | COMPLETE | MHHS-ART139 | T3-TE-0021 | SITAG | T3 | 30/8 - lee said date is 30/10 |
| 668 | 1.4.1.4.1.7.2.3 | Internal Connectivity Proving Phase |  | 10d | 2023-10-09 A | 2023-10-20 A | 666FS+1d | 100% | 2023-10-09 | 2023-10-20 | 10d |  |  |  |  | PP | PP,SI Test | 5.10 | Simon Berry | Systems Integration Testing (SIT) | Complete | COMPLETE |  |  |  |  |  |
| 669 | 1.4.1.4.1.7.2.4 | Internal Connectivity Proving Phase Complete | milestone | 0d | 2023-10-20 A | 2023-10-20 A | 668 | 100% | 2023-10-20 | 2023-10-20 | 0d |  |  |  |  | PP | PP,SI Test | 5.10 | Simon Berry | Systems Integration Testing (SIT) | Complete | COMPLETE |  |  |  |  |  |
| 670 | 1.4.1.4.1.7.2.5 | DIP Onboarding Activity (1. PKI Officers and Certificates, 2. Set-up Validation, 3. End Point Creation, 4. Controlled Smoke Test ) |  | 35d | 2023-10-30 A | 2023-12-15 A | 669FS+5d | 100% | 2023-10-30 | 2023-11-10 | 10d |  |  |  |  | PP | PP,DIP Provider | 5.10 | Simon Berry | Systems Integration Testing (SIT) | Complete | COMPLETE |  |  |  |  |  |
| 671 | 1.4.1.4.1.7.2.6 | DIP Onboarding Complete | milestone | 0d | 2023-12-15 A | 2023-12-15 A | 670 | 100% | 2023-11-10 | 2023-11-10 | 0d |  |  |  |  | PP | PP,DIP Provider | 5.10 | Simon Berry | Systems Integration Testing (SIT) | Complete | COMPLETE |  |  |  |  |  |
| 672 | 1.4.1.4.1.7.2.7 | PPs Register PKI Officers and Request PKI certificates Complete - Interval 3 | milestone | 0d | 2023-12-15 A | 2023-12-15 A | 671FF | 100% | 2023-11-10 | 2023-11-10 | 0d | 2023-10-02 | 2023-10-06 |  |  | PP | PP,DIP Provider | 5.13 | Simon Berry | Systems Integration Testing (SIT) | Complete | COMPLETE |  | T3-TE-0099 | SITAG | T3 |  |
| 673 | 1.4.1.4.1.7.2.8 | PP Code Deployment | milestone | 0d | 2023-11-10 A | 2023-11-10 A | 669FS+15d | 100% | 2023-11-10 | 2023-11-10 | 0d |  |  | start no earlier than 2023-10-20 |  | PP | PP | 5.10 | Simon Berry | Systems Integration Testing (SIT) | Complete | COMPLETE |  |  |  |  |  |

Notes:
- 658: Amber because of dependency on PPs PIT and known reduced window to review and prepare documentation. No impact currently known. No action. 7/11 - Approved at TMAG on 6/11 with work-off
- 672: 09/01 - 1 participant yet to complete onboarding. Anticipated resolution unknown

| ID | WBS | Task | Type | Duration | Start | Finish | Predecessors | Complete | Baseline start | Baseline finish | Baseline duration | Baseline 1 start | Baseline 1 finish | Constraint | Baseline cost | Responsible | Involved | Update Version | MHHS Resource Name | MHHS Programme Phase | Sched Status | RAG | Artefact ID | Milestone ID | Text29 | Tier |
| --- | --- | --- | --- | --- | --- | --- | --- | --- | --- | --- | --- | --- | --- | --- | --- | --- | --- | --- | --- | --- | --- | --- | --- | --- | --- | --- |
| 674 | 1.4.1.4.1.7.3 | **Test Data (SIT A) Interval 3** |  | 34d | 2023-10-03 A | 2023-11-17 A |  | 100% | 2023-10-02 | 2023-11-03 | 25d | 2023-10-02 | 2023-11-03 |  |  | N/A | N/A | 5.0 | N/A | Systems Integration Testing (SIT) |  |  |  |  |  |  |
| 675 | 1.4.1.4.1.7.3.1 | Run data allocation |  | 4d | 2023-10-03 A | 2023-10-06 A | 645SS | 100% | 2023-10-02 | 2023-10-06 | 5d | 2023-10-02 | 2023-10-06 |  |  | SI Test |  | 5.0 | Cesar Lopes | Systems Integration Testing (SIT) | Complete | COMPLETE |  |  |  |  |
| 676 | 1.4.1.4.1.7.3.2 | Cleanse and populate data post cut |  | 5d | 2023-10-09 A | 2023-10-13 A | 675 | 100% | 2023-10-09 | 2023-10-13 | 5d | 2023-10-09 | 2023-10-13 |  |  | SI Test |  | 5.0 | Cesar Lopes | Systems Integration Testing (SIT) | Complete | COMPLETE |  |  |  |  |
| 677 | 1.4.1.4.1.7.3.3 | Transmit data sets to PPs |  | 2d | 2023-10-16 A | 2023-10-17 A | 676 | 100% | 2023-10-16 | 2023-10-17 | 2d | 2023-10-16 | 2023-10-17 |  |  | SI Test |  | 5.0 | Cesar Lopes | Systems Integration Testing (SIT) | Complete | COMPLETE |  |  |  |  |
| 678 | 1.4.1.4.1.7.3.4 | PP - Load test data to test environments |  | 8d | 2023-10-18 A | 2023-10-27 A | 677 | 100% | 2023-10-18 | 2023-10-27 | 8d | 2023-10-18 | 2023-10-27 |  |  | PP |  | 5.0 | Cesar Lopes | Systems Integration Testing (SIT) | Complete | COMPLETE |  |  |  |  |
| 679 | 1.4.1.4.1.7.3.5 | PP Check data integrity on test environment |  | 15d | 2023-10-30 A | 2023-11-17 A | 678 | 100% | 2023-10-30 | 2023-11-03 | 5d | 2023-10-30 | 2023-11-03 |  |  | PP |  | 5.0 | Cesar Lopes | Systems Integration Testing (SIT) | Complete | COMPLETE |  |  |  |  |
| 680 | 1.4.1.4.1.7.3.6 | PP submit self-declaration to Programme to confirm loading & verification of test data | milestone | 0d | 2023-11-17 A | 2023-11-17 A | 679FF | 100% | 2023-11-03 | 2023-11-03 | 0d | 2023-11-03 | 2023-11-03 |  |  | PP | SI Test | 5.0 | Cesar Lopes | Systems Integration Testing (SIT) | Complete | COMPLETE |  |  |  |  |
| 681 | 1.4.1.4.1.7.3.7 | Test Data (SIT A) Interval 3 Complete | milestone | 0d | 2023-11-17 A | 2023-11-17 A | 680 | 100% | 2023-11-03 | 2023-11-03 | 0d |  |  |  |  | SI Test | PP | 5.13 | Cesar Lopes | Systems Integration Testing (SIT) | Complete | COMPLETE | MHHS-ART148/169 | T3-TE-0075 | SITAG | T3 |
| 682 | 1.4.1.4.1.7.4 | **Other Preparation** |  | 25d | 2023-10-16 A | 2023-11-17 A |  | 100% | 2023-07-17 | 2023-10-06 | 60d | 2023-07-17 | 2023-10-06 |  |  | N/A | N/A | 5.0 | N/A | Systems Integration Testing (SIT) |  |  |  |  |  |  |
| 683 | 1.4.1.4.1.7.4.1 | Onboarding of Test Participants to Test Management Tool (Azure DevOps) |  | 25d | 2023-10-16 A | 2023-11-17 A |  | 100% | 2023-07-17 | 2023-10-06 | 60d | 2023-07-17 | 2023-10-06 | start no earlier than 2023-10-16 |  | SI Test | PP | 5.0 | Simon Berry | Systems Integration Testing (SIT) | Complete | COMPLETE |  |  |  |  |
| 684 | 1.4.1.4.1.7.4.2 | Test Management Tool onboarding |  | 25d | 2023-10-16 A | 2023-11-17 A |  | 100% | 2023-07-17 | 2023-10-06 | 60d | 2023-07-17 | 2023-10-06 | start no earlier than 2023-10-16 |  | PP | SI Test | 5.0 | Simon Berry | Systems Integration Testing (SIT) | Complete | COMPLETE |  |  |  |  |
| 685 | 1.4.1.4.1.7.5 | **SIT Component Integration Test Readiness Report** |  | 25d | 2023-10-16 A | 2023-11-17 A |  | 100% | 2023-10-16 | 2023-11-17 | 25d | 2023-10-16 | 2023-11-17 |  |  | N/A | N/A | 5.0 | N/A | Systems Integration Testing (SIT) |  |  |  |  |  |  |
| 686 | 1.4.1.4.1.7.5.1 | PP submit Test Readiness Report to Programme for assurance | milestone | 0d | 2023-11-03 A | 2023-11-03 A | 570 | 100% | 2023-11-03 | 2023-11-03 | 0d | 2023-11-03 | 2023-11-03 |  |  | PP | SI Test | 5.0 |  | Systems Integration Testing (SIT) | Complete | COMPLETE |  |  |  |  |
| 687 | 1.4.1.4.1.7.5.2 | SI assure Test Participants' Test Readiness Reports |  | 5d | 2023-11-06 A | 2023-11-10 A | 686FF+5d | 100% | 2023-11-06 | 2023-11-10 | 5d | 2023-11-06 | 2023-11-10 |  |  | SI Test | PP,IPA | 5.0 |  | Systems Integration Testing (SIT) | Complete | COMPLETE |  |  |  |  |
| 688 | 1.4.1.4.1.7.5.3 | SI develop Overarching SIT Component Integration Test Readiness Report |  | 20d | 2023-10-16 A | 2023-11-10 A | 687FF | 100% | 2023-10-16 | 2023-11-10 | 20d | 2023-10-16 | 2023-11-10 |  |  | SI Test |  | 5.0 |  | Systems Integration Testing (SIT) | Complete | COMPLETE |  |  |  |  |
| 689 | 1.4.1.4.1.7.5.4 | Artefact review (via TMAG) and updates |  | 5d | 2023-11-13 A | 2023-11-17 A | 688 | 100% | 2023-11-13 | 2023-11-17 | 5d | 2023-11-13 | 2023-11-17 |  |  | SI Test | PP,IPA | 5.0 |  | Systems Integration Testing (SIT) | Complete | COMPLETE |  |  |  |  |
| 690 | 1.4.1.4.1.7.6 | SIT Component Integration Testing 3 Preparation Complete (incl. approval of SI SIT Component Integration Test Readiness Report) | milestone | 0d | 2023-11-20 A | 2023-11-20 A | 689FS+1d, 663, 667, 686, 684, 681, 281 | 100% | 2023-11-20 | 2023-11-20 | 0d | 2023-11-20 | 2023-11-20 |  |  | SI Test | PP,IPA | 5.12 |  | Systems Integration Testing (SIT) | Complete | COMPLETE | MHHS-ART071 | T2-TE-0350 | SITAG | T2 |
| 691 | 1.4.1.4.1.8 | **CIT Interval 4 Preparation** |  | 36d | 2023-10-16 A | 2023-12-04 A |  | 100% | 2023-10-16 | 2023-12-04 | 36d | 2022-11-16 | 2023-12-04 |  | -0 | N/A | N/A | 5.0 | N/A | Systems Integration Testing (SIT) |  |  |  |  |  |  |
| 692 | 1.4.1.4.1.8.1 | **PIT Test Completion Report (incl. evidence)** |  | 21d | 2023-10-27 A | 2023-11-24 A |  | 100% | 2023-10-27 | 2023-11-24 | 21d | 2023-10-27 | 2023-11-24 |  |  | N/A | N/A | 5.0 | N/A | Systems Integration Testing (SIT) |  |  |  |  |  |  |
| 693 | 1.4.1.4.1.8.1.1 | Submit draft PIT Test Completion Report (incl. evidence) and submit to Programme for assurance |  | 1d | 2023-10-27 A | 2023-10-27 A |  | 100% | 2023-10-27 | 2023-10-27 | 1d | 2023-10-27 | 2023-10-27 | must start on 2023-10-27 |  | PP | SI Test | 5.0 |  | Systems Integration Testing (SIT) | Complete | COMPLETE |  |  |  |  |
| 694 | 1.4.1.4.1.8.1.2 | Finalise PIT Test Completion Report (incl. evidence) |  | 15d | 2023-10-30 A | 2023-11-17 A | 693 | 100% | 2023-10-30 | 2023-11-17 | 15d | 2023-10-30 | 2023-11-17 |  |  | PP | SI Test | 5.0 |  | Systems Integration Testing (SIT) | Complete | COMPLETE |  |  |  |  |
| 695 | 1.4.1.4.1.8.1.3 | PP PIT Completion Report (excl. Migration/Reverse Migration) submitted to Programme for assurance CIT Interval 4 | milestone | 0d | 2023-11-17 A | 2023-11-17 A | 694, 80, 96 | 100% | 2023-11-17 | 2023-11-17 | 0d | 2023-11-17 | 2023-11-17 |  |  | PP | SI Test | 5.13 |  | Systems Integration Testing (SIT) | Complete | COMPLETE |  | T3-DB-0019 | SITAG | T3 |
| 696 | 1.4.1.4.1.8.1.4 | PP Final PIT Completion Reports assured by SI |  | 5d | 2023-11-20 A | 2023-11-24 A | 695 | 100% | 2023-11-20 | 2023-11-24 | 5d | 2023-11-20 | 2023-11-24 |  |  | SI Test | PP | 5.0 |  | Systems Integration Testing (SIT) | Complete | COMPLETE |  |  |  |  |
| 697 | 1.4.1.4.1.8.2 | **Environments (SIT A)** |  | 25d | 2023-10-23 A | 2023-11-24 A |  | 100% | 2023-10-20 | 2023-11-24 | 25d | 2022-11-16 | 2023-11-24 |  | -0 | N/A | N/A | 5.0 | N/A | Systems Integration Testing (SIT) |  |  |  |  |  |  |
| 698 | 1.4.1.4.1.8.2.1 | Programme Participants Ready to Start Connectivity Proving | milestone | 0d | 2023-10-23 A | 2023-10-23 A |  | 100% | 2023-10-23 | 2023-10-23 | 0d |  |  | start no earlier than 2023-10-23 |  | PP |  | 5.10 | Simon Berry | Systems Integration Testing (SIT) | Complete | COMPLETE |  |  |  |  |
| 699 | 1.4.1.4.1.8.2.2 | SIT Participants' SIT A environments ready to start connectivity proving CIT Interval 4 | milestone | 0d | 2023-10-23 A | 2023-10-23 A | 698 | 100% | 2023-10-20 | 2023-10-20 | 0d | 2023-10-20 | 2023-10-20 |  |  | PP | PP,IPA | 5.10 | Simon Berry | Systems Integration Testing (SIT) | Complete | COMPLETE | MHHS-ART139 | T3-TE-0022 | SITAG | T3 |
| 700 | 1.4.1.4.1.8.2.3 | Internal Connectivity Proving Phase |  | 10d | 2023-10-23 A | 2023-11-03 A | 699 | 100% | 2023-10-23 | 2023-11-03 | 10d |  |  |  |  | PP |  | 5.10 | Simon Berry | Systems Integration Testing (SIT) | Complete | COMPLETE |  |  |  |  |
| 701 | 1.4.1.4.1.8.2.4 | Internal Connectivity Proving Phase Complete | milestone | 0d | 2023-11-03 A | 2023-11-03 A | 700 | 100% | 2023-11-03 | 2023-11-03 | 0d |  |  |  |  | PP |  | 5.10 | Simon Berry | Systems Integration Testing (SIT) | Complete | COMPLETE |  |  |  |  |
| 702 | 1.4.1.4.1.8.2.5 | DIP Onboarding Activity (1. PKI Officers and Certificates, 2. Set-up Validation, 3. End Point Creation, 4. Controlled Smoke Test ) |  | 10d | 2023-11-13 A | 2023-11-24 A | 701FS+5d | 100% | 2023-11-13 | 2023-11-24 | 10d |  |  |  |  | PP |  | 5.10 | Simon Berry | Systems Integration Testing (SIT) | Complete | COMPLETE |  |  |  |  |
| 703 | 1.4.1.4.1.8.2.6 | DIP Onboarding Complete | milestone | 0d | 2023-11-24 A | 2023-11-24 A | 702 | 100% | 2023-11-24 | 2023-11-24 | 0d |  |  |  |  | PP |  | 5.10 | Simon Berry | Systems Integration Testing (SIT) | Complete | COMPLETE |  |  |  |  |
| 704 | 1.4.1.4.1.8.2.7 | PPs register PKI Officers and Request PKI Certificates Complete - Interval 4 | milestone | 0d | 2023-11-24 A | 2023-11-24 A | 703 | 100% | 2023-11-24 | 2023-11-24 | 0d |  |  |  |  | PP | DIP Provider | 5.16 | Simon Berry | Systems Integration Testing (SIT) | Complete | COMPLETE |  | T3-TE-0100 | SITAG | T3 |
| 705 | 1.4.1.4.1.8.2.8 | PP Code Deployment | milestone | 0d | 2023-11-17 A | 2023-11-17 A |  | 100% | 2023-11-17 | 2023-11-17 | 0d |  |  | start no earlier than 2023-11-17 |  | PP |  | 5.10 | Simon Berry | Systems Integration Testing (SIT) | Complete | COMPLETE |  |  |  |  |

Notes:
- 681: 28/7: CH: added in to be aT3 milestone. 14/11-Red because 8 out of 9 participants complete. Final data checks from PP to be made this week. No impact to CIT interval 3 start. / Action: 28/7: CH: Needs to be set-up as a reporting milestone. 31/7: Check with Cesar if has been approved so can be baselined
- 695: 21/11-Red because not all received. Reminders sent. No impact. No issue
- 704: 16/02 - Red because 2 participants yet to complete onboarding. Completed 19/1/24

| ID | WBS | Task | Type | Duration | Start | Finish | Predecessors | Complete | Baseline start | Baseline finish | Baseline duration | Baseline 1 start | Baseline 1 finish | Constraint | Baseline cost | Responsible | Involved | Update Version | MHHS Resource Name | MHHS Programme Phase | Sched Status | RAG | Artefact ID | Milestone ID | Text29 | Tier |
| --- | --- | --- | --- | --- | --- | --- | --- | --- | --- | --- | --- | --- | --- | --- | --- | --- | --- | --- | --- | --- | --- | --- | --- | --- | --- | --- |
| 706 | 1.4.1.4.1.8.3 | **Test Data (SIT A) Interval 4** |  | 30d | 2023-10-23 A | 2023-12-01 A |  | 100% | 2023-10-16 | 2023-11-17 | 25d | 2023-10-16 | 2023-11-17 |  |  | N/A | N/A | 5.0 | N/A | Systems Integration Testing (SIT) |  |  |  |  |  |  |
| 707 | 1.4.1.4.1.8.3.1 | Run data allocation |  | 5d | 2023-10-23 A | 2023-10-27 A | 676FS+5d | 100% | 2023-10-16 | 2023-10-20 | 5d | 2023-10-16 | 2023-10-20 |  |  | SI Test |  | 5.0 | Cesar Lopes | Systems Integration Testing (SIT) | Complete | COMPLETE |  |  |  |  |
| 708 | 1.4.1.4.1.8.3.2 | Cleanse and populate data post cut |  | 2d | 2023-10-30 A | 2023-10-31 A | 707 | 100% | 2023-10-23 | 2023-10-27 | 5d | 2023-10-23 | 2023-10-27 |  |  | SI Test |  | 5.0 | Cesar Lopes | Systems Integration Testing (SIT) | Complete | COMPLETE |  |  |  |  |
| 709 | 1.4.1.4.1.8.3.3 | Transmit data sets to PPs |  | 5d | 2023-11-01 A | 2023-11-07 A | 708 | 100% | 2023-10-30 | 2023-10-31 | 2d | 2023-10-30 | 2023-10-31 |  |  | SI Test |  | 5.0 | Cesar Lopes | Systems Integration Testing (SIT) | Complete | COMPLETE |  |  |  |  |
| 710 | 1.4.1.4.1.8.3.4 | PP - Load test data to test environments |  | 5d | 2023-11-08 A | 2023-11-14 A | 709 | 100% | 2023-11-01 | 2023-11-10 | 8d | 2023-11-01 | 2023-11-10 |  |  | PP |  | 5.0 | Cesar Lopes | Systems Integration Testing (SIT) | Complete | COMPLETE |  |  |  |  |
| 711 | 1.4.1.4.1.8.3.5 | PP Check data integrity on test environment |  | 13d | 2023-11-15 A | 2023-12-01 A | 710 | 100% | 2023-11-13 | 2023-11-17 | 5d | 2023-11-13 | 2023-11-17 |  |  | PP |  | 5.0 | Richard Puddephatt | Systems Integration Testing (SIT) | Complete | COMPLETE |  |  |  |  |
| 712 | 1.4.1.4.1.8.3.6 | PP submit self-declaration to Programme to confirm loading & verification of test data | milestone | 0d | 2023-12-01 A | 2023-12-01 A | 711FF | 100% | 2023-11-17 | 2023-11-17 | 0d | 2023-11-17 | 2023-11-17 |  |  | PP | SI Test | 5.0 | Richard Puddephatt | Systems Integration Testing (SIT) | Complete | COMPLETE |  |  |  |  |
| 713 | 1.4.1.4.1.8.3.7 | Test Data (SIT A) Interval 4 Complete | milestone | 0d | 2023-12-01 A | 2023-12-01 A | 712 | 100% | 2023-11-17 | 2023-11-17 | 0d |  |  |  |  | SI Test | PP | 5.13 | Richard Puddephatt | Systems Integration Testing (SIT) | Complete | COMPLETE | MHHS-ART148/169 | T3-TE-0076 | SITAG | T3 |
| 714 | 1.4.1.4.1.8.4 | **Other Preparation** |  | 25d | 2023-10-30 A | 2023-12-01 A |  | 100% | 2023-10-30 | 2023-12-01 | 25d | 2023-07-31 | 2023-10-20 |  | -0 | N/A | N/A | 5.0 | N/A | Systems Integration Testing (SIT) |  |  |  |  |  |  |
| 715 | 1.4.1.4.1.8.4.1 | Onboarding of Test Participants to Test Management Tool (Azure DevOps) |  | 25d | 2023-10-30 A | 2023-12-01 A |  | 100% | 2023-10-30 | 2023-12-01 | 25d | 2023-07-31 | 2023-10-20 | start no earlier than 2023-10-30 |  | SI Test | PP | 5.0 | Simon Berry | Systems Integration Testing (SIT) | Complete | COMPLETE |  |  |  |  |
| 716 | 1.4.1.4.1.8.4.2 | Test Management Tool onboarding |  | 25d | 2023-10-30 A | 2023-12-01 A |  | 100% | 2023-10-30 | 2023-12-01 | 25d | 2023-07-31 | 2023-10-20 | start no earlier than 2023-10-30 |  | PP | SI Test | 5.0 | Simon Berry | Systems Integration Testing (SIT) | Complete | COMPLETE |  |  |  |  |
| 717 | 1.4.1.4.1.8.5 | **SIT Component Integration Test Readiness Report** |  | 27d | 2023-10-16 A | 2023-11-21 A |  | 100% | 2023-10-30 | 2023-12-01 | 25d | 2023-10-30 | 2023-12-01 |  |  | N/A | N/A | 5.0 | N/A | Systems Integration Testing (SIT) |  |  |  |  |  |  |
| 718 | 1.4.1.4.1.8.5.1 | PP submit Test Readiness Report to Programme for assurance | milestone | 0d | 2023-11-03 A | 2023-11-03 A | 570 | 100% | 2023-11-17 | 2023-11-17 | 0d | 2023-11-17 | 2023-11-17 |  |  | PP | SI Test | 5.0 |  | Systems Integration Testing (SIT) | Complete | COMPLETE |  |  |  |  |
| 719 | 1.4.1.4.1.8.5.2 | SI assure Test Participants' Test Readiness Reports |  | 5d | 2023-11-06 A | 2023-11-10 A | 718FF+5d | 100% | 2023-11-20 | 2023-11-24 | 5d | 2023-11-20 | 2023-11-24 |  |  | SI Test | PP,IPA | 5.0 |  | Systems Integration Testing (SIT) | Complete | COMPLETE |  |  |  |  |
| 720 | 1.4.1.4.1.8.5.3 | SI develop Overarching SIT Component Integration Test Readiness Report |  | 20d | 2023-10-16 A | 2023-11-10 A | 719FF | 100% | 2023-10-30 | 2023-11-24 | 20d | 2023-10-30 | 2023-11-24 |  |  | SI Test |  | 5.0 |  | Systems Integration Testing (SIT) | Complete | COMPLETE |  |  |  |  |
| 721 | 1.4.1.4.1.8.5.4 | Artefact review (via SITAG) and updates |  | 7d | 2023-11-13 A | 2023-11-21 A | 720 | 100% | 2023-11-27 | 2023-12-01 | 5d | 2023-11-27 | 2023-12-01 |  |  | SI Test | PP,IPA | 5.0 |  | Systems Integration Testing (SIT) | Complete | COMPLETE |  |  |  |  |
| 722 | 1.4.1.4.1.8.6 | SIT Component Integration Testing 4 Preparation Complete (incl. approval of SI SIT Component Integration Test Readiness Report) | milestone | 0d | 2023-12-04 A | 2023-12-04 A | 721FS+2d, 695, 699, 718, 713, 298FS+1d | 100% | 2023-12-04 | 2023-12-04 | 0d | 2023-12-04 | 2023-12-04 |  |  | SI Test | PP,IPA | 5.13 |  | Systems Integration Testing (SIT) | Complete | COMPLETE | MHHS-ART071 | T2-TE-0400 | SITAG | T2 |
| 723 | 1.4.1.4.1.9 | **CIT Interval 5 Preparation** |  | 53d | 2023-11-01 A | 2024-01-12 A |  | 100% | 2023-10-30 | 2024-01-12 | 55d | 2022-11-16 | 2024-01-08 |  | -0 | N/A | N/A | 5.0 | N/A | Systems Integration Testing (SIT) |  |  |  |  |  |  |
| 724 | 1.4.1.4.1.9.1 | **PIT Test Completion Report (incl. evidence)** |  | 21d | 2023-11-17 A | 2023-12-15 A |  | 100% | 2023-11-17 | 2023-12-15 | 21d | 2023-11-17 | 2023-12-15 |  |  | N/A | N/A | 5.0 | N/A | Systems Integration Testing (SIT) |  |  |  |  |  |  |
| 725 | 1.4.1.4.1.9.1.1 | Submit draft PIT Test Completion Report (incl. evidence) and submit to Programme for assurance |  | 1d | 2023-11-17 A | 2023-11-17 A |  | 100% | 2023-11-17 | 2023-11-17 | 1d | 2023-11-17 | 2023-11-17 | must start on 2023-11-17 |  | PP | SI Test | 5.0 | Lee Cox | Systems Integration Testing (SIT) | Complete | COMPLETE |  |  |  |  |
| 726 | 1.4.1.4.1.9.1.2 | Finalise PIT Test Completion Report (incl. evidence) |  | 15d | 2023-11-20 A | 2023-12-08 A | 725 | 100% | 2023-11-20 | 2023-12-08 | 15d | 2023-11-20 | 2023-12-08 |  |  | PP | SI Test | 5.0 | Lee Cox | Systems Integration Testing (SIT) | Complete | COMPLETE |  |  |  |  |
| 727 | 1.4.1.4.1.9.1.3 | PP PIT Completion Report (excl. Migration/Reverse Migration) submitted to Programme for assurance CIT Interval 5 | milestone | 0d | 2023-12-08 A | 2023-12-08 A | 726, 80, 96 | 100% | 2023-12-08 | 2023-12-08 | 0d | 2023-12-08 | 2023-12-08 |  |  | PP | SI Test | 5.14 | Lee Cox | Systems Integration Testing (SIT) | Complete | COMPLETE |  | T3-DB-0021 | SITAG | T3 |
| 728 | 1.4.1.4.1.9.1.4 | PP Final PIT Completion Reports assured by SI |  | 5d | 2023-12-11 A | 2023-12-15 A | 727 | 100% | 2023-12-11 | 2023-12-15 | 5d | 2023-12-11 | 2023-12-15 |  |  | SI Test | PP | 5.0 | Lee Cox | Systems Integration Testing (SIT) | Complete | COMPLETE |  |  |  |  |
| 729 | 1.4.1.4.1.9.2 | **Environments (SIT A)** |  | 21d | 2023-11-10 A | 2023-12-08 A |  | 100% | 2023-11-10 | 2023-12-08 | 21d | 2022-11-16 | 2023-12-15 |  | -0 | N/A | N/A | 5.0 | N/A | Systems Integration Testing (SIT) |  |  |  |  |  |  |
| 730 | 1.4.1.4.1.9.2.1 | Programme Participants Ready to Start Connectivity Proving | milestone | 0d | 2023-11-10 A | 2023-11-10 A |  | 100% | 2023-11-10 | 2023-11-10 | 0d |  |  | start no earlier than 2023-11-10 |  | PP |  | 5.10 | Simon Berry | Systems Integration Testing (SIT) | Complete | COMPLETE |  |  |  |  |
| 731 | 1.4.1.4.1.9.2.2 | SIT Participants' SIT A environments ready to start connectivity proving CIT Interval 5 | milestone | 0d | 2023-11-10 A | 2023-11-10 A | 730 | 100% | 2023-11-10 | 2023-11-10 | 0d | 2023-11-10 | 2023-11-10 |  |  | PP | PP,IPA | 5.6 | Simon Berry | Systems Integration Testing (SIT) | Complete | COMPLETE | MHHS-ART139 | T3-TE-0023 | SITAG | T3 |
| 732 | 1.4.1.4.1.9.2.3 | Internal Connectivity Proving Phase |  | 10d | 2023-11-13 A | 2023-11-24 A | 730FS+1d | 100% | 2023-11-13 | 2023-11-24 | 10d |  |  |  |  | PP |  | 5.10 | Simon Berry | Systems Integration Testing (SIT) | Complete | COMPLETE |  |  |  |  |
| 733 | 1.4.1.4.1.9.2.4 | Internal Connectivity Proving Phase Complete | milestone | 0d | 2023-11-24 A | 2023-11-24 A | 732 | 100% | 2023-11-24 | 2023-11-24 | 0d |  |  |  |  | PP |  | 5.10 | Simon Berry | Systems Integration Testing (SIT) | Complete | COMPLETE |  |  |  |  |
| 734 | 1.4.1.4.1.9.2.5 | DIP Onboarding Activity (1. PKI Officers and Certificates, 2. Set-up Validation, 3. End Point Creation, 4. Controlled Smoke Test ) |  | 10d | 2023-11-27 A | 2023-12-08 A | 733 | 100% | 2023-11-27 | 2023-12-08 | 10d |  |  |  |  | PP |  | 5.10 | Simon Berry | Systems Integration Testing (SIT) | Complete | COMPLETE |  |  |  |  |
| 735 | 1.4.1.4.1.9.2.6 | DIP Onboarding Complete | milestone | 0d | 2023-12-08 A | 2023-12-08 A | 734 | 100% | 2023-12-08 | 2023-12-08 | 0d |  |  |  |  | PP |  | 5.10 | Simon Berry | Systems Integration Testing (SIT) | Complete | COMPLETE |  |  |  |  |
| 736 | 1.4.1.4.1.9.2.7 | PPs register PKI Officers and Request PKI Certificates Complete - Interval 5 | milestone | 0d | 2023-12-08 A | 2023-12-08 A | 735 | 100% | 2023-12-08 | 2023-12-08 | 0d | 2023-11-06 | 2023-11-10 |  |  | PP | DIP Provider | 5.17 | Simon Berry | Systems Integration Testing (SIT) | Complete | COMPLETE |  | T3-TE-0101 | SITAG | T3 |
| 737 | 1.4.1.4.1.9.2.8 | PP Code Deployment | milestone | 0d | 2023-12-08 A | 2023-12-08 A | 736 | 100% | 2023-12-08 | 2023-12-08 | 0d |  |  | start no earlier than 2023-10-20 |  | PP |  | 5.10 | Simon Berry | Systems Integration Testing (SIT) | Complete | COMPLETE |  |  |  |  |

Notes:
- 713: 28/11 - red because data was delivered 1 week late. This led to an onward impact. We expect data to be loaded and checked by 1/12. No impact on CIT Tests Start date
- 722: 5/12 - Approved at Etmag on 4/12 with work off plan
- 727: 4/12- Amber because not all received yet. No impact. No action. 19/12 - complete on 14/12
- 736: 16/01- Red because 1 has yet to complete onboarding. 30/1 - Completed on 26/1/24

| ID | WBS | Task | Type | Duration | Start | Finish | Predecessors | Complete | Baseline start | Baseline finish | Baseline duration | Baseline 1 start | Baseline 1 finish | Constraint | Baseline cost | Responsible | Involved | Update Version | MHHS Resource Name | MHHS Programme Phase | Sched Status | RAG | Artefact ID | Milestone ID | Text29 | Tier |
| --- | --- | --- | --- | --- | --- | --- | --- | --- | --- | --- | --- | --- | --- | --- | --- | --- | --- | --- | --- | --- | --- | --- | --- | --- | --- | --- |
| 738 | 1.4.1.4.1.9.3 | **Test Data (SIT A) Interval 5** |  | 33d | 2023-11-01 A | 2023-12-15 A |  | 100% | 2023-10-30 | 2023-12-08 | 30d | 2023-10-30 | 2023-12-08 |  |  | N/A | N/A | 5.0 | N/A | Systems Integration Testing (SIT) |  |  |  |  |  |  |
| 739 | 1.4.1.4.1.9.3.1 | Run data allocation |  | 5d | 2023-11-01 A | 2023-11-07 A | 709SS | 100% | 2023-10-30 | 2023-11-10 | 10d | 2023-10-30 | 2023-11-10 |  |  | SI Test |  | 5.0 | Cesar Lopes | Systems Integration Testing (SIT) | Complete | COMPLETE |  |  |  |  |
| 740 | 1.4.1.4.1.9.3.2 | Cleanse and populate data post cut |  | 8d | 2023-11-08 A | 2023-11-17 A | 739 | 100% | 2023-11-13 | 2023-11-17 | 5d | 2023-11-13 | 2023-11-17 |  |  | SI Test |  | 5.0 | Cesar Lopes | Systems Integration Testing (SIT) | Complete | COMPLETE |  |  |  |  |
| 741 | 1.4.1.4.1.9.3.3 | Transmit data sets to PPs |  | 2d | 2023-11-20 A | 2023-11-21 A | 740 | 100% | 2023-11-20 | 2023-11-21 | 2d | 2023-11-20 | 2023-11-21 |  |  | SI Test |  | 5.0 | Cesar Lopes | Systems Integration Testing (SIT) | Complete | COMPLETE |  |  |  |  |
| 742 | 1.4.1.4.1.9.3.4 | PP - Load test data to test environments |  | 8d | 2023-11-22 A | 2023-12-01 A | 741 | 100% | 2023-11-22 | 2023-12-01 | 8d | 2023-11-22 | 2023-12-01 |  |  | PP |  | 5.0 | Richard Puddephatt | Systems Integration Testing (SIT) | Complete | COMPLETE |  |  |  |  |
| 743 | 1.4.1.4.1.9.3.5 | PP Check data integrity on test environment |  | 10d | 2023-12-04 A | 2023-12-15 A | 742 | 100% | 2023-12-04 | 2023-12-08 | 5d | 2023-12-04 | 2023-12-08 |  |  | PP |  | 5.0 | Richard Puddephatt | Systems Integration Testing (SIT) | Complete | COMPLETE |  |  |  |  |
| 744 | 1.4.1.4.1.9.3.6 | PP submit self-declaration to Programme to confirm loading & verification of test data | milestone | 0d | 2023-12-15 A | 2023-12-15 A | 743FF | 100% | 2023-12-08 | 2023-12-08 | 0d | 2023-12-08 | 2023-12-08 |  |  | PP | SI Test | 5.0 | Richard Puddephatt | Systems Integration Testing (SIT) | Complete | COMPLETE |  |  |  |  |
| 745 | 1.4.1.4.1.9.3.7 | Test Data (SIT A) Interval 5 Complete | milestone | 0d | 2023-12-15 A | 2023-12-15 A | 744 | 100% | 2023-12-08 | 2023-12-08 | 0d |  |  |  |  | SI Test | PP | 5.14 | Richard Puddephatt | Systems Integration Testing (SIT) | Complete | COMPLETE | MHHS-ART148/169 | T3-TE-0077 | SITAG | T3 |
| 746 | 1.4.1.4.1.9.4 | **Other Preparation** |  | 40d | 2023-11-20 A | 2024-01-12 A |  | 100% | 2023-11-20 | 2024-01-12 | 40d | 2023-08-21 | 2023-11-10 |  | -0 | N/A | N/A | 5.0 | N/A | Systems Integration Testing (SIT) |  |  |  |  |  |  |
| 747 | 1.4.1.4.1.9.4.1 | Onboarding of Test Participants to Test Management Tool (Azure DevOps) |  | 40d | 2023-11-20 A | 2024-01-12 A |  | 100% | 2023-11-20 | 2024-01-12 | 40d | 2023-08-21 | 2023-11-10 | start no earlier than 2023-11-20 |  | SI Test | PP | 5.0 | Simon Berry | Systems Integration Testing (SIT) | Complete | COMPLETE |  |  |  |  |
| 748 | 1.4.1.4.1.9.4.2 | Test Management Tool onboarding |  | 36d | 2023-11-20 A | 2024-01-08 A |  | 100% | 2023-11-20 | 2024-01-08 | 36d | 2023-08-21 | 2023-11-10 | start no earlier than 2023-11-20 |  | PP | SI Test | 5.0 | Simon Berry | Systems Integration Testing (SIT) | Complete | COMPLETE |  |  |  |  |
| 749 | 1.4.1.4.1.9.5 | **SIT Component Integration Test Readiness Report** |  | 35d | 2023-11-20 A | 2024-01-05 A |  | 100% | 2023-11-20 | 2024-01-05 | 35d | 2023-11-20 | 2024-01-05 |  |  | N/A | N/A | 5.0 | N/A | Systems Integration Testing (SIT) |  |  |  |  |  |  |
| 750 | 1.4.1.4.1.9.5.1 | PP submit Test Readiness Report to Programme for assurance | milestone | 0d | 2023-12-08 A | 2023-12-08 A | 574 | 100% | 2023-12-08 | 2023-12-08 | 0d | 2023-12-08 | 2023-12-08 |  |  | PP | SI Test | 5.0 | Lee Cox | Systems Integration Testing (SIT) | Complete | COMPLETE |  |  |  |  |
| 751 | 1.4.1.4.1.9.5.2 | SI assure Test Participants' Test Readiness Reports |  | 5d | 2023-12-11 A | 2023-12-15 A | 750FF+5d | 100% | 2023-12-11 | 2023-12-15 | 5d | 2023-12-11 | 2023-12-15 |  |  | SI Test | PP,IPA | 5.0 | Lee Cox | Systems Integration Testing (SIT) | Complete | COMPLETE |  |  |  |  |
| 752 | 1.4.1.4.1.9.5.3 | SI develop Overarching SIT Component Integration Test Readiness Report |  | 20d | 2023-11-20 A | 2023-12-15 A | 751FF | 100% | 2023-11-20 | 2023-12-15 | 20d | 2023-11-20 | 2023-12-15 |  |  | SI Test |  | 5.0 | Lee Cox | Systems Integration Testing (SIT) | Complete | COMPLETE |  |  |  |  |
| 753 | 1.4.1.4.1.9.5.4 | Artefact review (via SITAG) and updates |  | 15d | 2023-12-18 A | 2024-01-05 A | 752 | 100% | 2023-12-18 | 2024-01-05 | 15d | 2023-12-18 | 2024-01-05 |  |  | SI Test | PP,IPA | 5.0 | Lee Cox | Systems Integration Testing (SIT) | Complete | COMPLETE |  |  |  |  |
| 754 | 1.4.1.4.1.9.6 | SIT Component Integration Testing 5 Preparation Complete (incl. approval of SI SIT Component Integration Test Readiness Report) | milestone | 0d | 2024-01-08 A | 2024-01-08 A | 753FS+1d, 727, 731, 748, 750, 745, 400, 383 | 100% | 2024-01-08 | 2024-01-08 | 0d | 2024-01-08 | 2024-01-08 |  |  | SI Test | PP,IPA | 5.15 |  | Systems Integration Testing (SIT) | Complete | COMPLETE | MHHS-ART071 | T2-TE-0450 | SITAG | T2 |
| 755 | 1.4.1.4.1.10 | **CIT Interval 6 Preparation** |  | 45d | 2023-11-20 A | 2024-01-19 A |  | 100% | 2023-11-20 | 2024-01-22 | 46d | 2022-11-16 | 2024-01-22 |  | -0 | N/A | N/A | 5.0 | N/A | Systems Integration Testing (SIT) |  |  |  |  |  |  |
| 756 | 1.4.1.4.1.10.1 | **PIT Test Completion Report (incl. evidence)** |  | 31d | 2023-12-01 A | 2024-01-12 A |  | 100% | 2023-12-01 | 2024-01-12 | 31d | 2023-12-01 | 2024-01-12 |  |  | N/A | N/A | 5.0 | N/A | Systems Integration Testing (SIT) |  |  |  |  |  |  |
| 757 | 1.4.1.4.1.10.1.1 | Submit draft PIT Test Completion Report (incl. evidence) and submit to Programme for assurance |  | 1d | 2023-12-01 A | 2023-12-01 A |  | 100% | 2023-12-01 | 2023-12-01 | 1d | 2023-12-01 | 2023-12-01 | must start on 2023-12-01 |  | PP | SI Test | 5.0 |  | Systems Integration Testing (SIT) | Complete | COMPLETE |  |  |  |  |
| 758 | 1.4.1.4.1.10.1.2 | Finalise PIT Test Completion Report (incl. evidence) |  | 25d | 2023-12-04 A | 2024-01-05 A | 757 | 100% | 2023-12-04 | 2024-01-05 | 25d | 2023-12-04 | 2024-01-05 |  |  | PP | SI Test | 5.0 |  | Systems Integration Testing (SIT) | Complete | COMPLETE |  |  |  |  |
| 759 | 1.4.1.4.1.10.1.3 | PP PIT Completion Report (excl. Migration/Reverse Migration) submitted to Programme for assurance CIT Interval 6 | milestone | 0d | 2024-01-05 A | 2024-01-05 A | 758, 80, 96, 220, 225, 228 | 100% | 2024-01-05 | 2024-01-05 | 0d | 2024-01-05 | 2024-01-05 |  |  | PP | SI Test | 5.19 |  | Systems Integration Testing (SIT) | Complete | COMPLETE |  | T3-DB-0023 | SITAG | T3 |
| 760 | 1.4.1.4.1.10.1.4 | PP Final PIT Completion Reports assured by SI |  | 5d | 2024-01-08 A | 2024-01-12 A | 759 | 100% | 2024-01-08 | 2024-01-12 | 5d | 2024-01-08 | 2024-01-12 |  |  | SI Test | PP | 5.19 |  | Systems Integration Testing (SIT) | Complete | COMPLETE |  |  |  |  |
| 761 | 1.4.1.4.1.10.2 | **Environments (SIT A)** |  | 30d | 2023-11-24 A | 2024-01-05 A |  | 100% | 2023-11-24 | 2024-01-05 | 30d | 2022-11-16 | 2024-01-05 |  | -0 | N/A | N/A | 5.0 | N/A | Systems Integration Testing (SIT) |  |  |  |  |  |  |
| 762 | 1.4.1.4.1.10.2.1 | Programme Participants Ready to Start Connectivity Proving | milestone | 0d | 2023-11-24 A | 2023-11-24 A |  | 100% | 2023-11-24 | 2023-11-24 | 0d |  |  | start no earlier than 2023-11-24 |  | PP |  | 5.10 | Simon Berry | Systems Integration Testing (SIT) | Complete | COMPLETE |  |  |  |  |
| 763 | 1.4.1.4.1.10.2.2 | SIT Participants' SIT A environments ready to start connectivity proving CIT Interval 6 | milestone | 0d | 2023-11-24 A | 2023-11-24 A | 762 | 100% | 2023-11-24 | 2023-11-24 | 0d | 2023-11-24 | 2023-11-24 |  |  | PP | PP,IPA | 5.6 | Simon Berry | Systems Integration Testing (SIT) | Complete | COMPLETE | MHHS-ART139 | T3-TE-0024 | SITAG | T3 |
| 764 | 1.4.1.4.1.10.2.3 | Internal Connectivity Proving Phase |  | 10d | 2023-11-27 A | 2023-12-08 A | 763FS+1d | 100% | 2023-11-27 | 2023-12-08 | 10d |  |  |  |  | PP |  | 5.10 | Simon Berry | Systems Integration Testing (SIT) | Complete | COMPLETE |  |  |  |  |
| 765 | 1.4.1.4.1.10.2.4 | Internal Connectivity Proving Phase Complete | milestone | 0d | 2023-12-08 A | 2023-12-08 A | 764 | 100% | 2023-12-08 | 2023-12-08 | 0d |  |  |  |  | PP |  | 5.10 | Simon Berry | Systems Integration Testing (SIT) | Complete | COMPLETE |  |  |  |  |
| 766 | 1.4.1.4.1.10.2.5 | DIP Onboarding Activity (1. PKI Officers and Certificates, 2. Set-up Validation, 3. End Point Creation, 4. Controlled Smoke Test ) |  | 5d | 2023-12-04 A | 2023-12-08 A | 763FS+6d | 100% | 2023-12-04 | 2023-12-08 | 5d |  |  |  |  | PP |  | 5.10 | Simon Berry | Systems Integration Testing (SIT) | Complete | COMPLETE |  |  |  |  |
| 767 | 1.4.1.4.1.10.2.6 | DIP Onboarding Complete | milestone | 0d | 2023-12-08 A | 2023-12-08 A | 766 | 100% | 2023-12-08 | 2023-12-08 | 0d |  |  |  |  | PP |  | 5.10 | Simon Berry | Systems Integration Testing (SIT) | Complete | COMPLETE |  |  |  |  |
| 768 | 1.4.1.4.1.10.2.7 | PPs register PKI Officers and Request PKI Certificates Complete - Interval 6 | milestone | 0d | 2023-12-08 A | 2023-12-08 A | 767 | 100% | 2023-12-08 | 2023-12-08 | 0d | 2023-11-20 | 2023-11-24 | start no earlier than 2023-12-08 |  | PP | DIP Provider | 5.17 | Simon Berry | Systems Integration Testing (SIT) | Complete | COMPLETE |  | T3-TE-0102 | SITAG | T3 |
| 769 | 1.4.1.4.1.10.2.8 | PP Code Deployment | milestone | 0d | 2024-01-05 A | 2024-01-05 A |  | 100% | 2024-01-05 | 2024-01-05 | 0d |  |  | start no earlier than 2024-01-05 |  | PP |  | 5.10 | Simon Berry | Systems Integration Testing (SIT) | Complete | COMPLETE |  |  |  |  |

Notes:
- 745: 28/7: CH: added in to be aT3 milestone. 12/12 - Red because PPs required additional time due to some data changes required. No impact. Action to follow-up with PPs for latest progress / Action: 28/7: CH: Needs to be set-up as a reporting milestone. 31/7: Check with Cesar if has been approved so can be baselined
- 754: 2/1/24 - Approved at Dec TMAG following change in CIT governance
- 759: 9/1 - Not all completion reports yet received. Completed 22/2/24
- 763: 29/11 - Red because forecast date missed. Participants status to be determined by 4th December. No risk to future milestones
- 766: 5/12 -
- 768: 12/12 - Red because 1 Participant still to complete. 30/1 - Completed 29/1/24

| ID | WBS | Task | Type | Duration | Start | Finish | Predecessors | Complete | Remaining | Baseline start | Baseline finish | Baseline duration | Baseline 1 start | Baseline 1 finish | Total slack | Constraint | Baseline cost | Responsible | Involved | Update Version | MHHS Resource Name | MHHS Programme Phase | Sched Status | RAG | Artefact ID | Milestone ID | Text29 | Tier |
| --- | --- | --- | --- | --- | --- | --- | --- | --- | --- | --- | --- | --- | --- | --- | --- | --- | --- | --- | --- | --- | --- | --- | --- | --- | --- | --- | --- | --- |
| 770 | 1.4.1.4.1.10.3 | **Test Data (SIT A) Interval 6** |  | 25d | 2023-11-20 A | 2023-12-22 A |  | 100% |  | 2023-11-20 | 2023-12-22 | 25d | 2023-11-20 | 2023-12-22 |  |  |  | N/A | N/A | 5.0 | N/A | Systems Integration Testing (SIT) |  |  |  |  |  |  |
| 771 | 1.4.1.4.1.10.3.1 | Run data allocation |  | 10d | 2023-11-20 A | 2023-12-01 A | 741SS | 100% |  | 2023-11-20 | 2023-11-24 | 5d | 2023-11-20 | 2023-11-24 |  |  |  | SI Test |  | 5.0 | Richard Puddephatt | Systems Integration Testing (SIT) | Complete | COMPLETE |  |  |  |  |
| 772 | 1.4.1.4.1.10.3.2 | Cleanse and populate data post cut |  | 1d | 2023-12-04 A | 2023-12-04 A | 771 | 100% |  | 2023-11-27 | 2023-12-01 | 5d | 2023-11-27 | 2023-12-01 |  |  |  | SI Test |  | 5.0 | Richard Puddephatt | Systems Integration Testing (SIT) | Complete | COMPLETE |  |  |  |  |
| 773 | 1.4.1.4.1.10.3.3 | Transmit data sets to PPs |  | 1d | 2023-12-05 A | 2023-12-05 A | 772 | 100% |  | 2023-12-04 | 2023-12-05 | 2d | 2023-12-04 | 2023-12-05 |  |  |  | SI Test |  | 5.0 | Richard Puddephatt | Systems Integration Testing (SIT) | Complete | COMPLETE |  |  |  |  |
| 774 | 1.4.1.4.1.10.3.4 | PP - Load test data to test environments |  | 8d | 2023-12-06 A | 2023-12-15 A | 773 | 100% |  | 2023-12-06 | 2023-12-15 | 8d | 2023-12-06 | 2023-12-15 |  |  |  | PP |  | 5.0 | Richard Puddephatt | Systems Integration Testing (SIT) | Complete | COMPLETE |  |  |  |  |
| 775 | 1.4.1.4.1.10.3.5 | PP Check data integrity on test environment |  | 5d | 2023-12-18 A | 2023-12-22 A | 774 | 100% |  | 2023-12-18 | 2023-12-22 | 5d | 2023-12-18 | 2023-12-22 |  |  |  | PP |  | 5.0 | Richard Puddephatt | Systems Integration Testing (SIT) | Complete | COMPLETE |  |  |  |  |
| 776 | 1.4.1.4.1.10.3.6 | PP submit self-declaration to Programme to confirm loading & verification of test data | milestone | 0d | 2023-12-22 A | 2023-12-22 A | 775FF | 100% |  | 2023-12-22 | 2023-12-22 | 0d | 2023-12-22 | 2023-12-22 |  |  |  | PP | SI Test | 5.0 | Richard Puddephatt | Systems Integration Testing (SIT) | Complete | COMPLETE |  |  |  |  |
| 777 | 1.4.1.4.1.10.3.7 | Test Data (SIT A) Interval 6 Complete | milestone | 0d | 2023-12-22 A | 2023-12-22 A | 776 | 100% |  | 2023-12-22 | 2023-12-22 | 0d |  |  |  |  |  | SI Test | PP | 5.5 | Richard Puddephatt | Systems Integration Testing (SIT) | Complete | COMPLETE | MHHS-ART148/169 | T3-TE-0078 | SITAG | T3 |
| 778 | 1.4.1.4.1.10.4 | **Other Preparation** |  | 31d | 2023-12-04 A | 2024-01-15 A |  | 100% |  | 2023-12-04 | 2024-01-15 | 31d | 2023-09-04 | 2023-11-24 |  |  | -0 | N/A | N/A | 5.0 | N/A | Systems Integration Testing (SIT) |  |  |  |  |  |  |
| 779 | 1.4.1.4.1.10.4.1 | Onboarding of Test Participants to Test Management Tool (Azure DevOps) |  | 31d | 2023-12-04 A | 2024-01-15 A |  | 100% |  | 2023-12-04 | 2024-01-15 | 31d | 2023-09-04 | 2023-11-24 |  | start no earlier than 2023-12-04 |  | SI Test | PP | 5.0 | Simon Berry | Systems Integration Testing (SIT) | Complete | COMPLETE |  |  |  |  |
| 780 | 1.4.1.4.1.10.4.2 | Test Management Tool onboarding |  | 31d | 2023-12-04 A | 2024-01-15 A |  | 100% |  | 2023-12-04 | 2024-01-15 | 31d | 2023-09-04 | 2023-11-24 |  | start no earlier than 2023-12-04 |  | PP | SI Test | 5.0 | Simon Berry | Systems Integration Testing (SIT) | Complete | COMPLETE |  |  |  |  |
| 781 | 1.4.1.4.1.10.5 | **SIT Component Integration Test Readiness Report** |  | 25d | 2023-11-20 A | 2023-12-22 A |  | 100% |  | 2023-12-18 | 2024-01-19 | 25d | 2023-12-18 | 2024-01-19 |  |  |  | N/A | N/A | 5.0 | N/A | Systems Integration Testing (SIT) |  |  |  |  |  |  |
| 782 | 1.4.1.4.1.10.5.1 | PP submit Test Readiness Report to Programme for assurance | milestone | 0d | 2023-12-08 A | 2023-12-08 A | 574 | 100% |  | 2024-01-05 | 2024-01-05 | 0d | 2024-01-05 | 2024-01-05 |  |  |  | PP | SI Test | 5.0 |  | Systems Integration Testing (SIT) | Complete | COMPLETE |  |  |  |  |
| 783 | 1.4.1.4.1.10.5.2 | SI assure Test Participants' Test Readiness Reports |  | 5d | 2023-12-11 A | 2023-12-15 A | 782FF+5d | 100% |  | 2024-01-08 | 2024-01-12 | 5d | 2024-01-08 | 2024-01-12 |  |  |  | SI Test | PP,IPA | 5.0 |  | Systems Integration Testing (SIT) | Complete | COMPLETE |  |  |  |  |
| 784 | 1.4.1.4.1.10.5.3 | SI develop Overarching SIT Component Integration Test Readiness Report |  | 20d | 2023-11-20 A | 2023-12-15 A | 783FF | 100% |  | 2023-12-18 | 2024-01-12 | 20d | 2023-12-18 | 2024-01-12 |  |  |  | SI Test |  | 5.0 |  | Systems Integration Testing (SIT) | Complete | COMPLETE |  |  |  |  |
| 785 | 1.4.1.4.1.10.5.4 | Artefact review (via TMAG) and updates |  | 5d | 2023-12-18 A | 2023-12-22 A | 784 | 100% |  | 2024-01-15 | 2024-01-19 | 5d | 2024-01-15 | 2024-01-19 |  |  |  | SI Test | PP,IPA | 5.0 |  | Systems Integration Testing (SIT) | Complete | COMPLETE |  |  |  |  |
| 786 | 1.4.1.4.1.10.6 | SIT Component Integration Testing 6 Preparation Complete (incl. approval of SI SIT Component Integration Test Readiness Report) | milestone | 0d | 2024-01-19 A | 2024-01-19 A | 785FS+1d, 759, 763, 780, 782, 777, 246, 417 | 100% |  | 2024-01-22 | 2024-01-22 | 0d | 2024-01-22 | 2024-01-22 |  |  |  | SI Test | PP,IPA | 5.15 |  | Systems Integration Testing (SIT) | Complete | COMPLETE | MHHS-ART071 | T2-TE-0500 | SITAG | T2 |
| 787 | 1.4.1.4.2 | **SIT Functional Preparation** |  | 635d? | 2022-10-31 A | 2025-04-04 |  | 78% | 136.87d? | 2022-10-31 | 2024-10-25 | 520d | 2022-10-31 | 2024-03-01 | 32452d |  | -0 | N/A | N/A | 5.0 | N/A | Systems Integration Testing (SIT) |  |  |  |  |  |  |
| 788 | 1.4.1.4.2.1 | Environment Approach and Plan - SIT Functional |  | 1d? | 2023-11-20 A | 2023-11-20 A |  | 100% |  |  |  |  |  |  |  | start no earlier than 2023-11-20 |  |  |  | 6.0 |  |  | Complete | COMPLETE |  |  |  |  |
| 789 | 1.4.1.4.2.2 | **Test Approach & Plan** |  | 208d | 2022-10-31 A | 2023-08-16 A |  | 100% |  | 2022-10-31 | 2023-08-16 | 208d | 2022-10-31 | 2023-08-16 |  |  |  | N/A | N/A | 5.0 | N/A | Systems Integration Testing (SIT) |  |  |  |  |  |  |
| 790 | 1.4.1.4.2.2.1 | Develop document with SITWG |  | 179d | 2022-10-31 A | 2023-07-06 A |  | 100% |  | 2022-10-31 | 2023-07-06 | 179d | 2022-10-31 | 2023-07-06 |  | finish no earlier than 2023-07-06 |  | SI Test |  | 5.0 |  | Systems Integration Testing (SIT) | Complete | COMPLETE |  |  |  |  |
| 791 | 1.4.1.4.2.2.2 | Industry Consultation |  | 10d | 2023-07-07 A | 2023-07-20 A | 790 | 100% |  | 2023-07-07 | 2023-07-20 | 10d |  |  |  |  |  | PP |  | 5.1 |  | Systems Integration Testing (SIT) | Complete | COMPLETE |  |  |  |  |
| 792 | 1.4.1.4.2.2.3 | Artefact review (via TMAG) and updates |  | 19d | 2023-07-21 A | 2023-08-16 A | 791 | 100% |  | 2023-07-21 | 2023-08-16 | 19d | 2023-07-07 | 2023-08-03 |  | finish no earlier than 2023-08-03 |  | SI Test | PP,IPA,Code Bodies | 5.5 |  | Systems Integration Testing (SIT) | Complete | COMPLETE |  |  |  |  |
| 793 | 1.4.1.4.2.2.4 | SIT Functional Testing Test Approach & Plan approved | milestone | 0d | 2023-08-16 A | 2023-08-16 A |  | 100% |  | 2023-08-16 | 2023-08-16 | 0d | 2023-08-16 | 2023-08-16 |  | finish no earlier than 2023-08-16 |  | SI Test | PP | 5.0 |  | Systems Integration Testing (SIT) | Complete | COMPLETE | MHHS-ART073 | T3-TE-0013 | SITAG | T3 |

Notes:
- 777: 28/7: CH: added in to be aT3 milestone / Action: 28/7: CH: Needs to be set-up as a reporting milestone. 31/7: Check with Cesar if has been approved so can be baselined
- 786: 2/1/24 - Approved at Dec TMAG following change in CIT governance

| ID | WBS | Task | Type | Duration | Start | Finish | Predecessors | Complete | Remaining | Baseline start | Baseline finish | Baseline duration | Baseline 1 start | Baseline 1 finish | Total slack | Free slack | Constraint | Baseline cost | Responsible | Involved | Update Version | MHHS Resource Name | MHHS Programme Phase | Sched Status | RAG | Artefact ID | Milestone ID | Text29 | Tier | Action | Guidance | Task Status |
| --- | --- | --- | --- | --- | --- | --- | --- | --- | --- | --- | --- | --- | --- | --- | --- | --- | --- | --- | --- | --- | --- | --- | --- | --- | --- | --- | --- | --- | --- | --- | --- | --- |
| 794 | 1.4.1.4.2.3 | **Test Data Approach & Plan** |  | 29d | 2023-07-07 A | 2023-08-16 A |  | 100% |  | 2023-07-07 | 2023-08-16 | 29d | 2023-07-07 | 2023-08-16 |  |  |  |  | N/A | N/A | 5.0 | N/A | Systems Integration Testing (SIT) |  |  |  |  |  |  |  |  |  |
| 795 | 1.4.1.4.2.3.1 | Industry Consultation |  | 10d | 2023-07-07 A | 2023-07-20 A | 791SS | 100% |  | 2023-07-07 | 2023-07-20 | 10d |  |  |  |  |  |  | PP |  | 5.1 | Cesar Lopes | Systems Integration Testing (SIT) | Complete | COMPLETE |  |  |  |  |  |  |  |
| 796 | 1.4.1.4.2.3.2 | Artefact review (via TMAG) and updates |  | 19d | 2023-07-21 A | 2023-08-16 A | 795 | 100% |  | 2023-07-21 | 2023-08-16 | 19d | 2023-07-07 | 2023-08-03 |  |  |  |  | SI Test |  | 5.5 | Cesar Lopes | Systems Integration Testing (SIT) | Complete | COMPLETE |  |  |  |  |  |  |  |
| 797 | 1.4.1.4.2.3.3 | SIT Functional Testing Test Data Approach & Plan approved | milestone | 0d | 2023-08-16 A | 2023-08-16 A | 796 | 100% |  | 2023-08-16 | 2023-08-16 | 0d | 2023-08-16 | 2023-08-16 |  |  |  |  | SI Test | PP,IPA | 5.5 | Cesar Lopes | Systems Integration Testing (SIT) | Complete | COMPLETE |  |  |  |  |  |  |  |
| 798 | 1.4.1.4.2.4 | **Test scenarios** |  | 298d | 2023-01-02 A | 2024-02-21 A |  | 100% |  | 2023-01-02 | 2024-02-21 | 298d | 2023-01-02 | 2023-06-02 |  |  |  | -0 | N/A | N/A | 5.0 | N/A | Systems Integration Testing (SIT) |  |  |  |  |  |  |  |  |  |
| 799 | 1.4.1.4.2.4.1 | Development of test scenarios |  | 85d | 2023-01-02 A | 2023-04-28 A | 790SS+45d | 100% |  | 2023-01-02 | 2023-04-28 | 85d | 2023-01-02 | 2023-04-28 |  |  |  |  | SI Test | PP, Code Bodies | 5.0 |  | Systems Integration Testing (SIT) | Complete | COMPLETE |  |  |  |  |  |  |  |
| 800 | 1.4.1.4.2.4.2 | Review test scenarios with SIT Working Group |  | 65d | 2023-08-17 A | 2023-11-15 A | 799FS+78d | 100% |  | 2023-08-17 | 2023-11-15 | 65d | 2023-02-01 | 2023-05-26 |  |  |  |  | SI Test | PP, Code Bodies, IPA | 5.0 |  | Systems Integration Testing (SIT) | Complete | COMPLETE |  |  |  |  |  |  |  |
| 801 | 1.4.1.4.2.4.3 | SIT Functional Testing Test scenarios (themes 1-5) approved | milestone | 0d | 2023-12-08 A | 2023-12-08 A | 800FS+17d | 100% |  | 2023-12-08 | 2023-12-08 | 0d | 2023-06-02 | 2023-06-02 |  |  |  |  | SI Test | PP | 5.14 |  | Systems Integration Testing (SIT) | Complete | COMPLETE | MMHS-ART073 | T3-TE-0015 | SITAG | T3 |  |  |  |
| 802 | 1.4.1.4.2.4.4 | SIT Functional Testing Test scenarios (themes 6,7,9) approved | milestone | 0d | 2024-01-17 A | 2024-01-17 A | 801FS+28d | 100% |  | 2024-01-17 | 2024-01-17 | 0d | 2023-06-02 | 2023-06-02 |  |  |  |  | SI Test | PP | 5.16 |  | Systems Integration Testing (SIT) | Complete | COMPLETE | MMHS-ART073 | T3-TE-0106 | SITAG | T3 |  |  |  |
| 803 | 1.4.1.4.2.4.5 | SIT Functional Testing Test scenarios (theme 8) approved | milestone | 0d | 2024-02-21 A | 2024-02-21 A | 802FS+25d | 100% |  | 2024-02-21 | 2024-02-21 | 0d | 2023-06-02 | 2023-06-02 |  |  |  |  | SI Test | PP | 5.14 |  | Systems Integration Testing (SIT) | Complete | COMPLETE | MMHS-ART073 | T3-TE-0107 | SITAG | T3 |  |  |  |
| 804 | 1.4.1.4.2.5 | **Test cases** |  | 365d? | 2023-05-01 A | 2024-09-20 |  | 77% | 85.74d? | 2023-05-01 | 2024-02-21 | 213d | 2023-05-01 | 2023-09-01 | 32592d |  |  |  | N/A | N/A | 5.0 | N/A | Systems Integration Testing (SIT) |  |  |  |  |  |  | 25/7 - needs to be replanned |  |  |
| 805 | 1.4.1.4.2.5.1 | **SI Test cases** |  | 213d | 2023-05-01 A | 2024-02-21 A |  | 100% |  | 2023-05-01 | 2024-02-21 | 213d | 2023-05-01 | 2023-09-01 |  |  |  |  | N/A | N/A | 5.0 | N/A | Systems Integration Testing (SIT) |  |  |  |  |  |  | 25/7 - needs to be replanned |  |  |
| 806 | 1.4.1.4.2.5.1.1 | Development of Test cases |  | 150d | 2023-05-01 A | 2023-11-24 A | 799 | 100% |  | 2023-05-01 | 2023-11-24 | 150d | 2023-05-01 | 2023-07-28 |  |  |  |  | SI Test |  | 5.0 |  | Systems Integration Testing (SIT) | Complete | COMPLETE |  |  |  |  | 25/7 - needs to be replanned |  |  |
| 807 | 1.4.1.4.2.5.1.2 | Review Test cases with SIT Working Group |  | 78d | 2023-09-25 A | 2024-01-10 A | 806SS+105d | 100% |  | 2023-09-25 | 2024-01-10 | 78d | 2023-05-26 | 2023-08-25 |  |  |  |  | SI Test | PP,IPA | 5.0 |  | Systems Integration Testing (SIT) | Complete | COMPLETE |  |  |  |  | 25/7 - needs to be replanned |  |  |
| 808 | 1.4.1.4.2.5.1.3 | SIT Functional Testing Test Cases (themes 1-5) approved | milestone | 0d | 2024-01-17 A | 2024-01-17 A | 807FS+5d | 100% |  | 2024-01-17 | 2024-01-17 | 0d | 2023-09-01 | 2023-09-01 |  |  |  |  | SI Test | PP | 5.14 |  | Systems Integration Testing (SIT) | Complete | COMPLETE | MHHS-ART140 | T3-TE-0070 | SITAG | T3 |  | 2/1/24 - Approved at Dec TMAG |  |
| 809 | 1.4.1.4.2.5.1.4 | SIT Functional Testing Test cases (themes 6,7,9) approved | milestone | 0d | 2024-01-17 A | 2024-01-17 A | 808 | 100% |  | 2024-01-17 | 2024-01-17 | 0d | 2023-09-01 | 2023-09-01 |  |  |  |  | SI Test | PP | 5.14 |  | Systems Integration Testing (SIT) | Complete | COMPLETE | MHHS-ART140 | T3-TE-0108 | SITAG | T3 |  |  |  |
| 810 | 1.4.1.4.2.5.1.5 | SIT Functional Testing Test cases (theme 8) approved | milestone | 0d | 2024-02-21 A | 2024-02-21 A | 809FS+25d | 100% |  | 2024-02-21 | 2024-02-21 | 0d | 2023-09-01 | 2023-09-01 |  |  |  |  | SI Test | PP | 5.14 |  | Systems Integration Testing (SIT) | Complete | COMPLETE | MHHS-ART140 | T3-TE-0109 | SITAG | T3 |  |  |  |
| 811 | 1.4.1.4.2.5.2 | **SIT Functional Programme RTTM** |  | 40d? | 2024-07-29 | 2024-09-20 |  |  |  |  |  |  |  |  | 32592d |  |  |  |  |  |  |  |  | Overdue Start | RED |  |  |  |  |  |  | -687.67 |
| 812 | 1.4.1.4.2.5.2.1 | Development of Manual SIT Functional RTTM |  | 30d? | 2024-07-29 | 2024-09-06 |  |  |  |  |  |  |  |  | 32602d | 0d | start no earlier than 2024-07-29 |  |  |  |  |  |  | Overdue Start | GREEN |  |  |  |  |  |  | -52.67 |
| 813 | 1.4.1.4.2.5.2.2 | Manual SIT Functional RTTM Complete | milestone | 0d? | 2024-09-06 | 2024-09-06 | 812 |  |  |  |  |  |  |  | 32602d |  | start no earlier than 2024-07-29 |  |  |  |  |  |  | No BL | GREEN |  |  |  |  |  |  | -13.29 |
| 814 | 1.4.1.4.2.5.2.3 | Development of Automated SIT Functional RTTM |  | 40d? | 2024-07-29 | 2024-09-20 |  |  |  |  |  |  |  |  | 32592d | 0d | start no earlier than 2024-07-29 |  |  |  |  |  |  | Overdue Start | GREEN |  |  |  |  |  |  | -52.67 |
| 815 | 1.4.1.4.2.5.2.4 | Automated SIT Functional RTTM Complete | milestone | 0d? | 2024-09-20 | 2024-09-20 | 814 |  |  |  |  |  |  |  | 32592d |  | finish no earlier than 2024-09-20 |  |  |  |  |  |  | No BL | GREEN |  |  |  |  |  |  | 0.71 |
| 816 | 1.4.1.4.2.6 | **Environments (SIT-Staging)** |  | 10d | 2023-12-04 A | 2023-12-15 A |  | 100% |  | 2022-11-16 | 2024-02-09 | 323d | 2022-11-16 | 2024-02-09 |  |  |  |  | N/A | N/A | 5.0 | N/A | Systems Integration Testing (SIT) |  |  |  |  |  |  |  |  |  |
| 817 | 1.4.1.4.2.6.1 | **SIT Functional pre-requisites** |  | 10d | 2023-12-04 A | 2023-12-15 A |  | 100% |  | 2023-12-04 | 2023-12-15 | 10d |  |  |  |  |  |  | N/A | N/A | 5.3 | N/A | Systems Integration Testing (SIT) |  |  |  |  |  |  |  |  |  |
| 818 | 1.4.1.4.2.6.1.1 | **DCC** |  | 10d | 2023-12-04 A | 2023-12-15 A |  | 100% |  | 2023-12-04 | 2023-12-15 | 10d |  |  |  |  |  |  | N/A | N/A | 5.3 | N/A | Systems Integration Testing (SIT) |  |  |  |  |  |  |  |  | -254.67 |
| 819 | 1.4.1.4.2.6.1.1.1 | **CSS** |  | 10d | 2023-12-04 A | 2023-12-15 A |  | 100% |  | 2023-12-04 | 2023-12-15 | 10d |  |  |  |  |  |  | N/A | N/A | 5.3 | N/A | Systems Integration Testing (SIT) |  |  |  |  |  |  |  |  | -254.67 |
| 820 | 1.4.1.4.2.6.1.1.1.1 | SIT participants have requested DCC CSS PKI certificates for access to UIT-B environment |  | 10d | 2023-12-04 A | 2023-12-15 A |  | 100% |  | 2023-12-04 | 2023-12-15 | 10d |  |  |  |  | start no earlier than 2023-12-04 |  | SIT Participants (Suppliers & Third Parties) | PP | 5.3 | Simon Berry | Systems Integration Testing (SIT) | Complete | COMPLETE |  |  |  |  |  |  |  |
| 821 | 1.4.1.4.2.6.1.1.1.2 | SIT participants have received DCC CSS PKI certificates for UIT-B environment | milestone | 0d | 2023-12-15 A | 2023-12-15 A | 820 | 100% |  | 2023-12-15 | 2023-12-15 | 0d |  |  |  |  |  |  | SIT Participants (Suppliers & Third Parties) | PP | 5.5 | Simon Berry | Systems Integration Testing (SIT) | Complete | COMPLETE |  | T3-TE-0088 | SITAG | T3 | 7/8 - added as a T3 milestone. Awaiting approval at TMAG |  |  |

Notes:
- 801: Red because 8/12 TMAG moved to 20/12 due to reduction of Dec TMAGS. 5/12 Name change to SIT Functional Testing Test scenarios (themes 1-5) approved 20/12 - Approved at TMAG on 20/12
- 802: 5/12 - New milestone to go to 20/12 TMAG for approval. Added because of new delivery approach for SIT functional artifacts 20/12 - Approved at TMAG on 20/12
- 803: 5/12 - New milestone to go to 20/12 TMAG for approval. Added because of new delivery approach for SIT functional artifacts 20/12 - Approved at TMAG on 20/12
- 806: 15/9 - Potentially add in additional lines to track against progress
- 808: 5/12 Name change to SIT Functional Testing Test Cases (themes 1-5) approved 20/12 - Approved at TMAG on 20/12
- 809: 5/12- New milestone added because revised delivery approach for SIT Functional 20/12 - Approved at TMAG on 20/12
- 810: 5/12- New milestone added because revised delivery approach for SIT Functional
- 821: To be proposed as a T3 Milestone at next TMAG

| ID | WBS | Task | Type | Duration | Start | Finish | Predecessors | Complete | Remaining | Baseline start | Baseline finish | Baseline duration | Baseline 1 start | Baseline 1 finish | Total slack | Free slack | Constraint | Baseline cost | Responsible | Involved | Task Status | Update Version | MHHS Resource Name | MHHS Programme Phase | Sched Status | RAG | Action | Milestone ID | Text29 | Tier | Artefact ID |
| --- | --- | --- | --- | --- | --- | --- | --- | --- | --- | --- | --- | --- | --- | --- | --- | --- | --- | --- | --- | --- | --- | --- | --- | --- | --- | --- | --- | --- | --- | --- | --- |
| 822 | 1.4.1.4.2.6.1.1.2 | **DSP** |  | 10d | 2023-12-04 A | 2023-12-15 A |  | 100% |  | 2023-12-04 | 2023-12-15 | 10d |  |  |  |  |  |  | N/A | N/A | -254.67 | 5.3 | N/A | Systems Integration Testing (SIT) |  |  |  |  |  |  |  |
| 823 | 1.4.1.4.2.6.1.1.2.1 | SIT participants have requested DCC DSP PKI certificates for access to UIT-B environment |  | 10d | 2023-12-04 A | 2023-12-15 A |  | 100% |  | 2023-12-04 | 2023-12-15 | 10d |  |  |  |  | start no earlier than 2023-12-04 |  | PPs in SDS Market Role | PP |  | 5.3 | Simon Berry | Systems Integration Testing (SIT) | Complete | COMPLETE |  |  |  |  |  |
| 824 | 1.4.1.4.2.6.1.1.2.2 | SIT participants have received DCC DSP PKI certificates for UIT-B environment | milestone | 0d | 2023-12-15 A | 2023-12-15 A | 823 | 100% |  | 2023-12-15 | 2023-12-15 | 0d |  |  |  |  |  |  | PPs in SDS Market Role | PP |  | 5.5 | Simon Berry | Systems Integration Testing (SIT) | Complete | COMPLETE | 7/8 - added as a T3 milestone. Awaiting approval at TMAG | T3-TE-0089 | SITAG | T3 |  |
| 825 | 1.4.1.4.2.7 | **Stand up SIT A Environment** |  | 25d | 2024-02-05 A | 2024-03-08 A |  | 100% |  | 2024-01-08 | 2024-02-09 | 25d | 2024-02-05 | 2024-02-09 |  |  |  |  | N/A | N/A |  | 6.0 | N/A | Systems Integration Testing (SIT) |  |  |  |  |  |  |  |
| 826 | 1.4.1.4.2.7.1 | **SIT Functional Connectivity Proving** |  | 15d | 2024-02-12 A | 2024-03-01 A |  | 100% |  | 2024-01-08 | 2024-02-02 | 20d |  |  |  |  |  |  | N/A | N/A | -288.67 | 5.5 | N/A | Systems Integration Testing (SIT) |  |  |  |  |  |  |  |
| 827 | 1.4.1.4.2.7.1.1 | SIT Functional Connectivity Proving Period |  | 15d | 2024-02-12 A | 2024-03-01 A |  | 100% |  | 2024-02-12 | 2024-03-01 | 20d |  |  |  |  | start no earlier than 2024-01-08 |  | SI Test | PP |  | 5.19 | Simon Berry | Systems Integration Testing (SIT) | Complete | COMPLETE |  |  |  |  |  |
| 828 | 1.4.1.4.2.7.1.2 | SIT Functional Connectivity Proving Complete | milestone | 0d | 2024-03-01 A | 2024-03-01 A | 827 | 100% |  | 2024-03-01 | 2024-03-01 | 0d |  |  |  |  | start no earlier than 2024-03-01 |  | SI Test | PP |  | 5.19 | Simon Berry | Systems Integration Testing (SIT) | Complete | COMPLETE |  | T3-TE-0103 | SITAG | T3 |  |
| 829 | 1.4.1.4.2.7.2 | **PP Environments (SIT A)** |  | 25d | 2024-02-05 A | 2024-03-08 A |  | 100% |  | 2024-02-05 | 2024-02-09 | 5d | 2024-02-05 | 2024-02-09 |  |  |  |  | N/A | N/A |  | 5.0 | N/A | Systems Integration Testing (SIT) |  |  |  |  |  |  |  |
| 830 | 1.4.1.4.2.7.2.1 | Deployment of MHHS solution code to SIT A environments |  | 25d | 2024-02-05 A | 2024-03-08 A |  | 100% |  | 2024-02-05 | 2024-02-09 | 5d | 2024-02-05 | 2024-02-09 |  |  | start no earlier than 2024-02-05 |  | PP | SI Test |  | 5.0 | Simon Berry | Systems Integration Testing (SIT) | Complete | COMPLETE |  |  |  |  |  |
| 831 | 1.4.1.4.2.7.3 | **SI Environments (SIT A)** |  | 25d | 2024-02-05 A | 2024-03-08 A |  | 100% |  | 2024-02-05 | 2024-02-09 | 5d | 2024-02-05 | 2024-02-09 |  |  |  |  | N/A | N/A |  | 5.0 | N/A | Systems Integration Testing (SIT) |  |  |  |  |  |  |  |
| 832 | 1.4.1.4.2.7.3.1 | Coordinate deployment of MHHS solution code to SIT Participants' SIT A environments |  | 25d | 2024-02-05 A | 2024-03-08 A | 830SS | 100% |  | 2024-02-05 | 2024-02-09 | 5d | 2024-02-05 | 2024-02-09 |  |  |  |  | SI Test | PP |  | 5.0 | Simon Berry | Systems Integration Testing (SIT) | Complete | COMPLETE |  |  |  |  |  |
| 833 | 1.4.1.4.2.8 | **Test data (SIT A)** |  | 340d | 2023-12-18 A | 2025-04-04 |  | 38% | 211.66d | 2023-12-18 | 2024-10-25 | 225d |  |  | 27d |  |  | -0 | N/A | N/A | -269.67 | 5.4 | N/A | Systems Integration Testing (SIT) |  |  |  |  |  |  |  |
| 834 | 1.4.1.4.2.8.1 | **Cycle 1 Test data (SIT A)** |  | 55d | 2023-12-18 A | 2024-03-01 A |  | 100% |  | 2023-12-18 | 2024-03-01 | 55d |  |  |  |  |  | -0 | N/A | N/A | -269.67 | 5.4 | N/A | Systems Integration Testing (SIT) |  |  |  |  |  |  |  |
| 835 | 1.4.1.4.2.8.1.1 | Prepare, Generate and Allocate Test Data |  | 28d | 2023-12-18 A | 2024-01-24 A | 606, 614 | 100% |  | 2023-12-18 | 2024-01-24 | 28d |  |  |  |  | start no earlier than 2023-12-11 |  | SI Test Data |  |  | 5.14 | Richard Puddephatt | Systems Integration Testing (SIT) | Complete | COMPLETE |  |  |  |  |  |
| 836 | 1.4.1.4.2.8.1.2 | Transmit Data Sets to PPs |  | 4d | 2024-01-26 A | 2024-01-31 A | 835FS+1d | 100% |  | 2024-01-25 | 2024-01-26 | 2d |  |  |  |  |  |  | SI Test Data |  |  | 5.14 | Richard Puddephatt | Systems Integration Testing (SIT) | Complete | COMPLETE |  |  |  |  |  |
| 837 | 1.4.1.4.2.8.1.3 | PP's Iterative load and data integrity check |  | 22d | 2024-02-01 A | 2024-03-01 A | 836 | 100% |  | 2024-01-29 | 2024-02-09 | 10d |  |  |  |  |  |  | PP |  |  | 5.14 | Richard Puddephatt | Systems Integration Testing (SIT) | Complete | COMPLETE |  |  |  |  |  |
| 838 | 1.4.1.4.2.8.1.4 | Cycle 1 - PP's confirmation that test data is ready for SIT Functional | milestone | 0d | 2024-03-01 A | 2024-03-01 A | 837 | 100% |  | 2024-03-01 | 2024-03-01 | 0d |  |  |  |  |  |  | SI Test Data |  |  | 5.18 | Richard Puddephatt | Systems Integration Testing (SIT) | Complete | COMPLETE | 2/8 - added as a T3 milestone. Awaiting approval at TMAG | T3-TE-0079 | SITAG | T3 | MHHS-ART140 MHHS-ART169 |
| 839 | 1.4.1.4.2.8.2 | **Cycle 2 Test data (inc. Settlement Data) (SIT A)** |  | 57d | 2024-03-28 A | 2024-06-14 A |  | 100% |  | 2024-03-28 | 2024-05-31 | 47d |  |  |  |  |  | -0 | N/A | N/A |  | 6.0 | N/A | Systems Integration Testing (SIT) |  |  |  |  |  |  |  |
| 840 | 1.4.1.4.2.8.2.1 | Prepare, Generate and Allocate Test Data |  | 31d | 2024-03-28 A | 2024-05-09 A | 838FS+18d | 100% |  | 2024-03-28 | 2024-05-09 | 31d |  |  |  |  |  |  | SI Test Data |  |  | 5.14 | Richard Puddephatt | Systems Integration Testing (SIT) | Complete | COMPLETE |  |  |  |  |  |
| 841 | 1.4.1.4.2.8.2.2 | Transmit Data Sets to PPs |  | 3d | 2024-05-10 A | 2024-05-14 A | 840 | 100% |  | 2024-05-10 | 2024-05-14 | 3d |  |  |  |  |  |  | SI Test Data |  |  | 5.14 | Richard Puddephatt | Systems Integration Testing (SIT) | Complete | COMPLETE |  |  |  |  |  |
| 842 | 1.4.1.4.2.8.2.3 | PP's Iterative load and data integrity check |  | 13d | 2024-05-15 A | 2024-05-31 A | 841 | 100% |  | 2024-05-15 | 2024-05-31 | 13d |  |  |  |  |  |  | PP |  |  | 5.14 | Richard Puddephatt | Systems Integration Testing (SIT) | Complete | COMPLETE |  |  |  |  |  |
| 843 | 1.4.1.4.2.8.2.4 | Cycle 2 - PP's confirmation that test data is ready for SIT Functional | milestone | 0d | 2024-06-14 A | 2024-06-14 A | 842FS+10d | 100% |  | 2024-05-31 | 2024-05-31 | 0d |  |  |  |  |  |  | SI Test Data |  |  | 5.27 | Richard Puddephatt | Systems Integration Testing (SIT) | Complete | COMPLETE | 2/8 - added as a T3 milestone. Awaiting approval at TMAG | T3-TE-0080 | SITAG | T3 | MHHS-ART140 MHHS-ART169 |
| 844 | 1.4.1.4.2.8.3 | **Cycle 3 Test data (SIT A) (2)** |  | 85d | 2024-06-24 A | 2024-10-18 |  | 15% | 72d | 2024-06-24 | 2024-08-19 | 41d |  |  | 27d |  |  | -0 | N/A | N/A |  | 5.4 | N/A | Systems Integration Testing (SIT) |  |  |  |  |  |  |  |
| 845 | 1.4.1.4.2.8.3.1 | Prepare, Generate and Allocate Test Data |  | 60d | 2024-06-24 A | 2024-09-13 | 843FS+5d | 22% | 47d | 2024-06-24 | 2024-07-17 | 18d |  |  | 27d | 0d |  |  | SI Test Data |  |  | 5.14 | Richard Puddephatt | Systems Integration Testing (SIT) | Red | RED |  |  |  |  |  |
| 846 | 1.4.1.4.2.8.3.2 | Transmit Data Sets to PPs |  | 2d | 2024-09-16 | 2024-09-17 | 845 |  |  | 2024-07-18 | 2024-07-19 | 2d |  |  | 27d | 0d |  |  | SI Test Data |  | -3.67 | 5.14 | Richard Puddephatt | Systems Integration Testing (SIT) | Red | RED |  |  |  |  |  |
| 847 | 1.4.1.4.2.8.3.3 | PP's Iterative load and data integrity check |  | 23d | 2024-09-18 | 2024-10-18 | 846 |  |  | 2024-07-22 | 2024-08-19 | 21d |  |  | 27d | 0d |  |  | PP |  | -1.67 | 5.14 | Richard Puddephatt | Systems Integration Testing (SIT) | Red | RED |  |  |  |  |  |
| 848 | 1.4.1.4.2.8.3.4 | Cycle 3 - PP's confirmation that test data is ready for SIT Functional (end 18/10/24) | milestone | 0d | 2024-10-18 | 2024-10-18 | 847 |  |  | 2024-08-19 | 2024-08-19 | 0d |  |  | 27d | 0d |  |  | SI Test Data |  | 28.71 | 5.14 | Richard Puddephatt | Systems Integration Testing (SIT) | Red | RED | 2/8 - added as a T3 milestone. Awaiting approval at TMAG | T3-TE-0081 | SITAG | T3 | MHHS-ART140 MHHS-ART169 |

Notes:
- 824: 19/12 - MHHS PPs who require DCC, DSP, PKI certificates will request them in order to participate in DCC UEPT
- 825: 12/09/24 - Name change in line with SI Plan
- 827: 16/8 - Needs to start 8 weeks before SIT Functional Testing starts
- 828: 21/2/24 - Date change approved at SITAG on 21/2/24. 4/3 - PPs in the process of completing the activity, two thirds complete, the remain under in various stages of completeness
- 838: 21/2/24 - Date change approved at SITAG on 21/2/24. 5/3 - Red because 20% of PPs differed the data load to 6/3. These PPs have an action plan to complete this.
- 839: 12/09/24 - Name change in line with the SI Plan
- 843: 4/6: Date missed because there are 3 separate data loads for each PP to complete. This is proving time consuming but is expected to complete by 14/6
- 848: Date re-forecast in line with short term scenario planning. Introduction of 5 weeks of additional sprints.

| ID | WBS | Task | Type | Duration | Start | Finish | Predecessors | Complete | Remaining | Baseline start | Baseline finish | Baseline duration | Baseline 1 start | Baseline 1 finish | Total slack | Free slack | Constraint | Baseline cost | Responsible | Involved | Update Version | MHHS Resource Name | MHHS Programme Phase | Task Status | Sched Status | RAG | Artefact ID | Action | Milestone ID | Text29 | Tier |
| --- | --- | --- | --- | --- | --- | --- | --- | --- | --- | --- | --- | --- | --- | --- | --- | --- | --- | --- | --- | --- | --- | --- | --- | --- | --- | --- | --- | --- | --- | --- | --- |
| 849 | 1.4.1.4.2.8.4 | **Regression Test data (SIT A)** |  | 116d | 2024-10-25 | 2025-04-04 |  |  |  | 2024-08-26 | 2024-10-25 | 45d |  |  | 27d |  |  | -0 | N/A | N/A | 5.4 | N/A | Systems Integration Testing (SIT) |  |  |  |  |  |  |  |  |
| 850 | 1.4.1.4.2.8.4.1 | Prepare, Generate and Allocate Test Data |  | 94d | 2024-10-25 | 2025-03-05 | 848FS+4d |  |  | 2024-08-26 | 2024-09-25 | 23d |  |  | 27d | 0d |  |  | SI Test Data |  | 5.14 | Richard Puddephatt | Systems Integration Testing (SIT) | 35.33 | Red | RED |  |  |  |  |  |
| 851 | 1.4.1.4.2.8.4.2 | Transmit Data Sets to PPs |  | 2d | 2025-03-06 | 2025-03-07 | 850 |  |  | 2024-09-23 | 2024-10-04 | 10d |  |  | 27d | 0d |  |  | SI Test Data |  | 5.14 | Richard Puddephatt | Systems Integration Testing (SIT) | 167.33 | Red | RED |  |  |  |  |  |
| 852 | 1.4.1.4.2.8.4.3 | PP's Iterative load and data integrity check |  | 20d | 2025-03-10 | 2025-04-04 | 851 |  |  | 2024-10-21 | 2024-10-25 | 5d |  |  | 27d | 0d |  |  | PP |  | 5.14 | Richard Puddephatt | Systems Integration Testing (SIT) | 171.33 | Red | RED |  |  |  |  |  |
| 853 | 1.4.1.4.2.8.4.4 | Regression - PP's confirmation that test data is ready for SIT Functional | milestone | 0d | 2025-04-04 | 2025-04-04 | 852 |  |  | 2024-10-25 | 2024-10-25 | 0d |  |  | 27d | 0d |  |  | SI Test Data |  | 5.14 | Richard Puddephatt | Systems Integration Testing (SIT) | 196.71 | Red | RED | MHHS-ART140 MHHS-ART169 | 2/8 - added as a T3 milestone. Awaiting approval at TMAG | T3-TE-0082 | SITAG | T3 |
| 854 | 1.4.1.4.2.9 | **SIT Functional Test Readiness Report** |  | 45d | 2024-01-01 A | 2024-03-01 A |  | 100% |  | 2024-01-01 | 2024-02-29 | 44d | 2024-01-01 | 2024-02-23 |  |  |  | -0 | N/A | N/A | 5.0 | N/A | Systems Integration Testing (SIT) |  |  |  |  |  |  |  |  |
| 855 | 1.4.1.4.2.9.1 | **PP SIT Functional Test Readiness Report** |  | 44d | 2024-01-01 A | 2024-02-29 A |  | 100% |  | 2024-01-01 | 2024-02-29 | 44d | 2024-01-01 | 2024-02-09 |  |  |  | -0 | N/A | N/A | 5.0 | N/A | Systems Integration Testing (SIT) |  |  |  |  |  |  |  |  |
| 856 | 1.4.1.4.2.9.1.1 | Develop draft Test Readiness Report and submit to Programme for assurance |  | 21d | 2024-01-01 A | 2024-01-29 A |  | 100% |  | 2024-01-01 | 2024-01-29 | 20d | 2024-01-01 | 2024-01-29 |  |  | start no earlier than 2024-01-01 |  | PP | SI Test | 5.0 |  | Systems Integration Testing (SIT) |  | Complete | COMPLETE |  |  |  |  |  |
| 857 | 1.4.1.4.2.9.1.2 | Placing Reliance Stage 2 Review |  | 34d | 2024-01-15 A | 2024-02-29 A | 856SS+10d | 100% |  | 2024-01-15 | 2024-02-29 | 34d |  |  |  |  |  |  | SI Test | PP | 5.12 |  | Systems Integration Testing (SIT) |  | Complete | COMPLETE |  |  |  |  |  |
| 858 | 1.4.1.4.2.9.1.3 | Finalise Test Readiness Report and submit to Programme for assurance |  | 9d | 2024-01-30 A | 2024-02-09 A | 856 | 100% |  | 2024-01-29 | 2024-02-09 | 10d | 2024-01-29 | 2024-02-09 |  |  |  |  | PP | SI Test | 5.0 |  | Systems Integration Testing (SIT) |  | Complete | COMPLETE |  |  |  |  |  |
| 859 | 1.4.1.4.2.9.2 | **SI SIT Functional Test Readiness Report** |  | 40d | 2024-01-01 A | 2024-02-23 A |  | 100% |  | 2024-01-01 | 2024-02-23 | 40d | 2024-01-01 | 2024-02-23 |  |  |  |  | N/A | N/A | 5.0 | N/A | Systems Integration Testing (SIT) |  |  |  |  |  |  |  |  |
| 860 | 1.4.1.4.2.9.2.1 | Assure Test Participants' Test Readiness Reports |  | 35d | 2024-01-01 A | 2024-02-16 A | 856SS, 858FF+5d | 100% |  | 2024-01-01 | 2024-02-16 | 35d | 2024-01-01 | 2024-02-16 |  |  |  |  | SI Test | PP,IPA | 5.0 |  | Systems Integration Testing (SIT) |  | Complete | COMPLETE |  |  |  |  |  |
| 861 | 1.4.1.4.2.9.2.2 | Develop Overarching SIT Functional Test Readiness Report |  | 20d | 2024-01-22 A | 2024-02-16 A | 860FF | 100% |  | 2024-01-22 | 2024-02-16 | 20d | 2024-01-22 | 2024-02-16 |  |  |  |  | SI Test |  | 5.0 |  | Systems Integration Testing (SIT) |  | Complete | COMPLETE |  |  |  |  |  |
| 862 | 1.4.1.4.2.9.2.3 | Artefact review (via TMAG) and updates |  | 5d | 2024-02-19 A | 2024-02-23 A | 861 | 100% |  | 2024-02-19 | 2024-02-23 | 5d | 2024-02-19 | 2024-02-23 |  |  |  |  | SI Test | PP,IPA | 5.0 |  | Systems Integration Testing (SIT) |  | Complete | COMPLETE |  |  |  |  |  |
| 863 | 1.4.1.4.2.9.3 | SIT Functional Testing Preparation Complete | milestone | 0d | 2024-03-01 A | 2024-03-01 A | 862FF+5d, 793, 315, 857, 801, 808, 838 | 100% |  | 2024-03-01 | 2024-03-01 | 0d | 2024-03-01 | 2024-03-01 |  |  |  |  | SI Test | PP,IPA | 5.0 |  | Systems Integration Testing (SIT) |  | Complete | COMPLETE |  |  | T2-TE-0550 | SITAG | T2 |
| 864 | 1.4.1.4.3 | **SIT Migration Testing Preparation** |  | 500d? | 2022-10-31 A | 2024-09-27 |  | 97% | 14.24d? | 2022-10-31 | 2024-06-07 | 420d | 2022-11-16 | 2024-06-03 | 32587d |  |  | -0 | N/A | N/A | 5.21 | N/A | Systems Integration Testing (SIT) |  |  |  |  |  |  |  |  |
| 865 | 1.4.1.4.3.1 | **Test Approach & Plan** |  | 75d | 2023-09-07 A | 2023-12-20 A |  | 100% |  | 2023-09-07 | 2023-12-20 | 75d | 2023-09-07 | 2023-12-20 |  |  |  | -0 | N/A | N/A | 5.0 |  | Systems Integration Testing (SIT) |  |  |  |  |  |  |  |  |
| 866 | 1.4.1.4.3.1.1 | Develop document with SITWG |  | 32d | 2023-09-07 A | 2023-10-20 A | 2001 | 100% |  | 2023-09-07 | 2023-10-11 | 25d | 2023-09-07 | 2023-10-11 |  |  | finish no earlier than 2023-10-11 |  | SI Test |  | 5.0 |  | Systems Integration Testing (SIT) |  | Complete | COMPLETE |  |  |  |  |  |
| 867 | 1.4.1.4.3.1.2 | Draft document review with Code Bodies |  | 8d | 2023-10-23 A | 2023-11-01 A | 866 | 100% |  | 2023-10-12 | 2023-10-25 | 10d | 2023-10-12 | 2023-10-25 |  |  |  |  | SI Test | Code Bodies | 5.0 |  | Systems Integration Testing (SIT) |  | Complete | COMPLETE |  |  |  |  |  |
| 868 | 1.4.1.4.3.1.3 | Industry Consultation |  | 10d | 2023-11-02 A | 2023-11-15 A | 867 | 100% |  | 2023-11-02 | 2023-11-15 | 10d |  |  |  |  |  |  | PP |  | 5.1 |  | Systems Integration Testing (SIT) |  | Complete | COMPLETE |  |  |  |  |  |
| 869 | 1.4.1.4.3.1.4 | Artefact review (via TMAG) and updates |  | 25d | 2023-11-16 A | 2023-12-20 A | 868 | 100% |  | 2023-11-09 | 2023-12-20 | 30d | 2023-10-26 | 2023-12-20 |  |  |  |  | SI Test | PP,IPA,Code Bodies | 5.0 |  | Systems Integration Testing (SIT) |  | Complete | COMPLETE |  |  |  |  |  |
| 870 | 1.4.1.4.3.1.5 | SIT Migration Testing Test Approach & Plan approved | milestone | 0d | 2023-12-20 A | 2023-12-20 A | 869 | 100% |  | 2023-12-20 | 2023-12-20 | 1d | 2023-12-20 | 2023-12-20 |  |  | finish no earlier than 2023-12-20 |  | SI Test | PP | 5.14 |  | Systems Integration Testing (SIT) |  | Complete | COMPLETE | MHHS-ART073 |  | T3-TE-0018 | SITAG | T3 |
| 871 | 1.4.1.4.3.2 | **Test Data Approach & Plan** |  | 35d | 2023-11-02 A | 2023-12-20 A |  | 100% |  | 2023-11-02 | 2023-12-20 | 35d | 2023-10-26 | 2023-12-20 |  |  |  | -0 | N/A | N/A | 5.0 | N/A | Systems Integration Testing (SIT) |  |  |  |  |  |  |  |  |
| 872 | 1.4.1.4.3.2.1 | Industry Consultation |  | 10d | 2023-11-02 A | 2023-11-15 A | 868SS | 100% |  | 2023-11-02 | 2023-11-15 | 10d |  |  |  |  |  |  | PP |  | 5.1 | PP | Systems Integration Testing (SIT) |  | Complete | COMPLETE |  |  |  |  |  |
| 873 | 1.4.1.4.3.2.2 | Artefact review (via TMAG) and updates |  | 25d | 2023-11-16 A | 2023-12-20 A | 872 | 100% |  | 2023-11-09 | 2023-12-20 | 30d | 2023-10-26 | 2023-12-20 |  |  |  |  | SI Test Data |  | 5.0 | Richard Puddephatt | Systems Integration Testing (SIT) |  | Complete | COMPLETE |  |  |  |  |  |
| 874 | 1.4.1.4.3.2.3 | SIT Migration Test Data Test Approach & Plan approved | milestone | 0d | 2023-12-20 A | 2023-12-20 A | 873 | 100% |  | 2023-12-20 | 2023-12-20 | 0d | 2023-12-20 | 2023-12-20 |  |  |  |  | SI Test Data | PP,IPA | 5.14 | Richard Puddephatt | Systems Integration Testing (SIT) |  | Complete | COMPLETE |  |  |  |  |  |

Notes:
- 853: 02/09/24: Date at risk due to programme scenario re-planning.
- 863: 28/11 - At risk because of challenges with CCP and PP readiness & dependent on successful Secondary Routing Testing. Approved at 1/3 eSITAG
- 870: 24/10 - Amber because consultation window delayed by 5 days. 20/12 - Approved to complete at TMAG on 20/12
- 874: 20/12 - approved at TMAG on 20/12

| ID | WBS | Task | Type | Duration | Start | Finish | Predecessors | Complete | Remaining | Baseline start | Baseline finish | Baseline duration | Baseline 1 start | Baseline 1 finish | Total slack | Free slack | Constraint | Baseline cost | Responsible | Involved | Update Version | MHHS Resource Name | MHHS Programme Phase | Task Status | Sched Status | RAG | Milestone ID | Text29 |
| --- | --- | --- | --- | --- | --- | --- | --- | --- | --- | --- | --- | --- | --- | --- | --- | --- | --- | --- | --- | --- | --- | --- | --- | --- | --- | --- | --- | --- |
| 875 | 1.4.1.4.3.3 | **Test scenarios & Test Cases** |  | 202d? | 2023-12-21 A | 2024-09-27 |  | 86% | 27.9d? | 2023-12-21 | 2024-03-20 | 65d | 2023-07-24 | 2024-01-17 | 32587d |  |  | -0 | N/A | N/A | 5.16 | N/A | Systems Integration Testing (SIT) |  |  |  |  |  |
| 876 | 1.4.1.4.3.3.1 | **Theme 1** |  | 65d | 2023-12-21 A | 2024-03-20 A |  | 100% |  | 2023-12-21 | 2024-03-20 | 65d |  |  |  |  |  | -0 | N/A | N/A | 5.16 | N/A | Systems Integration Testing (SIT) | -448.67 |  |  |  |  |
| 877 | 1.4.1.4.3.3.1.1 | Develop Test Scenarios & Test Cases |  | 25d | 2023-12-21 A | 2024-01-24 A | 870 | 100% |  | 2023-12-21 | 2024-01-24 | 25d |  |  |  |  |  |  | SI Test | SI Test, PP | 5.16 |  |  |  | Complete | COMPLETE |  |  |
| 878 | 1.4.1.4.3.3.1.2 | Industry Review Workshop |  | 1d | 2024-01-25 A | 2024-01-25 A | 877 | 100% |  | 2024-01-25 | 2024-01-25 | 1d |  |  |  |  |  |  | SI Test, PP | SI Test, PP | 5.16 |  |  |  | Complete | COMPLETE |  |  |
| 879 | 1.4.1.4.3.3.1.3 | Industry Consultation Review |  | 6d | 2024-02-05 A | 2024-02-12 A | 878FS+6d | 100% |  | 2024-02-05 | 2024-02-12 | 6d |  |  |  |  |  |  | SI Test, PP | SI Test, PP | 5.16 |  |  |  | Complete | COMPLETE |  |  |
| 880 | 1.4.1.4.3.3.1.4 | Review with SIT Working Group |  | 5d | 2024-02-29 A | 2024-03-06 A | 879FS+12d | 100% |  | 2024-02-29 | 2024-03-06 | 5d |  |  |  |  |  |  | SI Test, PP | SI Test, PP | 5.19 |  |  |  | Complete | COMPLETE |  |  |
| 881 | 1.4.1.4.3.3.1.5 | SIT Migration Test scenarios & Test Cases Approved - Theme 1 | milestone | 0d | 2024-03-20 A | 2024-03-20 A | 880FS+10d | 100% |  | 2024-03-20 | 2024-03-20 | 0d |  |  |  |  |  |  | SI Test | SI Test, PP | 5.21 |  | Systems Integration Testing (SIT) |  | Complete | COMPLETE | T3-TE-0110 | SITAG |
| 882 | 1.4.1.4.3.3.2 | **Theme 2** |  | 85d | 2023-12-21 A | 2024-04-17 A |  | 100% |  | 2023-12-21 | 2024-04-17 | 85d |  |  |  |  |  | -0 | N/A | N/A | 5.16 | N/A | Systems Integration Testing (SIT) | -448.67 |  |  |  |  |
| 883 | 1.4.1.4.3.3.2.1 | Develop Test Scenarios & Test Cases |  | 40d | 2023-12-21 A | 2024-02-14 A | 870 | 100% |  | 2023-12-21 | 2024-02-14 | 40d |  |  |  |  |  |  | SI Test | SI Test, PP | 5.16 |  |  |  | Complete | COMPLETE |  |  |
| 884 | 1.4.1.4.3.3.2.2 | Industry Review Workshop |  | 1d | 2024-02-15 A | 2024-02-15 A | 883 | 100% |  | 2024-02-15 | 2024-02-15 | 1d |  |  |  |  |  |  | SI Test, PP | SI Test, PP | 5.16 |  |  |  | Complete | COMPLETE |  |  |
| 885 | 1.4.1.4.3.3.2.3 | Industry Consultation Review |  | 6d | 2024-02-26 A | 2024-03-04 A | 884FS+6d | 100% |  | 2024-02-26 | 2024-03-04 | 6d |  |  |  |  |  |  | SI Test, PP | SI Test, PP | 5.19 |  |  |  | Complete | COMPLETE |  |  |
| 886 | 1.4.1.4.3.3.2.4 | Review with SIT Working Group |  | 5d | 2024-03-28 A | 2024-04-03 A | 885FS+17d | 100% |  | 2024-03-28 | 2024-04-03 | 5d |  |  |  |  |  |  | SI Test, PP | SI Test, PP | 5.16 |  |  |  | Complete | COMPLETE |  |  |
| 887 | 1.4.1.4.3.3.2.5 | SIT Migration Test scenarios & Test Cases Approved - Theme 2 | milestone | 0d | 2024-04-17 A | 2024-04-17 A | 886FS+10d | 100% |  | 2024-04-17 | 2024-04-17 | 0d |  |  |  |  |  |  | SI Test | SI Test, PP | 5.22 |  | Systems Integration Testing (SIT) |  | Complete | COMPLETE | T3-TE-0111 | SITAG |
| 888 | 1.4.1.4.3.3.3 | **Theme 3** |  | 85d | 2023-12-21 A | 2024-04-17 A |  | 100% |  | 2023-12-21 | 2024-04-17 | 85d |  |  |  |  |  | -0 | N/A | N/A | 5.16 | N/A | Systems Integration Testing (SIT) | -448.67 |  |  |  |  |
| 889 | 1.4.1.4.3.3.3.1 | Develop Test Scenarios & Test Cases |  | 55d | 2023-12-21 A | 2024-03-06 A | 870 | 100% |  | 2023-12-21 | 2024-03-06 | 55d |  |  |  |  |  |  | SI Test | SI Test, PP | 5.19 |  |  |  | Complete | COMPLETE |  |  |
| 890 | 1.4.1.4.3.3.3.2 | Industry Review Workshop |  | 1d | 2024-03-07 A | 2024-03-07 A | 889 | 100% |  | 2024-03-07 | 2024-03-07 | 1d |  |  |  |  |  |  | SI Test, PP | SI Test, PP | 5.16 |  |  |  | Complete | COMPLETE |  |  |
| 891 | 1.4.1.4.3.3.3.3 | Industry Consultation Review |  | 6d | 2024-03-13 A | 2024-03-20 A | 890FS+3d | 100% |  | 2024-03-13 | 2024-03-20 | 6d |  |  |  |  |  |  | SI Test, PP | SI Test, PP | 5.16 |  |  |  | Complete | COMPLETE |  |  |
| 892 | 1.4.1.4.3.3.3.4 | Review with SIT Working Group |  | 5d | 2024-03-28 A | 2024-04-03 A | 891FS+5d | 100% |  | 2024-03-28 | 2024-04-03 | 5d |  |  |  |  |  |  | SI Test, PP | SI Test, PP | 5.16 |  |  |  | Complete | COMPLETE |  |  |
| 893 | 1.4.1.4.3.3.3.5 | SIT Migration Test scenarios & Test Cases Approved - Theme 3 | milestone | 0d | 2024-04-17 A | 2024-04-17 A | 892FS+10d | 100% |  | 2024-04-17 | 2024-04-17 | 0d |  |  |  |  |  |  | SI Test | SI Test, PP | 5.22 |  | Systems Integration Testing (SIT) |  | Complete | COMPLETE | T3-TE-0112 | SITAG |
| 894 | 1.4.1.4.3.3.4 | **SIT Migration Programme RTTM** |  | 15d? | 2024-09-09 | 2024-09-27 |  |  |  |  |  |  |  |  | 32587d |  |  |  |  |  |  |  |  | -687.67 | Overdue Start | RED |  |  |
| 895 | 1.4.1.4.3.3.4.1 | Develop Manual SIT Migration RTTM |  | 10d? | 2024-09-09 | 2024-09-20 |  |  |  |  |  |  |  |  | 32592d | 0d | finish no earlier than 2024-09-20 |  |  |  |  |  |  | -10.67 | No BL | GREEN |  |  |
| 896 | 1.4.1.4.3.3.4.2 | Manual SIT Migration RTTM Complete | milestone | 0d | 2024-09-20 | 2024-09-20 | 895 |  |  |  |  |  |  |  | 32592d |  | start no earlier than 2024-09-09 |  |  |  |  |  |  | 0.71 | No BL | GREEN |  |  |
| 897 | 1.4.1.4.3.3.4.3 | Develop Automated SIT Migration RTTM |  | 15d? | 2024-09-09 | 2024-09-27 |  |  |  |  |  |  |  |  | 32587d | 0d | start no earlier than 2024-09-09 |  |  |  |  |  |  | -10.67 | No BL | GREEN |  |  |
| 898 | 1.4.1.4.3.3.4.4 | Automated SIT Migration RTTM Complete | milestone | 0d? | 2024-09-27 | 2024-09-27 | 897 |  |  |  |  |  |  |  | 32587d |  | start no earlier than 2024-09-09 |  |  |  |  |  |  | 7.71 | No BL | GREEN |  |  |

Notes:
- 881: 23/1 - New milestones added because of new themed delivery approach. To go to Feb SITAG for approval
- 887: 23/1 - New milestones added because of new themed delivery approach
- 893: 23/1 - New milestones added because of new themed delivery approach

| ID | WBS | Task | Type | Duration | Start | Finish | Predecessors | Complete | Remaining | Baseline start | Baseline finish | Baseline duration | Baseline 1 start | Baseline 1 finish | Total slack | Constraint | Baseline cost | Responsible | Involved | Update Version | MHHS Resource Name | MHHS Programme Phase | Sched Status | RAG | Milestone ID | Text29 | Tier | Artefact ID | Guidance |
| --- | --- | --- | --- | --- | --- | --- | --- | --- | --- | --- | --- | --- | --- | --- | --- | --- | --- | --- | --- | --- | --- | --- | --- | --- | --- | --- | --- | --- | --- |
| 899 | 1.4.1.4.3.4 | **Environments (SIT B)** |  | 435d | 2022-10-31 A | 2024-06-28 A |  | 100% |  | 2022-10-31 | 2024-06-07 | 420d | 2022-11-16 | 2024-05-13 |  |  | -0 | N/A | N/A | 5.0 | N/A | Systems Integration Testing (SIT) |  |  |  |  |  |  |  |
| 900 | 1.4.1.4.3.4.1 | **PP Environments (SIT B)** |  | 41d | 2024-05-03 A | 2024-06-28 A |  | 100% |  | 2024-05-03 | 2024-06-07 | 26d | 2022-11-16 | 2024-05-13 |  |  | -0 | N/A | N/A | 5.0 | N/A | Systems Integration Testing (SIT) |  |  |  |  |  |  |  |
| 901 | 1.4.1.4.3.4.1.1 | PP Environments available | milestone | 0d | 2024-05-03 A | 2024-05-03 A | 468 | 100% |  | 2024-05-03 | 2024-05-03 | 0d | 2022-11-16 | 2024-04-01 |  | start no earlier than 2024-05-03 |  | PP | SI Test | 5.21 | Simon Berry | Systems Integration Testing (SIT) | Complete | COMPLETE |  |  |  |  |  |
| 902 | 1.4.1.4.3.4.1.2 | PP Onboarding / Smoke test |  | 35d | 2024-05-13 A | 2024-06-28 A | 901FS+6d | 100% |  | 2024-05-13 | 2024-06-07 | 20d | 2022-11-16 | 2024-04-01 |  |  |  | PP | SI Test | 5.21 | Simon Berry | Systems Integration Testing (SIT) | Complete | COMPLETE |  |  |  |  |  |
| 903 | 1.4.1.4.3.4.1.3 | DTN Connectivity Proving Complete |  | 5d | 2024-06-10 A | 2024-06-14 A | 901FS+26d | 100% |  | 2024-05-31 | 2024-05-31 | 0d | 2024-04-15 | 2024-04-26 |  |  |  | PP | SI Test | 5.21 | Simon Berry | Systems Integration Testing (SIT) | Complete | COMPLETE |  |  |  |  |  |
| 904 | 1.4.1.4.3.4.1.4 | PP Code Deployment | milestone | 0d | 2024-06-14 A | 2024-06-14 A | 903 | 100% |  | 2024-06-03 | 2024-06-03 | 0d | 2024-04-29 | 2024-05-13 |  |  |  | PP | SI Test | 5.21 | Simon Berry | Systems Integration Testing (SIT) | Complete | COMPLETE |  |  |  |  |  |
| 905 | 1.4.1.4.3.4.2 | **SI Environments (SIT B)** |  | 425d | 2022-10-31 A | 2024-06-14 A |  | 100% |  | 2022-10-31 | 2024-06-07 | 420d | 2022-11-16 | 2024-05-10 |  |  | -0 | N/A | N/A | 5.0 | N/A | Systems Integration Testing (SIT) |  |  |  |  |  |  |  |
| 906 | 1.4.1.4.3.4.2.1 | Coordinate SIT Participants' SIT B environment preparation |  | 420d | 2022-10-31 A | 2024-06-07 A |  | 100% |  | 2022-10-31 | 2024-06-07 | 420d | 2022-11-16 | 2024-04-01 |  |  |  | SI Test | PP | 5.21 | Simon Berry | Systems Integration Testing (SIT) | Complete | COMPLETE |  |  |  |  |  |
| 907 | 1.4.1.4.3.4.2.2 | Assure PPs' self-declaration of environment preparation complete (incl. security certificates and security compliance) | milestone | 0d | 2024-06-07 A | 2024-06-07 A | 906 | 100% |  | 2024-06-07 | 2024-06-07 | 0d | 2022-11-16 | 2024-03-29 |  |  |  | SI Test | PP | 5.21 | Simon Berry | Systems Integration Testing (SIT) | Complete | COMPLETE |  |  |  |  |  |
| 908 | 1.4.1.4.3.4.2.3 | SIT Participants' SIT B environments ready to start connectivity proving (incl. certificates and security compliance) | milestone | 0d | 2024-06-05 A | 2024-06-05 A | 901FS+24d | 100% |  | 2024-05-03 | 2024-05-03 | 0d | 2024-04-01 | 2024-04-01 |  |  |  | SI Test | PP,IPA | 5.26 | Simon Berry | Systems Integration Testing (SIT) | Complete | COMPLETE | T3-TE-0033 | SITAG | T3 |  |  |
| 909 | 1.4.1.4.3.4.2.4 | Coordinate SIT Participants' SIT B environment connectivity proving |  | 2d | 2024-06-06 A | 2024-06-07 A | 908 | 100% |  | 2024-05-14 | 2024-06-07 | 19d | 2024-04-01 | 2024-04-26 |  |  |  | SI Test | PP | 5.21 | Simon Berry | Systems Integration Testing (SIT) | Complete | COMPLETE |  |  |  |  |  |
| 910 | 1.4.1.4.3.4.2.5 | Coordinate deployment of MHHS solution code to SIT Participants' SIT B environments | milestone | 0d | 2024-06-14 A | 2024-06-14 A | 904 | 100% |  | 2024-06-04 | 2024-06-07 | 4d | 2024-04-15 | 2024-04-26 |  |  |  | SI Test | PP | 5.21 | Simon Berry | Systems Integration Testing (SIT) | Complete | COMPLETE |  |  |  |  |  |
| 911 | 1.4.1.4.3.5 | **SIT Migration Test Readiness Report** |  | 44d | 2024-04-02 A | 2024-05-31 A |  | 100% |  | 2024-04-02 | 2024-05-31 | 44d | 2024-04-02 | 2024-05-27 |  |  | -0 | N/A | N/A | 5.0 | N/A | Systems Integration Testing (SIT) |  |  |  |  |  |  |  |
| 912 | 1.4.1.4.3.5.1 | **PP SIT Migration Test Readiness Report** |  | 44d | 2024-04-02 A | 2024-05-31 A |  | 100% |  | 2024-04-02 | 2024-05-31 | 44d | 2024-04-02 | 2024-05-13 |  |  | -0 | N/A | N/A | 5.0 | N/A | Systems Integration Testing (SIT) |  |  |  |  |  |  |  |
| 913 | 1.4.1.4.3.5.1.1 | Develop draft Test Readiness Report and submit to Programme for assurance |  | 20d | 2024-04-02 A | 2024-04-29 A |  | 100% |  | 2024-04-02 | 2024-04-30 | 20d | 2024-04-02 | 2024-04-30 |  | start no earlier than 2024-04-02 |  | PP | SI Test | 5.0 |  | Systems Integration Testing (SIT) | Complete | COMPLETE |  |  |  |  |  |
| 914 | 1.4.1.4.3.5.1.2 | Placing Reliance Stage 2 Review |  | 35d | 2024-04-15 A | 2024-05-31 A | 913SS+9d | 100% |  | 2024-04-15 | 2024-05-31 | 35d |  |  |  |  |  | SI Test | PP | 5.12 |  | Systems Integration Testing (SIT) | Complete | COMPLETE |  |  |  |  |  |
| 915 | 1.4.1.4.3.5.1.3 | Finalise Test Readiness Report and submit to Programme for assurance |  | 10d | 2024-04-30 A | 2024-05-13 A | 913 | 100% |  | 2024-04-30 | 2024-05-13 | 10d | 2024-04-30 | 2024-05-13 |  |  |  | PP | SI Test | 5.0 |  | Systems Integration Testing (SIT) | Complete | COMPLETE |  |  |  |  |  |
| 916 | 1.4.1.4.3.5.2 | **SI SIT Migration Test Readiness Report** |  | 40d | 2024-04-02 A | 2024-05-27 A |  | 100% |  | 2024-04-02 | 2024-05-27 | 40d | 2024-04-02 | 2024-05-27 |  |  |  | N/A | N/A | 5.0 | N/A | Systems Integration Testing (SIT) |  |  |  |  |  |  |  |
| 917 | 1.4.1.4.3.5.2.1 | Assure Test Participants' Test Readiness Reports |  | 35d | 2024-04-02 A | 2024-05-20 A | 913SS, 915FF+5d | 100% |  | 2024-04-02 | 2024-05-20 | 35d | 2024-04-02 | 2024-05-20 |  |  |  | SI Test | PP,IPA | 5.0 |  | Systems Integration Testing (SIT) | Complete | COMPLETE |  |  |  |  |  |
| 918 | 1.4.1.4.3.5.2.2 | Develop Overarching SIT Migration Test Readiness Report |  | 20d | 2024-04-23 A | 2024-05-20 A | 917FF | 100% |  | 2024-04-23 | 2024-05-20 | 20d | 2024-04-23 | 2024-05-20 |  |  |  | SI Test |  | 5.0 |  | Systems Integration Testing (SIT) | Complete | COMPLETE |  |  |  |  |  |
| 919 | 1.4.1.4.3.5.2.3 | Artefact review (via SITAG) and updates |  | 5d | 2024-05-21 A | 2024-05-27 A | 918 | 100% |  | 2024-05-21 | 2024-05-27 | 5d | 2024-05-21 | 2024-05-27 |  |  |  | SI Test | PP,IPA | 5.0 |  | Systems Integration Testing (SIT) | Complete | COMPLETE |  |  |  |  |  |
| 920 | 1.4.1.4.3.6 | SIT Migration Testing Preparation Complete | milestone | 0d | 2024-06-03 A | 2024-06-03 A | 919FF+5d, 870, 332, 914, 881, 887, 893 | 100% |  | 2024-06-03 | 2024-06-03 | 0d | 2024-06-03 | 2024-06-03 |  |  |  | SI Test | PP,IPA | 5.0 |  | Systems Integration Testing (SIT) | Complete | COMPLETE | T2-TE-0650 | SITAG | T2 |  |  |
| 921 | 1.4.1.4.4 | **SIT Non-Functional Preparation** |  | 367d? | 2023-11-30 A | 2025-04-25 |  | 50% | 183.73d? | 2023-11-30 | 2024-08-27 | 193d | 2023-07-03 | 2024-08-26 | 32437d |  | -0 | N/A | N/A | 5.0 | N/A | Systems Integration Testing (SIT) |  |  |  |  |  |  |  |
| 922 | 1.4.1.4.4.1 | **Test Approach & Plan** |  | 120d | 2023-11-30 A | 2024-05-15 A |  | 100% |  | 2023-11-30 | 2024-05-15 | 120d | 2023-11-30 | 2024-03-20 |  |  | -0 | N/A | N/A | 5.0 | N/A | Systems Integration Testing (SIT) |  |  |  |  |  |  |  |
| 923 | 1.4.1.4.4.1.1 | Develop document with SITWG |  | 67d | 2023-11-30 A | 2024-03-01 A |  | 100% |  | 2023-11-30 | 2024-03-01 | 67d | 2023-11-30 | 2024-01-10 |  | must start on 2023-11-30 |  | SI Test |  | 5.0 |  | Systems Integration Testing (SIT) | Complete | COMPLETE |  |  |  |  |  |
| 924 | 1.4.1.4.4.1.2 | Draft document review with Code Bodies |  | 10d | 2024-03-04 A | 2024-03-15 A | 923 | 100% |  | 2024-03-04 | 2024-03-15 | 10d | 2024-01-11 | 2024-01-24 |  |  |  | SI Test | Code Bodies | 5.0 |  | Systems Integration Testing (SIT) | Complete | COMPLETE |  |  |  |  |  |
| 925 | 1.4.1.4.4.1.3 | Industry Consultation |  | 10d | 2024-03-18 A | 2024-03-29 A | 924 | 100% |  | 2024-03-18 | 2024-03-29 | 10d |  |  |  |  |  | PP |  | 5.1 |  | Systems Integration Testing (SIT) | Complete | COMPLETE |  |  |  |  |  |
| 926 | 1.4.1.4.4.1.4 | Industry Assurance Review |  | 5d | 2024-04-11 A | 2024-04-17 A | 925FS+8d | 100% |  | 2024-04-11 | 2024-04-17 | 5d |  |  |  |  |  |  |  | 5.16 |  |  | Complete | COMPLETE |  |  |  |  |  |
| 927 | 1.4.1.4.4.1.5 | SIT Non-Functional Testing Test Approach & Plan approved | milestone | 0d | 2024-05-15 A | 2024-05-15 A | 926FS+20d | 100% |  | 2024-05-15 | 2024-05-15 | 0d | 2024-03-20 | 2024-03-20 |  |  |  | SI Test | PP | 5.30 | Roger Robar | Systems Integration Testing (SIT) | Complete | COMPLETE | T3-TE-0026 | SITAG | T3 | MHHS-ART073 | 30/7/24: Approved at esitag on 26/7/24 |

Notes:
- 908: 3/6: SI coordinated smoke test will run from 5th - 7th June
- 920: 28/5: Amber because subject to SITAG agreement on work-off items. 4/6 eSITAG approved milestone completion subject to work-off items
- 927: Deferred from May SITAG approval, pending further confirmation and agreement of DIP-Helix Phase 1 testing.~ Start of SIT Non-Functional Testing at risk. Phase / Notes (2): 1 approach to be concluded and re-issued for SITAG approval. Forecast SITAG TBC

| ID | WBS | Task | Type | Duration | Start | Finish | Predecessors | Complete | Remaining | Actual finish | Baseline start | Baseline finish | Baseline duration | Baseline 1 start | Baseline 1 finish | Total slack | Free slack | Constraint | Baseline cost | Responsible | Involved | Update Version | MHHS Resource Name | MHHS Programme Phase | Sched Status | RAG | Milestone ID | Text29 | Task Status | Guidance |
| --- | --- | --- | --- | --- | --- | --- | --- | --- | --- | --- | --- | --- | --- | --- | --- | --- | --- | --- | --- | --- | --- | --- | --- | --- | --- | --- | --- | --- | --- | --- |
| 928 | 1.4.1.4.4.2 | **Test Data Approach & Plan** |  | 41d | 2024-03-20 A | 2024-05-15 A |  | 100% |  |  | 2024-03-20 | 2024-05-15 | 41d | 2024-01-25 | 2024-03-20 |  |  |  | -0 | N/A | N/A | 5.0 | N/A | Systems Integration Testing (SIT) |  |  |  |  |  |  |
| 929 | 1.4.1.4.4.2.1 | Industry Consultation |  | 14d | 2024-03-20 A | 2024-04-08 A | 925SS+2d | 100% |  |  | 2024-03-20 | 2024-04-08 | 14d |  |  |  |  |  |  | PP |  | 5.1 | Richard Puddephatt | Systems Integration Testing (SIT) | Complete | COMPLETE |  |  |  |  |
| 930 | 1.4.1.4.4.2.2 | Artefact review (via SITAG) and updates |  | 27d | 2024-04-09 A | 2024-05-15 A | 929 | 100% |  |  | 2024-04-09 | 2024-05-15 | 27d | 2024-01-25 | 2024-03-13 |  |  |  |  | SI Test |  | 5.0 | Richard Puddephatt | Systems Integration Testing (SIT) | Complete | COMPLETE |  |  |  |  |
| 931 | 1.4.1.4.4.2.3 | SIT Non-Functional Testing Test Data Approach & Plan approved | milestone | 0d | 2024-05-15 A | 2024-05-15 A | 927FF, 930 | 100% |  |  | 2024-05-15 | 2024-05-15 | 0d | 2024-03-20 | 2024-03-20 |  |  |  |  | SI Test | PP,IPA | 5.24 | Richard Puddephatt | Systems Integration Testing (SIT) | Complete | COMPLETE | T3-TE-0113 | SITAG |  |  |
| 932 | 1.4.1.4.4.3 | **Test scenarios & Test Cases** |  | 98d? | 2024-03-04 A | 2024-07-17 |  | 93% | 7.28d? |  | 2024-03-04 | 2024-08-21 | 123d | 2023-07-24 | 2024-01-17 |  |  |  | -0 | N/A | N/A | 5.21 | N/A | Systems Integration Testing (SIT) |  |  |  |  |  |  |
| 933 | 1.4.1.4.4.3.1 | **Theme 1** |  | 78d | 2024-03-04 A | 2024-06-19 A |  | 100% |  |  | 2024-03-04 | 2024-06-19 | 78d |  |  |  |  |  | -0 | N/A | N/A | 5.21 | N/A | Systems Integration Testing (SIT) |  |  |  |  | -448.67 |  |
| 934 | 1.4.1.4.4.3.1.1 | Develop Test Scenarios & Test Cases |  | 33d | 2024-03-04 A | 2024-04-17 A | 923 | 100% |  |  | 2024-03-04 | 2024-04-17 | 33d |  |  |  |  |  |  | SI Test | SI Test, PP | 5.21 |  |  | Complete | COMPLETE |  |  |  |  |
| 935 | 1.4.1.4.4.3.1.2 | Industry Review Workshop |  | 1d | 2024-04-18 A | 2024-04-18 A | 934 | 100% |  |  | 2024-04-18 | 2024-04-18 | 1d |  |  |  |  |  |  | SI Test, PP | SI Test, PP | 5.21 |  |  | Complete | COMPLETE |  |  |  |  |
| 936 | 1.4.1.4.4.3.1.3 | Industry Consultation Review |  | 7d | 2024-05-02 A | 2024-05-10 A | 935FS+9d | 100% |  |  | 2024-05-02 | 2024-05-10 | 7d |  |  |  |  |  |  | SI Test, PP | SI Test, PP | 5.21 |  |  | Complete | COMPLETE |  |  |  |  |
| 937 | 1.4.1.4.4.3.1.4 | Review with NFT Working Group |  | 5d | 2024-05-31 A | 2024-06-06 A | 936FS+14d | 100% |  |  | 2024-05-31 | 2024-06-06 | 5d |  |  |  |  |  |  | SI Test, PP | SI Test, PP | 5.21 |  |  | Complete | COMPLETE |  |  |  |  |
| 938 | 1.4.1.4.4.3.1.5 | SIT NFT Scenarios & Test Cases Approved - Theme 1 | milestone | 0d | 2024-06-19 A | 2024-06-19 A | 937FS+9d | 100% |  |  | 2024-06-19 | 2024-06-19 | 0d |  |  |  |  |  |  | SI Test | SI Test, PP | 5.30 | Roger Robar | Systems Integration Testing (SIT) | Complete | COMPLETE | T3-TE-0114 | SITAG |  | 30/7/24: Approved at esitag on 26/7/24 |
| 939 | 1.4.1.4.4.3.2 | **Theme 2** |  | 98d | 2024-03-04 A | 2024-07-17 A |  | 100% |  |  | 2024-03-04 | 2024-07-17 | 98d |  |  |  |  |  |  | N/A | N/A | 5.21 | N/A | Systems Integration Testing (SIT) |  |  |  |  | -448.67 |  |
| 940 | 1.4.1.4.4.3.2.1 | Develop Test Scenarios & Test Cases |  | 53d | 2024-03-04 A | 2024-05-15 A | 923 | 100% |  |  | 2024-03-04 | 2024-05-15 | 53d |  |  |  |  |  |  | SI Test | SI Test, PP | 5.21 |  |  | Complete | COMPLETE |  |  |  |  |
| 941 | 1.4.1.4.4.3.2.2 | Industry Review Workshop |  | 1d | 2024-05-16 A | 2024-05-16 A | 940 | 100% |  |  | 2024-05-16 | 2024-05-16 | 1d |  |  |  |  |  |  | SI Test, PP | SI Test, PP | 5.21 |  |  | Complete | COMPLETE |  |  |  |  |
| 942 | 1.4.1.4.4.3.2.3 | Industry Consultation Review |  | 7d | 2024-05-20 A | 2024-05-28 A | 941FS+1d | 100% |  |  | 2024-05-20 | 2024-05-28 | 7d |  |  |  |  |  |  | SI Test, PP | SI Test, PP | 5.21 |  |  | Complete | COMPLETE |  |  |  |  |
| 943 | 1.4.1.4.4.3.2.4 | Review with NFT Working Group |  | 5d | 2024-06-28 A | 2024-07-04 A | 942FS+22d | 100% |  |  | 2024-06-28 | 2024-07-04 | 5d |  |  |  |  |  |  | SI Test, PP | SI Test, PP | 5.21 |  |  | Complete | COMPLETE |  |  |  |  |
| 944 | 1.4.1.4.4.3.2.5 | SIT NFT Scenarios & Test Cases Approved - Theme 2 | milestone | 0d | 2024-07-17 A | 2024-07-17 A | 943FS+9d | 100% |  |  | 2024-07-17 | 2024-07-17 | 0d |  |  |  |  |  |  | SI Test | SI Test, PP | 5.22 |  | Systems Integration Testing (SIT) | Complete | COMPLETE | T3-TE-0115 | SITAG |  |  |
| 945 | 1.4.1.4.4.3.3 | **Theme 3** |  | 98d? | 2024-03-04 A | 2024-07-17 |  | 100% |  | 2024-09-18 | 2024-03-04 | 2024-08-21 | 123d |  |  |  |  |  | -0 | N/A | N/A | 6.0 | N/A | Systems Integration Testing (SIT) |  |  |  |  | -448.67 |  |
| 946 | 1.4.1.4.4.3.3.1 | Develop Test Scenarios & Test Cases |  | 63d | 2024-03-04 A | 2024-05-29 A | 923 | 100% |  |  | 2024-03-04 | 2024-05-29 | 63d |  |  |  |  |  |  | SI Test | SI Test, PP | 6.0 |  |  | Complete | COMPLETE |  |  |  |  |
| 947 | 1.4.1.4.4.3.3.2 | Industry Review Workshop |  | 1d | 2024-05-30 A | 2024-05-30 A | 946 | 100% |  |  | 2024-05-30 | 2024-05-30 | 1d |  |  |  |  |  |  | SI Test, PP | SI Test, PP | 6.0 |  |  | Complete | COMPLETE |  |  |  |  |
| 948 | 1.4.1.4.4.3.3.3 | Industry Consultation Review |  | 6d | 2024-06-10 A | 2024-06-17 A | 947FS+6d | 100% |  |  | 2024-06-10 | 2024-06-17 | 6d |  |  |  |  |  |  | SI Test, PP | SI Test, PP | 6.0 |  |  | Complete | COMPLETE |  |  |  |  |
| 949 | 1.4.1.4.4.3.3.4 | Review with NFT Working Group |  | 5d | 2024-06-28 A | 2024-07-04 A | 948FS+8d | 100% |  |  | 2024-06-28 | 2024-08-08 | 30d |  |  |  |  |  |  | SI Test, PP | SI Test, PP | 6.0 | Roger Robar |  | Complete | COMPLETE |  |  |  |  |
| 950 | 1.4.1.4.4.3.3.5 | SIT NFT Scenarios & Test Cases Approved - Theme 3 | milestone | 0d | 2024-09-18 A | 2024-09-18 A | 949FS+9d | 100% |  |  | 2024-08-21 | 2024-08-21 | 0d |  |  |  |  | start no earlier than 2024-09-18 |  | SI Test | SI Test, PP | 5.30 | Roger Robar | Systems Integration Testing (SIT) | Complete | COMPLETE | T3-TE-0116 | SITAG |  | 31/7/24: baseline date change approved at esitag on 26/7/24 |
| 951 | 1.4.1.4.4.3.4 | **SIT NFT Programme RTTM** |  | 15d | 2024-09-18 | 2024-10-08 |  |  |  |  |  |  |  |  |  | 32580d |  |  |  |  |  |  |  |  | Overdue Start | RED |  |  | -197.67 |  |
| 952 | 1.4.1.4.4.3.4.1 | Develop Manual SIT NFT RTTM |  | 10d | 2024-09-18 | 2024-10-01 | 950 |  |  |  |  |  |  |  |  | 32580d | 0d |  |  |  |  |  |  |  | No BL | GREEN |  |  | -1.67 |  |
| 953 | 1.4.1.4.4.3.4.2 | Manual SIT NFT RTTM Complete | milestone | 0d | 2024-10-01 | 2024-10-01 | 952 |  |  |  |  |  |  |  |  | 32580d | 0d |  |  |  |  |  |  |  | No BL | GREEN |  |  | 11.71 |  |
| 954 | 1.4.1.4.4.3.4.3 | Develop Automated SIT NFT RTTM |  | 5d | 2024-10-02 | 2024-10-08 | 953 |  |  |  |  |  |  |  |  | 32580d | 0d |  |  |  |  |  |  |  | No BL | GREEN |  |  | 12.33 |  |
| 955 | 1.4.1.4.4.3.4.4 | Automated SIT NFT RTTM Complete | milestone | 0d | 2024-10-08 | 2024-10-08 | 954 |  |  |  |  |  |  |  |  | 32580d |  |  |  |  |  |  |  |  | No BL | GREEN |  |  | 18.71 |  |

Notes:
- 931: 13/2 - To go to Feb SITAG as a new milestone. 21/2/24 - Approved at SITAG on 21/2/24 as a new milestone. 3/4 At risk because of tight delivery schedule (added as amber to align with Lee's status)
- 932: 12/09/24 - Forecast date changed to reflect the SI Plan
- 938: Deferred from June SITAG approval, pending further confirmation and agreement of DIP-Helix Phase 1 testing. Start of SIT Non-Functional Testing at risk. Phase 1 approach to be concluded and re-issued for SITAG approval. Forecast SITAG TBC
- 944: Date missed because of the deferment of the SIT Non-Functional Test Approach and Plan. This increases the risk to the start of SIT Non-Functional Testing
- 945: 12/09/24 - Forecast date changed in line with SI Plan
- 949: 12/09/24 - Duration shortened to 5 days to be in line with the SI Plan.
- 950: Date missed because of uncertainty around test scenarios based PPs engagement. Test cases may not be ready in time for the start of SIT Non-Functional testing. Approval forecast at Sep SITAG in prep for testing commencing 7/10.

| ID | WBS | Task | Type | Duration | Start | Finish | Predecessors | Complete | Remaining | Baseline start | Baseline finish | Baseline duration | Baseline 1 start | Baseline 1 finish | Total slack | Free slack | Constraint | Baseline cost | Responsible | Involved | Update Version | MHHS Resource Name | MHHS Programme Phase | Action | Task Status | Sched Status | RAG | Milestone ID | Text29 | Tier |
| --- | --- | --- | --- | --- | --- | --- | --- | --- | --- | --- | --- | --- | --- | --- | --- | --- | --- | --- | --- | --- | --- | --- | --- | --- | --- | --- | --- | --- | --- | --- |
| 956 | 1.4.1.4.4.4 | **Environments (SIT B)** |  | 94d? | 2024-08-27 | 2025-01-03 |  |  |  | 2024-08-27 | 2024-08-27 | 0d | 2024-07-30 | 2024-08-05 | 31892d |  |  | -0 | N/A | N/A | 5.0 | N/A | Systems Integration Testing (SIT) |  |  |  |  |  |  |  |
| 957 | 1.4.1.4.4.4.1 | **PP Environments (SIT B)** |  | 0d | 2024-08-27 | 2024-08-27 |  |  |  | 2024-08-27 | 2024-08-27 | 0d | 2024-07-30 | 2024-08-05 | 32611d |  |  | -0 | N/A | N/A | 5.0 | N/A | Systems Integration Testing (SIT) |  |  |  |  |  |  |  |
| 958 | 1.4.1.4.4.4.1.1 | Deployment of MHHS solution code to SIT B environments | milestone | 0d | 2024-08-27 | 2024-08-27 |  |  |  | 2024-08-27 | 2024-08-27 | 0d | 2024-07-30 | 2024-08-05 | 32611d | 0d | start no earlier than 2024-08-27 |  | PP | SI Test | 5.21 | Simon Berry | Systems Integration Testing (SIT) | 26/3/24: Lee said change to SB and align to IR7 | -23.67 | Green | GREEN |  |  |  |
| 959 | 1.4.1.4.4.4.2 | **SI Environments (SIT B)** |  | 0d | 2024-08-27 | 2024-08-27 |  |  |  | 2024-08-27 | 2024-08-27 | 0d | 2024-07-30 | 2024-08-05 | 32611d |  |  | -0 | N/A | N/A | 5.0 | N/A | Systems Integration Testing (SIT) |  |  |  |  |  |  |  |
| 960 | 1.4.1.4.4.4.2.1 | Coordinate deployment of MHHS solution code to SIT Participants' SIT B environments | milestone | 0d | 2024-08-27 | 2024-08-27 | 958SS |  |  | 2024-08-27 | 2024-08-27 | 0d | 2024-07-30 | 2024-08-05 | 32611d |  |  |  | SI Test | PP | 5.21 | Simon Berry | Systems Integration Testing (SIT) |  | -23.67 | Green | GREEN |  |  |  |
| 961 | 1.4.1.4.4.4.3 | **Helix and Avanade Environments Upscale** |  | 10d? | 2024-12-23 | 2025-01-03 |  |  |  |  |  |  |  |  | 31808d |  |  |  |  |  |  |  |  |  | -686.67 | Overdue Start | RED |  |  |  |
| 962 | 1.4.1.4.4.4.3.1 | Environment Uplift Window |  | 10d? | 2024-12-23 | 2025-01-03 | 1114 |  |  |  |  |  |  |  | 31808d | 0d |  |  |  |  |  |  |  |  | 94.33 | No BL | GREEN |  |  |  |
| 963 | 1.4.1.4.4.5 | **Test Data - Non-Functional and Operational (SIT B)** |  | 50d? | 2025-01-06 | 2025-03-14 |  |  |  |  |  |  |  |  | 31808d |  |  |  |  |  |  |  |  |  | -686.67 | Overdue Start | RED |  |  |  |
| 964 | 1.4.1.4.4.5.1 | **Data Load** |  | 50d? | 2025-01-06 | 2025-03-14 |  |  |  |  |  |  |  |  | 31808d |  |  |  |  |  |  |  |  |  | -689.67 | Overdue Start | RED |  |  |  |
| 965 | 1.4.1.4.4.5.1.1 | Non-Functional Theme 1 (Helix & DIP Volume Testing) Data Load |  | 5d? | 2025-01-06 | 2025-01-10 | 962 |  |  |  |  |  |  |  | 31808d | 0d |  |  |  |  |  |  |  |  | 108.33 | No BL | GREEN |  |  |  |
| 966 | 1.4.1.4.4.5.1.2 | Non-Functional Theme 2 & 3 (Helix and DIP) Data Load |  | 5d | 2025-02-03 | 2025-02-07 | 1170 |  |  |  |  |  |  |  | 31813d | 0d |  |  |  |  |  |  |  |  | 136.33 | No BL | GREEN |  |  |  |
| 967 | 1.4.1.4.4.5.1.3 | Non-Functional Themes 2 & 3 (Central Parties and PPs) Data Load |  | 20d? | 2025-01-06 | 2025-01-31 | 962 |  |  |  |  |  |  |  | 31843d | 30d |  |  |  |  |  |  |  |  | 108.33 | No BL | GREEN |  |  |  |
| 968 | 1.4.1.4.4.5.1.4 | Operational Themes 1, 2 & 3 (Batch 2) (Central Parties and PPs) Data Load |  | 20d? | 2025-01-06 | 2025-01-31 | 962 |  |  |  |  |  |  |  | 31813d | 5d | start no earlier than 2025-01-06 |  |  |  |  |  |  |  | 108.33 | No BL | GREEN |  |  |  |
| 969 | 1.4.1.4.4.5.1.5 | Operational Themes 1, 2 & 3 (Batch 2) (Helix & DIP) Data Load |  | 5d | 2025-02-03 | 2025-02-07 | 1170 |  |  |  |  |  |  |  | 31808d | 0d |  |  |  |  |  |  |  |  | 136.33 | No BL | GREEN |  |  |  |
| 970 | 1.4.1.4.4.5.1.6 | Non-Functional and Operational Test Data Preparation Complete | milestone | 0d | 2025-02-07 | 2025-02-07 | 969 |  |  |  |  |  |  |  | 32492d |  |  |  |  |  |  |  |  |  | 140.71 | No BL | GREEN |  |  |  |
| 971 | 1.4.1.4.4.5.1.7 | Non-Functional Theme 2 & 3 PP Preparation |  | 25d? | 2025-02-10 | 2025-03-14 | 966 |  |  |  |  |  |  |  | 31813d | 0d |  |  |  |  |  |  |  |  | 143.33 | No BL | GREEN |  |  |  |
| 972 | 1.4.1.4.4.6 | **SIT Non-Functional Test Readiness Report** |  | 219d | 2024-06-25 A | 2025-04-25 |  | 22% | 171.09d | 2024-06-25 | 2024-08-23 | 44d | 2024-06-25 | 2024-08-19 | 31778d |  |  | -0 | N/A | N/A | 5.0 | N/A | Systems Integration Testing (SIT) |  |  |  |  |  |  |  |
| 973 | 1.4.1.4.4.6.1 | **PP SIT Non-Functional Test Readiness Report** |  | 219d | 2024-06-25 A | 2025-04-25 |  | 22% | 169.84d | 2024-06-25 | 2024-08-23 | 44d | 2024-06-25 | 2024-08-05 | 31778d |  |  | -0 | N/A | N/A | 5.0 | N/A | Systems Integration Testing (SIT) |  |  |  |  |  |  |  |
| 974 | 1.4.1.4.4.6.1.1 | Develop draft Test Readiness Report and submit to Programme for assurance |  | 20d | 2024-06-25 A | 2024-07-22 A |  | 100% |  | 2024-06-25 | 2024-07-22 | 20d | 2024-06-25 | 2024-07-22 |  |  | start no earlier than 2024-06-25 |  | PP | SI Test | 5.0 | Roger Robar | Systems Integration Testing (SIT) |  |  | Complete | COMPLETE |  |  |  |
| 975 | 1.4.1.4.4.6.1.2 | Placing Reliance Stage 2 Review |  | 215d | 2024-07-01 A | 2025-04-25 | 974SS+4d | 13% | 187d | 2024-07-01 | 2024-08-23 | 40d |  |  | 31778d | 0d |  |  | SI Test | PP | 5.12 | Roger Robar | Systems Integration Testing (SIT) |  |  | Red | RED |  |  |  |
| 976 | 1.4.1.4.4.6.1.3 | Finalise Test Readiness Report and submit to Programme for assurance |  | 10d | 2024-07-23 A | 2024-08-05 | 974 | 70% | 3d | 2024-07-23 | 2024-08-05 | 10d | 2024-07-23 | 2024-08-05 | 79d |  |  |  | PP | SI Test | 5.0 | Roger Robar | Systems Integration Testing (SIT) |  |  | Overdue | RED |  |  |  |
| 977 | 1.4.1.4.4.6.2 | **SI SIT Non-Functional Test Readiness Report** |  | 132d | 2024-06-25 A | 2024-12-25 |  | 21% | 104.46d | 2024-06-25 | 2024-08-19 | 40d | 2024-06-25 | 2024-08-19 | 31860d |  |  |  | N/A | N/A | 5.0 | N/A | Systems Integration Testing (SIT) |  |  |  |  |  |  |  |
| 978 | 1.4.1.4.4.6.2.1 | Assure Test Participants' Test Readiness Reports |  | 114d | 2024-06-25 A | 2024-11-29 | 974SS, 976FF+5d | 19% | 92d | 2024-06-25 | 2024-08-12 | 35d | 2024-06-25 | 2024-08-12 | 0d |  |  |  | SI Test | PP,IPA | 5.0 | Roger Robar | Systems Integration Testing (SIT) |  |  | Red | RED |  |  |  |
| 979 | 1.4.1.4.4.6.2.2 | Develop Overarching SIT Non-Functional Test Readiness Report |  | 20d | 2024-11-08 A | 2024-12-18 | 978 | 35% | 13d | 2024-07-16 | 2024-08-12 | 20d | 2024-07-16 | 2024-08-12 | 31860d | 0d |  |  | SI Test |  | 5.0 | Roger Robar | Systems Integration Testing (SIT) |  |  | Red | RED |  |  |  |
| 980 | 1.4.1.4.4.6.2.3 | Artefact review (via SITAG) and updates |  | 5d | 2024-12-19 | 2024-12-25 | 979 |  |  | 2024-08-13 | 2024-08-19 | 5d | 2024-08-13 | 2024-08-19 | 31860d | 82d |  |  | SI Test | PP,IPA | 5.0 | Roger Robar | Systems Integration Testing (SIT) |  | 90.33 | Red | RED |  |  |  |
| 981 | 1.4.1.4.4.7 | SIT Non-Functional Testing Preparation Complete | milestone | 0d | 2025-04-25 | 2025-04-25 | 980FF+5d, 793, 349, 975, 938, 944, 950 |  |  | 2024-08-26 | 2024-08-26 | 0d | 2024-08-26 | 2024-08-26 | 31778d | 0d |  |  | SI Test | PP,IPA | 5.0 | Roger Robar | Systems Integration Testing (SIT) |  | 217.71 | Red | RED | T2-TE-0700 | SITAG | T2 |

Notes:
- 958: 25/3: SB - Date aligns to IR8 code delivery for SIT B
- 960: 25/3: SB - Date aligns to IR8 code delivery for SIT B
- 981: Date at risk due to lower than expected SIT functional test velocity. Date re-forecast in line with short term scenario planning. Introduction of 5 weeks additional sprints.

| ID | WBS | Task | Type | Duration | Start | Finish | Predecessors | Complete | Remaining | Baseline start | Baseline finish | Baseline duration | Baseline 1 start | Baseline 1 finish | Total slack | Constraint | Baseline cost | Responsible | Involved | Update Version | MHHS Resource Name | MHHS Programme Phase | Sched Status | RAG | Artefact ID | Milestone ID | Text29 | Tier | Task Status | Guidance |
| --- | --- | --- | --- | --- | --- | --- | --- | --- | --- | --- | --- | --- | --- | --- | --- | --- | --- | --- | --- | --- | --- | --- | --- | --- | --- | --- | --- | --- | --- | --- |
| 982 | 1.4.1.4.5 | **SIT Operational Preparation** |  | 262d? | 2024-02-01 A | 2025-01-31 |  | 30% | 184.66d? | 2024-02-01 | 2025-03-03 | 283d | 2023-08-03 | 2025-03-10 | 32497d |  | -0 | N/A | N/A | 5.0 | N/A | Systems Integration Testing (SIT) |  |  |  |  |  |  |  |  |
| 983 | 1.4.1.4.5.1 | **Test Approach & Plan** |  | 75d | 2024-02-01 A | 2024-05-15 A |  | 100% |  | 2024-02-01 | 2024-05-15 | 75d | 2024-02-01 | 2024-05-15 |  |  | -0 | N/A | N/A | 5.0 | N/A | Systems Integration Testing (SIT) |  |  |  |  |  |  |  |  |
| 984 | 1.4.1.4.5.1.1 | Develop document with SITWG |  | 25d | 2024-02-01 A | 2024-03-06 A |  | 100% |  | 2024-02-01 | 2024-03-06 | 25d | 2024-02-01 | 2024-03-06 |  | must start on 2024-02-01 |  | SI Test |  | 5.0 |  | Systems Integration Testing (SIT) | Complete | COMPLETE |  |  |  |  |  |  |
| 985 | 1.4.1.4.5.1.2 | Draft document review with Code Bodies |  | 4d | 2024-03-21 A | 2024-03-26 A | 984FS+10d | 100% |  | 2024-03-07 | 2024-03-20 | 10d | 2024-03-07 | 2024-03-20 |  |  |  | SI Test | Code Bodies | 5.0 |  | Systems Integration Testing (SIT) | Complete | COMPLETE |  |  |  |  |  |  |
| 986 | 1.4.1.4.5.1.3 | Industry Consultation |  | 10d | 2024-03-27 A | 2024-04-09 A | 985 | 100% |  | 2024-03-27 | 2024-04-09 | 10d |  |  |  |  |  | PP |  | 5.1 |  | Systems Integration Testing (SIT) | Complete | COMPLETE |  |  |  |  |  |  |
| 987 | 1.4.1.4.5.1.4 | Artefact review (via SITAG) and updates |  | 26d | 2024-04-10 A | 2024-05-15 A | 986 | 100% |  | 2024-04-04 | 2024-05-15 | 30d | 2024-03-21 | 2024-05-15 |  |  |  | SI Test | PP,IPA,Code Bodies | 5.0 |  | Systems Integration Testing (SIT) | Complete | COMPLETE |  |  |  |  |  |  |
| 988 | 1.4.1.4.5.1.5 | SIT Operational Testing Test Approach & Plan approved | milestone | 0d | 2024-05-15 A | 2024-05-15 A | 987 | 100% |  | 2024-05-15 | 2024-05-15 | 0d | 2024-05-15 | 2024-05-15 |  |  |  | SI Test | PP | 5.24 |  | Systems Integration Testing (SIT) | Complete | COMPLETE | MHHS-ART073 | T3-TE-0029 | SITAG | T3 |  |  |
| 989 | 1.4.1.4.5.2 | **Test Data Approach & Plan** |  | 36d | 2024-03-27 A | 2024-05-15 A |  | 100% |  | 2024-03-27 | 2024-05-15 | 36d | 2024-03-21 | 2024-05-15 |  |  | -0 | N/A | N/A | 5.0 | N/A | Systems Integration Testing (SIT) |  |  |  |  |  |  |  |  |
| 990 | 1.4.1.4.5.2.1 | Industry Consultation |  | 10d | 2024-03-27 A | 2024-04-09 A | 986SS | 100% |  | 2024-03-27 | 2024-04-09 | 10d |  |  |  |  |  | PP |  | 5.1 | Richard Puddephatt | Systems Integration Testing (SIT) | Complete | COMPLETE |  |  |  |  |  |  |
| 991 | 1.4.1.4.5.2.2 | Artefact review (via SITAG) and updates |  | 26d | 2024-04-10 A | 2024-05-15 A | 990 | 100% |  | 2024-04-10 | 2024-05-15 | 26d | 2024-03-21 | 2024-05-15 |  |  |  | SI Test |  | 5.0 | Richard Puddephatt | Systems Integration Testing (SIT) | Complete | COMPLETE |  |  |  |  |  |  |
| 992 | 1.4.1.4.5.2.3 | SIT Operational Testing Test Data Approach & Plan approved | milestone | 0d | 2024-05-15 A | 2024-05-15 A | 991 | 100% |  | 2024-05-15 | 2024-05-15 | 0d | 2024-05-15 | 2024-05-15 |  |  |  | SI Test | PP,IPA | 5.0 | Richard Puddephatt | Systems Integration Testing (SIT) | Complete | COMPLETE |  |  |  |  |  |  |
| 993 | 1.4.1.4.5.3 | **Test scenarios & Test Cases** |  | 213d? | 2024-04-10 A | 2025-01-31 |  | 27% | 155.13d? | 2024-04-10 | 2024-09-18 | 116d | 2023-07-24 | 2024-01-17 | 32497d |  | -0 | N/A | N/A | 5.21 | N/A | Systems Integration Testing (SIT) |  |  |  |  |  |  |  |  |
| 994 | 1.4.1.4.5.3.1 | **Theme 1** |  | 108d | 2024-04-10 A | 2024-09-06 A |  | 100% |  | 2024-04-10 | 2024-08-21 | 96d |  |  |  |  | -0 | N/A | N/A | 6.0 | N/A | Systems Integration Testing (SIT) |  |  |  |  |  |  | -448.67 |  |
| 995 | 1.4.1.4.5.3.1.1 | Develop Test Scenarios & Test Cases |  | 53d | 2024-04-10 A | 2024-06-21 A | 986 | 100% |  | 2024-04-10 | 2024-05-01 | 16d |  |  |  |  |  | SI Test | SI Test, PP | 6.0 |  |  | Complete | COMPLETE |  |  |  |  |  |  |
| 996 | 1.4.1.4.5.3.1.2 | Industry Review Workshop |  | 1d | 2024-06-24 A | 2024-06-24 A | 995 | 100% |  | 2024-05-02 | 2024-05-02 | 1d |  |  |  |  |  | SI Test, PP | SI Test, PP | 6.0 |  |  | Complete | COMPLETE |  |  |  |  |  |  |
| 997 | 1.4.1.4.5.3.1.3 | Industry Consultation Review |  | 6d | 2024-07-02 A | 2024-07-09 A | 996FS+17d | 100% |  | 2024-05-28 | 2024-06-04 | 6d |  |  |  |  |  | SI Test, PP | SI Test, PP | 6.0 |  |  | Complete | COMPLETE |  |  |  |  |  |  |
| 998 | 1.4.1.4.5.3.1.4 | Review with SIT Working Group |  | 5d | 2024-08-19 A | 2024-08-23 A | 997FS+16d | 100% |  | 2024-06-27 | 2024-07-03 | 5d |  |  |  |  |  | SI Test, PP | SI Test, PP | 6.0 |  |  | Complete | COMPLETE |  |  |  |  |  |  |
| 999 | 1.4.1.4.5.3.1.5 | SIT Operational Scenarios & Test Cases Approved - Theme 1 | milestone | 0d | 2024-09-06 A | 2024-09-06 A | 998FS+10d | 100% |  | 2024-08-21 | 2024-08-21 | 0d |  |  |  | start no earlier than 2024-09-06 |  | SI Test | SI Test, PP | 6.0 | Roger Robar | Systems Integration Testing (SIT) | Complete | COMPLETE |  | T3-TE-0117 | SITAG |  |  | 31/7/24: baseline date change approved at esitag on 26/7/24 |
| 1000 | 1.4.1.4.5.3.2 | **Theme 2** |  | 107d | 2024-04-10 A | 2024-09-06 A |  | 100% |  | 2024-04-10 | 2024-07-17 | 71d |  |  |  |  |  | N/A | N/A | 6.0 | N/A | Systems Integration Testing (SIT) |  |  |  |  |  |  | -448.67 |  |
| 1001 | 1.4.1.4.5.3.2.1 | Develop Test Scenarios & Test Cases |  | 53d | 2024-04-10 A | 2024-06-21 A | 986 | 100% |  | 2024-04-10 | 2024-05-22 | 31d |  |  |  | finish no earlier than 2024-06-21 |  | SI Test | SI Test, PP | 6.0 |  |  | Complete | COMPLETE |  |  |  |  |  |  |
| 1002 | 1.4.1.4.5.3.2.2 | Industry Review Workshop |  | 1d | 2024-06-24 A | 2024-06-24 A | 1001 | 100% |  | 2024-05-23 | 2024-05-23 | 1d |  |  |  |  |  | SI Test, PP | SI Test, PP | 6.0 |  |  | Complete | COMPLETE |  |  |  |  |  |  |
| 1003 | 1.4.1.4.5.3.2.3 | Industry Consultation Review |  | 6d | 2024-07-02 A | 2024-07-09 A | 1002FS+7d | 100% |  | 2024-06-04 | 2024-06-11 | 6d |  |  |  |  |  | SI Test, PP | SI Test, PP | 6.0 |  |  | Complete | COMPLETE |  |  |  |  |  |  |
| 1004 | 1.4.1.4.5.3.2.4 | Review with SIT Working Group |  | 5d | 2024-08-19 A | 2024-08-23 A | 1003FS+11d | 100% |  | 2024-06-27 | 2024-07-03 | 5d |  |  |  |  |  | SI Test, PP | SI Test, PP | 6.0 |  |  | Complete | COMPLETE |  |  |  |  |  |  |
| 1005 | 1.4.1.4.5.3.2.5 | SIT Operational Scenarios & Test Cases Approved - Theme 2 | milestone | 0d | 2024-09-06 A | 2024-09-06 A | 1004FS+10d | 100% |  | 2024-07-17 | 2024-07-17 | 0d |  |  |  |  |  | SI Test | SI Test, PP | 6.0 |  | Systems Integration Testing (SIT) | Complete | COMPLETE |  | T3-TE-0118 | SITAG |  |  |  |

Notes:
- 988: 26/3 - At risk because of tight delivery schedule
- 995: 12/09/24 - Duration increased from 16 days to 53 days, in line with the SI Plan
- 996: 12/09/24 - Forecast date changed in line with SI Plan.
- 997: 12/09/24 - Forecast date changed in line with SI Plan.
- 998: 12/09/24 - Forecast date changed in line with SI Plan.
- 999: 12/09/24 - Lag reduced from 35 days to 10 days in line with the SI Plan. Confirmed with Roger R that this is complete.
- 1001: 12/09/24 - Duration increased from 31 days to 53 days, in line with the SI Plan
- 1002: 12/09/24 - Forecast date changed in line with SI Plan.
- 1003: 12/09/24 - Forecast date changed in line with SI Plan.
- 1004: 12/09/24 - Forecast date changed in line with SI Plan.
- 1005: 23/1 - New milestone added because of Operational themed delivery approach. To go to April SITAG for approval. 17/4: Approved as new milestone at SITAG on 17/4/24. Roger R confirmed this is complete.

| ID | WBS | Task | Type | Duration | Start | Finish | Predecessors | Complete | Remaining | Baseline start | Baseline finish | Baseline duration | Total slack | Free slack | Constraint | Baseline cost | Task Status | Sched Status | RAG | Responsible | Involved | Update Version | MHHS Resource Name | MHHS Programme Phase | Guidance | Milestone ID | Text29 |
| --- | --- | --- | --- | --- | --- | --- | --- | --- | --- | --- | --- | --- | --- | --- | --- | --- | --- | --- | --- | --- | --- | --- | --- | --- | --- | --- | --- |
| 1006 | 1.4.1.4.5.3.3 | **Elexon / Helix Service Management Test Prep** |  | 145d? | 2024-07-15 | 2025-01-31 |  |  |  |  |  |  | 31858d |  |  |  | -688.67 | Overdue Start | RED |  |  |  |  |  |  |  |  |
| 1007 | 1.4.1.4.5.3.3.1 | Elexon Service Now Build and Implementation |  | 145d? | 2024-07-15 | 2025-01-31 |  |  |  |  |  |  | 31858d | 0d | start no earlier than 2024-07-15 |  | -66.67 | Overdue Start | GREEN |  |  |  |  |  |  |  |  |
| 1008 | 1.4.1.4.5.3.3.2 | Helix Engagement and Comms |  | 105d? | 2024-09-09 | 2025-01-31 |  |  |  |  |  |  | 31858d | 0d | start no earlier than 2024-09-09 |  | -10.67 | No BL | GREEN |  |  |  |  |  |  |  |  |
| 1009 | 1.4.1.4.5.3.3.3 | Helix Service Management Documentation (Service Design Pack and Service User Op Model) |  | 105d? | 2024-09-09 | 2025-01-31 |  |  |  |  |  |  | 31858d | 0d | start no earlier than 2024-09-09 |  | -10.67 | No BL | GREEN |  |  |  |  |  |  |  |  |
| 1010 | 1.4.1.4.5.3.3.4 | Helix Knowledge Articles |  | 105d? | 2024-09-09 | 2025-01-31 |  |  |  |  |  |  | 31858d | 0d | start no earlier than 2024-09-09 |  | -10.67 | No BL | GREEN |  |  |  |  |  |  |  |  |
| 1011 | 1.4.1.4.5.3.4 | **Theme 3 (Batch 2)** |  | 60d? | 2024-09-19 A | 2024-12-11 |  | 14% | 51.85d? | 2024-04-10 | 2024-09-18 | 116d | 32534d |  |  | -0 | -448.67 |  |  | N/A | N/A | 6.0 | N/A | Systems Integration Testing (SIT) |  |  |  |
| 1012 | 1.4.1.4.5.3.4.1 | Conclude BCDR Scope with SRO, Code Bodies and DIP Manager |  | 17d | 2024-09-19 | 2024-10-11 |  |  |  |  |  |  | 32577d |  | start no earlier than 2024-09-19 |  | -0.67 | No BL | GREEN |  |  |  |  |  |  |  |  |
| 1013 | 1.4.1.4.5.3.4.2 | Develop BDCR Test Scenarios & Test Cases (Batch 2) |  | 10d | 2024-10-14 A | 2024-10-25 A | 1012 | 100% |  |  |  |  |  |  |  |  |  | Complete | COMPLETE |  |  | 6.0 |  |  |  |  |  |
| 1014 | 1.4.1.4.5.3.4.3 | Develop DIP Test Scenarios and Test Cases (Batch 2) |  | 27d | 2024-09-19 | 2024-10-25 |  |  |  |  |  |  | 1d | 0d | start no earlier than 2024-09-19 |  | -0.67 | No BL | GREEN |  |  |  |  |  |  |  |  |
| 1015 | 1.4.1.4.5.3.4.4 | SRO Review |  | 5d | 2024-10-28 | 2024-11-01 | 1014 |  |  |  |  |  | 1d | 0d | start no earlier than 2024-10-28 |  | 38.33 | No BL | GREEN |  |  |  |  |  |  |  |  |
| 1016 | 1.4.1.4.5.3.4.5 | Industry Review Workshop (Batch 2) |  | 10d | 2024-11-04 A | 2024-11-15 | 1015 | 10% | 9d | 2024-06-13 | 2024-06-13 | 1d | 31842d | 0d |  |  |  | Red | RED | SI Test, PP | SI Test, PP | 6.0 |  |  |  |  |  |
| 1017 | 1.4.1.4.5.3.4.6 | Review Feedback and Update |  | 5d | 2024-11-18 | 2024-11-22 | 1016 |  |  |  |  |  | 31842d | 0d |  |  | 59.33 | No BL | GREEN |  |  |  |  |  |  |  |  |
| 1018 | 1.4.1.4.5.3.4.7 | Review with SIT WG (Batch 2) |  | 6d | 2024-11-28 | 2024-12-05 | 1017FS+3d |  |  |  |  |  | 31842d | 0d |  |  | 69.33 | No BL | GREEN |  |  |  |  |  |  |  |  |
| 1019 | 1.4.1.4.5.3.4.8 | SITAG Approval (Batch 2) |  | 1d? | 2024-12-11 | 2024-12-11 | 1018FS+3d |  |  |  |  |  | 31842d | 0d |  |  | 82.33 | No BL | GREEN |  |  |  |  |  |  |  |  |
| 1020 | 1.4.1.4.5.3.5 | **Theme 3 (Batch 1)** |  | 176d? | 2024-04-10 A | 2024-12-11 |  | 58% | 74.31d? |  |  |  | 31842d |  |  |  | -688.67 | Overdue Start | RED |  |  |  |  |  |  |  |  |
| 1021 | 1.4.1.4.5.3.5.1 | Develop Test Scenarios & Test Cases (Batch 1) |  | 78d | 2024-04-10 A | 2024-07-26 A | 986 | 100% |  | 2024-04-10 | 2024-06-12 | 46d |  |  |  |  |  | Complete | COMPLETE | SI Test | SI Test, PP | 6.0 |  |  |  |  |  |
| 1022 | 1.4.1.4.5.3.5.2 | Conclude Industry Consultation (Batch 1) |  | 11d | 2024-09-05 | 2024-09-19 |  |  |  |  |  |  | 31842d | 0d | start no earlier than 2024-09-05 |  | -14.67 | No BL | GREEN |  |  |  |  |  |  |  |  |
| 1023 | 1.4.1.4.5.3.5.3 | Review Feedback and Update |  | 5d | 2024-09-20 | 2024-09-26 | 1022 |  |  |  |  |  | 31842d | 0d |  |  | 0.33 | No BL | GREEN |  |  |  |  |  |  |  |  |
| 1024 | 1.4.1.4.5.3.5.4 | Draft Test Cases from Feedback and Approved LLSD |  | 15d? | 2024-09-30 | 2024-10-18 | 1023FS+1d, 1033 |  |  |  |  |  | 31842d | 0d |  |  | 10.33 | No BL | GREEN |  |  |  |  |  |  |  |  |
| 1025 | 1.4.1.4.5.3.5.5 | SRO Review |  | 5d? | 2024-10-21 | 2024-10-25 | 1024 |  |  |  |  |  | 31842d | 0d |  |  | 31.33 | No BL | GREEN |  |  |  |  |  |  |  |  |
| 1026 | 1.4.1.4.5.3.5.6 | Industry Consultation |  | 10d? | 2024-10-28 | 2024-11-08 | 1025 |  |  |  |  |  | 31842d | 0d |  |  | 38.33 | No BL | GREEN |  |  |  |  |  |  |  |  |
| 1027 | 1.4.1.4.5.3.5.7 | Review Feedback and Update |  | 5d | 2024-11-11 | 2024-11-15 | 1026 |  |  |  |  |  | 31842d | 0d |  |  | 52.33 | No BL | GREEN |  |  |  |  |  |  |  |  |
| 1028 | 1.4.1.4.5.3.5.8 | Review with SITWG (Batch 1) |  | 5d? | 2024-11-28 | 2024-12-04 | 1027FS+8d |  |  |  |  |  | 31842d | 0d |  |  | 69.33 | No BL | GREEN |  |  |  |  |  |  |  |  |
| 1029 | 1.4.1.4.5.3.5.9 | SITAG for approval (Batch 1) |  | 1d | 2024-12-11 | 2024-12-11 | 1028FS+4d |  |  |  |  |  | 31842d | 0d |  |  | 82.33 | No BL | GREEN |  |  |  |  |  |  |  |  |
| 1030 | 1.4.1.4.5.3.5.10 | SIT Operational Scenarios & Test Cases Approved - Theme 3 (Batch 1 + 2) | milestone | 0d | 2024-12-11 | 2024-12-11 | 1033, 1019, 1029 |  |  | 2024-09-18 | 2024-09-18 | 0d | 31842d | 0d |  |  | 82.71 | Red | RED | SI Test | SI Test, PP | 6.0 | Roger Robar | Systems Integration Testing (SIT) | 31/7/24: baseline date change approved at esitag on 26/7/24 | T3-TE-0119 | SITAG |

Notes:
- 1013: 12/09/24 - Added new milestone for Batch 2
- 1016: 12/09/24 - Forecast date changed in line with SI Plan.
- 1021: 12/09/24 - Duration increased from 46 days to 78 days to reflect the SI Plan.
- 1030: 12/09/24 - Lag reduced from 35 days to 15 days in line with the SI Plan.

| ID | WBS | Task | Type | Duration | Start | Finish | Predecessors | Baseline start | Baseline finish | Baseline duration | Baseline 1 start | Baseline 1 finish | Total slack | Free slack | Constraint | Baseline cost | Task Status | Sched Status | RAG | Responsible | Involved | Update Version | MHHS Resource Name | MHHS Programme Phase | Milestone ID | Text29 | Tier |
| --- | --- | --- | --- | --- | --- | --- | --- | --- | --- | --- | --- | --- | --- | --- | --- | --- | --- | --- | --- | --- | --- | --- | --- | --- | --- | --- | --- |
| 1031 | 1.4.1.4.5.3.6 | **Helix SDD and LLSD Development and Approval** |  | 1d | 2024-09-27 | 2024-09-30 |  |  |  |  |  |  | 31843d |  |  |  | -688.67 | Overdue Start | RED |  |  |  |  |  |  |  |  |
| 1032 | 1.4.1.4.5.3.6.1 | Development | milestone | 0d | 2024-09-27 | 2024-09-27 |  |  |  |  |  |  | 32588d |  | start no earlier than 2024-09-27 |  | 7.33 | No BL | GREEN |  |  |  |  |  |  |  |  |
| 1033 | 1.4.1.4.5.3.6.2 | Approval | milestone | 0d | 2024-09-30 | 2024-09-30 |  |  |  |  |  |  | 31842d | 0d | start no earlier than 2024-09-30 |  | 10.33 | No BL | GREEN |  |  |  |  |  |  |  |  |
| 1034 | 1.4.1.4.5.4 | **SIT Operational Programme RTTM** |  | 27d? | 2024-12-12 | 2025-01-17 |  |  |  |  |  |  | 32507d |  |  |  | -686.67 | Overdue Start | RED |  |  |  |  |  |  |  |  |
| 1035 | 1.4.1.4.5.4.1 | Develop Manual SIT Operational RTTM |  | 22d? | 2024-12-12 | 2025-01-10 | 1030 |  |  |  |  |  | 32507d | 0d |  |  | 83.33 | No BL | GREEN |  |  |  |  |  |  |  |  |
| 1036 | 1.4.1.4.5.4.2 | Manual SIT Operational RTTM Complete | milestone | 0d | 2025-01-10 | 2025-01-10 | 1035 |  |  |  |  |  | 32512d |  |  |  | 112.71 | No BL | GREEN |  |  |  |  |  |  |  |  |
| 1037 | 1.4.1.4.5.4.3 | Develop Automated SIT Operational RTTM |  | 5d | 2025-01-13 | 2025-01-17 | 1035 |  |  |  |  |  | 32507d | 0d |  |  | 115.33 | No BL | GREEN |  |  |  |  |  |  |  |  |
| 1038 | 1.4.1.4.5.4.4 | Automated SIT Operational RTTM Complete | milestone | 0d | 2025-01-17 | 2025-01-17 | 1037 |  |  |  |  |  | 32507d |  |  |  | 119.71 | No BL | GREEN |  |  |  |  |  |  |  |  |
| 1039 | 1.4.1.4.5.5 | **Environments (SIT B)** |  | 0d | 2024-10-04 | 2024-10-04 |  | 2024-08-27 | 2024-08-27 | 0d | 2024-09-03 | 2024-09-09 | 31808d |  |  | -0 |  |  |  | N/A | N/A | 5.0 | N/A | Systems Integration Testing (SIT) |  |  |  |
| 1040 | 1.4.1.4.5.5.1 | **PP Environments (SIT B)** |  | 0d | 2024-10-04 | 2024-10-04 |  | 2024-08-27 | 2024-08-27 | 0d | 2024-09-03 | 2024-09-09 | 31808d |  |  | -0 |  |  |  | N/A | N/A | 5.0 | N/A | Systems Integration Testing (SIT) |  |  |  |
| 1041 | 1.4.1.4.5.5.1.1 | Deployment of MHHS solution code to SIT B environments | milestone | 0d | 2024-10-04 | 2024-10-04 | 142 | 2024-08-27 | 2024-08-27 | 0d | 2024-09-03 | 2024-09-09 | 31808d | 0d | start no earlier than 2024-08-27 |  | 14.71 | Red | RED | PP | SI Test | 5.21 | Simon Berry | Systems Integration Testing (SIT) |  |  |  |
| 1042 | 1.4.1.4.5.5.2 | **SI Environments (SIT B)** |  | 0d | 2024-10-04 | 2024-10-04 |  | 2024-08-27 | 2024-08-27 | 0d | 2024-09-03 | 2024-09-09 | 31808d |  |  | -0 |  |  |  | N/A | N/A | 5.0 | N/A | Systems Integration Testing (SIT) |  |  |  |
| 1043 | 1.4.1.4.5.5.2.1 | Coordinate deployment of MHHS solution code to SIT Participants' SIT B environments | milestone | 0d | 2024-10-04 | 2024-10-04 | 1041SS | 2024-08-27 | 2024-08-27 | 0d | 2024-09-03 | 2024-09-09 | 31808d | 0d |  |  | 14.71 | Red | RED | SI Test | PP | 5.21 | Simon Berry | Systems Integration Testing (SIT) |  |  |  |
| 1044 | 1.4.1.4.5.6 | **SIT Operational Test Readiness Report** |  | 33d | 2024-08-05 | 2024-09-18 |  | 2024-08-05 | 2025-03-03 | 151d | 2025-01-07 | 2025-03-03 |  |  |  | -0 |  |  |  | N/A | N/A | 6.0 | N/A | Systems Integration Testing (SIT) |  |  |  |
| 1045 | 1.4.1.4.5.6.1 | **PP SIT Operational Test Readiness Report** |  | 0d | 2024-08-05 | 2024-08-05 |  | 2024-08-05 | 2025-02-03 | 131d | 2025-01-07 | 2025-02-17 |  |  |  | -0 |  |  |  | N/A | N/A | 6.0 | N/A | Systems Integration Testing (SIT) |  |  |  |
| 1046 | 1.4.1.4.5.6.1.1 | Test Readiness Report submitted to Programme for assurance | milestone | 0d | 2024-08-05 | 2024-08-05 |  | 2025-01-07 | 2025-02-03 | 20d | 2025-01-07 | 2025-02-03 | 32512d | 0d | start no earlier than 2024-08-05 |  | -45.67 | Overdue Start | GREEN | PP | SI Test | 6.0 | Roger Robar | Systems Integration Testing (SIT) |  |  |  |
| 1047 | 1.4.1.4.5.6.2 | **SI SIT Operational Test Readiness Report** |  | 120d | 2024-08-05 | 2025-01-17 |  | 2025-01-07 | 2025-03-03 | 40d | 2025-01-07 | 2025-03-03 | 31900d |  |  |  |  |  |  | N/A | N/A | 5.0 | N/A | Systems Integration Testing (SIT) |  |  |  |
| 1048 | 1.4.1.4.5.6.2.1 | Assure Test Participants' Test Readiness Reports |  | 115d | 2024-08-05 | 2025-01-10 | 1046 | 2025-01-07 | 2025-02-24 | 35d | 2025-01-07 | 2025-02-24 | 32512d |  |  |  | -45.67 | Overdue Start | GREEN | SI Test | PP,IPA | 6.0 | Roger Robar | Systems Integration Testing (SIT) |  |  |  |
| 1049 | 1.4.1.4.5.6.2.2 | Develop Overarching SIT Operational Test Readiness Report |  | 30d | 2024-12-02 | 2025-01-10 |  | 2025-01-28 | 2025-02-24 | 20d | 2025-01-28 | 2025-02-24 | 31815d | 0d | start no earlier than 2024-12-02 |  | 73.33 | Green | GREEN | SI Test |  | 6.0 | Roger Robar | Systems Integration Testing (SIT) |  |  |  |
| 1050 | 1.4.1.4.5.6.2.3 | Artefact review (via SITAG) and updates |  | 5d | 2025-01-13 | 2025-01-17 | 1049 | 2025-02-25 | 2025-03-03 | 5d | 2025-02-25 | 2025-03-03 | 31815d | 0d |  |  | 115.33 | Green | GREEN | SI Test | PP,IPA | 5.0 | Roger Robar | Systems Integration Testing (SIT) |  |  |  |
| 1051 | 1.4.1.4.5.7 | SIT Operational Testing Preparation Complete | milestone | 0d | 2025-01-17 | 2025-01-17 | 366, 999, 1005, 1030, 1050 | 2024-09-25 | 2024-09-25 | 0d | 2025-03-10 | 2025-03-10 | 31815d | 7d | finish no earlier than 2024-10-04 |  | 119.71 | Red | RED | SI Test | PP,IPA | 6.0 | Roger Robar | Systems Integration Testing (SIT) | T2-TE-0750 | SITAG | T2 |
| 1052 | 1.4.1.4.6 | **Regression Test Preperation** |  | 145d? | 2024-09-16 | 2025-04-04 |  |  |  |  |  |  | 130d |  |  |  | -686.67 | Overdue Start | RED |  |  |  |  |  |  |  |  |
| 1053 | 1.4.1.4.6.1 | **Regression Test Approach** |  | 30d? | 2024-09-16 | 2024-10-25 |  |  |  |  |  |  | 31884d |  |  |  | -686.67 | Overdue Start | RED |  |  |  |  |  |  |  |  |
| 1054 | 1.4.1.4.6.1.1 | Develop approach doc |  | 12d | 2024-09-16 | 2024-10-01 |  |  |  |  |  |  | 31884d | 0d | start no earlier than 2024-09-16 |  | -3.67 | No BL | GREEN |  |  |  |  |  |  |  |  |
| 1055 | 1.4.1.4.6.1.2 | SITWG Feedback on approach doc |  | 5d | 2024-10-02 | 2024-10-08 | 1054 |  |  |  |  |  | 31884d | 0d |  |  | 12.33 | No BL | GREEN |  |  |  |  |  |  |  |  |
| 1056 | 1.4.1.4.6.1.3 | SRO Review of approach doc |  | 5d | 2024-10-09 | 2024-10-15 | 1055 |  |  |  |  |  | 31884d | 0d |  |  | 19.33 | No BL | GREEN |  |  |  |  |  |  |  |  |
| 1057 | 1.4.1.4.6.1.4 | Incorporate SRO + SITWG feedback into approach doc |  | 1d? | 2024-10-23 | 2024-10-23 | 1056FS+5d |  |  |  |  |  | 31884d | 0d |  |  | 33.33 | No BL | GREEN |  |  |  |  |  |  |  |  |
| 1058 | 1.4.1.4.6.1.5 | SRO Approval |  | 1d | 2024-10-24 | 2024-10-24 | 1057 |  |  |  |  |  | 31884d | 0d |  |  | 34.33 | No BL | GREEN |  |  |  |  |  |  |  |  |
| 1059 | 1.4.1.4.6.1.6 | SIT Regression Testing Approach and Plan Approval |  | 1d? | 2024-10-25 | 2024-10-25 | 1058 |  |  |  |  |  | 31884d | 0d |  |  | 35.33 | No BL | GREEN |  |  |  |  |  |  |  |  |

Notes:
- 1044: 12/09/24 - Forecast start date brought forward to 05/08/24, duration extended from 19 days to 33 days in line with the SI Plan.
- 1045: 12/09/24 - Forecast start date brought forward to 05/08/24 in line with the SI Plan.
- 1046: 12/09/24 - Forecast start date brought forward to 05/08/24 in line with the SI Plan.
- 1048: 12/09/24 - Duration increased from 5 days to 25 days in line with the SI Plan.
- 1049: 12/09/24 - Duration increased from 4 days to 18 days in line with the SI Plan.
- 1051: 12/09/24 - Date updated in line with the SI Plan.

| ID | WBS | Task | Type | Duration | Start | Finish | Predecessors | Complete | Remaining | Baseline start | Baseline finish | Baseline duration | Baseline 1 start | Baseline 1 finish | Total slack | Free slack | Constraint | Baseline cost | Task Status | Sched Status | RAG | Responsible | Involved | Update Version | MHHS Resource Name | MHHS Programme Phase | Artefact ID | Milestone ID | Text29 | Tier | Text3 |
| --- | --- | --- | --- | --- | --- | --- | --- | --- | --- | --- | --- | --- | --- | --- | --- | --- | --- | --- | --- | --- | --- | --- | --- | --- | --- | --- | --- | --- | --- | --- | --- |
| 1060 | 1.4.1.4.6.2 | **Regression Test Suite** |  | 29d? | 2024-10-28 | 2024-12-05 |  |  |  |  |  |  |  |  | 31884d |  |  |  | -686.67 | Overdue Start | RED |  |  |  |  |  |  |  |  |  |  |
| 1061 | 1.4.1.4.6.2.1 | Build Regression Test Suite |  | 12d | 2024-10-28 | 2024-11-12 | 1059 |  |  |  |  |  |  |  | 31884d | 0d |  |  | 38.33 | No BL | GREEN |  |  |  |  |  |  |  |  |  |  |
| 1062 | 1.4.1.4.6.2.2 | SITWG Feedback on regression suite doc |  | 5d | 2024-11-13 | 2024-11-19 | 1061 |  |  |  |  |  |  |  | 31884d | 0d |  |  | 54.33 | No BL | GREEN |  |  |  |  |  |  |  |  |  |  |
| 1063 | 1.4.1.4.6.2.3 | SRO Review of regression suite doc |  | 10d | 2024-11-20 | 2024-12-03 | 1062 |  |  |  |  |  |  |  | 31884d | 0d |  |  | 61.33 | No BL | GREEN |  |  |  |  |  |  |  |  |  |  |
| 1064 | 1.4.1.4.6.2.4 | Incorporate SRO + SITWG feedback into regression suite doc |  | 1d? | 2024-12-04 | 2024-12-04 | 1063 |  |  |  |  |  |  |  | 31884d | 0d |  |  | 75.33 | No BL | GREEN |  |  |  |  |  |  |  |  |  |  |
| 1065 | 1.4.1.4.6.2.5 | SRO Approval |  | 1d | 2024-12-05 | 2024-12-05 | 1064 |  |  |  |  |  |  |  | 31884d | 106d |  |  | 76.33 | No BL | GREEN |  |  |  |  |  |  |  |  |  |  |
| 1066 | 1.4.1.4.6.3 | **Regression Test Data Load Window (SIT Functional and Migration) - SIT A** |  | 1d? | 2025-03-14 | 2025-03-17 |  |  |  |  |  |  |  |  |  |  |  |  | -686.67 | Overdue Start | RED |  |  |  |  |  |  |  |  |  |  |
| 1067 | 1.4.1.4.6.3.1 | Regression Test Data Load Start | milestone | 0d? | 2025-03-14 | 2025-03-14 | 1109, 1152 |  |  |  |  |  |  |  | 27d | 0d |  |  | 175.71 | No BL | GREEN |  |  |  |  |  |  |  |  |  |  |
| 1068 | 1.4.1.4.6.3.2 | Regression Test Data Load Window |  | 15d? | 2025-03-17 | 2025-04-04 | 1067 |  |  |  |  |  |  |  | 27d | 0d |  |  | 178.33 | No BL | GREEN |  |  |  |  |  |  |  |  |  |  |
| 1069 | 1.4.2 | **SIT Execution** |  | 1125d? | 2022-10-31 A | 2027-02-19 |  | 16% | 941.44d? | 2023-10-30 | 2025-04-25 | 390d | 2023-10-30 | 2025-04-25 | 31962d |  |  | -0 |  |  |  | N/A | N/A | 5.0 | N/A | Systems Integration Testing (SIT) |  |  |  |  |  |
| 1070 | 1.4.2.1 | System Integration Testing Start (M9) | milestone | 0d | 2023-10-30 A | 2023-10-30 A | 631FS+5d, 545 | 100% |  | 2023-10-30 | 2023-10-30 | 0d | 2023-10-30 | 2023-10-30 |  |  | must start on 2023-10-30 |  |  | Complete | COMPLETE | CPT | PMO | 5.11 |  | Systems Integration Testing (SIT) | MHHS-ART071 | T1-TE-1000 | PSG | T1 |  |
| 1071 | 1.4.2.2 | **SIT Component Integration Testing** |  | 96d | 2023-10-30 A | 2024-03-11 A |  | 100% |  | 2023-10-30 | 2024-03-08 | 95d | 2023-10-30 | 2024-03-08 |  |  |  |  |  |  |  | N/A | N/A | 5.0 | N/A | Systems Integration Testing (SIT) |  |  |  |  | D24A - Industry Integration Test Completion Report |
| 1072 | 1.4.2.2.1 | SIT Component Integration Testing Start | milestone | 0d | 2023-10-30 A | 2023-10-30 A | 1070 | 100% |  | 2023-10-30 | 2023-10-30 | 0d | 2023-10-30 | 2023-10-30 |  |  |  |  |  | Complete | COMPLETE | SI Test | PP | 5.11 |  | Systems Integration Testing (SIT) |  |  |  |  |  |
| 1073 | 1.4.2.2.2 | Component Integration Testing Interval 1 Start | milestone | 0d | 2023-10-30 A | 2023-10-30 A | 631SS+1d, 552, 556, 560, 115 | 100% |  | 2023-10-30 | 2023-10-30 | 0d | 2023-10-30 | 2023-10-30 |  |  |  |  |  | Complete | COMPLETE | SI Test | PP | 5.11 |  | Systems Integration Testing (SIT) | MHHS-ART071 | T3-TE-0060 | SITAG | T3 |  |
| 1074 | 1.4.2.2.3 | Component Integration Testing Interval 2 Start | milestone | 0d | 2023-11-13 A | 2023-11-13 A | 658SS+5d, 552, 560, 556, 115 | 100% |  | 2023-11-13 | 2023-11-13 | 0d | 2023-11-13 | 2023-11-13 |  |  |  |  |  | Complete | COMPLETE | SI Test | PP | 5.12 |  | Systems Integration Testing (SIT) |  | T3-TE-0061 | SITAG | T3 |  |
| 1075 | 1.4.2.2.4 | Component Integration Testing Interval 3 Start | milestone | 0d | 2023-11-27 A | 2023-11-27 A | 690SS+5d, 552, 556, 560, 115 | 100% |  | 2023-11-27 | 2023-11-27 | 0d | 2023-11-27 | 2023-11-27 |  |  |  |  |  | Complete | COMPLETE | SI Test | PP | 5.0 |  | Systems Integration Testing (SIT) |  | T3-TE-0062 | SITAG | T3 |  |
| 1076 | 1.4.2.2.5 | Component Integration Testing Interval 4 Start | milestone | 0d | 2023-12-11 A | 2023-12-11 A | 722SS+5d, 552, 556, 560, 115 | 100% |  | 2023-12-11 | 2023-12-11 | 0d | 2023-12-11 | 2023-12-11 |  |  |  |  |  | Complete | COMPLETE | SI Test | PP | 5.0 |  | Systems Integration Testing (SIT) |  | T3-TE-0063 | SITAG | T3 |  |
| 1077 | 1.4.2.2.6 | Component Integration Testing Interval 5 Start | milestone | 0d | 2024-01-15 A | 2024-01-15 A | 754SS+5d, 552, 556, 560, 115 | 100% |  | 2024-01-15 | 2024-01-15 | 0d | 2024-01-15 | 2024-01-15 |  |  |  |  |  | Complete | COMPLETE | SI Test | PP | 5.0 |  | Systems Integration Testing (SIT) |  | T3-TE-0064 |  | T3 |  |
| 1078 | 1.4.2.2.7 | Component Integration Testing Interval 6 Start | milestone | 0d | 2024-01-29 A | 2024-01-29 A | 552, 556, 560, 786, 115, 598 | 100% |  | 2024-01-29 | 2024-01-29 | 0d | 2024-01-29 | 2024-01-29 |  |  | must start on 2024-01-29 |  |  | Complete | COMPLETE | SI Test | PP | 5.0 |  | Systems Integration Testing (SIT) |  | T3-TE-0065 | SITAG | T3 |  |
| 1079 | 1.4.2.2.8 | SIT Component Integration Testing Execution |  | 85d | 2023-10-30 A | 2024-02-23 A | 1073SS | 100% |  | 2023-10-30 | 2024-02-23 | 85d | 2023-10-30 | 2024-02-23 |  |  | must start on 2023-10-30 |  |  | Complete | COMPLETE | SI Test | PP | 5.0 |  | Systems Integration Testing (SIT) |  |  |  |  | D24A - Industry Integration Test Completion Report |
| 1080 | 1.4.2.2.9 | SIT Component Integration Testing End (incl. confirmation that PPs have submitted their Test Completion Reports to Programme for assurance) | milestone | 0d | 2024-02-23 A | 2024-02-23 A | 1079FF | 100% |  | 2024-02-23 | 2024-02-23 | 0d | 2024-02-23 | 2024-02-23 |  |  |  |  |  | Complete | COMPLETE | SI Test | PP | 5.19 |  | Systems Integration Testing (SIT) | MHHS-ART074 | T3-TE-0032 | SITAG | T3 |  |
| 1081 | 1.4.2.2.10 | Assurance of PPs Test Completion Reports |  | 30d | 2024-01-22 A | 2024-03-01 A | 1080FF+5d | 100% |  | 2024-01-22 | 2024-03-01 | 30d | 2024-01-22 | 2024-03-01 |  |  |  |  |  | Complete | COMPLETE | SI Test | PP | 5.19 |  | Systems Integration Testing (SIT) |  |  |  |  |  |
| 1082 | 1.4.2.2.11 | **SIT CI Test Completion Report** |  | 18d | 2024-02-07 A | 2024-03-01 A |  | 100% |  | 2024-02-07 | 2024-03-01 | 18d | 2024-02-07 | 2024-03-01 |  |  |  |  |  |  |  | N/A | N/A | 5.0 | N/A | Systems Integration Testing (SIT) |  |  |  |  |  |
| 1083 | 1.4.2.2.11.1 | Develop document |  | 13d | 2024-02-07 A | 2024-02-23 A | 1080FF | 100% |  | 2024-02-07 | 2024-02-23 | 13d | 2024-02-07 | 2024-02-23 |  |  |  |  |  | Complete | COMPLETE | SI Test |  | 5.19 |  | Systems Integration Testing (SIT) |  |  |  |  |  |
| 1084 | 1.4.2.2.11.2 | Review & agree document |  | 5d | 2024-02-26 A | 2024-03-01 A | 1083, 1081FF | 100% |  | 2024-02-26 | 2024-03-01 | 5d | 2024-02-26 | 2024-03-01 |  |  |  |  |  | Complete | COMPLETE | SI Test | PP,IPA | 5.19 |  | Systems Integration Testing (SIT) |  |  |  |  |  |
| 1085 | 1.4.2.2.12 | SIT Component Integration Testing Test Completion Report Approved | milestone | 0d | 2024-03-11 A | 2024-03-11 A | 1084FS+6d | 100% |  | 2024-03-08 | 2024-03-08 | 0d | 2024-03-08 | 2024-03-08 |  |  |  |  |  | Complete | COMPLETE | SI Test | PP | 5.18 |  | Systems Integration Testing (SIT) | MHHS-ART074 | T2-TE-0600 | SITAG | T2 |  |

Notes:
- 1070: On track, however there are a number of associated risks that are being mitigated by the Programme
- 1073: On track, however there are a number of associated risks that are being mitigated by the Programme
- 1076: 13/12 - Complete noting a work-off plan and revised CIT Approach being taken to Dec TMAG
- 1077: 2/1//24 - Approved at 20/12 TMAG based on CIT Gov approach change
- 1078: 2/1//24 - Approved at 20/12 TMAG based on CIT Gov approach change
- 1080: All PPs are expected to complete their CIT by the target date on 09-Feb
- 1085: 20/2 - Date changed to align with SITAG meeting. On track for approval 11/3

| ID | WBS | Task | Type | Duration | Start | Finish | Predecessors | Complete | Remaining | Baseline start | Baseline finish | Baseline duration | Baseline 1 start | Baseline 1 finish | Total slack | Free slack | Constraint | Baseline cost | Responsible | Involved | Update Version | MHHS Resource Name | MHHS Programme Phase | Artefact ID | Sched Status | RAG | Milestone ID | Text29 | Tier | Text3 | Task Status |
| --- | --- | --- | --- | --- | --- | --- | --- | --- | --- | --- | --- | --- | --- | --- | --- | --- | --- | --- | --- | --- | --- | --- | --- | --- | --- | --- | --- | --- | --- | --- | --- |
| 1086 | 1.4.2.3 | **SIT - Minimum Viable Cohort (MVC)** |  | 1125d? | 2022-10-31 A | 2027-02-19 |  | 10% | 1017.67d? | 2024-03-11 | 2025-02-07 | 240d | 2024-03-11 | 2025-02-07 | 31962d |  |  | -0 | N/A | N/A | 5.0 | N/A | Systems Integration Testing (SIT) |  |  |  |  |  |  |  |  |
| 1087 | 1.4.2.3.1 | **SIT Functional Testing (MVC)** |  | 1125d? | 2022-10-31 A | 2027-02-19 |  | 21% | 890.91d? | 2024-03-11 | 2025-01-17 | 225d | 2024-03-11 | 2025-01-17 | 31962d |  |  |  | N/A | N/A | 5.0 | N/A | Systems Integration Testing (SIT) |  |  |  |  |  |  |  |  |
| 1088 | 1.4.2.3.1.1 | SIT Functional Testing Start | milestone | 0d | 2024-03-11 A | 2024-03-11 A | 1085, 863FS+5d, 793, 801, 802, 803, 810 | 100% |  | 2024-03-11 | 2024-03-11 | 0d | 2024-03-11 | 2024-03-11 |  |  |  |  | SI Test | PP | 5.0 |  | Systems Integration Testing (SIT) | MHHS-ART073 | Complete | COMPLETE | T3-TE-0034 | SITAG | T3 |  |  |
| 1089 | 1.4.2.3.1.2 | **SIT Functional Testing Execution (Minimum Viable Cohort)** |  | 690d? | 2022-10-31 A | 2025-06-20 |  | 21% | 546.42d? | 2024-03-11 | 2025-01-17 | 225d | 2024-03-11 | 2025-01-17 |  |  |  |  | N/A | N/A | 5.0 | N/A | Systems Integration Testing (SIT) |  |  |  |  |  |  | D24C - E2E Test Completion Report | M10 |
| 1090 | 1.4.2.3.1.2.1 | **Cycle 1 (Full Cycle)** |  | 70d | 2024-03-11 A | 2024-06-14 A |  | 100% |  | 2024-03-11 | 2024-07-12 | 90d | 2024-03-11 | 2024-07-12 |  |  |  |  | N/A | N/A | 5.0 | N/A | Systems Integration Testing (SIT) |  |  |  |  |  |  |  |  |
| 1091 | 1.4.2.3.1.2.1.1 | Test Execution |  | 55d | 2024-03-11 A | 2024-05-24 A | 1088SS-1d, 838 | 100% |  | 2024-03-11 | 2024-06-28 | 80d | 2024-03-11 | 2024-06-28 |  |  |  |  | PP | SI Test | 5.0 |  | Systems Integration Testing (SIT) |  | Complete | COMPLETE |  |  |  |  |  |
| 1092 | 1.4.2.3.1.2.1.2 | Defect resolution, assurance, review, data & environments maintenance |  | 15d | 2024-05-27 A | 2024-06-14 A | 1091 | 100% |  | 2024-07-01 | 2024-07-12 | 10d | 2024-07-01 | 2024-07-12 |  |  |  |  | SI Test | PP | 5.0 |  | Systems Integration Testing (SIT) |  | Complete | COMPLETE |  |  |  |  |  |
| 1093 | 1.4.2.3.1.2.2 | **Cycle 2 (Defect retests and targeted regression testing)** |  | 80d | 2024-06-17 A | 2024-10-04 |  | 41% | 47d | 2024-07-15 | 2024-09-20 | 50d | 2024-07-15 | 2024-09-20 | 32582d |  |  |  | N/A | N/A | 5.0 | N/A | Systems Integration Testing (SIT) |  |  |  |  |  |  |  |  |
| 1094 | 1.4.2.3.1.2.2.1 | Test Execution |  | 70d | 2024-06-17 A | 2024-09-20 | 1092, 843 | 47% | 37d | 2024-07-15 | 2024-09-06 | 40d | 2024-07-15 | 2024-09-06 | 31933d | 0d |  |  | PP | SI Test | 5.0 | Roger Robar | Systems Integration Testing (SIT) |  | Red | RED |  |  |  |  |  |
| 1095 | 1.4.2.3.1.2.2.2 | Defect resolution, assurance, review, data & environments maintenance |  | 10d | 2024-09-23 | 2024-10-04 | 1094 |  |  | 2024-09-09 | 2024-09-20 | 10d | 2024-09-09 | 2024-09-20 | 32582d | 0d |  |  | SI Test | PP | 5.0 | Roger Robar | Systems Integration Testing (SIT) |  | Red | RED |  |  |  |  | 3.33 |
| 1096 | 1.4.2.3.1.2.3 | **SIT Functional Testing back-up progress risk-assessment** |  | 0d | 2022-10-31 | 2022-10-31 |  |  |  | 2024-09-23 | 2024-10-18 | 20d | 2024-09-23 | 2024-10-18 | 33087d |  |  |  | N/A | N/A | 5.31 | N/A | Systems Integration Testing (SIT) |  |  |  |  |  |  |  |  |
| 1097 | 1.4.2.3.1.2.3.1 | Back-up risk-assessment of SIT Functional progress to assess whether Qualification Execution can start early | inactive | 15d | 2024-10-07 | 2024-10-25 | 1095 |  |  | 2024-09-23 | 2024-10-11 | 15d | 2024-09-23 | 2024-10-11 | 32562d | 0d |  |  | SI Test | Code Bodies,PP,IPA | 5.31 | Nicola Farley | Systems Integration Testing (SIT) |  |  | RED |  |  |  |  | 17.33 |
| 1098 | 1.4.2.3.1.2.3.2 | Back-up SITAG decision on early Qualification Testing Execution start | milestone, inactive | 0d | 2024-11-01 | 2024-11-01 | 1097FS+5d |  |  | 2024-10-18 | 2024-10-18 | 0d | 2024-10-18 | 2024-10-18 | 32562d |  |  |  | SI Test | Code Bodies,PP,IPA | 5.31 | Nicola Farley | Systems Integration Testing (SIT) |  |  | RED | T3-TE-0041 | QAG | T3 |  | 42.71 |
| 1099 | 1.4.2.3.1.2.4 | **Cycle 3 (Defect retests and targeted regression testing)** |  | 610d? | 2024-10-21 | 2027-02-19 |  |  |  | 2024-09-23 | 2024-11-01 | 30d | 2024-09-23 | 2024-11-01 |  |  |  |  | N/A | N/A | 5.0 | N/A | Systems Integration Testing (SIT) |  |  |  |  |  |  |  |  |
| 1100 | 1.4.2.3.1.2.4.1 | Sprint 5 |  | 10d? | 2024-10-21 | 2024-11-01 | 141 |  |  |  |  |  |  |  | 27d | 0d | start no earlier than 2024-10-21 |  |  |  |  | Roger Robar |  |  | No BL | GREEN |  |  |  |  | 31.33 |
| 1101 | 1.4.2.3.1.2.4.2 | Sprint 6 |  | 10d? | 2024-11-04 | 2024-11-15 | 1100 |  |  |  |  |  |  |  | 27d | 0d |  |  |  |  |  | Roger Robar |  |  | No BL | GREEN |  |  |  |  | 45.33 |
| 1102 | 1.4.2.3.1.2.4.3 | Sprint 7 |  | 10d? | 2024-11-18 | 2024-11-29 | 1101 |  |  |  |  |  |  |  | 27d | 0d |  |  |  |  |  | Roger Robar |  |  | No BL | GREEN |  |  |  |  | 59.33 |
| 1103 | 1.4.2.3.1.2.4.4 | Sprint 8 |  | 15d? | 2024-12-02 | 2024-12-20 | 1102 |  |  |  |  |  |  |  | 27d | 0d |  |  |  |  |  | Roger Robar |  |  | No BL | GREEN |  |  |  |  | 73.33 |
| 1104 | 1.4.2.3.1.2.4.5 | Christmas downtime |  | 10d? | 2024-12-23 | 2025-01-03 | 1103 |  |  |  |  |  |  |  | 27d | 0d |  |  |  |  |  | Roger Robar |  |  | No BL | GREEN |  |  |  |  | 94.33 |
| 1105 | 1.4.2.3.1.2.4.6 | Sprint 9 |  | 10d? | 2025-01-06 | 2025-01-17 | 1104 |  |  |  |  |  |  |  | 27d | 0d |  |  |  |  |  | Roger Robar |  |  | No BL | GREEN |  |  |  |  | 108.33 |
| 1106 | 1.4.2.3.1.2.4.7 | Sprint 10 |  | 10d? | 2025-01-20 | 2025-01-31 | 1105 |  |  |  |  |  |  |  | 27d | 0d |  |  |  |  |  | Roger Robar |  |  | No BL | GREEN |  |  |  |  | 122.33 |
| 1107 | 1.4.2.3.1.2.4.8 | Sprint 11 |  | 10d? | 2025-02-03 | 2025-02-14 | 1106 |  |  |  |  |  |  |  | 27d | 0d |  |  |  |  |  | Roger Robar |  |  | No BL | GREEN |  |  |  |  | 136.33 |
| 1108 | 1.4.2.3.1.2.4.9 | Sprint 12 |  | 10d? | 2025-02-17 | 2025-02-28 | 1107 |  |  |  |  |  |  |  | 27d | 0d |  |  |  |  |  | Roger Robar |  |  | No BL | GREEN |  |  |  |  | 150.33 |
| 1109 | 1.4.2.3.1.2.4.10 | Sprint 13 (RTTM gap analysis scope) |  | 10d? | 2025-03-03 | 2025-03-14 | 1108 |  |  |  |  |  |  |  | 27d | 0d |  |  |  |  |  | Roger Robar |  |  | No BL | GREEN |  |  |  |  | 164.33 |
| 1110 | 1.4.2.3.1.2.4.11 | Defect resolution, assurance, review, data & environments maintenance |  | 10d | 2024-10-21 | 2024-11-01 |  |  |  | 2024-10-21 | 2024-11-01 | 10d | 2024-10-21 | 2024-11-01 | 32561d | 0d |  |  | SI Test | PP | 5.0 | Roger Robar | Systems Integration Testing (SIT) |  | Green | GREEN |  |  |  |  | 31.33 |
| 1111 | 1.4.2.3.1.2.5 | Core Systems Code Freeze | milestone | 0d | 2024-11-01 | 2024-11-01 | 1110FF |  |  | 2024-11-01 | 2024-11-01 | 0d | 2024-11-01 | 2024-11-01 | 32561d | 69d |  |  | SI Test | PP | 5.0 | Roger Robar | Systems Integration Testing (SIT) |  | Green | AMBER | T3-TE-0045 | SITAG | T3 |  | 42.71 |

Notes:
- 1088: 28/11 - At risk because of challenges with CCP and PP readiness & dependent on successful Secondary Routing Testing
- 1097: Action: 5/12 - LC said change name from his to nicola and check dates based on new start date for non sit ldso testing
- 1098: 15/8/24: Milestone to be removed as no longer applicable / Guidance: 13/8/24: To be removed because SIT has not made sufficient progress to allow early quaifation test start. 22/8/24: Approved at QAG on 22/8/24 to be removed
- 1111: 6/8/24: Date at risk due to lower than expected test velocity. Completion of Functional could be delayed. Programme-wide scenario re-planning underway

| ID | WBS | Task | Type | Duration | Start | Finish | Predecessors | Complete | Remaining | Actual start | Baseline start | Baseline finish | Baseline duration | Baseline 1 start | Baseline 1 finish | Total slack | Free slack | Constraint | Baseline cost | Task Status | Sched Status | RAG | Responsible | Involved | Update Version | MHHS Programme Phase | MHHS Resource Name | Artefact ID | Milestone ID | Text29 | Tier |
| --- | --- | --- | --- | --- | --- | --- | --- | --- | --- | --- | --- | --- | --- | --- | --- | --- | --- | --- | --- | --- | --- | --- | --- | --- | --- | --- | --- | --- | --- | --- | --- |
| 1112 | 1.4.2.3.1.2.6 | **SIT Functional Settlement Testing** |  | 230d? | 2024-06-17 | 2025-05-02 |  |  |  |  |  |  |  |  |  | 237d |  |  |  | -685.67 | Overdue Start | RED |  |  |  |  |  |  |  |  |  |
| 1113 | 1.4.2.3.1.2.6.1 | Settlement Testing Cycle 1 |  | 70d | 2024-06-17 | 2024-09-20 |  |  |  |  |  |  |  |  |  | 32592d |  | start no earlier than 2024-06-17 |  | -94.67 | Overdue Start | GREEN |  |  |  |  |  |  |  |  |  |
| 1114 | 1.4.2.3.1.2.6.2 | Settlement Testing Cycle 2 |  | 55d? | 2024-10-07 | 2024-12-20 | 1043 |  |  |  |  |  |  |  |  | 31808d | 0d | start no earlier than 2024-10-07 |  | 17.33 | No BL | GREEN |  |  |  |  |  |  |  |  |  |
| 1115 | 1.4.2.3.1.2.6.3 | Settlement Testing Cycle 3 (CoS Settlement Testing) |  | 20d? | 2025-04-07 | 2025-05-02 | 853, 1068 |  |  |  |  |  |  |  |  | 27d | 0d |  |  | 199.33 | No BL | GREEN |  |  |  |  |  |  |  |  |  |
| 1116 | 1.4.2.3.1.2.7 | **SIT Functional MVC Regression Testing (code freeze)** |  | 40d? | 2025-05-05 | 2025-06-27 |  |  |  |  | 2024-11-04 | 2025-01-03 | 45d | 2024-11-04 | 2025-01-03 | 31778d |  |  |  | 84.33 | Red | RED | PP | SI Test | 5.0 | Systems Integration Testing (SIT) |  |  |  |  |  |
| 1117 | 1.4.2.3.1.2.7.1 | Regression Sprint 1 |  | 10d? | 2025-05-05 | 2025-05-16 | 1115, 1065 |  |  |  |  |  |  |  |  | 31778d | 0d |  |  | 227.33 | No BL | GREEN |  |  |  |  | Roger Robar |  |  |  |  |
| 1118 | 1.4.2.3.1.2.7.2 | Regression Sprint 2 |  | 10d | 2025-05-19 | 2025-05-30 | 1117 |  |  |  |  |  |  |  |  | 31778d | 0d |  |  | 241.33 | No BL | GREEN |  |  |  |  | Roger Robar |  |  |  |  |
| 1119 | 1.4.2.3.1.2.7.3 | Regression Sprint 3 |  | 15d | 2025-06-02 | 2025-06-20 | 1118 |  |  |  |  |  |  |  |  | 31778d | 0d |  |  | 255.33 | No BL | GREEN |  |  |  |  | Roger Robar |  |  |  |  |
| 1120 | 1.4.2.3.1.2.7.4 | SIT Functional Testing End (Minimum Viable Cohort) (incl. confirmation that PPs have submitted their Test Completion Reports to Programme for assurance) | milestone | 0d | 2025-06-20 | 2025-06-20 | 1119 |  |  |  | 2025-01-03 | 2025-01-03 | 0d | 2025-01-03 | 2025-01-03 | 31778d | 0d | start no earlier than 2025-03-14 |  | 273.71 | Red | RED | SI Test | PP | 6.0 | Systems Integration Testing (SIT) | Roger Robar | MHHS-ART072 | T3-TE-0046 | SITAG | T3 |
| 1121 | 1.4.2.3.1.2.7.5 | Assurance of PPs Test Completion Reports |  | 30d | 2025-05-19 | 2025-06-27 | 1120FF+5d |  |  |  | 2024-12-02 | 2025-01-10 | 30d | 2024-12-02 | 2025-01-10 | 31778d | 0d |  |  | 241.33 | Red | RED | SI Test | PP | 5.0 | Systems Integration Testing (SIT) | Roger Robar |  |  |  |  |
| 1122 | 1.4.2.3.1.2.8 | **SIT Functional Test Completion Report (Minimum Viable Cohort)** |  | 25d | 2025-06-02 | 2025-07-04 |  |  |  |  | 2024-12-16 | 2025-01-10 | 20d | 2024-12-16 | 2025-01-10 | 31778d |  |  |  |  |  |  | N/A | N/A | 5.0 | Systems Integration Testing (SIT) | N/A |  |  |  |  |
| 1123 | 1.4.2.3.1.2.8.1 | Develop document |  | 15d | 2025-06-02 | 2025-06-20 | 1120FF |  |  |  | 2024-12-16 | 2025-01-03 | 15d | 2024-12-16 | 2025-01-03 | 31778d | 0d |  |  | 255.33 | Red | RED | SI Test |  | 5.0 | Systems Integration Testing (SIT) | Roger Robar |  |  |  |  |
| 1124 | 1.4.2.3.1.2.8.2 | Review & agree document |  | 5d | 2025-06-23 | 2025-06-27 | 1123, 1121FF |  |  |  | 2025-01-06 | 2025-01-10 | 5d | 2025-01-06 | 2025-01-10 | 31778d | 0d |  |  | 276.33 | Red | RED | SI Test | PP,IPA | 5.0 | Systems Integration Testing (SIT) | Roger Robar |  |  |  |  |
| 1125 | 1.4.2.3.1.2.8.3 | SIT Functional Testing Test Completion Report (Minimum Viable Cohort) Approved | milestone | 0d | 2025-07-04 | 2025-07-04 | 1124FF+5d |  |  |  | 2025-01-17 | 2025-01-17 | 0d | 2025-01-17 | 2025-01-17 | 31778d | 0d |  |  | 287.71 | Red | RED | SI Test | PP | 5.0 | Systems Integration Testing (SIT) | Roger Robar | MHHS-ART072 | T2-TE-0850 | SITAG | T2 |
| 1126 | 1.4.2.3.2 | **Helix E2E Settlement Testing** |  | 65d | 2025-05-05 | 2025-08-01 |  |  |  |  |  |  |  |  |  | 32367d |  |  |  | -689.67 | Overdue Start | RED |  |  |  |  |  |  |  |  |  |
| 1127 | 1.4.2.3.2.1 | Helix E2E Settlement Testing Execution |  | 65d | 2025-05-05 | 2025-08-01 | 1115 |  |  |  |  |  |  |  |  | 32367d | 0d |  |  | 227.33 | No BL | GREEN |  |  |  |  |  |  |  |  |  |
| 1128 | 1.4.2.3.2.2 | Helix E2E Settlement Testing Execution Complete | milestone | 0d | 2025-08-01 | 2025-08-01 | 1127 |  |  |  |  |  |  |  |  | 32367d |  |  |  | 315.71 | No BL | GREEN |  |  |  |  |  |  |  |  |  |
| 1129 | 1.4.2.3.2.3 | MHHSP Helix E2E Testing Assurance |  | 65d | 2025-05-05 | 2025-08-01 | 1115 |  |  |  |  |  |  |  |  | 32367d | 0d |  |  | 227.33 | No BL | GREEN |  |  |  |  |  |  |  |  |  |
| 1130 | 1.4.2.3.2.4 | MHHSP Helix E2E Testing Assurance Complete | milestone | 0d | 2025-08-01 | 2025-08-01 | 1129 |  |  |  |  |  |  |  |  | 32367d |  |  |  | 315.71 | No BL | GREEN |  |  |  |  |  |  |  |  |  |
| 1131 | 1.4.2.3.3 | **SIT Migration Testing (MVC)** |  | 700d? | 2022-10-31 A | 2025-07-04 |  | 7% | 654.19d? |  | 2024-06-10 | 2025-01-10 | 155d | 2024-06-10 | 2024-10-18 | 32387d |  |  | -0 |  | Overdue | GREEN | N/A | N/A | 5.0 | Systems Integration Testing (SIT) | N/A |  |  |  |  |
| 1132 | 1.4.2.3.3.1 | SIT Migration Testing Start | milestone | 0d? | 2024-03-11 | 2024-03-11 |  |  |  |  |  |  |  |  |  | 32732d |  | start no earlier than 2024-03-11 |  | -192.67 | Overdue Start | RED |  |  |  |  |  |  |  |  |  |
| 1133 | 1.4.2.3.3.2 | **SIT Migration Testing Execution (Minimum Viable Cohort)** |  | 690d? | 2022-10-31 | 2025-06-20 |  | 7% | 644.85d? | 2024-03-11 |  |  |  |  |  |  |  |  |  | -685.67 | Overdue Start | RED |  |  |  |  |  |  |  |  |  |
| 1134 | 1.4.2.3.3.2.1 | **Cycle 1 (Full Cycle)** |  | 70d? | 2024-03-11 | 2024-06-14 |  |  |  |  |  |  |  |  |  |  |  |  |  | -685.67 | Overdue Start | RED |  |  |  |  |  |  |  |  |  |
| 1135 | 1.4.2.3.3.2.1.1 | Test Execution |  | 55d? | 2024-03-11 | 2024-05-24 |  |  |  |  |  |  |  |  |  | 32677d |  | start no earlier than 2024-03-11 |  | -192.67 | Overdue Start | RED |  |  |  |  |  |  |  |  |  |
| 1136 | 1.4.2.3.3.2.1.2 | Defect resolution, assurance, review, data& environments maintenance |  | 15d? | 2024-05-27 | 2024-06-14 |  |  |  |  |  |  |  |  |  | 32562d | 0d | finish no earlier than 2024-06-14 |  | -115.67 | Overdue Start | RED |  |  |  |  |  |  |  |  |  |

Notes:
- 1120: 16/09/24 - Date pushed back to 14/03/25, in line with recalibration exercise.
- 1125: 6/8/24: Date at risk due to lower than expected test velocity. Completion of Functional could be delayed. Programme-wide scenario re-planning underway

| ID | WBS | Task | Type | Duration | Start | Finish | Predecessors | Complete | Remaining | Baseline start | Baseline finish | Baseline duration | Baseline 1 start | Baseline 1 finish | Total slack | Free slack | Constraint | Task Status | Sched Status | RAG | Responsible | Involved | Artefact ID | Update Version | MHHS Programme Phase | Milestone ID | Text29 | Tier | Text3 | MHHS Resource Name |
| --- | --- | --- | --- | --- | --- | --- | --- | --- | --- | --- | --- | --- | --- | --- | --- | --- | --- | --- | --- | --- | --- | --- | --- | --- | --- | --- | --- | --- | --- | --- |
| 1137 | 1.4.2.3.3.2.2 | **Cycle 2 (Defect retests and targeted regression testing)** |  | 80d? | 2024-03-11 | 2024-06-28 |  |  |  |  |  |  |  |  |  |  |  | -685.67 | Overdue Start | RED |  |  |  |  |  |  |  |  |  |  |
| 1138 | 1.4.2.3.3.2.2.1 | Test Execution |  | 70d? | 2024-06-17 | 2024-09-20 | 1136 |  |  |  |  |  |  |  | 32562d | 0d | start no earlier than 2024-06-17 | -94.67 | Overdue Start | GREEN |  |  |  |  |  |  |  |  |  |  |
| 1139 | 1.4.2.3.3.2.2.2 | Defect resolution, assurance, review, data & environments maintenance |  | 10d? | 2024-09-23 | 2024-10-04 | 1138 |  |  |  |  |  |  |  | 32562d | 0d | finish no earlier than 2024-10-04 | 3.33 | No BL | GREEN |  |  |  |  |  |  |  |  |  |  |
| 1140 | 1.4.2.3.3.2.3 | **SIT Functional Testing back-up progress risk-assessment** |  | 70d? | 2024-06-17 | 2024-09-20 |  |  |  |  |  |  |  |  |  |  |  | -685.67 | Overdue Start | RED |  |  |  |  |  |  |  |  |  |  |
| 1141 | 1.4.2.3.3.2.3.1 | Back-up risk-assessment of SIT Migration progress to assess whether Qualification Execution can start early |  | 15d? | 2024-10-07 | 2024-10-25 | 1139 |  |  |  |  |  |  |  | 32562d | 0d | finish no earlier than 2024-10-04 | 17.33 | No BL | GREEN |  |  |  |  |  |  |  |  |  |  |
| 1142 | 1.4.2.3.3.2.3.2 | Back-up SITAG decision on early Qualification Testing Execution start | milestone | 0d? | 2024-11-01 | 2024-11-01 | 1141FS+5d |  |  |  |  |  |  |  | 32562d |  |  | 42.71 | No BL | GREEN |  |  |  |  |  |  |  |  |  |  |
| 1143 | 1.4.2.3.3.2.4 | **Cycle 3 (Defect retests and targeted regression testing)** |  | 15d? | 2024-10-07 | 2024-10-25 |  |  |  |  |  |  |  |  |  |  |  | -685.67 | Overdue Start | RED |  |  |  |  |  |  |  |  |  |  |
| 1144 | 1.4.2.3.3.2.4.1 | Sprint 5 |  | 10d | 2024-10-21 | 2024-11-01 | 141 |  |  |  |  |  |  |  | 37d | 0d | start no earlier than 2024-10-21 | 31.33 | No BL | GREEN |  |  |  |  |  |  |  |  |  |  |
| 1145 | 1.4.2.3.3.2.4.2 | Sprint 6 |  | 10d | 2024-11-04 | 2024-11-15 | 1144 |  |  |  |  |  |  |  | 37d | 0d | start no earlier than 2024-11-04 | 45.33 | No BL | GREEN |  |  |  |  |  |  |  |  |  |  |
| 1146 | 1.4.2.3.3.2.4.3 | Sprint 7 |  | 10d | 2024-11-18 | 2024-11-29 | 1145 |  |  |  |  |  |  |  | 37d | 0d |  | 59.33 | No BL | GREEN |  |  |  |  |  |  |  |  |  |  |
| 1147 | 1.4.2.3.3.2.4.4 | Sprint 8 |  | 15d | 2024-12-02 | 2024-12-20 | 1146 |  |  |  |  |  |  |  | 37d | 0d | finish no earlier than 2024-11-15 | 73.33 | No BL | GREEN |  |  |  |  |  |  |  |  |  |  |
| 1148 | 1.4.2.3.3.2.4.5 | Christmas downtime |  | 10d | 2024-12-23 | 2025-01-03 | 1147 |  |  |  |  |  |  |  | 37d | 0d | finish no earlier than 2024-11-29 | 94.33 | No BL | GREEN |  |  |  |  |  |  |  |  |  |  |
| 1149 | 1.4.2.3.3.2.4.6 | Sprint 9 |  | 10d | 2025-01-06 | 2025-01-17 | 1148 |  |  |  |  |  |  |  | 37d | 0d | finish no earlier than 2024-12-20 | 108.33 | No BL | GREEN |  |  |  |  |  |  |  |  |  |  |
| 1150 | 1.4.2.3.3.2.4.7 | Sprint 10 |  | 10d | 2025-01-20 | 2025-01-31 | 1149 |  |  |  |  |  |  |  | 37d | 0d | finish no earlier than 2025-01-03 | 122.33 | No BL | GREEN |  |  |  |  |  |  |  |  |  |  |
| 1151 | 1.4.2.3.3.2.4.8 | Sprint 11 |  | 10d | 2025-02-03 | 2025-02-14 | 1150 |  |  |  |  |  |  |  | 37d | 0d | finish no earlier than 2025-01-17 | 136.33 | No BL | GREEN |  |  |  |  |  |  |  |  |  |  |
| 1152 | 1.4.2.3.3.2.4.9 | Sprint 12 |  | 10d | 2025-02-17 | 2025-02-28 | 1151 |  |  |  |  |  |  |  | 37d | 10d | finish no earlier than 2025-01-31 | 150.33 | No BL | GREEN |  |  |  |  |  |  |  |  |  |  |
| 1153 | 1.4.2.3.3.2.5 | **SIT Migration MVC Regression Testing (code freeze)** |  | 35d? | 2025-05-05 | 2025-06-20 |  |  |  |  |  |  |  |  | 32397d |  |  | -685.67 | Overdue Start | RED |  |  |  |  |  |  |  |  |  |  |
| 1154 | 1.4.2.3.3.2.5.1 | Regression Sprint 1 |  | 10d? | 2025-05-05 | 2025-05-16 | 1115 |  |  |  |  |  |  |  | 32397d | 0d |  | 227.33 | No BL | GREEN |  |  |  |  |  |  |  |  |  |  |
| 1155 | 1.4.2.3.3.2.5.2 | Regression Sprint 2 |  | 10d? | 2025-05-19 | 2025-05-30 | 1154 |  |  |  |  |  |  |  | 32397d | 0d |  | 241.33 | No BL | GREEN |  |  |  |  |  |  |  |  |  |  |
| 1156 | 1.4.2.3.3.2.5.3 | Regression Sprint 3 |  | 15d? | 2025-06-02 | 2025-06-20 | 1155 |  |  |  |  |  |  |  | 32397d |  |  | 255.33 | No BL | GREEN |  |  |  |  |  |  |  |  |  |  |
| 1157 | 1.4.2.3.3.2.5.4 | SIT Migration Testing End (Minimum Viable Cohort) (incl. confirmation that PPs have submitted their Test Completion Reports to Programme for assurance) | milestone | 0d | 2025-06-20 | 2025-06-20 |  |  |  |  |  |  |  |  | 32398d |  | start no earlier than 2025-06-20 | 273.33 | No BL | GREEN |  |  |  |  |  |  |  |  |  |  |
| 1158 | 1.4.2.3.3.2.6 | **SIT Migration Test Completion Report (Minimum Viable Cohort)** |  | 144d | 2024-06-18 A | 2025-01-03 | 920FS+10d, 870, 874, 881, 887, 893 | 22% | 112d | 2024-06-10 | 2024-06-10 | 0d | 2024-06-10 | 2024-06-10 | 32512d |  |  |  | Complete | COMPLETE | SI Test | PP | MHHS-ART076 | 5.27 | Systems Integration Testing (SIT) | T3-TE-0038 | SITAG | T3 |  |  |
| 1159 | 1.4.2.3.3.2.6.1 | Develop document |  | 89d | 2024-06-18 A | 2024-10-18 |  | 36% | 57d | 2024-06-10 | 2024-10-04 | 85d | 2024-06-10 | 2024-10-04 | 32512d | 0d |  |  | Red | RED | SI Test | PP |  | 5.0 | Systems Integration Testing (SIT) |  |  |  | D24E - Migration Test Completion Report | Roger Robar |
| 1160 | 1.4.2.3.3.2.6.2 | Review& agree document |  | 10d | 2024-10-21 | 2024-11-01 | 1159 |  |  | 2024-10-21 | 2024-11-01 | 10d | 2024-10-21 | 2024-11-01 | 32512d | 0d |  | 31.33 | Green | GREEN | SI Test | PP |  | 5.27 | Systems Integration Testing (SIT) |  |  |  |  | Roger Robar |
| 1161 | 1.4.2.3.3.2.6.3 | SIT Migration Testing Test Completion Report (Minimum Viable Cohort) Approved |  | 45d | 2024-11-04 | 2025-01-03 | 1160 |  |  | 2024-11-04 | 2025-01-03 | 45d |  |  | 32512d | 49d |  | 45.33 | Green | GREEN |  |  |  | 5.27 |  |  |  |  |  |  |
| 1162 | 1.4.2.3.3.2.7 | SIT Migration Testing End (Minimum Viable Cohort) (incl. confirmation that PPs have submitted their Test Completion Reports to Programme for assurance) | milestone | 0d | 2025-03-14 | 2025-03-14 | 1159FF, 1161 |  |  | 2025-01-03 | 2025-01-03 | 0d | 2024-10-04 | 2024-10-04 | 32463d | 0d | start no earlier than 2025-03-14 | 175.33 | Red | RED | SI Test | PP | MHHS-ART076 | 6.0 | Systems Integration Testing (SIT) | T3-TE-0043 | SITAG | T3 |  | Roger Robar |
| 1163 | 1.4.2.3.3.2.8 | Assurance of PPs Test Completion Reports |  | 30d | 2025-02-07 | 2025-03-20 | 1162FF+5d |  |  | 2024-12-02 | 2025-01-10 | 30d | 2024-09-02 | 2024-10-11 | 32463d |  |  | 140.33 | Red | RED | SI Test | PP |  | 5.0 | Systems Integration Testing (SIT) |  |  |  |  | Roger Robar |

Notes:
- 1158: 21/5: at risk because dependant on prioritised SIT F CoA tests. Subject to approval at eSITAG on 10/6. 11/6: Missed date because MPRS data and code not ready. Decision deferred to 17/6
- 1162: 16/09/24 - Date pushed back to 14/03/25, in line with recalibration exercise.

| ID | WBS | Task | Type | Duration | Start | Finish | Predecessors | Baseline start | Baseline finish | Baseline duration | Baseline 1 start | Baseline 1 finish | Total slack | Free slack | Constraint | Responsible | Involved | Update Version | MHHS Resource Name | MHHS Programme Phase | Task Status | Sched Status | RAG | Artefact ID | Milestone ID | Text29 | Tier | Guidance | Text3 |
| --- | --- | --- | --- | --- | --- | --- | --- | --- | --- | --- | --- | --- | --- | --- | --- | --- | --- | --- | --- | --- | --- | --- | --- | --- | --- | --- | --- | --- | --- |
| 1164 | 1.4.2.3.3.2.9 | **SIT Migration Testing Test Completion Report (Minimum Viable Cohort)** |  | 20d | 2025-06-02 | 2025-06-27 |  | 2024-09-16 | 2024-10-11 | 20d | 2024-09-16 | 2024-10-11 | 32387d |  |  | N/A | N/A | 5.0 | N/A | Systems Integration Testing (SIT) |  |  |  |  |  |  |  |  |  |
| 1165 | 1.4.2.3.3.2.9.1 | Develop document |  | 15d | 2025-06-02 | 2025-06-20 |  | 2024-09-16 | 2024-10-04 | 15d | 2024-09-16 | 2024-10-04 | 32387d | 0d | start no earlier than 2025-06-02 | SI Test |  | 5.0 | Roger Robar | Systems Integration Testing (SIT) | 255.33 | Red | RED |  |  |  |  |  |  |
| 1166 | 1.4.2.3.3.2.9.2 | Review & agree document |  | 5d | 2025-06-23 | 2025-06-27 | 1165 | 2024-10-07 | 2024-10-11 | 5d | 2024-10-07 | 2024-10-11 | 32387d | 0d |  | SI Test | PP,IPA | 5.0 | Roger Robar | Systems Integration Testing (SIT) | 276.33 | Red | RED |  |  |  |  |  |  |
| 1167 | 1.4.2.3.3.2.10 | SIT Migration Testing Test Completion Report (Minimum Viable Cohort) Approved | milestone | 0d | 2025-07-04 | 2025-07-04 | 1166FS+5d | 2024-10-18 | 2024-10-18 | 0d | 2024-10-18 | 2024-10-18 | 32387d |  |  | SI Test | PP | 5.28 | Roger Robar | Systems Integration Testing (SIT) | 287.71 | Red | RED | MHHS-ART076 | T2-TE-0800 | SITAG | T2 |  |  |
| 1168 | 1.4.2.3.4 | **SIT Non-Functional Testing (all SIT PPs)** |  | 130d? | 2025-01-13 | 2025-07-11 |  | 2024-09-02 | 2025-01-17 | 100d | 2024-09-02 | 2025-01-17 | 31778d |  |  | N/A | N/A | 5.0 | N/A | Systems Integration Testing (SIT) |  |  |  |  |  |  |  |  |  |
| 1169 | 1.4.2.3.4.1 | Theme 1 (Helix and DIP Volume Testing) Start | milestone | 0d? | 2025-01-13 | 2025-01-13 | 965 |  |  |  |  |  | 31808d | 0d | start no earlier than 2025-01-13 |  |  |  |  |  | 115.33 | No BL | GREEN |  | T3-TE-0040 |  |  |  |  |
| 1170 | 1.4.2.3.4.2 | Theme 1 (Helix and DIP Volume Testing) Execution |  | 15d? | 2025-01-13 | 2025-01-31 | 1169 |  |  |  |  |  | 31808d | 0d | start no earlier than 2025-01-13 |  |  |  |  |  | 115.33 | No BL | GREEN |  |  |  |  |  |  |
| 1171 | 1.4.2.3.4.3 | Theme 2 SIT Non-Functional Testing Start | milestone | 0d | 2025-05-02 | 2025-05-02 | 981FS+5d, 1094FS+5d, 927, 931, 938, 944, 950, 967, 971 | 2024-09-02 | 2024-09-02 | 0d | 2024-09-02 | 2024-09-02 | 31778d | 0d |  | SI Test | PP | 5.0 | Roger Robar | Systems Integration Testing (SIT) | 224.71 | Red | RED | MHHS-ART079 | T3-TE-0040 | SITAG | T3 | 12/8/24: needs to be 7/10/24 |  |
| 1172 | 1.4.2.3.4.4 | Theme 2 SIT Non-Functional Testing Execution |  | 40d | 2025-05-05 | 2025-06-27 | 1171SS | 2024-09-02 | 2025-01-03 | 90d | 2024-09-02 | 2025-01-03 | 31778d | 0d |  | SI Test | PP | 5.0 | Roger Robar | Systems Integration Testing (SIT) | 227.33 | Red | RED |  |  |  |  |  | D24D - NF Test Completion Report |
| 1173 | 1.4.2.3.4.5 | Theme 3 SIT Non-Functional Testing Start |  | 1d? | 2025-03-17 | 2025-03-17 | 967, 971 |  |  |  |  |  | 31813d | 0d |  |  |  |  |  |  | 178.33 | No BL | GREEN |  |  |  |  |  |  |
| 1174 | 1.4.2.3.4.6 | Theme 3 SIT Non-Functional Testing Execution |  | 40d? | 2025-03-17 | 2025-05-09 | 1173SS |  |  |  |  |  | 31813d | 35d |  |  |  |  |  |  | 178.33 | No BL | GREEN |  |  |  |  |  |  |
| 1175 | 1.4.2.3.4.7 | SIT Non-Functional Testing End (all SIT PPs) (incl. confirmation that PPs have submitted their Test Completion Reports to Programme for assurance) | milestone | 0d | 2025-06-27 | 2025-06-27 | 1172FF, 1174FF | 2025-01-03 | 2025-01-03 | 0d | 2025-01-03 | 2025-01-03 | 31778d | 0d | start no earlier than 2025-05-23 | SI Test | PP | 5.0 | Roger Robar | Systems Integration Testing (SIT) | 280.71 | Red | RED | MHHS-ART079 | T3-TE-0047 | SITAG | T3 |  |  |
| 1176 | 1.4.2.3.4.8 | Assurance of PPs Test Completion Reports |  | 20d | 2025-06-09 | 2025-07-04 | 1175FF+5d | 2024-12-02 | 2025-01-10 | 30d | 2024-12-02 | 2025-01-10 | 31778d | 0d |  | SI Test | PP | 5.0 | Roger Robar | Systems Integration Testing (SIT) | 262.33 | Red | RED |  |  |  |  |  |  |
| 1177 | 1.4.2.3.4.9 | **SIT Non-Functional Testing Test Completion Report (all SIT PPs)** |  | 20d | 2025-06-09 | 2025-07-04 |  | 2024-12-16 | 2025-01-10 | 20d | 2024-12-16 | 2025-01-10 | 31778d |  |  | N/A | N/A | 5.0 | N/A | Systems Integration Testing (SIT) |  |  |  |  |  |  |  |  |  |
| 1178 | 1.4.2.3.4.9.1 | Develop document |  | 15d | 2025-06-09 | 2025-06-27 | 1175FF | 2024-12-16 | 2025-01-03 | 15d | 2024-12-16 | 2025-01-03 | 31778d | 0d |  | SI Test |  | 5.0 | Roger Robar | Systems Integration Testing (SIT) | 262.33 | Red | RED |  |  |  |  |  |  |
| 1179 | 1.4.2.3.4.9.2 | Review & agree document |  | 5d | 2025-06-30 | 2025-07-04 | 1178, 1176FF | 2025-01-06 | 2025-01-10 | 5d | 2025-01-06 | 2025-01-10 | 31778d | 0d |  | SI Test | PP,IPA | 5.0 | Roger Robar | Systems Integration Testing (SIT) | 283.33 | Red | RED |  |  |  |  |  |  |
| 1180 | 1.4.2.3.4.10 | SIT Non-Functional Testing Test Completion Report (all SIT PPs) Approved | milestone | 0d | 2025-07-11 | 2025-07-11 | 1179FF+5d | 2025-01-17 | 2025-01-17 | 0d | 2025-01-17 | 2025-01-17 | 31778d | 0d |  | SI Test | PP | 5.0 | Roger Robar | Systems Integration Testing (SIT) | 294.71 | Red | RED | MHHS-ART079 | T2-TE-0900 | SITAG | T2 |  |  |
| 1181 | 1.4.2.3.5 | **SIT Operational Testing (all SIT PPs)** |  | 89d? | 2025-02-03 | 2025-06-05 |  | 2024-10-07 | 2025-02-07 | 90d | 2024-10-07 | 2025-02-07 | 31804d |  |  | N/A | N/A | 5.0 | N/A | Systems Integration Testing (SIT) |  |  |  |  |  |  |  |  |  |
| 1182 | 1.4.2.3.5.1 | **Non-SIT B Testing** |  | 25d? | 2025-02-03 | 2025-03-07 |  |  |  |  |  |  | 31858d |  |  |  |  |  |  |  | -686.67 | Overdue Start | RED |  |  |  |  |  |  |
| 1183 | 1.4.2.3.5.1.1 | SIT Operational Testing Start (Theme 3 - Batch 1 (Service Management)) | milestone | 0d? | 2025-02-03 | 2025-02-03 | 1030, 1007, 1008, 1009, 1010, 1029 |  |  |  |  |  | 31858d | 0d | start no earlier than 2025-02-03 |  |  | 6.0 |  |  | 136.33 | No BL | GREEN |  | T3-TE-0121 |  |  |  |  |
| 1184 | 1.4.2.3.5.1.2 | SIT Operational Testing Execution Window (Theme 3 - Batch 1 (Service Management)) |  | 25d? | 2025-02-03 | 2025-03-07 | 1183 |  |  |  |  |  | 31858d | 54d | start no earlier than 2025-01-06 |  |  |  |  |  | 136.33 | No BL | GREEN |  |  |  |  |  |  |
| 1185 | 1.4.2.3.5.2 | **SIT B Testing** |  | 70d? | 2025-02-07 | 2025-05-16 |  |  |  |  |  |  | 31808d |  |  |  |  |  |  |  | -686.67 | Overdue Start | RED |  |  |  |  |  |  |
| 1186 | 1.4.2.3.5.2.1 | SIT Operational Testing Start (SIT B) | milestone | 0d | 2025-02-07 | 2025-02-07 | 1051FS+8d, 988, 992, 999, 1005, 1030, 968, 969 | 2024-10-07 | 2024-10-07 | 0d | 2024-10-07 | 2024-10-07 | 31808d | 0d |  | SI Test | PP | 5.0 | Roger Robar | Systems Integration Testing (SIT) | 140.71 | Red | RED | MHHS-ART073 MHHS-ART143 | T3-TE-0042 | SITAG | T3 |  |  |
| 1187 | 1.4.2.3.5.2.2 | SIT Operational Testing Execution Theme 3 Batch 2 |  | 25d? | 2025-02-10 | 2025-03-14 | 1186, 1019 |  |  |  |  |  | 31808d | 0d |  |  |  |  |  |  | 143.33 | No BL | GREEN |  |  |  |  |  |  |
| 1188 | 1.4.2.3.5.2.3 | SIT Operational Testing Execution Theme 1 |  | 25d? | 2025-03-17 | 2025-04-18 | 1187 |  |  |  |  |  | 31808d | 0d |  |  |  |  |  |  | 178.33 | No BL | GREEN |  |  |  |  |  |  |
| 1189 | 1.4.2.3.5.2.4 | SIT Operational Testing Execution Theme 2 |  | 20d? | 2025-04-21 | 2025-05-16 | 1188 |  |  |  |  |  | 31808d | 4d |  |  |  |  |  |  | 213.33 | No BL | GREEN |  |  |  |  |  |  |
| 1190 | 1.4.2.3.5.3 | SIT Operational Testing End (all SIT PPs) (incl. confirmation that PPs have submitted their Test Completion Reports to Programme for assurance) | milestone | 0d | 2025-05-23 | 2025-05-23 | 1189, 1184 | 2025-01-24 | 2025-01-24 | 0d | 2025-01-24 | 2025-01-24 | 31804d | 0d | start no earlier than 2025-05-23 | SI Test | PP | 6.0 | Roger Robar | Systems Integration Testing (SIT) | 245.33 | Red | RED | MHHS-ART081 | T3-TE-0050 | SITAG | T3 |  |  |
| 1191 | 1.4.2.3.5.4 | Assurance of PPs Test Completion Reports |  | 30d | 2025-04-18 | 2025-05-29 | 1190FF+5d | 2024-12-23 | 2025-01-31 | 30d | 2024-12-23 | 2025-01-31 | 31804d | 0d |  | SI Test | PP | 5.0 | Roger Robar | Systems Integration Testing (SIT) | 210.33 | Red | RED |  |  |  |  |  |  |

Notes:
- 1167: Date change because the plan did not consider SIT Migration regression testing. SIT Migration Test Completion Report date was incorrect. Revise plan to align to Jan 25 SITAG approval. Date change to form part of Programme CR 55.
- 1171: Date will be missed due to low~SIT functional test velocity. Start of SIT-Non Functional (MVC) will be delayed. Date re-forecast in line with scenario planning. Introduction of 5 weeks additional sprints
- 1175: 16/09/24 - Date pushed back to 23/05/25, in line with recalibration exercise.
- 1180: 6/8/24: Date at risk due to lower than expected test velocity. Start of SIT-Non Functional (MVC) could be delayed. Programme-wide scenario re-planning underway
- 1183: 17/09/23 - Added new milestone
- 1186: Team has a dependency on Helix documentation that has been submitted late, which has impacted the approval of Theme 3 test scripts and test design. ~Date expected to move to 04/11.
- 1190: 16/09/24 - Date pushed back to 23/05/25, in line with recalibration exercise.

| ID | WBS | Task | Type | Duration | Start | Finish | Predecessors | Complete | Remaining | Baseline start | Baseline finish | Baseline duration | Baseline 1 start | Baseline 1 finish | Total slack | Free slack | Baseline cost | Responsible | Involved | Update Version | MHHS Resource Name | MHHS Programme Phase | Task Status | Sched Status | RAG | Artefact ID | Milestone ID | Text29 | Tier | Text3 |
| --- | --- | --- | --- | --- | --- | --- | --- | --- | --- | --- | --- | --- | --- | --- | --- | --- | --- | --- | --- | --- | --- | --- | --- | --- | --- | --- | --- | --- | --- | --- |
| 1192 | 1.4.2.3.5.5 | **SIT Operational Testing Test Completion Report (all SIT PPs)** |  | 20d | 2025-05-02 | 2025-05-29 |  |  |  | 2025-01-06 | 2025-01-31 | 20d | 2025-01-06 | 2025-01-31 | 31804d |  |  | N/A | N/A | 5.0 | N/A | Systems Integration Testing (SIT) |  |  |  |  |  |  |  |  |
| 1193 | 1.4.2.3.5.5.1 | Develop document |  | 15d | 2025-05-02 | 2025-05-23 | 1190FF |  |  | 2025-01-06 | 2025-01-24 | 15d | 2025-01-06 | 2025-01-24 | 31804d | 0d |  | SI Test |  | 5.0 | Roger Robar | Systems Integration Testing (SIT) | 224.33 | Red | RED |  |  |  |  |  |
| 1194 | 1.4.2.3.5.5.2 | Review & agree document |  | 5d | 2025-05-23 | 2025-05-29 | 1193, 1191FF |  |  | 2025-01-27 | 2025-01-31 | 5d | 2025-01-27 | 2025-01-31 | 31804d | 0d |  | SI Test | PP,IPA | 5.0 | Roger Robar | Systems Integration Testing (SIT) | 245.33 | Red | RED |  |  |  |  |  |
| 1195 | 1.4.2.3.5.6 | SIT Operational Testing Test Completion Report (all SIT PPs) Approved | milestone | 0d | 2025-06-05 | 2025-06-05 | 1194FF+5d |  |  | 2025-02-07 | 2025-02-07 | 0d | 2025-02-07 | 2025-02-07 | 31804d | 26d |  | SI Test | PP | 5.0 | Roger Robar | Systems Integration Testing (SIT) | 258.71 | Red | RED | MHHS-ART081 | T2-TE-0950 | SITAG | T2 |  |
| 1196 | 1.4.2.3.6 | **SIT MVC Test Exit Report** |  | 20d | 2025-06-02 | 2025-06-27 |  |  |  | 2025-01-06 | 2025-01-31 | 20d | 2025-01-06 | 2025-01-31 | 32392d |  |  | N/A | N/A | 5.0 | N/A | Systems Integration Testing (SIT) |  |  |  |  |  |  |  |  |
| 1197 | 1.4.2.3.6.1 | Develop document |  | 15d | 2025-06-02 | 2025-06-20 | 1123FF |  |  | 2025-01-06 | 2025-01-24 | 15d | 2025-01-06 | 2025-01-24 | 32392d | 0d |  | SI Test |  | 5.0 | Roger Robar | Systems Integration Testing (SIT) | 255.33 | Red | RED |  |  |  |  |  |
| 1198 | 1.4.2.3.6.2 | Review & agree document |  | 5d | 2025-06-23 | 2025-06-27 | 1197 |  |  | 2025-01-27 | 2025-01-31 | 5d | 2025-01-27 | 2025-01-31 | 32392d |  |  | SI Test | PP,IPA | 5.0 | Roger Robar | Systems Integration Testing (SIT) | 276.33 | Red | RED |  |  |  |  |  |
| 1199 | 1.4.2.3.7 | SIT Minimum Viable Cohort Complete (SIT Minimum Viable Cohort Test Exit Report Approved) | milestone | 0d | 2025-07-11 | 2025-07-11 | 1085, 1125FS+5d, 1180, 1195 |  |  | 2025-02-07 | 2025-02-07 | 0d | 2025-02-07 | 2025-02-07 | 31778d | 0d |  | CPT | PP,IPA | 5.0 | Roger Robar | Systems Integration Testing (SIT) | 294.71 | Red | RED | MHHS-ART081 | T1-TE-2000 | PSG | T1 |  |
| 1200 | 1.4.2.4 | **SIT (non-MVC)** |  | 119d? | 2025-05-05 A | 2025-10-16 |  | 10% | 106.64d? | 2024-03-11 | 2025-04-25 | 295d | 2024-03-11 | 2025-04-25 | 31794d |  | -0 | N/A | N/A | 5.0 | N/A | Systems Integration Testing (SIT) | M10,M11 |  |  |  |  |  |  | D24D - NF Test Completion Report |
| 1201 | 1.4.2.4.1 | **SIT Functional Testing (non-MVC)** |  | 110d? | 2025-05-05 | 2025-10-03 |  |  |  | 2024-03-11 | 2025-04-25 | 295d | 2024-03-11 | 2025-04-25 | 31794d |  |  | N/A | N/A | 5.0 | N/A | Systems Integration Testing (SIT) |  |  |  |  |  |  |  |  |
| 1202 | 1.4.2.4.1.1 | **SIT Functional Testing Execution (non-MVC)** |  | 95d? | 2025-05-05 | 2025-09-12 |  |  |  | 2024-03-11 | 2025-04-04 | 280d | 2024-03-11 | 2025-04-04 | 31794d |  |  | N/A | N/A | 5.0 | N/A | Systems Integration Testing (SIT) | M10 |  |  |  |  |  |  | D24C - E2E Test Completion Report |
| 1203 | 1.4.2.4.1.1.1 | Test Execution (Cycle 3 Completion and Regression Testing) |  | 95d? | 2025-05-05 | 2025-09-12 | 1115 |  |  |  |  |  |  |  | 31794d | 0d |  |  |  |  |  |  | 227.33 | No BL | GREEN |  |  |  |  |  |
| 1204 | 1.4.2.4.1.1.2 | SIT Functional Testing End (non-MVC) (incl. confirmation that PPs have submitted their Test Completion Reports to Programme for assurance) | milestone | 0d | 2025-09-12 | 2025-09-12 | 1203FF |  |  | 2025-04-04 | 2025-04-04 | 0d | 2025-04-04 | 2025-04-04 | 31794d | 0d |  | SI Test | PP | 5.0 | Roger Robar | Systems Integration Testing (SIT) | 357.71 | Red | RED | MHHS-ART072 | T3-TE-0052 | SITAG | T3 |  |
| 1205 | 1.4.2.4.1.2 | Assurance of PPs Test Completion Reports |  | 5d | 2025-09-22 | 2025-09-26 | 1204FS+5d |  |  | 2025-04-14 | 2025-04-18 | 5d | 2025-04-14 | 2025-04-18 | 31794d | 0d |  | SI Test | PP | 5.0 | Roger Robar | Systems Integration Testing (SIT) | 367.33 | Red | RED |  |  |  |  |  |
| 1206 | 1.4.2.4.1.3 | **SIT Functional Testing Test Completion Report (non-MVC)** |  | 25d | 2025-08-25 | 2025-09-26 |  |  |  | 2025-03-17 | 2025-04-18 | 25d | 2025-03-17 | 2025-04-18 | 31794d |  |  | N/A | N/A | 5.0 | N/A | Systems Integration Testing (SIT) |  |  |  |  |  |  |  |  |
| 1207 | 1.4.2.4.1.3.1 | Develop document |  | 15d | 2025-08-25 | 2025-09-12 | 1204FF |  |  | 2025-03-17 | 2025-04-04 | 15d | 2025-03-17 | 2025-04-04 | 31799d | 5d |  | SI Test |  | 5.0 | Roger Robar | Systems Integration Testing (SIT) | 339.33 | Red | RED |  |  |  |  |  |
| 1208 | 1.4.2.4.1.3.2 | Review & agree document |  | 5d | 2025-09-22 | 2025-09-26 | 1207, 1205FF |  |  | 2025-04-14 | 2025-04-18 | 5d | 2025-04-14 | 2025-04-18 | 31794d | 0d |  | SI Test | PP,IPA | 5.0 | Roger Robar | Systems Integration Testing (SIT) | 367.33 | Red | RED |  |  |  |  |  |
| 1209 | 1.4.2.4.1.4 | SIT Functional Testing Test Completion Report (non-MVC) Approved | milestone | 0d | 2025-10-03 | 2025-10-03 | 1208FF+5d |  |  | 2025-04-25 | 2025-04-25 | 0d | 2025-04-25 | 2025-04-25 | 31794d | 0d |  | SI Test | PP | 5.0 | Roger Robar | Systems Integration Testing (SIT) | 378.71 | Red | RED | MHHS-ART072 | T3-TE-0055 | SITAG | T3 |  |
| 1210 | 1.4.2.4.2 | **SIT Migration Testing (non-MVC)** |  | 110d | 2025-05-05 A | 2025-10-03 |  | 23% | 85.25d | 2024-06-10 | 2025-04-25 | 230d | 2024-06-10 | 2025-04-25 | 31794d |  |  | N/A | N/A | 5.0 | N/A | Systems Integration Testing (SIT) |  |  |  |  |  |  |  |  |
| 1211 | 1.4.2.4.2.1 | Test Execution (Cycle 3 Completion and Regression Testing) |  | 95d | 2025-05-05 A | 2025-09-12 | 1115 | 28% | 68d | 2024-06-10 | 2025-04-04 | 215d | 2024-06-10 | 2025-04-04 | 31794d | 0d |  | SI Test | PP | 5.0 | Roger Robar | Systems Integration Testing (SIT) |  | Red | RED |  |  |  |  | D24E - Migration Test Completion Report |
| 1212 | 1.4.2.4.2.2 | SIT Migration Testing End (non-MVC) (incl. confirmation that PPs have submitted their Test Completion Reports to Programme for assurance) | milestone | 0d | 2025-09-12 | 2025-09-12 | 1211FF |  |  | 2025-04-04 | 2025-04-04 | 0d | 2025-04-04 | 2025-04-04 | 31794d | 0d |  | SI Test | PP | 5.0 | Roger Robar | Systems Integration Testing (SIT) | 357.71 | Red | RED | MHHS-ART076 | T3-TE-0051 | SITAG | T3 |  |
| 1213 | 1.4.2.4.2.3 | Assurance of PPs Test Completion Reports |  | 5d | 2025-09-22 | 2025-09-26 | 1212FS+5d |  |  | 2025-04-14 | 2025-04-18 | 5d | 2025-04-14 | 2025-04-18 | 31794d | 0d |  | SI Test | PP | 5.0 | Roger Robar | Systems Integration Testing (SIT) | 367.33 | Red | RED |  |  |  |  |  |
| 1214 | 1.4.2.4.2.4 | **SIT Migration Testing Test Completion Report (non-MVC)** |  | 25d | 2025-08-25 | 2025-09-26 |  |  |  | 2025-03-17 | 2025-04-18 | 25d | 2025-03-17 | 2025-04-18 | 31794d |  |  | N/A | N/A | 5.0 | N/A | Systems Integration Testing (SIT) |  |  |  |  |  |  |  |  |
| 1215 | 1.4.2.4.2.4.1 | Develop document |  | 15d | 2025-08-25 | 2025-09-12 | 1212FF |  |  | 2025-03-17 | 2025-04-04 | 15d | 2025-03-17 | 2025-04-04 | 31799d | 5d |  | SI Test |  | 5.0 | Roger Robar | Systems Integration Testing (SIT) | 339.33 | Red | RED |  |  |  |  |  |
| 1216 | 1.4.2.4.2.4.2 | Review & agree document |  | 5d | 2025-09-22 | 2025-09-26 | 1215, 1213FF |  |  | 2025-04-14 | 2025-04-18 | 5d | 2025-04-14 | 2025-04-18 | 31794d | 0d |  | SI Test | PP,IPA | 5.0 | Roger Robar | Systems Integration Testing (SIT) | 367.33 | Red | RED |  |  |  |  |  |
| 1217 | 1.4.2.4.2.5 | SIT Migration Testing Test Completion Report (non-MVC Approved) | milestone | 0d | 2025-10-03 | 2025-10-03 | 1216FF+5d |  |  | 2025-04-25 | 2025-04-25 | 0d | 2025-04-25 | 2025-04-25 | 31794d | 0d |  | SI Test | PP | 5.0 | Roger Robar | Systems Integration Testing (SIT) | 378.71 | Red | RED | MHHS-ART076 | T3-TE-0056 | SITAG | T3 |  |

Notes:
- 1195: 6/8/24: Date at risk due to lower than expected test velocity. Start of SIT Operational (MVC) could be delayed. Programme-wide scenario re-planning underway
- 1199: 6/8/24: Date at risk due to lower than expected test velocity. Start of SIT Operational (MVC) could be delayed. Programme-wide scenario re-planning underway
- 1204: 6/8/24: Date at risk due to lower than expected test velocity. Completion of SIT Functional Testing (Other Participants) could be delayed. Programme-wide scenario re-planning underway
- 1205: 6/8/24: Date at risk due to lower than expected test velocity. Completion of SIT Functional Testing (Other Participants) could be delayed. Programme-wide scenario re-planning underway
- 1207: 6/8/24: Date at risk due to lower than expected test velocity. Completion of SIT Functional Testing (Other Participants) could be delayed. Programme-wide scenario re-planning underway
- 1208: 6/8/24: Date at risk due to lower than expected test velocity. Completion of SIT Functional Testing (Other Participants) could be delayed. Programme-wide scenario re-planning underway
- 1209: 6/8/24: Date at risk due to lower than expected test velocity. Completion of SIT Functional Testing (Other Participants) could be delayed. Programme-wide scenario re-planning underway
- 1212: 6/8/24: Date at risk due to lower than expected test velocity. Completion of SIT Migration Testing (Other Participants) could be delayed. Programme-wide scenario re-planning underway
- 1217: 6/8/24: Date at risk due to lower than expected test velocity. Completion of SIT Migration Testing (Other Participants) could be delayed. Programme-wide scenario re-planning underway

| ID | WBS | Task | Type | Duration | Start | Finish | Predecessors | Complete | Remaining | Baseline start | Baseline finish | Baseline duration | Baseline 1 start | Baseline 1 finish | Total slack | Free slack | Constraint | Baseline cost | Responsible | Involved | Update Version | MHHS Resource Name | MHHS Programme Phase | Task Status | Sched Status | RAG | Artefact ID | Milestone ID | Text29 | Tier |
| --- | --- | --- | --- | --- | --- | --- | --- | --- | --- | --- | --- | --- | --- | --- | --- | --- | --- | --- | --- | --- | --- | --- | --- | --- | --- | --- | --- | --- | --- | --- |
| 1218 | 1.4.2.4.3 | **SIT non-MVC Test Exit Report** |  | 20d | 2025-09-15 | 2025-10-10 |  |  |  | 2025-03-17 | 2025-04-11 | 20d | 2025-03-17 | 2025-04-11 | 31794d |  |  |  | N/A | N/A | 5.0 | N/A | Systems Integration Testing (SIT) |  |  |  |  |  |  |  |
| 1219 | 1.4.2.4.3.1 | Develop document |  | 15d | 2025-09-15 | 2025-10-03 | 1209FF, 1217FF |  |  | 2025-03-17 | 2025-04-04 | 15d | 2025-03-17 | 2025-04-04 | 31794d | 0d |  |  | SI Test |  | 5.0 | Roger Robar | Systems Integration Testing (SIT) | 360.33 | Red | RED |  |  |  |  |
| 1220 | 1.4.2.4.3.2 | Review & agree document |  | 5d | 2025-10-06 | 2025-10-10 | 1219 |  |  | 2025-04-07 | 2025-04-11 | 5d | 2025-04-07 | 2025-04-11 | 31794d | 0d |  |  | SI Test | PP,IPA | 5.0 | Roger Robar | Systems Integration Testing (SIT) | 381.33 | Red | RED |  |  |  |  |
| 1221 | 1.4.2.4.4 | SIT non-MVC Complete | milestone | 0d | 2025-10-16 | 2025-10-16 | 1220FS+4d, 1209, 1217 |  |  | 2025-04-25 | 2025-04-25 | 0d | 2025-04-21 | 2025-04-21 | 31794d | 0d |  |  | SI Test | PP | 5.27 | Roger Robar | Systems Integration Testing (SIT) | 391.71 | Red | RED | MHHS-ART081 | T3-TE-0059 | SITAG | T3 |
| 1222 | 1.4.3 | **UIT Environment Preparation** |  | 700d | 2022-10-31 A | 2025-07-04 |  | 46% | 379.59d | 2022-10-31 | 2025-06-06 | 680d | 2022-10-31 | 2025-06-06 | 32387d |  |  | -0 | N/A | N/A | 5.0 | N/A | Systems Integration Testing (SIT) |  |  |  |  |  |  |  |
| 1223 | 1.4.3.1 | **Test Artefact Development** |  | 361d | 2023-03-01 A | 2024-07-18 |  | 54% | 167.03d | 2023-03-01 | 2024-07-18 | 361d | 2023-03-01 | 2023-08-04 | 32639d |  |  | -0 | N/A | N/A | 5.0 | N/A | Systems Integration Testing (SIT) |  |  |  |  |  |  |  |
| 1224 | 1.4.3.1.1 | **E2E Sandbox Guidance** |  | 361d | 2023-03-01 A | 2024-07-18 A |  | 100% |  | 2023-03-01 | 2024-07-18 | 361d | 2023-03-01 | 2023-08-04 |  |  |  | -0 | N/A | N/A | 5.0 | N/A | Systems Integration Testing (SIT) |  |  |  |  |  |  |  |
| 1225 | 1.4.3.1.1.1 | Develop document |  | 83d | 2023-03-01 A | 2023-06-23 A |  | 100% |  | 2023-03-01 | 2023-06-23 | 83d | 2023-03-01 | 2023-06-23 |  |  | start no earlier than 2023-03-01 |  | SI Test |  | 5.0 | Stuart Scott | Systems Integration Testing (SIT) |  | Complete | COMPLETE |  |  |  |  |
| 1226 | 1.4.3.1.1.2 | Artefact review (via SITAG) and updates |  | 25d | 2023-06-26 A | 2023-07-28 A | 1225 | 100% |  | 2023-06-26 | 2023-07-28 | 25d | 2023-06-26 | 2023-07-28 |  |  |  |  | SI Test | PP,IPA | 5.0 | Stuart Scott | Systems Integration Testing (SIT) |  | Complete | COMPLETE |  |  |  |  |
| 1227 | 1.4.3.1.1.3 | E2E Sandbox Guidance approved | milestone | 0d | 2024-07-18 A | 2024-07-18 A | 1226FF+5d | 100% |  | 2024-07-18 | 2024-07-18 | 0d | 2023-08-04 | 2023-08-04 |  |  | start no earlier than 2024-07-18 |  | SI Test | PP | 5.29 | Stuart Scott | Systems Integration Testing (SIT) |  | Complete | COMPLETE | MHHS-ART154 | T3-TE-0067 | QAG | T3 |
| 1228 | 1.4.3.1.2 | **E2E Sandbox Test Data Approach & Plan** |  | 93d | 2023-03-29 | 2023-08-04 |  |  |  | 2023-03-29 | 2023-08-04 | 93d | 2023-03-29 | 2023-08-04 | 32887d |  |  |  | N/A | N/A | 5.0 | N/A | Systems Integration Testing (SIT) |  |  |  |  |  |  |  |
| 1229 | 1.4.3.1.2.1 | Develop document |  | 68d | 2023-03-29 | 2023-06-30 | 1225SS+20d |  |  | 2023-03-29 | 2023-06-30 | 68d | 2023-03-29 | 2023-06-30 | 32887d | 0d |  |  | SI Test |  | 5.0 | Stuart Scott | Systems Integration Testing (SIT) | -540.67 | Overdue Start | RED |  |  |  |  |
| 1230 | 1.4.3.1.2.2 | Review, update & agree document internally |  | 25d | 2023-07-03 | 2023-08-04 | 1229 |  |  | 2023-07-03 | 2023-08-04 | 25d | 2023-07-03 | 2023-08-04 | 32887d |  |  |  | SI Test | PP,IPA | 5.0 | Stuart Scott | Systems Integration Testing (SIT) | -444.67 | Overdue Start | RED |  |  |  |  |
| 1231 | 1.4.3.2 | **UIT Stub Specification and Delivery** |  | 190d | 2023-12-04 A | 2024-08-23 |  | 88% | 22d | 2023-12-04 | 2024-08-23 | 190d | 2023-10-27 | 2024-08-23 | 32612d |  |  | -0 | N/A | N/A | 5.0 | N/A | Systems Integration Testing (SIT) |  |  |  |  |  |  |  |
| 1232 | 1.4.3.2.1 | **Qualification Test Stubs** |  | 190d | 2023-12-04 A | 2024-08-23 |  | 88% | 22d | 2023-12-04 | 2024-08-23 | 190d | 2023-10-27 | 2024-08-23 | 32612d |  |  | -0 | N/A | N/A | 5.16 | N/A | Systems Integration Testing (SIT) |  |  |  |  |  |  |  |
| 1233 | 1.4.3.2.1.1 | Specify |  | 44d | 2023-12-04 A | 2024-02-01 A | 472FS+13d | 100% |  | 2023-12-04 | 2024-02-01 | 44d | 2023-10-27 | 2023-12-29 |  |  |  |  | SI DevOps | Qualification,SRO | 5.0 | Matthew Bray | Systems Integration Testing (SIT) |  | Complete | COMPLETE |  |  |  |  |
| 1234 | 1.4.3.2.1.2 | Build & Test |  | 141d | 2024-02-02 A | 2024-08-16 | 1233 | 88% | 17d | 2024-02-02 | 2024-08-16 | 141d | 2023-12-29 | 2024-05-24 | 32612d | 0d |  |  | SI DevOps | Qualification,SRO | 5.23 | Matthew Bray | Systems Integration Testing (SIT) |  | Overdue | RED |  |  |  |  |
| 1235 | 1.4.3.2.1.3 | Prepare for release |  | 5d | 2024-08-19 | 2024-08-23 | 1234 |  |  | 2024-08-19 | 2024-08-23 | 5d | 2024-07-29 | 2024-08-23 | 32612d | 0d |  |  | SI DevOps | Qualification,SRO | 5.0 | Matthew Bray | Systems Integration Testing (SIT) | -31.67 | Overdue Start | RED |  |  |  |  |
| 1236 | 1.4.3.2.1.4 | Non-SIT LDSO Test Harness Released | milestone | 0d | 2024-08-23 | 2024-08-23 | 1235 |  |  | 2024-08-23 | 2024-08-23 | 0d | 2024-08-23 | 2024-08-23 | 32612d |  |  |  | SI DevOps | Qualification,SRO | 5.27 | Matthew Bray | Systems Integration Testing (SIT) | -27.29 | Overdue | RED | MHHS-ART080 | T3-TE-0035 | QAG | T3 |
| 1237 | 1.4.3.3 | **Environments (UIT)** |  | 700d | 2022-10-31 A | 2025-07-04 |  | 44% | 389.54d | 2022-10-31 | 2025-06-06 | 680d | 2022-10-31 | 2025-06-06 | 32387d |  |  | -0 | N/A | N/A | 5.0 | N/A | Systems Integration Testing (SIT) |  |  |  |  |  |  |  |
| 1238 | 1.4.3.3.1 | **Central Party (Avenade) Environments (UIT)** |  | 488d | 2022-11-16 A | 2024-09-27 |  | 97% | 14.82d | 2022-11-16 | 2024-10-04 | 493d | 2022-11-16 | 2024-10-04 | 32587d |  |  | -0 | N/A | N/A | 5.28 | N/A | Systems Integration Testing (SIT) |  |  |  |  |  |  |  |
| 1239 | 1.4.3.3.1.1 | Central Party (Avendae) environment preparation (incl. security certificates and security compliance) |  | 447d | 2022-11-16 A | 2024-08-01 A | 468 | 100% |  | 2022-11-16 | 2024-08-23 | 463d | 2022-11-16 | 2024-08-23 |  |  |  |  | PP | SI Test | 5.28 | Simon Berry | Systems Integration Testing (SIT) |  | Complete | COMPLETE |  |  |  |  |
| 1240 | 1.4.3.3.1.2 | Submit self-declaration of environment preparation complete (incl. security certificates and security compliance) to Programme for assurance |  | 447d | 2022-11-16 A | 2024-08-01 A | 1239SS | 100% |  | 2022-11-16 | 2024-08-23 | 463d | 2022-11-16 | 2024-08-23 |  |  |  |  | PP | SI Test | 5.28 | Simon Berry | Systems Integration Testing (SIT) |  | Complete | COMPLETE |  |  |  |  |
| 1241 | 1.4.3.3.1.3 | Central Party (Avenade) UIT environment connectivity proving |  | 25d | 2024-08-26 | 2024-09-27 | 1253 |  |  | 2024-08-26 | 2024-09-27 | 25d | 2024-08-27 | 2024-09-20 | 32586d | 0d |  |  | PP | SI Test | 5.28 | Simon Berry | Systems Integration Testing (SIT) | -24.67 | Green | GREEN |  |  |  |  |
| 1242 | 1.4.3.3.1.4 | Deployment of MHHS solution code to UIT environments |  | 2d | 2024-07-29 | 2024-07-30 |  |  |  | 2024-09-09 | 2024-09-20 | 10d | 2024-09-09 | 2024-09-20 | 32629d | 0d | start no earlier than 2024-07-29 |  | PP | SI Test | 5.28 | Simon Berry | Systems Integration Testing (SIT) | -52.67 | Overdue Start | GREEN |  |  |  |  |
| 1243 | 1.4.3.3.1.5 | Central Party (Avenade) UIT environment Regression Testing |  | 1d | 2024-07-31 | 2024-07-31 | 1242 |  |  | 2024-09-23 | 2024-10-04 | 10d | 2024-09-23 | 2024-10-04 | 32629d |  |  |  | PP | SI Test | 5.28 | Simon Berry | Systems Integration Testing (SIT) | -50.67 | Overdue Start | GREEN |  |  |  |  |

Notes:
- 1219: 6/8/24: Date at risk due to lower than expected test velocity. Completion of SIT- Other Particiapnts Test Exit report could be delayed. Programme-wide scenario re-planning underway
- 1220: 6/8/24: Date at risk due to lower than expected test velocity. Completion of SIT- Other Particiapnts Test Exit report could be delayed. Programme-wide scenario re-planning underway
- 1221: 6/8/24: Date at risk due to lower than expected test velocity. Completion of SIT- Other Particiapnts Test Exit report could be delayed. Programme-wide scenario re-planning underway
- 1227: 26/6: Baseline date change approved at QAG on 20/6/24. 11/7/24: Date change approved at QAG on 20/6/24 from 4/08/24 to 18/7/24
- 1234: 30/4: Removed previous testing phases as were no longer relevant and extended task to push out to align with existing dates
- 1236: Date will be missed due to Sims & Ems being blocked from completing connectivity and regression testing activities, since message functionality is disabled in the current UIT environment version (IR7.3), only becoming enabled from 2/9 (release of IR8.1 UIT). Decision not to seek milestone date change and RAG as red was requested by SRO, with a corresponding acknowledgement that Sims & Ems are blocked due to external factors. LDP working towards getting the milestone date changed to September (exact date TBC). / Notes (2): 9/8/24: the meantime, and acknowledges that the reason for this is due to external factors (being blocked from completing final delivery activities due to UIT functionality until September) rather than S&E missing the deadline
- 1238: 8/7/24: Updated to reflect Avende are the only PP

| ID | WBS | Task | Type | Duration | Start | Finish | Predecessors | Complete | Remaining | Baseline start | Baseline finish | Baseline duration | Baseline 1 start | Baseline 1 finish | Total slack | Free slack | Constraint | Responsible | Involved | Update Version | MHHS Resource Name | MHHS Programme Phase | Task Status | Sched Status | RAG | Milestone ID | Text29 | Tier | Artefact ID |
| --- | --- | --- | --- | --- | --- | --- | --- | --- | --- | --- | --- | --- | --- | --- | --- | --- | --- | --- | --- | --- | --- | --- | --- | --- | --- | --- | --- | --- | --- |
| 1244 | 1.4.3.3.2 | **E2E Sandbox Participants (UIT)** |  | 680d | 2022-10-31 | 2025-06-06 |  |  |  | 2022-10-31 | 2025-06-06 | 680d | 2022-10-31 | 2025-06-06 | 0d |  |  | N/A | N/A | 5.0 | N/A | Systems Integration Testing (SIT) |  |  |  |  |  |  |  |
| 1245 | 1.4.3.3.2.1 | E2E Sandbox Participants environment preparation (incl. security certificates and security compliance) |  | 660d | 2022-10-31 | 2025-05-09 |  |  |  | 2022-10-31 | 2025-05-09 | 660d | 2022-10-31 | 2025-05-09 | 0d |  | must finish on 2025-05-09 | PP | SI Test | 5.0 | Simon Berry | Systems Integration Testing (SIT) | -689.67 | Overdue Start | GREEN |  |  |  |  |
| 1246 | 1.4.3.3.2.2 | Submit self-declaration of environment preparation complete (incl. security certificates and security compliance) to Programme for assurance |  | 660d | 2022-10-31 | 2025-05-09 |  |  |  | 2022-10-31 | 2025-05-09 | 660d | 2022-10-31 | 2025-05-09 | 32407d | 0d |  | PP | SI Test | 5.0 | Simon Berry | Systems Integration Testing (SIT) | -689.67 | Overdue Start | GREEN |  |  |  |  |
| 1247 | 1.4.3.3.2.3 | E2E Sandbox Participants UIT environment connectivity proving |  | 20d | 2025-05-12 | 2025-06-06 | 1246 |  |  | 2025-05-12 | 2025-06-06 | 20d | 2025-05-12 | 2025-06-06 | 32407d | 0d |  | PP | SI Test | 5.0 | Simon Berry | Systems Integration Testing (SIT) | 234.33 | Green | GREEN |  |  |  |  |
| 1248 | 1.4.3.3.2.4 | Deployment of MHHS solution code to UIT environments |  | 10d | 2025-05-26 | 2025-06-06 | 1247FF |  |  | 2025-05-26 | 2025-06-06 | 10d | 2025-05-26 | 2025-06-06 | 32407d |  |  | PP | SI Test | 5.0 | Simon Berry | Systems Integration Testing (SIT) | 248.33 | Green | GREEN |  |  |  |  |
| 1249 | 1.4.3.3.2.5 | Coordinate E2E Sandbox Participants' UIT environment preparation (for E2E Sandbox Testing Start) |  | 463d | 2022-10-31 | 2024-08-07 | 1245SS |  |  | 2022-10-31 | 2024-08-07 | 463d | 2022-10-31 | 2024-08-07 | 32624d |  |  | SI Test | PP | 5.0 | Simon Berry | Systems Integration Testing (SIT) | -689.67 | Overdue Start | RED |  |  |  |  |
| 1250 | 1.4.3.3.3 | **SI Environments (UIT)** |  | 688d | 2022-11-16 A | 2025-07-04 |  | 69% | 215.33d | 2022-10-31 | 2025-06-06 | 680d | 2022-10-31 | 2025-06-06 | 32387d |  |  | N/A | N/A | 5.0 | N/A | Systems Integration Testing (SIT) |  |  |  |  |  |  |  |
| 1251 | 1.4.3.3.3.1 | Coordinate Central Parties' UIT environment preparation |  | 447d | 2022-11-16 A | 2024-08-01 A | 1239SS | 100% |  | 2022-11-16 | 2024-08-23 | 463d | 2022-11-16 | 2024-08-23 |  |  |  | SI Test | PP | 5.0 | Simon Berry | Systems Integration Testing (SIT) |  | Complete | COMPLETE |  |  |  |  |
| 1252 | 1.4.3.3.3.2 | Assure Central Parties' self-declaration of environment preparation complete (incl. security certificates and security compliance) |  | 463d | 2022-11-16 A | 2024-08-23 | 1240SS | 97% | 12d | 2022-11-16 | 2024-08-23 | 463d | 2022-11-16 | 2024-08-23 | 32612d |  |  | SI Test | PP | 5.0 | Simon Berry | Systems Integration Testing (SIT) |  | Overdue | RED |  |  |  |  |
| 1253 | 1.4.3.3.3.3 | Central Parties' UIT environments ready to start connectivity proving (incl. certificates and security compliance) | milestone | 0d | 2024-08-23 A | 2024-08-23 A | 1236 | 100% |  | 2024-08-23 | 2024-08-23 | 0d | 2024-08-23 | 2024-08-23 |  |  |  | SI Test | PP | 5.0 | Simon Berry | Systems Integration Testing (SIT) |  | Complete | COMPLETE | T3-TE-0044 | QAG | T3 |  |
| 1254 | 1.4.3.3.3.4 | Coordinate Central Parties' UIT environment connectivity proving |  | 26d | 2024-08-26 | 2024-09-30 | 1241SS |  |  | 2025-05-12 | 2025-06-05 | 19d | 2025-05-12 | 2025-06-05 | 32586d |  |  | SI Test | PP | 5.0 | Simon Berry | Systems Integration Testing (SIT) | -24.67 | Green | GREEN |  |  |  |  |
| 1255 | 1.4.3.3.3.5 | Coordinate deployment of MHHS solution code to Central Parties' UIT environments |  | 2d | 2024-07-29 A | 2024-07-30 A | 1242SS | 100% |  | 2025-05-26 | 2025-06-06 | 10d | 2025-05-26 | 2025-06-06 |  |  |  | SI Test | PP | 5.0 | Simon Berry | Systems Integration Testing (SIT) |  | Complete | COMPLETE |  |  |  |  |
| 1256 | 1.4.3.3.3.6 | Coordinate Central Parties' UIT environment Regression Testing |  | 1d | 2024-07-31 | 2024-07-31 | 1255 |  |  | 2024-09-23 | 2024-10-04 | 10d | 2024-09-23 | 2024-10-04 | 32629d |  |  | SI Test | PP | 5.0 | Simon Berry | Systems Integration Testing (SIT) | -50.67 | Overdue Start | GREEN |  |  |  |  |
| 1257 | 1.4.3.3.3.7 | **Environments (Non-SIT LDSO)** |  | 43d | 2024-08-01 | 2024-09-30 |  |  |  | 2024-08-06 | 2025-01-13 | 115d | 2024-08-06 | 2025-01-13 | 32586d |  |  | N/A | N/A | 5.28 | N/A | Qualification |  |  |  |  |  |  |  |
| 1258 | 1.4.3.3.3.7.1 | Coordinate Qualification Participants' environment preparation |  | 17d | 2024-08-01 | 2024-08-23 |  |  |  | 2024-08-06 | 2024-10-28 | 60d | 2024-08-06 | 2024-10-28 | 32612d |  | start no earlier than 2024-08-01 | SI Test | Code Bodies, PP | 5.28 | Simon Berry | Qualification | -49.67 | Overdue Start | GREEN |  |  |  |  |
| 1259 | 1.4.3.3.3.7.2 | Coordinate deployment of MHHS solution code to Qualification Participants' UIT environments |  | 17d | 2024-08-01 | 2024-08-23 |  |  |  | 2024-10-15 | 2024-10-28 | 10d | 2024-10-15 | 2024-10-28 | 32586d | 0d | start no earlier than 2024-08-01 | SI Test | Code Bodies, PP | 5.28 | Simon Berry | Qualification | -49.67 | Overdue Start | GREEN |  |  |  |  |
| 1260 | 1.4.3.3.3.7.3 | Qualification Testing Tranche 1 Participants' UIT environments ready to start connectivity proving (incl. certificates and security compliance) | milestone | 0d | 2024-08-26 | 2024-08-26 | 1259FS+1d |  |  | 2024-11-04 | 2024-11-04 | 0d | 2024-11-04 | 2024-11-04 | 32586d | 0d |  | SI Test | Code Bodies, PP, IPA | 5.28 | Simon Berry | Qualification | -24.29 | Green | GREEN | T3-QU-0017 | QAG | T3 | MHHS-ART073 |
| 1261 | 1.4.3.3.3.7.4 | **Coordinate Qualification Participants' connectivity proving (Non-SIT LDSO)** |  | 25d | 2024-08-27 | 2024-09-30 |  |  |  | 2024-11-05 | 2025-01-13 | 50d | 2024-11-05 | 2025-01-13 | 32586d |  |  | N/A | N/A | 5.0 | N/A | Qualification |  |  |  |  |  |  |  |
| 1262 | 1.4.3.3.3.7.4.1 | Assurance of Qualification Participants' connectivity proving |  | 25d | 2024-08-27 | 2024-09-30 | 1260 |  |  | 2024-11-05 | 2025-01-13 | 50d | 2024-11-05 | 2025-01-13 | 32586d |  |  | SI Test | Code Bodies, PP | 5.0 |  | Qualification | -23.67 | Green | GREEN |  |  |  |  |
| 1263 | 1.4.3.3.3.8 | **Environments (S&A) Wave 1** |  | 41d | 2024-08-01 | 2024-09-26 |  |  |  | 2024-08-06 | 2025-01-13 | 115d | 2024-08-06 | 2025-01-13 |  |  |  | N/A | N/A | 5.28 | N/A | Qualification |  |  |  |  |  |  |  |
| 1264 | 1.4.3.3.3.8.1 | Coordinate Qualification Participants' environment preparation |  | 20d | 2024-09-02 | 2024-09-27 |  |  |  | 2024-08-06 | 2024-10-28 | 60d | 2024-08-06 | 2024-10-28 | 32587d |  | start no earlier than 2024-09-02 | SI Test | Code Bodies, PP | 5.28 | Simon Berry | Qualification | -17.67 | Green | GREEN |  |  |  |  |
| 1265 | 1.4.3.3.3.8.2 | Coordinate deployment of MHHS solution code to Qualification Participants' UIT environments |  | 10d | 2024-10-21 | 2024-11-01 |  |  |  | 2024-10-15 | 2024-10-28 | 10d | 2024-10-15 | 2024-10-28 | 32517d | 0d | start no earlier than 2024-10-21 | SI Test | Code Bodies, PP | 5.28 | Simon Berry | Qualification | 31.33 | yellow | RED |  |  |  |  |
| 1266 | 1.4.3.3.3.8.3 | Qualification Testing Wave 1 Participants' UIT environments ready to start connectivity proving (incl. certificates and security compliance) |  | 19d | 2024-11-05 | 2024-11-29 | 1265FS+1d |  |  | 2024-11-04 | 2024-11-04 | 0d | 2024-11-04 | 2024-11-04 | 32517d | 0d |  | SI Test | Code Bodies, PP, IPA | 5.28 | Simon Berry | Qualification | 46.33 | Red | RED | New? | QAG | T3 | MHHS-ART073 |
| 1267 | 1.4.3.3.3.8.4 | **Coordinate Qualification Participants' connectivity proving (S&A)** |  | 25d | 2024-12-02 | 2025-01-03 |  |  |  | 2024-11-05 | 2025-01-13 | 50d | 2024-11-05 | 2025-01-13 | 32517d |  |  | N/A | N/A | 5.0 | N/A | Qualification |  |  |  |  |  |  |  |
| 1268 | 1.4.3.3.3.8.4.1 | Assurance of Qualification Participants' connectivity proving |  | 25d | 2024-12-02 | 2025-01-03 | 1266 |  |  | 2024-11-05 | 2025-01-13 | 50d | 2024-11-05 | 2025-01-13 | 32517d |  |  | SI Test | Code Bodies, PP | 5.0 |  | Qualification | 73.33 | Green | GREEN |  |  |  |  |

Notes:
- 1257: 8/7/24: Updated to reflect the separation between non-sit and s and a and the 4 waves for s and a
- 1258: 8/7/24: Updated to reflect the separation between non-sit and s and a and the 4 waves for s and a
- 1259: 8/7/24: Updated to reflect the separation between non-sit and s and a and the 4 waves for s and a
- 1260: 8/7/24: Updated to reflect the separation between non-sit and s and a and the 4 waves for s and a
- 1263: 8/7/24: Updated to reflect the separation between non-sit and s and a and the 4 waves for s and a
- 1264: 8/7/24: Updated to reflect the separation between non-sit and s and a and the 4 waves for s and a
- 1265: 8/7/24: Updated to reflect the separation between non-sit and s and a and the 4 waves for s and a
- 1266: 8/7/24: Updated to reflect the separation between non-sit and s and a and the 4 waves for s and a

| ID | WBS | Task | Type | Duration | Start | Finish | Predecessors | Baseline start | Baseline finish | Baseline duration | Baseline 1 start | Baseline 1 finish | Total slack | Free slack | Constraint | Baseline cost | Responsible | Involved | Update Version | MHHS Resource Name | MHHS Programme Phase | Task Status | Sched Status | RAG | Artefact ID | Milestone ID | Text29 | Tier |
| --- | --- | --- | --- | --- | --- | --- | --- | --- | --- | --- | --- | --- | --- | --- | --- | --- | --- | --- | --- | --- | --- | --- | --- | --- | --- | --- | --- | --- |
| 1269 | 1.4.3.3.3.9 | **Environments (S&A) Wave 2** |  | 139d | 2024-08-27 | 2025-03-07 |  | 2024-08-06 | 2025-01-13 | 115d | 2024-08-06 | 2025-01-13 | 0d |  |  |  | N/A | N/A | 5.28 | N/A | Qualification |  |  |  |  |  |  |  |
| 1270 | 1.4.3.3.3.9.1 | Coordinate Qualification Participants' environment preparation |  | 20d | 2024-11-18 | 2024-12-13 |  | 2024-08-06 | 2024-10-28 | 60d | 2024-08-06 | 2024-10-28 | 32532d |  | start no earlier than 2024-11-18 |  | SI Test | Code Bodies, PP | 5.28 | Simon Berry | Qualification | 59.33 | Red | RED |  |  |  |  |
| 1271 | 1.4.3.3.3.9.2 | Coordinate deployment of MHHS solution code to Qualification Participants' UIT environments |  | 20d | 2024-12-16 | 2025-01-10 |  | 2024-10-15 | 2024-10-28 | 10d | 2024-10-15 | 2024-10-28 | 32472d | 0d | start no earlier than 2024-12-16 |  | SI Test | Code Bodies, PP | 5.28 | Simon Berry | Qualification | 87.33 | Red | RED |  |  |  |  |
| 1272 | 1.4.3.3.3.9.3 | Qualification Testing Wave 2 Participants' UIT environments ready to start connectivity proving (incl. certificates and security compliance) |  | 15d | 2025-01-13 | 2025-01-31 | 1271 | 2024-11-04 | 2024-11-04 | 0d | 2024-11-04 | 2024-11-04 | 32472d | 0d |  |  | SI Test | Code Bodies, PP, IPA | 5.28 | Simon Berry | Qualification | 115.33 | Red | RED | MHHS-ART073 | New? | QAG | T3 |
| 1273 | 1.4.3.3.3.9.4 | **Coordinate Qualification Participants' connectivity proving (S&A)** |  | 25d | 2024-08-27 | 2024-09-30 |  | 2024-11-05 | 2025-01-13 | 50d | 2024-11-05 | 2025-01-13 |  |  |  |  | N/A | N/A | 5.0 | N/A | Qualification |  |  |  |  |  |  |  |
| 1274 | 1.4.3.3.3.9.4.1 | Assurance of Qualification Participants' connectivity proving |  | 25d | 2025-02-03 | 2025-03-07 | 1272 | 2024-11-05 | 2025-01-13 | 50d | 2024-11-05 | 2025-01-13 | 32472d |  |  |  | SI Test | Code Bodies, PP | 5.0 |  | Qualification | 136.33 | Red | RED |  |  |  |  |
| 1275 | 1.4.3.3.3.10 | **Environments (S&A) Wave 3** |  | 80d | 2025-03-17 | 2025-07-04 |  | 2024-08-06 | 2025-01-13 | 115d | 2024-08-06 | 2025-01-13 | 32387d |  |  |  | N/A | N/A | 5.28 | N/A | Qualification |  |  |  |  |  |  |  |
| 1276 | 1.4.3.3.3.10.1 | Coordinate Qualification Participants' environment preparation |  | 30d | 2025-03-17 | 2025-04-25 |  | 2024-08-06 | 2024-10-28 | 60d | 2024-08-06 | 2024-10-28 | 32437d |  | start no earlier than 2025-03-17 |  | SI Test | Code Bodies, PP | 5.28 | Simon Berry | Qualification | 178.33 | Red | RED |  |  |  |  |
| 1277 | 1.4.3.3.3.10.2 | Coordinate deployment of MHHS solution code to Qualification Participants' UIT environments |  | 10d | 2025-04-28 | 2025-05-09 |  | 2024-10-15 | 2024-10-28 | 10d | 2024-10-15 | 2024-10-28 | 32387d | 0d | start no earlier than 2025-04-28 |  | SI Test | Code Bodies, PP | 5.28 | Simon Berry | Qualification | 220.33 | Red | RED |  |  |  |  |
| 1278 | 1.4.3.3.3.10.3 | Qualification Testing Wave 3 Participants' UIT environments ready to start connectivity proving (incl. certificates and security compliance) |  | 14d | 2025-05-13 | 2025-05-30 | 1277FS+1d | 2024-11-04 | 2024-11-04 | 0d | 2024-11-04 | 2024-11-04 | 32387d | 0d |  |  | SI Test | Code Bodies, PP, IPA | 5.28 | Simon Berry | Qualification | 235.33 | Red | RED | MHHS-ART073 | New? | QAG | T3 |
| 1279 | 1.4.3.3.3.10.4 | **Coordinate Qualification Participants' connectivity proving (S&A)** |  | 25d | 2025-06-02 | 2025-07-04 |  | 2024-11-05 | 2025-01-13 | 50d | 2024-11-05 | 2025-01-13 | 32387d |  |  |  | N/A | N/A | 5.0 | N/A | Qualification |  |  |  |  |  |  |  |
| 1280 | 1.4.3.3.3.10.4.1 | Assurance of Qualification Participants' connectivity proving |  | 25d | 2025-06-02 | 2025-07-04 | 1278 | 2024-11-05 | 2025-01-13 | 50d | 2024-11-05 | 2025-01-13 | 32387d |  |  |  | SI Test | Code Bodies, PP | 5.0 |  | Qualification | 255.33 | Red | RED |  |  |  |  |
| 1281 | 1.4.3.3.3.11 | **Environments (S&A) Wave 4** |  | 80d | 2025-03-17 | 2025-07-04 |  | 2024-08-06 | 2025-01-13 | 115d | 2024-08-06 | 2025-01-13 | 55d |  |  |  | N/A | N/A | 5.28 | N/A | Qualification |  |  |  |  |  |  |  |
| 1282 | 1.4.3.3.3.11.1 | Coordinate Qualification Participants' environment preparation |  | 30d | 2025-03-17 | 2025-04-25 |  | 2024-08-06 | 2024-10-28 | 60d | 2024-08-06 | 2024-10-28 | 32437d |  | finish no earlier than 2025-04-25 |  | SI Test | Code Bodies, PP | 5.28 | Simon Berry | Qualification | 178.33 | Red | RED |  |  |  |  |
| 1283 | 1.4.3.3.3.11.2 | Coordinate deployment of MHHS solution code to Qualification Participants' UIT environments |  | 10d | 2025-04-28 | 2025-05-09 |  | 2024-10-15 | 2024-10-28 | 10d | 2024-10-15 | 2024-10-28 | 32387d | 0d | finish no earlier than 2025-05-09 |  | SI Test | Code Bodies, PP | 5.28 | Simon Berry | Qualification | 220.33 | Red | RED |  |  |  |  |
| 1284 | 1.4.3.3.3.11.3 | Qualification Testing Wave 4 Participants' UIT environments ready to start connectivity proving (incl. certificates and security compliance) |  | 14d | 2025-05-13 | 2025-05-30 | 1283FS+1d | 2024-11-04 | 2024-11-04 | 0d | 2024-11-04 | 2024-11-04 | 32387d | 0d | finish no earlier than 2025-05-30 |  | SI Test | Code Bodies, PP, IPA | 5.28 | Simon Berry | Qualification | 235.33 | Red | RED | MHHS-ART073 | New? | QAG | T3 |
| 1285 | 1.4.3.3.3.11.4 | **Coordinate Qualification Participants' connectivity proving (S&A)** |  | 25d | 2025-06-02 | 2025-07-04 |  | 2024-11-05 | 2025-01-13 | 50d | 2024-11-05 | 2025-01-13 |  |  |  |  | N/A | N/A | 5.0 | N/A | Qualification |  |  |  |  |  |  |  |
| 1286 | 1.4.3.3.3.11.4.1 | Assurance of Qualification Participants' connectivity proving |  | 25d | 2025-06-02 | 2025-07-04 | 1284 | 2024-11-05 | 2025-01-13 | 50d | 2024-11-05 | 2025-01-13 | 32387d |  | start no earlier than 2025-06-02 |  | SI Test | Code Bodies, PP | 5.0 |  | Qualification | 255.33 | Red | RED |  |  |  |  |
| 1287 | 1.4.3.4 | **Test Data** |  | 30d | 2024-08-26 | 2024-10-04 |  | 2024-08-26 | 2024-10-04 | 30d | 2024-08-26 | 2024-10-04 | 32562d |  |  | -0 | N/A | N/A | 5.0 | N/A | Systems Integration Testing (SIT) |  |  |  |  |  |  |  |
| 1288 | 1.4.3.4.1 | **Central Parties (for E2E Sandbox & Qualification)** |  | 30d | 2024-08-26 | 2024-10-04 |  | 2024-08-26 | 2024-10-04 | 30d | 2024-08-26 | 2024-10-04 | 32562d |  |  |  | N/A | N/A | 5.0 | N/A | Systems Integration Testing (SIT) |  |  |  |  |  |  |  |
| 1289 | 1.4.3.4.1.1 | Central Parties' UIT environment test data loading & verification (& data cleansing, if required) |  | 30d | 2024-08-26 | 2024-10-04 |  | 2024-08-26 | 2024-10-04 | 30d | 2024-08-26 | 2024-10-04 | 32562d | 0d | start no earlier than 2024-08-26 |  | PP | SI Test | 5.0 | Richard Puddephatt | Systems Integration Testing (SIT) | -24.67 | Green | GREEN |  |  |  |  |
| 1290 | 1.4.3.4.1.2 | Submit self-declaration to Programme to confirm loading & verification of test data |  | 30d | 2024-08-26 | 2024-10-04 | 1289SS | 2024-08-26 | 2024-10-04 | 30d | 2024-08-26 | 2024-10-04 | 32562d | 0d |  |  | PP | SI Test | 5.0 | Richard Puddephatt | Systems Integration Testing (SIT) | -24.67 | Green | GREEN |  |  |  |  |
| 1291 | 1.4.3.4.2 | **E2E Sandbox Participants** |  | 30d | 2024-08-26 | 2024-10-04 |  | 2024-08-26 | 2024-10-04 | 30d | 2024-08-26 | 2024-10-04 | 32582d |  |  | -0 | N/A | N/A | 5.0 | N/A | Systems Integration Testing (SIT) |  |  |  |  |  |  |  |
| 1292 | 1.4.3.4.2.1 | E2E Sandbox Test Data Approach and Plan Approved | milestone | 0d | 2024-09-19 | 2024-09-19 |  | 2024-09-19 | 2024-09-19 | 0d |  |  | 32594d |  | start no earlier than 2024-09-19 |  | Sandbox (Qualification Governance) | Sandbox (Qualification Governance), Code Bodies, SRO | 5.28 | Stuart Scott |  | -0.67 | Green | GREEN |  | T3-QU-0124 | QAG |  |
| 1293 | 1.4.3.4.2.2 | UIT environment test data loading and verification (and data cleansing, if required) (for E2E Sandbox Testing Start) |  | 30d | 2024-08-26 | 2024-10-04 | 1289FF | 2024-08-26 | 2024-10-04 | 30d | 2024-08-26 | 2024-10-04 | 32582d | 0d |  |  | PP | SI Test | 5.0 | Richard Puddephatt | Systems Integration Testing (SIT) | -24.67 | Green | GREEN |  |  |  |  |

Notes:
- 1269: 8/7/24: Updated to reflect the separation between non-sit and s and a and the 4 waves for s and a
- 1270: 8/7/24: Updated to reflect the separation between non-sit and s and a and the 4 waves for s and a
- 1271: 8/7/24: Updated to reflect the separation between non-sit and s and a and the 4 waves for s and a
- 1272: 8/7/24: Updated to reflect the separation between non-sit and s and a and the 4 waves for s and a
- 1275: 8/7/24: Updated to reflect the separation between non-sit and s and a and the 4 waves for s and a
- 1276: 8/7/24: Updated to reflect the separation between non-sit and s and a and the 4 waves for s and a
- 1277: 8/7/24: Updated to reflect the separation between non-sit and s and a and the 4 waves for s and a
- 1278: 8/7/24: Updated to reflect the separation between non-sit and s and a and the 4 waves for s and a
- 1281: 8/7/24: Updated to reflect the separation between non-sit and s and a and the 4 waves for s and a
- 1282: 8/7/24: Updated to reflect the separation between non-sit and s and a and the 4 waves for s and a
- 1283: 8/7/24: Updated to reflect the separation between non-sit and s and a and the 4 waves for s and a
- 1284: 8/7/24: Updated to reflect the separation between non-sit and s and a and the 4 waves for s and a
- 1289: 1/5: changed from Simon berry to richard puddephatt. Link was 1143(5579) doesnt work now as the date has changed
- 1290: 1/5: changed from Simon berry to richard puddephatt
- 1292: Delays~experienced during~E2E Sandbox Test Data Approach and Plan development impacting when they'll be available for internal programme review and industry consultation. Industry consultation now targeted for~16-Sep-24 to 30-Sep-24. Approach and plan~will be presented to the next available QWG session on 8-Oct-24 for recommendation for approval, before returning~on 17-Oct-24 for formal approval.
- 1293: 1/5: changed from Simon berry to richard puddephatt

| ID | WBS | Task | Type | Duration | Start | Finish | Predecessors | Complete | Remaining | Baseline start | Baseline finish | Baseline duration | Baseline 1 start | Baseline 1 finish | Total slack | Free slack | Constraint | Baseline cost | Responsible | Involved | Update Version | MHHS Resource Name | MHHS Programme Phase | Task Status | Sched Status | RAG | Artefact ID | Milestone ID | Text29 | Tier | Text3 |
| --- | --- | --- | --- | --- | --- | --- | --- | --- | --- | --- | --- | --- | --- | --- | --- | --- | --- | --- | --- | --- | --- | --- | --- | --- | --- | --- | --- | --- | --- | --- | --- |
| 1294 | 1.4.3.4.3 | **SI Test Data** |  | 30d | 2024-08-26 | 2024-10-04 |  |  |  | 2024-08-26 | 2024-10-04 | 30d | 2024-08-26 | 2024-10-04 | 32582d |  |  |  | N/A | N/A | 5.0 | N/A | Systems Integration Testing (SIT) |  |  |  |  |  |  |  |  |
| 1295 | 1.4.3.4.3.1 | Coordinate Central Parties' UIT environment test data loading and verification (and data cleansing, if required) |  | 30d | 2024-08-26 | 2024-10-04 | 1289SS |  |  | 2024-08-26 | 2024-10-04 | 30d | 2024-08-26 | 2024-10-04 | 32582d |  |  |  | SI Test | PP | 5.0 | Richard Puddephatt | Systems Integration Testing (SIT) | -24.67 | Green | GREEN |  |  |  |  |  |
| 1296 | 1.4.3.4.3.2 | Assure evidence of Central Parties' UIT environment test data load and verification |  | 30d | 2024-08-26 | 2024-10-04 | 1290SS |  |  | 2024-08-26 | 2024-10-04 | 30d | 2024-08-26 | 2024-10-04 | 32582d |  |  |  | SI Test | PP | 5.0 | Richard Puddephatt | Systems Integration Testing (SIT) | -24.67 | Green | GREEN |  |  |  |  |  |
| 1297 | 1.4.3.4.3.3 | Coordinate E2E Sandbox Participants' UIT environment test data loading and verification (and data cleansing, if required) (for E2E Sandbox Testing Start) |  | 30d | 2024-08-26 | 2024-10-04 | 1293SS |  |  | 2024-08-26 | 2024-10-04 | 30d | 2024-08-26 | 2024-10-04 | 32582d |  |  |  | SI Test | PP | 5.0 | Richard Puddephatt | Systems Integration Testing (SIT) | -24.67 | Green | GREEN |  |  |  |  |  |
| 1298 | 1.4.3.5 | **Other Preparation** |  | 496d | 2022-10-31 A | 2024-09-23 |  | 59% | 201.3d | 2022-11-16 | 2024-09-23 | 484d | 2022-11-16 | 2024-09-23 | 32591d |  |  |  | N/A | N/A | 5.0 | N/A | Systems Integration Testing (SIT) |  |  |  |  |  |  |  |  |
| 1299 | 1.4.3.5.1 | **SI Other Preparation** |  | 66d | 2022-10-31 | 2023-01-30 |  |  |  | 2024-05-02 | 2024-08-01 | 66d | 2024-05-02 | 2024-08-01 | 33021d |  |  |  | N/A | N/A | 5.0 | N/A | Systems Integration Testing (SIT) |  |  |  |  |  |  |  |  |
| 1300 | 1.4.3.5.1.1 | Onboarding of UIT E2E Sandbox Participants to Test Management Tool for E2E Sandbox Testing Start (onboarding of participants will be ongoing hereafter) |  | 66d | 2022-10-31 | 2023-01-30 |  |  |  | 2024-05-02 | 2024-08-01 | 66d | 2024-05-02 | 2024-08-01 | 33021d | 393d |  |  | SI Test | PP | 5.0 | Stuart Scott | Systems Integration Testing (SIT) | -689.67 | Overdue Start | RED |  |  |  |  |  |
| 1301 | 1.4.3.5.2 | **Other Preparation (for Central Parties & E2E Sandbox Participants)** |  | 484d | 2022-11-16 A | 2024-09-23 |  | 67% | 161.92d | 2022-11-16 | 2024-09-23 | 484d | 2022-11-16 | 2024-09-23 | 32591d |  |  |  | N/A | N/A | 5.0 | N/A | Systems Integration Testing (SIT) |  |  |  |  |  |  |  |  |
| 1302 | 1.4.3.5.2.1 | Test Management Tool onboarding for E2E Sandbox Testing Start (onboarding will be ongoing hereafter) |  | 66d | 2024-05-02 | 2024-08-01 | 1300SS |  |  | 2024-05-02 | 2024-08-01 | 66d | 2024-05-02 | 2024-08-01 | 32628d |  | start no earlier than 2024-05-02 |  | PP | SI Test | 5.0 | Stuart Scott | Systems Integration Testing (SIT) | -140.67 | Overdue Start | RED |  |  |  |  |  |
| 1303 | 1.4.3.5.2.2 | Other Preparation (incl. test execution planning) |  | 484d | 2022-11-16 A | 2024-09-23 | 1239SS, 1245SS | 76% | 118d | 2022-11-16 | 2024-09-23 | 484d | 2022-11-16 | 2024-09-23 | 32591d |  |  |  | PP | SI Test | 5.0 | Stuart Scott | Systems Integration Testing (SIT) |  | Green | GREEN |  |  |  |  |  |
| 1304 | 1.4.3.6 | **UIT E2E Sandbox Test Readiness Report** |  | 114d | 2024-08-26 | 2025-01-31 |  |  |  | 2024-08-26 | 2025-01-31 | 114d | 2024-08-26 | 2024-10-25 | 32493d |  |  | -0 | N/A | N/A | 5.0 | N/A | Systems Integration Testing (SIT) |  |  |  |  |  |  |  |  |
| 1305 | 1.4.3.6.1 | **Central Parties E2E Sandbox Test Readiness Report** |  | 30d | 2024-08-26 | 2024-10-04 |  |  |  | 2024-08-26 | 2024-10-04 | 30d | 2024-08-26 | 2024-10-04 | 32562d |  |  |  | N/A | N/A | 5.0 | N/A | Systems Integration Testing (SIT) |  |  |  |  |  |  |  |  |
| 1306 | 1.4.3.6.1.1 | Develop draft Test Readiness Report and submit to Programme for assurance |  | 20d | 2024-08-26 | 2024-09-20 | 1290FF-10d |  |  | 2024-08-26 | 2024-09-20 | 20d | 2024-08-26 | 2024-09-20 | 32562d | 0d |  |  | PP | SI Test | 5.0 | Stuart Scott | Systems Integration Testing (SIT) | -24.67 | Green | GREEN |  |  |  |  |  |
| 1307 | 1.4.3.6.1.2 | Finalise Test Readiness Report and submit to Programme for assurance |  | 10d | 2024-09-23 | 2024-10-04 | 1290FF |  |  | 2024-09-23 | 2024-10-04 | 10d | 2024-09-23 | 2024-10-04 | 32562d | 0d |  |  | PP | SI Test | 5.0 | Stuart Scott | Systems Integration Testing (SIT) | 3.33 | Green | GREEN |  |  |  |  |  |
| 1308 | 1.4.3.6.2 | **SI E2E Sandbox Test Readiness Report** |  | 40d | 2024-08-26 | 2024-10-18 |  |  |  | 2024-08-26 | 2024-10-18 | 40d | 2024-08-26 | 2024-10-18 | 32562d |  |  |  | N/A | N/A | 5.0 | N/A | Systems Integration Testing (SIT) |  |  |  |  |  |  |  |  |
| 1309 | 1.4.3.6.2.1 | Assure Central Parties' E2E Sandbox Test Readiness Reports |  | 35d | 2024-08-26 | 2024-10-11 | 1306SS, 1307FF+5d |  |  | 2024-08-26 | 2024-10-11 | 35d | 2024-08-26 | 2024-10-11 | 32562d | 0d |  |  | SI Test | PP | 5.0 | Stuart Scott | Systems Integration Testing (SIT) | -24.67 | Green | GREEN |  |  |  |  |  |
| 1310 | 1.4.3.6.2.2 | Develop Overarching E2E Sandbox Test Readiness Report |  | 20d | 2024-09-16 | 2024-10-11 | 1309FF |  |  | 2024-09-16 | 2024-10-11 | 20d | 2024-09-16 | 2024-10-11 | 32562d | 0d |  |  | SI Test |  | 5.0 | Stuart Scott | Systems Integration Testing (SIT) | -3.67 | Green | GREEN |  |  |  |  |  |
| 1311 | 1.4.3.6.2.3 | Artefact review (via SITAG) and updates |  | 5d | 2024-10-14 | 2024-10-18 | 1310 |  |  | 2024-10-14 | 2024-10-18 | 5d | 2024-10-14 | 2024-10-18 | 32562d | 69d |  |  | SI Test | PP,IPA | 5.0 | Stuart Scott | Systems Integration Testing (SIT) | 24.33 | Green | GREEN |  |  |  |  |  |
| 1312 | 1.4.3.6.3 | UIT E2E Sandbox Preparation Complete | milestone | 0d | 2025-01-31 | 2025-01-31 | 1311FS+5d |  |  | 2025-01-31 | 2025-01-31 | 0d | 2024-10-25 | 2024-10-25 | 32493d | 1d | start no earlier than 2025-01-31 |  | SI Test | PP | 5.28 | Stuart Scott | Systems Integration Testing (SIT) | 133.33 | Green | GREEN | MHHS-ART154 MHHS-ART147 | T3-TE-0048 | QAG | T3 |  |
| 1313 | 1.4.4 | **SIT PPs E2E Sandbox Testing Execution** |  | 316d | 2025-02-07 | 2026-04-24 |  |  |  | 2024-11-04 | 2026-01-19 | 316d | 2024-11-04 | 2026-01-19 | 32177d |  |  | -0 | N/A | N/A | 5.0 | N/A | Systems Integration Testing (SIT) |  |  |  |  |  |  |  |  |
| 1314 | 1.4.4.1 | SIT PPs E2E Sandbox Testing Start | milestone | 0d | 2025-02-10 | 2025-02-10 | 1111FS+1d, 1312FS+5d |  |  | 2025-02-10 | 2025-02-10 | 0d | 2024-11-04 | 2024-11-04 | 32492d | 0d | start no earlier than 2025-02-10 |  | SI Test | PP | 5.28 | Stuart Scott | Systems Integration Testing (SIT) | 143.33 | Green | GREEN | MHHS-ART018 MHHS-ART154 MHHS-ART147 | T3-TE-0049 | QAG | T3 |  |
| 1315 | 1.4.4.2 | SIT PPs E2E Sandbox Testing Execution |  | 316d | 2025-02-07 | 2026-04-24 | 1314SS-1d |  |  | 2024-11-04 | 2026-01-19 | 316d | 2024-11-04 | 2026-01-19 | 32177d |  | start no earlier than 2024-11-04 |  | PP | SI Test | 5.0 | Stuart Scott | Systems Integration Testing (SIT) | 140.33 | Red | RED |  |  |  |  |  |
| 1316 | 1.4.5 | **System Integration Testing - Tier 1 Milestones** |  | 65d | 2025-08-13 | 2025-11-12 |  |  |  |  |  |  |  |  | 31778d |  |  |  |  |  |  |  |  | -685.67 | Overdue Start | RED |  |  |  |  |  |
| 1317 | 1.4.5.1 | Central systems ready for migrating MPANs (M10) | milestone | 0d | 2025-08-13 | 2025-08-13 | 1199FS+20d, 2360, 2120FS+2d, 2117, 2129, 2119, 2099, 2103 |  |  | 2025-03-07 | 2025-03-07 | 0d | 2025-03-07 | 2025-03-07 | 31778d | 0d | start no earlier than 2025-08-13 |  | CPT | CPT | 5.0 | CPT | Migration | 327.71 | Red | RED |  | T1-MI-1000 | PSG | T1 | Central systems ready for migrating MPANs |
| 1318 | 1.4.5.2 | Central systems ready for migrating MPANs (M10*) - Late Exit | milestone | 0d | 2025-11-12 | 2025-11-12 | 1317FS+65d |  |  | 2025-06-06 | 2025-06-06 | 0d | 2025-06-06 | 2025-06-06 | 32294d |  |  |  | CPT | CPT | 5.0 | CPT | Migration | 418.71 | Red | RED |  | T2-MI-1500 | PSG | T1 | Central systems ready for migrating MPANs |

Notes:
- 1312: 11/7/24: Date change approved at QAG on 20/6/24 from 25/10/24 to 31/1/25
- 1314: 11/7/24: Date change approved at QAG on 20/6/24 from 4/11/24 to 10/2/25
- 1317: 16/09/24 - Date updated to 13/08/25 in line with recalibration exercise.

| ID | WBS | Task | Type | Duration | Start | Finish | Predecessors | Complete | Remaining | Baseline start | Baseline finish | Baseline duration | Baseline 1 start | Baseline 1 finish | Total slack | Constraint | Baseline cost | Responsible | Involved | Update Version | MHHS Resource Name | MHHS Programme Phase | Sched Status | RAG | Task Status | Milestone ID | Text29 | Tier |
| --- | --- | --- | --- | --- | --- | --- | --- | --- | --- | --- | --- | --- | --- | --- | --- | --- | --- | --- | --- | --- | --- | --- | --- | --- | --- | --- | --- | --- |
| 1319 | 1.4.6 | **External Programme Dependency Management** |  | 174d | 2022-10-31 A | 2023-06-30 A |  | 100% |  | 2022-10-31 | 2023-06-30 | 174d | 2022-10-31 | 2023-06-30 |  |  |  | N/A | N/A | 5.0 | N/A | Systems Integration Testing (SIT) |  |  |  |  |  |  |
| 1320 | 1.4.6.1 | **BSC CP1558** |  | 173d | 2022-10-31 A | 2023-06-29 A |  | 100% |  | 2022-10-31 | 2023-06-29 | 173d | 2022-10-31 | 2023-06-29 |  |  |  | N/A | N/A | 5.0 | N/A | Systems Integration Testing (SIT) |  |  |  |  |  |  |
| 1321 | 1.4.6.1.1 | Monitor progress to implementation date |  | 173d | 2022-10-31 A | 2023-06-28 A |  | 100% |  | 2022-10-31 | 2023-06-28 | 173d | 2022-10-31 | 2023-06-28 |  |  |  | CPT | Code Bodies | 5.0 | Andrew Margan | Systems Integration Testing (SIT) | Complete | COMPLETE |  |  |  |  |
| 1322 | 1.4.6.1.2 | BSC CP1558 Implementation Date | milestone | 0d | 2023-06-29 A | 2023-06-29 A | 1321 | 100% |  | 2023-06-29 | 2023-06-29 | 0d | 2023-06-29 | 2023-06-29 |  | must start on 2023-06-29 |  | Code Bodies |  | 5.0 | Andrew Margan | Systems Integration Testing (SIT) | Complete | COMPLETE |  |  |  |  |
| 1323 | 1.4.6.2 | **REC CP R0032** |  | 174d | 2022-10-31 A | 2023-06-30 A |  | 100% |  | 2022-10-31 | 2023-06-30 | 174d | 2022-10-31 | 2023-06-30 |  |  |  | N/A | N/A | 5.0 | N/A | Systems Integration Testing (SIT) |  |  |  |  |  |  |
| 1324 | 1.4.6.2.1 | Monitor progress to implementation date |  | 174d | 2022-10-31 A | 2023-06-29 A |  | 100% |  | 2022-10-31 | 2023-06-29 | 174d | 2022-10-31 | 2023-06-29 |  |  |  | CPT | Code Bodies | 5.0 | Andrew Margan | Systems Integration Testing (SIT) | Complete | COMPLETE |  |  |  |  |
| 1325 | 1.4.6.2.2 | REC CP R0032 Implementation Date | milestone | 0d | 2023-06-30 A | 2023-06-30 A | 1324 | 100% |  | 2023-06-30 | 2023-06-30 | 0d | 2023-06-30 | 2023-06-30 |  | must start on 2023-06-30 |  | Code Bodies |  | 5.0 | Andrew Margan | Systems Integration Testing (SIT) | Complete | COMPLETE |  |  |  |  |
| 1326 | 1.4.6.3 | **REC CP R0044** |  | 173d | 2022-10-31 A | 2023-06-29 A |  | 100% |  | 2022-10-31 | 2023-06-29 | 173d | 2022-10-31 | 2023-06-29 |  |  |  | N/A | N/A | 5.0 | N/A | Systems Integration Testing (SIT) |  |  |  |  |  |  |
| 1327 | 1.4.6.3.1 | Monitor progress to implementation date |  | 173d | 2022-10-31 A | 2023-06-28 A |  | 100% |  | 2022-10-31 | 2023-06-28 | 173d | 2022-10-31 | 2023-06-28 |  |  |  | CPT | Code Bodies | 5.0 | Andrew Margan | Systems Integration Testing (SIT) | Complete | COMPLETE |  |  |  |  |
| 1328 | 1.4.6.3.2 | REC CP R0044 Implementation Date | milestone | 0d | 2023-06-29 A | 2023-06-29 A | 1327 | 100% |  | 2023-06-29 | 2023-06-29 | 0d | 2023-06-29 | 2023-06-29 |  | must start on 2023-06-29 |  | Code Bodies |  | 5.0 | Andrew Margan | Systems Integration Testing (SIT) | Complete | COMPLETE |  |  |  |  |
| 1329 | 1.5 | **NON SIT LDSO QUALIFICATION** |  | 453d? | 2023-11-07 A | 2025-07-31 |  | 74% | 115.97d? | 2023-11-07 | 2025-02-28 | 343d | 2024-01-29 | 2024-07-05 | 32368d |  | -0 | N/A | N/A |  | N/A | Systems Integration Testing (SIT) |  |  |  |  |  |  |
| 1330 | 1.5.1 | **Approach Planning** |  | 208d | 2023-11-07 A | 2024-08-22 A |  | 100% |  | 2023-11-07 | 2024-08-22 | 208d |  |  |  |  | -0 | N/A | N/A | 5.24 | N/A |  |  |  | -386.67 |  |  |  |
| 1331 | 1.5.1.1 | Develop Draft Testing Approach & Plan |  | 61d | 2023-11-07 A | 2024-01-30 A |  | 100% |  | 2023-11-07 | 2024-01-30 | 61d |  |  |  | start no earlier than 2023-11-07 |  | Non-SIT LDSO | Non-SIT LDSO | 5.24 | Ben Wickins |  | Complete | COMPLETE |  |  |  |  |
| 1332 | 1.5.1.2 | Draft Testing Approach & Plan Issued to LDSO for Review |  | 1d | 2024-01-31 A | 2024-01-31 A | 1331 | 100% |  | 2024-01-31 | 2024-01-31 | 1d |  |  |  |  |  | Non-SIT LDSO | Non-SIT LDSO | 5.24 | Ben Wickins |  | Complete | COMPLETE |  |  |  |  |
| 1333 | 1.5.1.3 | LDSO Review Complete |  | 10d | 2024-02-01 A | 2024-02-14 A | 1332 | 100% |  | 2024-02-01 | 2024-02-14 | 10d |  |  |  |  |  | LDSOs | Non-SIT LDSO | 5.24 | Ben Wickins |  | Complete | COMPLETE |  |  |  |  |
| 1334 | 1.5.1.4 | Update Following LDSO Review |  | 14d | 2024-02-15 A | 2024-03-05 A | 1333 | 100% |  | 2024-02-15 | 2024-03-05 | 14d |  |  |  |  |  | Non-SIT LDSO | Non-SIT LDSO, Code Bodies | 5.24 | Ben Wickins |  | Complete | COMPLETE |  |  |  |  |
| 1335 | 1.5.1.5 | QWG Review of Approach & Plan |  | 1d | 2024-03-12 A | 2024-03-12 A | 1334FS+4d | 100% |  | 2024-03-12 | 2024-03-12 | 1d |  |  |  |  |  | Non-SIT LDSO, PP | Non-SIT LDSO, Code Bodies | 5.24 | Ben Wickins |  | Complete | COMPLETE |  |  |  |  |
| 1336 | 1.5.1.6 | QAG Approval for Approach & Plan | milestone | 0d | 2024-03-21 A | 2024-03-21 A | 1335FS+7d | 100% |  | 2024-03-21 | 2024-03-21 | 0d |  |  |  |  |  | Code Bodies | Non-SIT LDSO,Code Bodies | 5.24 | Ben Wickins |  | Complete | COMPLETE |  |  |  |  |
| 1337 | 1.5.1.7 | Confirmation of Participants for Non-SIT LDSO Qualification Testing | milestone | 0d | 2024-03-21 A | 2024-03-21 A | 1336 | 100% |  | 2024-03-21 | 2024-03-21 | 0d | 2024-01-29 | 2024-01-29 |  |  |  | Non-SIT LDSO | SI Test, PP, IPA | 5.24 | Ben Wickins | Systems Integration Testing (SIT) | Complete | COMPLETE |  | T3-QU-0011 | QAG (Non-SIT LDSO) | T3 |
| 1338 | 1.5.1.8 | Update to Annex 1 for internal review (NF, Not Operational) |  | 15d | 2024-03-18 A | 2024-04-05 A | 924 | 100% |  | 2024-03-18 | 2024-04-05 | 15d |  |  |  |  |  | Non-SIT LDSO | PP, Code Bodies | 5.24 | Ben Wickins |  | Complete | COMPLETE |  |  |  |  |
| 1339 | 1.5.1.9 | Non-Functional, Operational & Migration Approaches Socialised with Code Bodies & LDSO & Feedback Actioned |  | 86d | 2024-04-08 A | 2024-08-05 A | 1338 | 100% |  | 2024-04-08 | 2024-08-05 | 86d |  |  |  |  |  | Non-SIT LDSO | PP, Code Bodies | 5.27 | Ben Wickins |  | Complete | COMPLETE |  |  |  |  |
| 1340 | 1.5.1.10 | QWG Review Operational, Non-Functional & Migration Annexes of Approach & Plan |  | 1d | 2024-08-13 A | 2024-08-13 A | 1339FS+5d | 100% |  | 2024-08-13 | 2024-08-13 | 1d |  |  |  |  |  | Non-SIT LDSO, PP | Non-SIT LDSO, PP, Code Bodies | 5.27 | Ben Wickins |  | Complete | COMPLETE |  |  |  |  |
| 1341 | 1.5.1.11 | Update Following QWG Review |  | 6d | 2024-08-14 A | 2024-08-21 A | 1340 | 100% |  | 2024-08-14 | 2024-08-21 | 6d |  |  |  |  |  | Non-SIT LDSO, PP | Non-SIT LDSO, Code Bodies | 5.27 | Ben Wickins |  | Complete | COMPLETE |  |  |  |  |
| 1342 | 1.5.1.12 | QAG Approval for Operational, Non-Functional & Migration Annexes of Approach & Plan | milestone | 0d | 2024-08-22 A | 2024-08-22 A | 1341FS+1d, 1337, 927 | 100% |  | 2024-08-22 | 2024-08-22 | 0d |  |  |  |  |  | Code Bodies | Non-SIT LDSO, Code Bodies | 5.29 | Ben Wickins |  | Complete | COMPLETE |  | T3-QU-0110 | QAG (Non-SIT LDSO) |  |

Notes:
- 1337: Have confirmed LDSOs going through SIT. We should receive notifications on non-SIT through January. Milestone holds to baseline. 13/5: date on cr47 was 18/4 but completed before CR approved
- 1338: Includes time to update Approach & Plan with updates / Guidance: 26/3: Linked to the development of SIT non functional plan
- 1342: Date missed because the Non-Functional Test Materials are not available for the July QAG and therefore to maintain our approach of approving plans in parallel with materials, the date has moved to the August QAG. There is no impact on the deliverability / Guidance: 18/7/24: Date change from 18/7/24 to 22/8/24 approved at QAG on 18/7/24 / Notes (2): of the overall project. Project to engage with Code Bodies and industry in sufficient time to review all required materials. To go to July QAG for baseline date change

| ID | WBS | Task | Type | Duration | Start | Finish | Predecessors | Complete | Remaining | Baseline start | Baseline finish | Baseline duration | Baseline 1 start | Baseline 1 finish | Total slack | Baseline cost | Responsible | Involved | Task Status | Update Version | MHHS Resource Name | Sched Status | RAG | Milestone ID | Text29 | MHHS Programme Phase | Tier |
| --- | --- | --- | --- | --- | --- | --- | --- | --- | --- | --- | --- | --- | --- | --- | --- | --- | --- | --- | --- | --- | --- | --- | --- | --- | --- | --- | --- |
| 1343 | 1.5.2 | **Functional Test Cases & Scenarios** |  | 58d | 2024-01-30 A | 2024-04-18 A |  | 100% |  | 2024-01-30 | 2024-04-18 | 58d |  |  |  | -0 | N/A | N/A | -385.67 | 5.24 | N/A |  |  |  |  |  |  |
| 1344 | 1.5.2.1 | **Functional Test Cases & Scenarios Batch 1** |  | 8d | 2024-01-30 A | 2024-02-08 A |  | 100% |  | 2024-01-30 | 2024-02-08 | 8d |  |  |  | -0 | N/A | N/A |  | 5.24 | N/A |  |  |  |  |  |  |
| 1345 | 1.5.2.1.1 | Walkthrough Test Cases & Scenarios Batch 1 with Code Bodies |  | 1d | 2024-01-30 A | 2024-01-30 A | 1331SS+60d | 100% |  | 2024-01-30 | 2024-01-30 | 1d |  |  |  |  | Non-SIT LDSO | Non-SIT LDSO, Code Bodies |  | 5.24 | Ben Wickins | Complete | COMPLETE |  |  |  |  |
| 1346 | 1.5.2.1.2 | Walkthrough Test Cases & Scenarios Batch 1 with LDSO |  | 1d | 2024-02-01 A | 2024-02-01 A | 1345 | 100% |  | 2024-02-01 | 2024-02-01 | 1d |  |  |  |  | LDSO, Non-SIT LDSO | LDSO, Non-SIT LDSO |  | 5.24 | Ben Wickins | Complete | COMPLETE |  |  |  |  |
| 1347 | 1.5.2.1.3 | Action Feedback on Test Cases & Scenarios Batch 1 |  | 5d | 2024-02-02 A | 2024-02-08 A | 1346 | 100% |  | 2024-02-02 | 2024-02-08 | 5d |  |  |  |  | Non-SIT LDSO | Non-SIT LDSO, LDSO , Code Bodies |  | 5.24 | Ben Wickins | Complete | COMPLETE |  |  |  |  |
| 1348 | 1.5.2.2 | **Functional Test Cases & Scenarios Batch 2** |  | 14d | 2024-02-20 A | 2024-03-08 A |  | 100% |  | 2024-02-20 | 2024-03-08 | 14d |  |  |  | -0 | N/A | N/A |  | 5.24 | N/A |  |  |  |  |  |  |
| 1349 | 1.5.2.2.1 | Walkthrough Test Cases & Scenarios Batch 2 with Code Bodies |  | 1d | 2024-02-20 A | 2024-02-20 A | 1331SS+75d | 100% |  | 2024-02-20 | 2024-02-20 | 1d |  |  |  |  | Non-SIT LDSO | Non-SIT LDSO, Code Bodies |  | 5.24 | Ben Wickins | Complete | COMPLETE |  |  |  |  |
| 1350 | 1.5.2.2.2 | Walkthrough Test Cases & Scenarios Batch 2 with LDSO |  | 1d | 2024-03-01 A | 2024-03-01 A | 1349FS+7d | 100% |  | 2024-03-01 | 2024-03-01 | 1d |  |  |  |  | LDSO, Non-SIT LDSO | LDSO, Non-SIT LDSO |  | 5.24 | Ben Wickins | Complete | COMPLETE |  |  |  |  |
| 1351 | 1.5.2.2.3 | Action Feedback on Test Cases & Scenarios Batch 2 |  | 5d | 2024-03-04 A | 2024-03-08 A | 1350 | 100% |  | 2024-03-04 | 2024-03-08 | 5d |  |  |  |  | Non-SIT LDSO | Non-SIT LDSO, LDSO , Code Bodies |  | 5.24 | Ben Wickins | Complete | COMPLETE |  |  |  |  |
| 1352 | 1.5.2.3 | **Functional Test Cases & Scenarios Batch 3** |  | 13d | 2024-03-20 A | 2024-04-05 A |  | 100% |  | 2024-03-20 | 2024-04-05 | 13d |  |  |  | -0 | N/A | N/A |  | 5.24 | N/A |  |  |  |  |  |  |
| 1353 | 1.5.2.3.1 | Walkthrough Test Cases & Scenarios Batch 3 with Code Bodies |  | 1d | 2024-03-20 A | 2024-03-20 A | 1331SS+96d | 100% |  | 2024-03-20 | 2024-03-20 | 1d |  |  |  |  | Non-SIT LDSO | Non-SIT LDSO, Code Bodies |  | 5.24 | Ben Wickins | Complete | COMPLETE |  |  |  |  |
| 1354 | 1.5.2.3.2 | Walkthrough Test Cases & Scenarios Batch 3 with LDSO |  | 1d | 2024-03-28 A | 2024-03-28 A | 1353FS+5d | 100% |  | 2024-03-28 | 2024-03-28 | 1d |  |  |  |  | LDSO, Non-SIT LDSO | LDSO, Non-SIT LDSO |  | 5.24 | Ben Wickins | Complete | COMPLETE |  |  |  |  |
| 1355 | 1.5.2.3.3 | Action Feedback on Test Cases & Scenarios Batch 3 |  | 6d | 2024-03-29 A | 2024-04-05 A | 1354 | 100% |  | 2024-03-29 | 2024-04-05 | 6d |  |  |  |  | Non-SIT LDSO | Non-SIT LDSO, LDSO , Code Bodies |  | 5.24 | Ben Wickins | Complete | COMPLETE |  |  |  |  |
| 1356 | 1.5.2.4 | Test Cases & Scenarios Batch 1-3 Discussion at QWG |  | 1d | 2024-04-09 A | 2024-04-09 A | 1347, 1351, 1355FS+1d | 100% |  | 2024-04-09 | 2024-04-09 | 1d |  |  |  |  | Non-SIT LDSO, PP | Non-SIT LDSO, Code Bodies |  | 5.24 | Ben Wickins | Complete | COMPLETE |  |  |  |  |
| 1357 | 1.5.2.5 | Action QWG Feedback on Test Cases & Scenarios Batch 1-3 |  | 2d | 2024-04-10 A | 2024-04-11 A | 1356 | 100% |  | 2024-04-10 | 2024-04-11 | 2d |  |  |  |  | Non-SIT LDSO | Non-SIT LDSO, Code Bodies |  | 5.24 | Ben Wickins | Complete | COMPLETE |  |  |  |  |
| 1358 | 1.5.2.6 | Batch 1-3 Non-SIT LDSO QT Functional Test Scenarios and Test Cases approved | milestone | 0d | 2024-04-18 A | 2024-04-18 A | 1357FS+5d | 100% |  | 2024-04-18 | 2024-04-18 | 0d |  |  |  |  | Code Bodies | Non-SIT LDSO, Code Bodies |  | 5.24 | Ben Wickins | Complete | COMPLETE | T3-QU-0069 | QAG (Non-SIT LDSO) |  |  |
| 1359 | 1.5.3 | **Test Execution Schedule** |  | 90d | 2024-04-19 A | 2024-08-22 |  | 99% | 0d | 2024-04-19 | 2024-08-22 | 90d | 2024-01-29 | 2024-04-26 | 32613d | -0 | N/A | N/A |  | 5.24 | N/A |  |  |  |  | Systems Integration Testing (SIT) |  |
| 1360 | 1.5.3.1 | Draft Test Delivery Schedule for Functional and Operational Testing |  | 20d | 2024-04-19 A | 2024-05-16 A | 1358 | 100% |  | 2024-04-19 | 2024-05-16 | 20d | 2024-01-29 | 2024-03-22 |  |  | Non-SIT LDSO | SI Test, PP, Non-SIT LDSO |  | 5.24 | Ben Wickins | Complete | COMPLETE |  |  | Systems Integration Testing (SIT) |  |
| 1361 | 1.5.3.2 | Socialise Test Delivery Schedule with Code Bodies & LDSO for Review & Action Feedback |  | 37d | 2024-05-17 A | 2024-07-08 A | 1360 | 100% |  | 2024-05-17 | 2024-07-08 | 37d |  |  |  |  | Non-SIT LDSO | LDSO, Code Bodies, Non-SIT LDSO |  | 5.24 | Ben Wickins | Complete | COMPLETE |  |  |  |  |
| 1362 | 1.5.3.3 | Agree Test Execution Timetable Format at QWG, Including Anonymisation Requirements |  | 1d | 2024-07-09 A | 2024-07-09 A | 1361 | 100% |  | 2024-07-09 | 2024-07-09 | 1d | 2024-03-25 | 2024-04-19 |  |  | Non-SIT LDSO, PP | Non-SIT LDSO, Code Bodies |  | 5.24 | Ben Wickins | Complete | COMPLETE |  |  | Systems Integration Testing (SIT) |  |
| 1363 | 1.5.3.4 | Action QWG Feedback |  | 3d | 2024-07-10 A | 2024-07-12 A | 1362 | 100% |  | 2024-07-10 | 2024-07-12 | 3d |  |  |  |  | Non-SIT LDSO, PP | Non-SIT LDSO, Code Bodies |  | 5.24 | Ben Wickins | Complete | COMPLETE |  |  |  |  |
| 1364 | 1.5.3.5 | Agree Test Execution Timetable Format at QAG, Including Anonymisation Requirements | milestone | 0d | 2024-07-18 A | 2024-07-18 A | 1363FS+4d | 100% |  | 2024-07-18 | 2024-07-18 | 0d |  |  |  |  | Code Bodies | Non-SIT LDSO, Code Bodies |  | 5.29 | Ben Wickins | Complete | COMPLETE | T3-QU-0111 | QAG (Non-SIT LDSO) |  |  |
| 1365 | 1.5.3.6 | Qualification Testing for Non-SIT LDSOs (Functional, Migration, NFT, Operational) Test Execution Schedule Complete | milestone | 0d | 2024-08-22 | 2024-08-22 | 1342 |  |  | 2024-08-22 | 2024-08-22 | 0d | 2024-04-26 | 2024-04-26 | 32613d |  | Non-SIT LDSO | Non-SIT LDSO, Code Bodies, PP | -28.29 | 5.29 | Ben Wickins | Overdue Start | RED | T3-QU-0008 | QAG (Non-SIT LDSO) | Systems Integration Testing (SIT) | T3 |
| 1366 | 1.5.4 | **Functional, Non-Functional, Operational & Migration Test Scenarios & Cases** |  | 110d | 2024-03-22 A | 2024-08-22 A |  | 100% |  | 2024-03-22 | 2024-08-22 | 110d |  |  |  | -0 | N/A | N/A |  | 5.24 | N/A |  |  |  |  |  |  |
| 1367 | 1.5.4.1 | Test Scenarios & Cases - Functional - Drafted, Reviewed |  | 14d | 2024-04-01 A | 2024-04-18 A | 1336 | 100% |  | 2024-04-01 | 2024-04-18 | 14d |  |  |  |  | Non-SIT LDSO | Non-SIT LDSO, LDSO, Code Bodies |  | 5.24 | Ben Wickins | Complete | COMPLETE |  |  |  |  |
| 1368 | 1.5.4.2 | Test Scenarios & Cases- Functional - Approved at QAG | milestone | 0d | 2024-04-18 A | 2024-04-18 A | 1367 | 100% |  | 2024-04-18 | 2024-04-18 | 0d |  |  |  |  | Non-SIT LDSO | Non-SIT LDSO, LDSO, Code Bodies |  | 5.24 | Ben Wickins | Complete | COMPLETE | T3-QU-0070 | QAG (Non-SIT LDSO) |  |  |
| 1369 | 1.5.4.3 | Test Scenarios & Cases - Non-Functional - Drafted, Reviewed |  | 110d | 2024-03-22 A | 2024-08-22 A | 1336, 944FF | 100% |  | 2024-03-22 | 2024-08-22 | 110d |  |  |  |  | Non-SIT LDSO | Non-SIT LDSO, LDSO, Code Bodies |  | 5.24 | Ben Wickins | Complete | COMPLETE |  |  |  |  |
| 1370 | 1.5.4.4 | Test Scenarios & Cases - Non-Functional - Approved at QAG | milestone | 0d | 2024-08-22 A | 2024-08-22 A | 1369 | 100% |  | 2024-08-22 | 2024-08-22 | 0d |  |  |  |  | Non-SIT LDSO | Non-SIT LDSO, LDSO, Code Bodies |  | 5.29 | Ben Wickins | Complete | COMPLETE | T3-QU-0071 | QAG (Non-SIT LDSO) |  |  |
| 1371 | 1.5.4.5 | Test Scenarios & Cases - Migration - Drafted, Reviewed |  | 45d | 2024-03-22 A | 2024-05-23 A | 1336 | 100% |  | 2024-03-22 | 2024-05-23 | 45d |  |  |  |  | Non-SIT LDSO | Non-SIT LDSO, LDSO, Code Bodies |  | 5.24 | Ben Wickins | Complete | COMPLETE |  |  |  |  |
| 1372 | 1.5.4.6 | Test Scenarios & Cases - Migration - Approved at QAG | milestone | 0d | 2024-05-23 A | 2024-05-23 A | 1371 | 100% |  | 2024-05-23 | 2024-05-23 | 0d |  |  |  |  | Non-SIT LDSO | Non-SIT LDSO, LDSO, Code Bodies |  | 5.24 | Ben Wickins | Complete | COMPLETE | T3-QU-0072 | QAG (Non-SIT LDSO) |  |  |
| 1373 | 1.5.4.7 | Test Scenarios & Cases - Operational - Drafted, Reviewed |  | 59d | 2024-06-03 A | 2024-08-22 A | 1336FS+51d | 100% |  | 2024-06-03 | 2024-08-22 | 59d |  |  |  |  | Non-SIT LDSO | Non-SIT LDSO, LDSO, Code Bodies |  | 5.24 | Ben Wickins | Complete | COMPLETE |  |  |  |  |
| 1374 | 1.5.4.8 | Test Scenarios & Cases - Operational - Approved at QAG | milestone | 0d | 2024-08-22 A | 2024-08-22 A | 1373, 944FF | 100% |  | 2024-08-22 | 2024-08-22 | 0d |  |  |  |  | Non-SIT LDSO | Non-SIT LDSO, LDSO, Code Bodies |  | 5.29 | Ben Wickins | Complete | COMPLETE | T3-QU-0073 | QAG (Non-SIT LDSO) |  |  |

Notes:
- 1358: 13/5: New milestone approved as part of cr47.
- 1365: Date not met because of re-planning activity around SIT Cycle 2 Maintenance window. Maintain dialog with Programme scenario planning from SIT. New forecast date will be defined after programme scenario CR is approved. / Guidance: 18/7/24: Date change from 15/8/24 to 22/8/24 approved at QAG on 18/7/24
- 1368: 13/5: New milestone approved as part of cr47.
- 1370: Date missed because Non-Functional Test Materials are not available for the July QAG. There is no impact the QT window and it will be approved at the August QAG. To go to July QAG for baseline date change / Guidance: 18/7/24: Date change from 18/7/24 to 22/8/24 approved at QAG on 18/7/24
- 1374: Date missed because Operational Test Materials are not available for the July QAG. There is no impact the QT window and it will be approved at the August QAG. To go to July QAG for baseline date change / Guidance: 18/7/24: Date change from 18/7/24 to 22/8/24 approved at QAG on 18/7/24

| ID | WBS | Task | Type | Duration | Start | Finish | Predecessors | Complete | Remaining | Baseline start | Baseline finish | Baseline duration | Total slack | Free slack | Constraint | Deadline | Baseline cost | Responsible | Involved | Task Status | Update Version | MHHS Resource Name | Sched Status | RAG | Milestone ID | Text29 |
| --- | --- | --- | --- | --- | --- | --- | --- | --- | --- | --- | --- | --- | --- | --- | --- | --- | --- | --- | --- | --- | --- | --- | --- | --- | --- | --- |
| 1375 | 1.5.5 | **Test Data** |  | 241d | 2024-01-22 A | 2024-12-23 |  | 61% | 94.1d | 2024-01-22 | 2024-12-23 | 241d | 32526d |  |  |  | -0 | N/A | N/A | -385.67 | 5.24 | N/A |  |  |  |  |
| 1376 | 1.5.5.1 | Test Data Plan Drafted & Reviewed |  | 89d | 2024-01-22 A | 2024-05-23 A | 1331 | 100% |  | 2024-01-22 | 2024-05-23 | 89d |  |  |  |  |  | Code Bodies | Non-SIT LDSO, Code Bodies |  | 5.24 | Ben Wickins | Complete | COMPLETE |  |  |
| 1377 | 1.5.5.2 | Non-SIT LDSO QT Test Data Plan Approved by QAG | milestone | 0d | 2024-05-23 A | 2024-05-23 A | 1376 | 100% |  | 2024-05-16 | 2024-05-16 | 0d |  |  |  |  |  | Code Bodies | Non-SIT LDSO, Code Bodies |  | 5.24 | Ben Wickins | Complete | COMPLETE | T3-QU-0074 | QAG (Non-SIT LDSO) |
| 1378 | 1.5.5.3 | Develop Test Data Matrices |  | 10d | 2024-05-24 A | 2024-06-06 A | 1377 | 100% |  | 2024-05-24 | 2024-06-06 | 10d |  |  |  |  |  | Non-SIT LDSO | Non-SIT LDSO |  | 5.24 | Ben Wickins | Complete | COMPLETE |  |  |
| 1379 | 1.5.5.4 | Test Data Cut |  | 17d | 2024-05-24 A | 2024-06-17 A | 1377 | 100% |  | 2024-05-24 | 2024-06-17 | 17d |  |  |  |  |  | PP, Non-SIT LDSO | PP, Non-SIT LDSO |  | 5.24 | Ben Wickins | Complete | COMPLETE |  |  |
| 1380 | 1.5.5.5 | Test Data Cut Complete | milestone | 0d | 2024-06-17 A | 2024-06-17 A | 1379, 1378 | 100% |  | 2024-06-17 | 2024-06-17 | 0d |  |  |  |  |  | PP, Non-SIT LDSO | PP, Non-SIT LDSO |  | 5.27 | Ben Wickins | Complete | COMPLETE | T3-QU-0112 | QAG (Non-SIT LDSO) |
| 1381 | 1.5.5.6 | Test Data Reviewed by the Programme |  | 39d | 2024-06-18 A | 2024-08-09 | 1380 | 95% | 2d | 2024-06-18 | 2024-08-09 | 39d | 32526d | 0d |  |  |  | Non-SIT LDSO | PP, Non-SIT LDSO |  | 5.24 | Ben Wickins | Overdue | RED |  |  |
| 1382 | 1.5.5.7 | Test Data Loaded |  | 17d | 2024-08-12 | 2024-09-03 | 1381 |  |  | 2024-08-12 | 2024-09-03 | 17d | 32526d | 0d |  |  |  | Non-SIT LDSO | PP, Non-SIT LDSO | -38.67 | 5.24 | Ben Wickins | Overdue Start | GREEN |  |  |
| 1383 | 1.5.5.8 | Test Data Signed Off | milestone | 0d | 2024-09-03 | 2024-09-03 | 1382 |  |  | 2024-09-03 | 2024-09-03 | 0d | 32526d | 0d |  |  |  | Non-SIT LDSO | PP, Non-SIT LDSO | -16.29 | 5.25 | Ben Wickins | Green | AMBER | T3-QU-0113 | QAG (Non-SIT LDSO) |
| 1384 | 1.5.5.9 | Test Execution Data Support |  | 79d | 2024-09-04 | 2024-12-23 | 1383 |  |  | 2024-09-04 | 2024-12-23 | 79d | 32526d |  |  |  |  | Non-SIT LDSO | Non-SIT LDSO | -15.67 | 5.24 | Ben Wickins | Green | GREEN |  |  |
| 1385 | 1.5.6 | **Tooling** |  | 148d | 2024-01-31 A | 2024-08-23 A |  | 100% |  | 2024-01-31 | 2024-08-23 | 148d |  |  |  |  | -0 | N/A | N/A | -385.67 | 5.24 | N/A |  |  |  |  |
| 1386 | 1.5.6.1 | Design Approach & Set-Up ADO Tool for Test & Defect Management Tool |  | 53d | 2024-01-31 A | 2024-04-12 A | 1331 | 100% |  | 2024-01-31 | 2024-04-12 | 53d |  |  |  |  |  | Non-SIT LDSO | Non-SIT LDSO, SI Test |  | 5.24 | Ben Wickins | Complete | COMPLETE |  |  |
| 1387 | 1.5.6.2 | Develop Training Requirements & Materials Inc. Day in the Life |  | 87d | 2024-04-15 A | 2024-08-13 A | 1386 | 100% |  | 2024-04-15 | 2024-08-13 | 87d |  |  |  |  |  | Non-SIT LDSO | Non-SIT LDSO, SI Test |  | 5.24 | Ben Wickins | Complete | COMPLETE |  |  |
| 1388 | 1.5.6.3 | ADO Launch complete |  | 1d | 2024-08-23 A | 2024-08-23 A | 1387, 1368, 1372, 1374 | 100% |  | 2024-08-23 | 2024-08-23 | 1d |  |  |  |  |  | Non-SIT LDSO | Non-SIT LDSO |  | 5.24 | Ben Wickins | Complete | COMPLETE |  |  |
| 1389 | 1.5.7 | **Pre-Integration Testing** |  | 218d | 2024-01-31 A | 2024-11-29 |  | 90% | 22.57d | 2024-01-31 | 2024-09-30 | 174d | 32542d |  |  |  | -0 | N/A | N/A | -385.67 | 5.24 | N/A |  |  |  |  |
| 1390 | 1.5.7.1 | PIT Guidance & Templates & Approach & Plans Developed |  | 106d | 2024-02-05 A | 2024-07-01 A | 1331FS+3d | 100% |  | 2024-02-05 | 2024-07-01 | 106d |  |  |  |  |  | Non-SIT LDSO | Non-SIT LDSO, LDSO |  | 5.27 | Ben Wickins | Complete | COMPLETE |  |  |
| 1391 | 1.5.7.2 | PIT Test Approach & Plan Deadline for Submission for Non-SIT LDSO​ QT | milestone | 0d | 2024-07-01 A | 2024-07-01 A | 1390 | 100% |  | 2024-07-01 | 2024-07-01 | 0d |  |  |  |  |  | Non-SIT LDSO | Non-SIT LDSO, LDSO |  | 5.28 | Ben Wickins | Complete | COMPLETE | T3-QU-0075 | QAG (Non-SIT LDSO) |
| 1392 | 1.5.7.3 | Develop and agree PIT Test Scenarios |  | 20d | 2024-07-02 A | 2024-07-29 A | 1391 | 100% |  | 2024-06-17 | 2024-07-29 | 31d |  |  |  |  |  | Non-SIT LDSO | Non-SIT LDSO, Code Bodies, LDSO |  | 5.24 | Ben Wickins | Complete | COMPLETE |  |  |
| 1393 | 1.5.7.4 | PIT Execution | manual | 45d | 2024-09-30 A | 2024-11-29 | 1392 | 16% | 38d | 2024-07-30 | 2024-09-30 | 45d |  |  | start no earlier than 2024-09-30 |  |  | Non-SIT LDSO | Non-SIT LDSO, LDSO |  | 5.24 | Ben Wickins | Red | RED |  |  |
| 1394 | 1.5.7.5 | Non-SIT LDSO Participants have submitted PIT Test Completion Report & evidence for QT Entry​ | milestone | 0d | 2024-11-29 | 2024-11-29 | 1393 |  |  | 2024-09-30 | 2024-09-30 | 0d | 32542d | 15d |  |  |  | Non-SIT LDSO | Non-SIT LDSO, LDSO | 70.71 | 5.24 | Ben Wickins | Red | RED | T3-QU-0076 | QAG (Non-SIT LDSO) |
| 1395 | 1.5.7.6 | **Placing Reliance - Code Body & LDSO Functional and Migration** |  | 147d | 2024-01-31 A | 2024-08-22 A |  | 100% |  | 2024-01-31 | 2024-08-22 | 147d |  |  |  |  | -0 | N/A | N/A | -100.67 | 5.24 | N/A |  |  |  |  |
| 1396 | 1.5.7.6.1 | Placing Reliance Submitted & Reviewed |  | 21d | 2024-01-31 A | 2024-02-28 A | 1331 | 100% |  | 2024-01-31 | 2024-02-28 | 21d |  |  |  | 2024-01-05 |  | LDSO, Non-SIT LDSO | LDSO, Non-SIT LDSO |  | 5.24 | Ben Wickins | Complete | COMPLETE |  |  |
| 1397 | 1.5.7.6.2 | Define & Agree QT Testing for Each LDSO |  | 22d | 2024-02-29 A | 2024-03-29 A | 1396 | 100% |  | 2024-02-29 | 2024-03-29 | 22d |  |  |  |  |  | Non-SIT LDSO | LDSO, Non-SIT LDSO |  | 5.24 | Ben Wickins | Complete | COMPLETE |  |  |
| 1398 | 1.5.7.6.3 | Develop Test Scope & Reliance Submissions |  | 20d | 2024-04-01 A | 2024-04-26 A | 1397 | 100% |  | 2024-04-01 | 2024-04-26 | 20d |  |  |  |  |  | Non-SIT LDSO | LDSO, Non-SIT LDSO, Code Bodies |  | 5.24 | Ben Wickins | Complete | COMPLETE |  |  |
| 1399 | 1.5.7.6.4 | Review and Consultation |  | 84d | 2024-04-29 A | 2024-08-22 A | 1398, 1342FF | 100% |  | 2024-04-29 | 2024-08-22 | 84d |  |  |  |  |  | Non-SIT LDSO | LDSO, Non-SIT LDSO |  | 5.27 | Ben Wickins | Complete | COMPLETE |  |  |

Notes:
- 1377: 13/5: New milestone approved as part of cr47. 13/5: Date change to line up with QAG
- 1380: 28/5 LDSO will complete test data cut between 3rd and 17th June
- 1383: Date will be missed due to QT execution replanning. Additionally, the Test Harness will be loaded with dummy suppliers MHHS (outgoing supplier) and MHHX (incoming supplier) for the Change of Supply Test Cases. For messages to flow between DIP, the LDSO systems and the Test Harness the LDSO systems need to be updated with these dummy suppliers. Test data is required from LDSOs by 13 Sept. New forecast date will be provided following conclusion of the scenario analysis / Notes (2): LDSOs will not be able to meet the standards of M10 and achieve Qualification. Through QWG and the LQTSG we have proposed and are discussing solutions with the LDSOs, with a view to achieving full test coverage for all
- 1391: 13/5: New milestone approved as part of cr47. 11/6: Missed date because additional time requested by PPs. 24/6: Approved at QAG on 20/6
- 1394: Date will be missed due to deferral of QT window. Forecast date to be updated from CR. Expected 16th Sept.

| ID | WBS | Task | Type | Duration | Start | Finish | Predecessors | Complete | Remaining | Baseline start | Baseline finish | Baseline duration | Baseline 1 start | Baseline 1 finish | Total slack | Free slack | Constraint | Baseline cost | Responsible | Involved | Task Status | Update Version | MHHS Resource Name | Sched Status | RAG | Milestone ID | Text29 | MHHS Programme Phase | Action | Tier |
| --- | --- | --- | --- | --- | --- | --- | --- | --- | --- | --- | --- | --- | --- | --- | --- | --- | --- | --- | --- | --- | --- | --- | --- | --- | --- | --- | --- | --- | --- | --- |
| 1400 | 1.5.7.7 | **Placing Reliance - Code Body & LDSO Non Functional and Operational** |  | 49d | 2024-06-17 A | 2024-08-22 A |  | 100% |  | 2024-06-17 | 2024-08-22 | 49d |  |  |  |  |  | -0 | N/A | N/A | -100.67 | 5.25 | N/A |  |  |  |  |  |  |  |
| 1401 | 1.5.7.7.1 | Placing Reliance Submitted & Reviewed |  | 32d | 2024-06-17 A | 2024-07-30 A | 1340FF-10d | 100% |  | 2024-06-17 | 2024-07-30 | 32d |  |  |  |  |  |  | LDSO, Non-SIT LDSO | LDSO, Non-SIT LDSO |  | 5.27 | Ben Wickins | Complete | COMPLETE |  |  |  |  |  |
| 1402 | 1.5.7.7.2 | Review and Consultation |  | 17d | 2024-07-31 A | 2024-08-22 A | 1401 | 100% |  | 2024-07-31 | 2024-08-22 | 17d |  |  |  |  |  |  | Non-SIT LDSO | LDSO, Non-SIT LDSO |  | 5.27 | Ben Wickins | Complete | COMPLETE |  |  |  |  |  |
| 1403 | 1.5.7.7.3 | PP Test Scope Presented at QAG | milestone | 0d | 2024-08-22 A | 2024-08-22 A | 1402, 1399 | 100% |  | 2024-08-22 | 2024-08-22 | 0d |  |  |  |  |  |  | Non-SIT LDSO | LDSO, Non-SIT LDSO |  | 5.29 | Ben Wickins | Complete | COMPLETE | T3-QU-0077 | QAG (Non-SIT LDSO) |  |  |  |
| 1404 | 1.5.8 | **LDSO Test Readiness Reporting** |  | 71d | 2024-04-19 A | 2024-07-26 A |  | 100% |  | 2024-04-19 | 2024-10-01 | 118d |  |  |  |  |  | -0 | N/A | N/A |  | 5.24 | N/A |  |  |  |  |  |  |  |
| 1405 | 1.5.8.1 | Interim Test Readiness Report & Plan Developed & Reviewed |  | 71d | 2024-04-19 A | 2024-07-26 A | 1358 | 100% |  | 2024-04-19 | 2024-07-26 | 71d |  |  |  |  |  |  | Non-SIT LDSO, LDSO | Non-SIT LDSO, LDSO |  | 5.24 | Ben Wickins | Complete | COMPLETE |  |  |  |  |  |
| 1406 | 1.5.8.2 | Test Plan Submission to MHHS Programme For Review | milestone | 0d | 2024-07-26 A | 2024-07-26 A | 1405 | 100% |  | 2024-07-26 | 2024-07-26 | 0d |  |  |  |  |  |  | LDSO | Non-SIT LDSO, LDSO |  | 5.30 | Ben Wickins | Complete | COMPLETE | T3-QU-0114 | QAG (Non-SIT LDSO) |  |  |  |
| 1407 | 1.5.9 | **Test Environment** |  | 111d | 2024-04-17 A | 2024-09-18 |  | 65% | 38.85d | 2024-04-17 | 2024-09-18 | 111d | 2024-01-29 | 2024-07-05 | 31862d |  |  | -0 | N/A | N/A |  | 5.24 | N/A |  |  |  |  | Systems Integration Testing (SIT) |  |  |
| 1408 | 1.5.9.1 | Define Test Harness Requirements and Sign-Off with SRO |  | 13d | 2024-04-17 A | 2024-05-03 A | 473 | 100% |  | 2024-04-17 | 2024-05-03 | 13d |  |  |  |  |  |  | Non-SIT LDSO | Non-SIT LDSO,SRO,Sims and Ems |  | 5.24 | Ben Wickins | Complete | COMPLETE |  |  |  |  |  |
| 1409 | 1.5.9.2 | Central System (DIP Env & Helix Test Harness) Test Environment DBT |  | 104d | 2024-04-17 A | 2024-09-09 | 473 | 73% | 28d | 2024-04-17 | 2024-08-22 | 92d |  |  | 31869d | 0d |  |  | LDSO | Non SIT-LDSO, LDSO |  | 5.24 | Ben Wickins | Red | RED |  |  |  |  |  |
| 1410 | 1.5.9.3 | Coordinate LDSO Env Preparation |  | 42d | 2024-07-12 A | 2024-09-09 | 1409FF | 33% | 28d | 2024-07-12 | 2024-08-22 | 30d |  |  | 31869d | 7d |  |  | Non-SIT LDSO | Non-SIT LDSO |  | 5.24 | Ben Wickins | Red | RED |  |  |  |  |  |
| 1411 | 1.5.9.4 | DIP available for Onboarding |  | 1d | 2024-08-01 A | 2024-08-01 A |  | 100% |  | 2024-08-01 | 2024-08-01 | 1d |  |  |  |  | start no earlier than 2024-08-01 |  | Test Env | Test Env, Non-SIT LDSO |  | 5.24 | Ben Wickins | Complete | COMPLETE |  |  |  | 11/3: Ask Simon B for the link |  |
| 1412 | 1.5.9.5 | Qualification Testing for Non-SIT LDSOs Participants' environments) Ready to start DIP onboarding (incl. certificates and security compliance) | milestone | 0d | 2024-08-05 A | 2024-08-05 A | 1411FS+2d | 100% |  | 2024-08-05 | 2024-08-05 | 0d | 2024-04-26 | 2024-04-26 |  |  |  |  | Non-SIT LDSO | Code Bodies, PP, IPA |  | 5.30 | Ben Wickins | Complete | COMPLETE | T3-QU-0009 | QAG (Non-SIT LDSO) | Systems Integration Testing (SIT) |  | T3 |
| 1413 | 1.5.9.6 | LDSO Test Environments Connection Confirmed to UIT Environment | milestone | 0d | 2024-09-18 | 2024-09-18 | 1412FS+32d, 1410 |  |  | 2024-09-18 | 2024-09-18 | 0d |  |  | 31862d | 77d |  |  | Non-SIT LDSO | Code Bodies, PP, IPA | -1.29 | 5.24 | Ben Wickins | Green | AMBER | T3-QU-0078 | QAG (Non-SIT LDSO) |  |  |  |
| 1414 | 1.5.10 | **Test Readiness** |  | 124d | 2024-07-02 A | 2024-12-20 |  | 22% | 97.22d | 2024-06-17 | 2024-09-30 | 76d |  |  | 32527d |  |  | -0 | N/A | N/A |  | 5.24 | N/A |  |  |  |  |  |  |  |
| 1415 | 1.5.10.1 | Preparation for Interim Test Readiness Report |  | 19d | 2024-07-02 A | 2024-07-26 A | 1391 | 100% |  | 2024-06-17 | 2024-07-26 | 30d |  |  |  |  |  |  | LDSO | LDSO, Non-SIT LDSO |  | 5.24 | Ben Wickins | Complete | COMPLETE |  |  |  |  |  |
| 1416 | 1.5.10.2 | Interim Test Readiness Report Submission to MHHS Programme for Review | milestone | 0d | 2024-07-26 A | 2024-07-26 A | 1415 | 100% |  | 2024-07-26 | 2024-07-26 | 0d |  |  |  |  |  |  | LDSO | Non-SIT LDSO, LDSO |  | 5.25 | Ben Wickins | Complete | COMPLETE | T3-QU-0116 | QAG (Non-SIT LDSO) |  |  |  |
| 1417 | 1.5.10.3 | LDSO Update Readiness Report & Final Assurance by Programme |  | 99d | 2024-07-29 A | 2024-12-12 | 1416 | 8% | 91d | 2024-07-29 | 2024-08-30 | 25d |  |  | 31785d | 0d |  |  | Non-SIT LDSO, LDSO | Non-SIT LDSO, LDSO |  | 5.24 | Ben Wickins | Red | RED |  |  |  |  |  |
| 1418 | 1.5.10.4 | Final Test Readiness Report Submitted to MHHS Programme |  | 1d | 2024-12-13 | 2024-12-13 | 1417 |  |  | 2024-09-02 | 2024-09-02 | 1d |  |  | 32527d | 0d |  |  | LDSO | Non-SIT LDSO, Code Bodies | 84.33 | 5.24 | Ben Wickins | Red | RED |  |  |  |  |  |
| 1419 | 1.5.10.5 | Final Programme Assurance of LDSO Test Readiness |  | 6d | 2024-12-13 | 2024-12-20 | 1417 |  |  | 2024-09-02 | 2024-09-30 | 21d |  |  | 31785d | 0d |  |  | Non-SIT LDSO | Non-SIT LDSO, LDSO | 84.33 | 5.24 | Ben Wickins | Red | RED |  |  |  |  |  |
| 1420 | 1.5.10.6 | Qualification Testing for Non-SIT LDSOs (Functional, Migration, NFT, Operational) Programme Test Readiness confirmed | milestone | 0d | 2024-12-20 | 2024-12-20 | 1418FS+5d, 1394, 1368, 1370, 1372, 1408 |  |  | 2024-09-30 | 2024-09-30 | 0d | 2024-07-05 | 2024-07-05 | 32527d |  |  |  | Non-SIT LDSO | SI Test, PP, Non-SIT LDSO | 91.71 | 5.24 | Ben Wickins | Red | RED | T3-QU-0007 | QAG (Non-SIT LDSO) | Systems Integration Testing (SIT) |  | T3 |
| 1421 | 1.5.10.7 | Qualification Testing for Non-SIT LDSOs (Functional, Migration, NFT, Operational) Test Readiness Confirmed (Final Test Readiness Review for LDSO) | milestone | 0d | 2024-12-20 | 2024-12-20 | 1417, 1419 |  |  | 2024-09-30 | 2024-09-30 | 0d | 2024-07-05 | 2024-07-05 | 31785d | 0d |  |  | LDSO | SI Test, PP, LDSO | 91.71 | 5.24 | Ben Wickins | Red | RED | T2-QU-0550 | QAG (Non-SIT LDSO) | Systems Integration Testing (SIT) |  |  |
| 1422 | 1.5.11 | **Test Window** |  | 94d? | 2025-01-06 | 2025-05-16 |  |  |  | 2024-10-01 | 2024-12-20 | 59d |  |  | 31785d |  |  | -0 | N/A | N/A | -527.67 | 5.24 | N/A |  |  |  |  |  |  |  |
| 1423 | 1.5.11.1 | **All Non-SIT LDSOs Qualification Testing** |  | 94d? | 2025-01-06 | 2025-05-16 | 1421, 1413 |  |  | 2024-10-01 | 2024-12-20 | 59d |  |  | 31785d | 10d |  |  | LDSO | Non-SIT LDSO,Code Bodies, LDSO | 118.33 | 5.24 | Ben Wickins | Red | RED |  |  |  |  |  |
| 1424 | 1.5.11.1.1 | Non-SIT LDSO QT Test Execution Starts | milestone | 0d | 2025-01-06 | 2025-01-06 | 1421FS+11d |  |  | 2024-10-01 | 2024-10-01 | 0d |  |  | 31785d | 0d | start no earlier than 2024-11-01 |  | Non-SIT LDSO | Non-SIT LDSO, LDSO, Code Bodies | 108.71 | 5.25 | Ben Wickins | Red | RED | T3-QU-0115 | QAG (Non-SIT LDSO) |  |  |  |
| 1425 | 1.5.11.1.2 | Non-SIT LDSO QT - Migration Testing |  | 20d? | 2025-01-06 | 2025-01-31 | 1424FS-1d |  |  |  |  |  |  |  | 31785d | 0d |  |  |  |  | 108.33 | 6.0 |  | No BL | GREEN |  |  |  |  |  |
| 1426 | 1.5.11.1.3 | Non-SIT LDSO QT - Functional Testing |  | 40d? | 2025-02-03 | 2025-03-28 | 1425 |  |  |  |  |  |  |  | 31785d | 0d |  |  |  |  | 136.33 | 6.0 |  | No BL | GREEN |  |  |  |  |  |
| 1427 | 1.5.11.1.4 | Non-SIT LDSO QT - Operational Testing |  | 15d? | 2025-03-31 | 2025-04-18 | 1426 |  |  |  |  |  |  |  | 31795d | 0d |  |  |  |  | 192.33 | 6.0 |  | No BL | GREEN |  |  |  |  |  |
| 1428 | 1.5.11.1.5 | Non-SIT LDSO QT - Non-Functional Testing |  | 15d? | 2025-04-21 | 2025-05-09 | 1427 |  |  |  |  |  |  |  | 31795d |  |  |  |  |  | 213.33 | 6.0 |  | No BL | GREEN |  |  |  |  |  |
| 1429 | 1.5.11.1.6 | Non-SIT LDSO QT - Regression Testing |  | 30d? | 2025-03-31 | 2025-05-09 | 1426 |  |  |  |  |  |  |  | 31785d | 4d |  |  |  |  | 192.33 | 6.0 |  | No BL | GREEN |  |  |  |  |  |
| 1430 | 1.5.11.1.7 | Qualification Testing for Non-SIT LDSOs (Functional, Migration, NFT, Operational) 1 End | milestone | 0d | 2025-05-16 | 2025-05-16 | 1429 |  |  | 2025-01-24 | 2025-01-24 | 0d |  |  | 31781d | 0d | start no earlier than 2025-05-16 |  |  |  | 238.33 | 5.24 |  | Red | RED | T3-QU-0010 |  |  |  |  |

Notes:
- 1403: Date missed because of the update to Supplier and Agent Approach and Plan. Finalised Test Scope will be presented for approval as part of the assurance around the update to Annex 1. To go to July QAG for baseline date change / Guidance: 18/7/24: Date change from 18/7/24 to 22/8/24 approved at QAG on 18/7/24
- 1406: 9 of the expected 12 Interim Test Readiness Reports and are following up with those who are outstanding. These are not a direct requirement of onboarding but a gap analysis ahead of test start
- 1413: At risk because of DIP env availability for the test harness. (Issue no: I186). Issue will be avoided if start of QT window is delayed
- 1416: 9 of the expected 12 Interim Test Readiness Reports have been received and are following up with those who are outstanding. These are not a direct requirement of onboarding but a gap analysis ahead of test start
- 1420: Date will be missed due to deferral of QT window. Forecast date to be updated from CR. Expected 16th Sept.
- 1421: 13/5: New milestone approved as part of cr47.
- 1423: 17/09/24: New milestones added and date shifted in line with programme recalibration.
- 1424: Date will be no earlier than 1st November. Forecast date to be updated from CR. Expected 16th Sept.
- 1430: 13/5: No change as part of cr47

| ID | WBS | Task | Type | Duration | Start | Finish | Predecessors | Complete | Remaining | Baseline start | Baseline finish | Baseline duration | Baseline 1 start | Baseline 1 finish | Total slack | Free slack | Constraint | Baseline cost | Responsible | Involved | Update Version | MHHS Resource Name | Task Status | Sched Status | RAG | Milestone ID | Text29 | MHHS Programme Phase |
| --- | --- | --- | --- | --- | --- | --- | --- | --- | --- | --- | --- | --- | --- | --- | --- | --- | --- | --- | --- | --- | --- | --- | --- | --- | --- | --- | --- | --- |
| 1431 | 1.5.12 | **Test Result Assurance** |  | 29d | 2025-04-21 | 2025-05-29 |  |  |  | 2024-11-04 | 2025-01-24 | 60d |  |  | 31781d |  |  | -0 | N/A | N/A | 5.24 | N/A |  |  |  |  |  |  |
| 1432 | 1.5.12.1 | LDSOs Develop & Submit Test Report (QT Test Completion Report) |  | 19d | 2025-04-21 | 2025-05-16 | 1430FF |  |  | 2024-11-04 | 2024-11-28 | 19d |  |  | 31781d | 0d |  |  | LDSO | Non-SIT LDSO, LDSO | 5.24 | Ben Wickins | 213.33 | Red | RED |  |  |  |
| 1433 | 1.5.12.2 | Test Reports Reviewed By MHHS & Code Bodies & Finalised |  | 10d | 2025-05-16 | 2025-05-29 | 1432 |  |  | 2024-11-29 | 2024-12-20 | 16d |  |  | 31781d | 0d |  |  | Non-SIT LDSO | Non-SIT LDSO, Code Bodies | 5.24 | Ben Wickins | 238.33 | Red | RED |  |  |  |
| 1434 | 1.5.12.3 | Non-SIT LDSOs submission deadline for their QT Test Completion Report to MHHS Programme | milestone | 0d | 2025-05-29 | 2025-05-29 | 1433, 1423 |  |  | 2024-12-20 | 2024-12-20 | 0d |  |  | 31781d | 0d |  |  | Non-SIT LDSO | Non-SIT LDSO | 5.24 | Ben Wickins | 251.71 | Red | RED | T3-QU-0079 | QAG (Non-SIT LDSO) |  |
| 1435 | 1.5.13 | **Non-SIT LDSO Qualification Closure** |  | 45d | 2025-05-30 | 2025-07-31 |  |  |  | 2024-12-23 | 2025-02-28 | 49d |  |  | 31781d |  |  | -0 | N/A | N/A | 5.24 | N/A |  |  |  |  |  |  |
| 1436 | 1.5.13.1 | Non-SIT LDSO Qualification Learned Captured |  | 15d | 2025-05-30 | 2025-06-19 | 1434 |  |  | 2024-12-23 | 2025-01-10 | 15d |  |  | 31781d | 0d |  |  | Non-SIT LDSO | Non-SIT LDSO | 5.24 | Ben Wickins | 252.33 | Red | RED |  |  |  |
| 1437 | 1.5.13.2 | Non-SIT LDSO Qualification Closure Down |  | 5d | 2025-06-20 | 2025-06-26 | 1436 |  |  | 2025-01-13 | 2025-01-17 | 5d |  |  | 31781d | 0d |  |  | Non-SIT LDSO | Non-SIT LDSO | 5.24 | Ben Wickins | 273.33 | Red | RED |  |  |  |
| 1438 | 1.5.13.3 | BSC PAB & REC Manager approval of Qualification for Non-SIT LDSOs (Start of Migration for Qualification Participants) | milestone | 0d | 2025-07-31 | 2025-07-31 | 1527, 1528, 1437FS+25d |  |  | 2025-02-28 | 2025-02-28 | 0d |  |  | 31781d | 0d |  |  | Non-SIT LDSO | Non-SIT LDSO | 5.24 | Ben Wickins | 314.71 | Red | RED | T2-QU-0500 | QAG (Non-SIT LDSO) |  |
| 1439 | 1.6 | **S & A QUALIFICATION** |  | 806d | 2023-11-07 A | 2026-12-08 |  | 33% | 537.64d | 2023-11-07 | 2026-02-27 | 603d | 2024-01-29 | 2024-07-05 | 32015d |  |  | -0 | N/A | N/A |  | N/A | -461.67 |  |  |  |  | Systems Integration Testing (SIT) |
| 1440 | 1.6.1 | **MHHS Qualification - Qualification Deliverables** |  | 349d | 2023-11-07 A | 2025-03-07 |  | 85% | 52.62d | 2023-11-07 | 2025-03-07 | 349d |  |  | 32472d |  |  | -0 | N/A | N/A | 5.24 | N/A | -131.67 |  |  |  |  |  |
| 1441 | 1.6.1.1 | **BSC & REC Assessment Criteria** |  | 213d | 2023-11-07 A | 2024-08-29 |  | 99% | 0d | 2023-11-07 | 2024-08-29 | 212d |  |  | 32608d |  |  | -0 | N/A | N/A | 5.24 | N/A | -131.67 |  |  |  |  |  |
| 1442 | 1.6.1.1.1 | Draft BSC Assessment Criteria (Functional) |  | 21d | 2023-11-07 A | 2023-12-05 A |  | 100% |  | 2023-11-07 | 2023-12-05 | 21d |  |  |  |  | finish no earlier than 2023-12-05 |  | Code Bodies | Code Bodies | 5.24 | Laura Kennedy |  | Complete | COMPLETE |  |  |  |
| 1443 | 1.6.1.1.2 | BSC PAB Review |  | 1d | 2023-12-14 A | 2023-12-14 A |  | 100% |  | 2023-12-14 | 2023-12-14 | 1d |  |  |  |  | start no earlier than 2023-12-14 |  | Code Bodies | Code Bodies | 5.24 | Laura Kennedy |  | Complete | COMPLETE |  |  |  |
| 1444 | 1.6.1.1.3 | Update BSC Assessment Criteria (Functional, Non-Functional, Migration) |  | 30d | 2024-02-07 A | 2024-03-19 A |  | 100% |  | 2024-02-07 | 2024-03-19 | 30d |  |  |  |  | finish no earlier than 2024-03-19 |  | Code Bodies | Code Bodies | 5.24 | Laura Kennedy |  | Complete | COMPLETE |  |  |  |
| 1445 | 1.6.1.1.4 | REC & BSC PAB Approval |  | 3d | 2024-03-26 A | 2024-03-28 A |  | 100% |  | 2024-03-26 | 2024-03-28 | 3d |  |  |  |  | start no earlier than 2024-03-28 |  | Code Bodies | Code Bodies | 5.24 | Laura Kennedy |  | Complete | COMPLETE |  |  |  |
| 1446 | 1.6.1.1.5 | Update BSC Assessment Criteria (Functional, Non-Functional, Migration, Operational) |  | 20d | 2024-07-24 A | 2024-08-20 A |  | 100% |  | 2024-07-24 | 2024-08-20 | 20d |  |  |  |  |  |  | Code Bodies | Code Bodies | 5.24 | Laura Kennedy |  | Complete | COMPLETE |  |  |  |
| 1447 | 1.6.1.1.6 | Assessment Criteria (Functional, Non-Functional, Migration, Operational) Approved by REC PAB and BSC PAB | milestone | 0d | 2024-08-29 | 2024-08-29 | 1446FS+7d |  |  | 2024-08-29 | 2024-08-29 | 0d |  |  | 32584d | 86d |  |  | Code Bodies | Code Bodies | 5.25 | Laura Kennedy | -21.29 | yellow | GREEN | T3-QU-0080 | QAG |  |
| 1448 | 1.6.1.2 | **Qualification Approach and Plan** |  | 194d | 2023-12-04 A | 2024-08-29 |  | 97% | 5.75d | 2023-12-04 | 2024-08-29 | 194d |  |  | 32608d |  |  | -0 | N/A | N/A | 5.24 | N/A | -131.67 |  |  |  |  |  |
| 1449 | 1.6.1.2.1 | **Qualification Approach and Plan v2** |  | 84d | 2023-12-04 A | 2024-03-28 A |  | 100% |  | 2023-12-04 | 2024-03-28 | 84d |  |  |  |  |  | -0 | N/A | N/A | 5.24 | N/A | -131.67 |  |  |  |  |  |
| 1450 | 1.6.1.2.1.1 | Draft Qualification Approach and Plan v2 |  | 30d | 2023-12-04 A | 2024-01-12 A |  | 100% |  | 2023-12-04 | 2024-01-12 | 30d |  |  |  |  | finish no earlier than 2024-01-12 |  | Code Bodies | Code Bodies | 5.24 | Laura Kennedy |  | Complete | COMPLETE |  |  |  |
| 1451 | 1.6.1.2.1.2 | Internal Review (Code Bodies and MHHSP) for Qualification Approach and Plan V2 |  | 10d | 2024-01-15 A | 2024-01-26 A | 1450 | 100% |  | 2024-01-15 | 2024-01-26 | 10d |  |  |  |  | finish no earlier than 2024-01-26 |  | Code Bodies, SI Team, SRO | Code Bodies, SI Team, SRO | 5.24 | Laura Kennedy |  | Complete | COMPLETE |  |  |  |
| 1452 | 1.6.1.2.1.3 | Industry consultation for Qualification Approach and Plan v2 |  | 11d | 2024-01-31 A | 2024-02-14 A | 1451 | 100% |  | 2024-01-31 | 2024-02-14 | 11d |  |  |  |  | start no earlier than 2024-01-31 |  | Participants | Participants | 5.24 | Laura Kennedy |  | Complete | COMPLETE |  |  |  |
| 1453 | 1.6.1.2.1.4 | Update Qualification Approach and Plan v2 post industry consultation |  | 10d | 2024-02-15 A | 2024-02-28 A | 1452 | 100% |  | 2024-02-15 | 2024-02-28 | 10d |  |  |  |  |  |  | Code Bodies | Code Bodies | 5.24 | Laura Kennedy |  | Complete | COMPLETE |  |  |  |
| 1454 | 1.6.1.2.1.5 | QWG Endorsement of Qualification Approach and Plan v2 |  | 1d | 2024-03-12 A | 2024-03-12 A |  | 100% |  | 2024-03-12 | 2024-03-12 | 1d |  |  |  |  | start no earlier than 2024-03-12 |  | Code Bodies | Code Bodies | 5.24 | Laura Kennedy |  | Complete | COMPLETE |  |  |  |
| 1455 | 1.6.1.2.1.6 | QAG Approval of Qualification Approach and Plan v2 |  | 1d | 2024-03-21 A | 2024-03-21 A |  | 100% |  | 2024-03-21 | 2024-03-21 | 1d |  |  |  |  | start no earlier than 2024-03-21 |  | Code Bodies | Code Bodies | 5.24 | Laura Kennedy |  | Complete | COMPLETE |  |  |  |
| 1456 | 1.6.1.2.1.7 | BSC and REC PAB Approval of Qualification Approach and Plan v2 |  | 3d | 2024-03-26 A | 2024-03-28 A |  | 100% |  | 2024-03-26 | 2024-03-28 | 3d |  |  |  |  | finish no earlier than 2024-03-28 |  | Code Bodies | Code Bodies | 5.24 | Laura Kennedy |  | Complete | COMPLETE |  |  |  |
| 1457 | 1.6.1.2.1.8 | Functional Testing elements of Qualification Approach & Plan v2 approvement by REC PAB and BSC PAB | milestone | 0d | 2024-03-28 A | 2024-03-28 A | 1456 | 100% |  | 2024-03-28 | 2024-03-28 | 0d |  |  |  |  |  |  | Code Bodies | Code Bodies | 5.24 | Laura Kennedy |  | Complete | COMPLETE | T3-QU-0063 | QAG |  |
| 1458 | 1.6.1.2.1.9 | Migration Testing elements of Qualification Approach & Plan v2 appoved by REC PAB and BSC PAB | milestone | 0d | 2024-03-28 A | 2024-03-28 A | 1456 | 100% |  | 2024-03-28 | 2024-03-28 | 0d |  |  |  |  |  |  | Code Bodies | Code Bodies | 5.24 | Laura Kennedy |  | Complete | COMPLETE | T3-QU-0064 | QAG |  |

Notes:
- 1434: 13/5: New milestone approved as part of cr47.
- 1438: 13/5: name changed as part of cr47.
- 1447: Date missed because additional changes were identified during test scope analysis, therefore assessment criteria needs further updates (a version was approved in June). On course to be approved at next PAB.

| ID | WBS | Task | Type | Duration | Start | Finish | Predecessors | Complete | Remaining | Baseline start | Baseline finish | Baseline duration | Total slack | Free slack | Constraint | Baseline cost | Responsible | Involved | Task Status | Update Version | MHHS Resource Name | Sched Status | RAG | Milestone ID | Text29 |
| --- | --- | --- | --- | --- | --- | --- | --- | --- | --- | --- | --- | --- | --- | --- | --- | --- | --- | --- | --- | --- | --- | --- | --- | --- | --- |
| 1459 | 1.6.1.2.2 | **Qualification Approach and Plan v3** |  | 84d | 2024-05-06 A | 2024-08-29 |  | 94% | 4.87d | 2024-05-06 | 2024-08-29 | 84d | 32608d |  |  | -0 | N/A | N/A | -133.67 | 5.24 | N/A |  |  |  |  |
| 1460 | 1.6.1.2.2.1 | Draft Qualification Approach and Plan v3 |  | 35d | 2024-05-06 A | 2024-06-21 A | 927 | 100% |  | 2024-05-06 | 2024-06-21 | 35d |  |  | finish no earlier than 2024-05-17 |  | Code Bodies | Code Bodies |  | 5.27 | Laura Kennedy | Complete | COMPLETE |  |  |
| 1461 | 1.6.1.2.2.2 | Internal Review (Code Bodies and MHHSP) of Qualification Approach and Plan v3 |  | 10d | 2024-06-24 A | 2024-07-05 A | 1460 | 100% |  | 2024-06-24 | 2024-07-05 | 10d |  |  |  |  | Code Bodies, SI Team, SRO | Code Bodies, SI Team, SRO |  | 5.27 | Laura Kennedy | Complete | COMPLETE |  |  |
| 1462 | 1.6.1.2.2.3 | Industry consultation for Qualification Approach and Plan v3 |  | 10d | 2024-07-08 A | 2024-07-19 A | 1461 | 100% |  | 2024-07-08 | 2024-07-19 | 10d |  |  |  |  | Participants | Participants |  | 5.27 | Laura Kennedy | Complete | COMPLETE |  |  |
| 1463 | 1.6.1.2.2.4 | Update Qualification Approach and Plan v3 Post-Consultation |  | 10d | 2024-07-22 A | 2024-08-02 A | 1462 | 100% |  | 2024-07-22 | 2024-08-02 | 10d |  |  |  |  | Code Bodies | Code Bodies |  | 5.27 | Laura Kennedy | Complete | COMPLETE |  |  |
| 1464 | 1.6.1.2.2.5 | QWG Endorsement of Qualification Approach and Plan v3 |  | 1d | 2024-08-13 | 2024-08-13 | 1463FS+6d |  |  | 2024-08-13 | 2024-08-13 | 1d | 32608d | 0d |  |  | Code Bodies | Code Bodies | -37.67 | 5.27 | Laura Kennedy | Overdue Start | RED |  |  |
| 1465 | 1.6.1.2.2.6 | QAG Approval of Qualification Approach and Plan v3 | milestone | 0d | 2024-08-22 | 2024-08-22 | 1464FS+7d |  |  | 2024-08-22 | 2024-08-22 | 0d | 32608d | 0d |  |  | Code Bodies | Code Bodies | -28.29 | 5.27 | Laura Kennedy | Overdue Start | RED | T3-QU-0081 | QAG |
| 1466 | 1.6.1.2.2.7 | BSC and REC PAB Approval of Qualification Approach and Plan v3 |  | 3d | 2024-08-27 | 2024-08-29 | 1465FS+2d |  |  | 2024-08-27 | 2024-08-29 | 3d | 32608d |  |  |  | Code Bodies | Code Bodies | -23.67 | 5.27 | Laura Kennedy | Green | GREEN |  |  |
| 1467 | 1.6.1.2.2.8 | Non-Functional Testing elements of Qualification Approach and Plan v3 approved by REC PAB and BSC PAB | milestone | 0d | 2024-08-29 A | 2024-08-29 A | 1466 | 100% |  | 2024-08-29 | 2024-08-29 | 0d |  |  |  |  | Code Bodies | Code Bodies |  | 5.27 | Laura Kennedy | Complete | COMPLETE | T3-QU-0065 | QAG |
| 1468 | 1.6.1.3 | **Qualification Assessment Document** |  | 316d | 2023-12-22 A | 2025-03-07 |  | 76% | 75.48d | 2023-12-22 | 2025-03-07 | 316d | 32472d |  |  | -0 | N/A | N/A | -131.67 | 5.24 | N/A |  |  |  |  |
| 1469 | 1.6.1.3.1 | **Qualification Assessment Document v1** |  | 70d | 2023-12-22 A | 2024-03-28 A |  | 100% |  | 2023-12-22 | 2024-03-28 | 70d |  |  |  | -0 | N/A | N/A | -131.67 | 5.24 | N/A |  |  |  |  |
| 1470 | 1.6.1.3.1.1 | Draft Qualification Assessment Document v1 |  | 30d | 2023-12-22 A | 2024-02-01 A |  | 100% |  | 2023-12-22 | 2024-02-01 | 30d |  |  | finish no earlier than 2024-02-01 |  | Code Bodies | Code Bodies |  | 5.24 | Laura Kennedy | Complete | COMPLETE |  |  |
| 1471 | 1.6.1.3.1.2 | Internal Review (Code Bodies and MHHSP) of Qualification Assessment Document v1 |  | 10d | 2024-02-01 A | 2024-02-14 A |  | 100% |  | 2024-02-01 | 2024-02-14 | 10d |  |  | finish no earlier than 2024-02-14 |  | Code Bodies, SI Team, SRO | Code Bodies, SI Team, SRO |  | 5.24 | Laura Kennedy | Complete | COMPLETE |  |  |
| 1472 | 1.6.1.3.1.3 | Industry consultation for Qualification Assessment Document v1 |  | 11d | 2024-02-16 A | 2024-03-01 A |  | 100% |  | 2024-02-16 | 2024-03-01 | 11d |  |  | start no earlier than 2024-02-16 |  | Participants | Participants |  | 5.24 | Laura Kennedy | Complete | COMPLETE |  |  |
| 1473 | 1.6.1.3.1.4 | Update Post-Consultation for Qualification Assessment Document v1 |  | 10d | 2024-03-04 A | 2024-03-15 A | 1472 | 100% |  | 2024-03-04 | 2024-03-15 | 10d |  |  |  |  | Code Bodies | Code Bodies |  | 5.24 | Laura Kennedy | Complete | COMPLETE |  |  |
| 1474 | 1.6.1.3.1.5 | BSC and REC PAB Approval of Qualification Assessment Document v1 |  | 3d | 2024-03-26 A | 2024-03-28 A |  | 100% |  | 2024-03-26 | 2024-03-28 | 3d |  |  | start no earlier than 2024-03-26 |  | Code Bodies | Code Bodies |  | 5.24 | Laura Kennedy | Complete | COMPLETE |  |  |
| 1475 | 1.6.1.3.1.6 | Qualification Assessment Document v1 approved by REC PAB and BSC PAB | milestone | 0d | 2024-03-28 A | 2024-03-28 A | 1474 | 100% |  | 2024-03-28 | 2024-03-28 | 0d |  |  |  |  | Code Bodies | Code Bodies |  | 5.24 | Laura Kennedy | Complete | COMPLETE | T3-QU-0066 | QAG |
| 1476 | 1.6.1.3.2 | **Qualification Assessment Document v3** |  | 110d | 2024-03-29 A | 2024-08-29 |  | 94% | 6.96d | 2024-03-29 | 2024-08-29 | 110d | 32608d |  |  | -0 | N/A | N/A | -131.67 | 5.24 | N/A |  |  |  |  |
| 1477 | 1.6.1.3.2.1 | Draft Qualification Assessment Document V1.1 |  | 26d | 2024-03-29 A | 2024-05-03 A | 1475 | 100% |  | 2024-03-29 | 2024-05-03 | 26d |  |  |  |  |  |  |  | 5.24 | Laura Kennedy | Complete | COMPLETE |  |  |
| 1478 | 1.6.1.3.2.2 | Industry Consultation for Qualification Assessment Document V1.1 |  | 12d | 2024-05-06 A | 2024-05-21 A | 1477 | 100% |  | 2024-05-06 | 2024-05-21 | 12d |  |  |  |  |  |  |  | 5.24 | Laura Kennedy | Complete | COMPLETE |  |  |
| 1479 | 1.6.1.3.2.3 | Draft Qualification Assessment Document v3 |  | 6d | 2024-06-14 A | 2024-06-21 A | 1002, 1478 | 100% |  | 2024-06-14 | 2024-06-21 | 6d |  |  |  |  | Code Bodies | Code Bodies |  | 5.24 | Laura Kennedy | Complete | COMPLETE |  |  |
| 1480 | 1.6.1.3.2.4 | Internal Review (Code Bodies and MHHSP) of Qualification Assessment Document v3 |  | 10d | 2024-06-24 A | 2024-07-05 A | 1479 | 100% |  | 2024-06-24 | 2024-07-05 | 10d |  |  |  |  | Code Bodies, SI Team, SRO | Code Bodies, SI Team, SRO |  | 5.24 | Laura Kennedy | Complete | COMPLETE |  |  |
| 1481 | 1.6.1.3.2.5 | Industry consultation for Qualification Assessment Document v3 |  | 10d | 2024-07-08 A | 2024-07-19 A | 1480 | 100% |  | 2024-07-08 | 2024-07-19 | 10d |  |  |  |  | Participants | Participants |  | 5.24 | Laura Kennedy | Complete | COMPLETE |  |  |
| 1482 | 1.6.1.3.2.6 | Update Post-Consultation for Qualification Assessment Document v3 |  | 10d | 2024-07-22 A | 2024-08-02 A | 1481 | 100% |  | 2024-07-22 | 2024-08-02 | 10d |  |  |  |  | Code Bodies | Code Bodies |  | 5.24 | Laura Kennedy | Complete | COMPLETE |  |  |
| 1483 | 1.6.1.3.2.7 | QWG Endorsement of Qualification Assessment Document v3 |  | 1d | 2024-08-13 | 2024-08-13 | 1482FS+6d |  |  | 2024-08-13 | 2024-08-13 | 1d | 32608d | 0d |  |  | Code Bodies | Code Bodies | -37.67 | 5.24 | Laura Kennedy | Overdue Start | RED |  |  |
| 1484 | 1.6.1.3.2.8 | QAG Endorsement of Qualification Assessment Document v3 |  | 1d | 2024-08-22 | 2024-08-22 | 1483FS+6d |  |  | 2024-08-22 | 2024-08-22 | 1d | 32608d | 0d |  |  | Code Bodies | Code Bodies | -28.67 | 5.25 | Laura Kennedy | Overdue Start | RED | T3-QU-0083 | QAG |
| 1485 | 1.6.1.3.2.9 | BSC and REC PAB Approval of Qualification Assessment Document v3 |  | 3d | 2024-08-27 | 2024-08-29 | 1484FS+2d |  |  | 2024-08-27 | 2024-08-29 | 3d | 32608d |  |  |  | Code Bodies | Code Bodies | -23.67 | 5.24 | Laura Kennedy | Green | GREEN |  |  |
| 1486 | 1.6.1.3.2.10 | Qualification Assessment Document v3 approved by REC PAB and BSC PAB | milestone | 0d | 2024-08-29 A | 2024-08-29 A | 1485 | 100% |  | 2024-08-29 | 2024-08-29 | 0d |  |  |  |  | Code Bodies | Code Bodies |  | 5.24 | Laura Kennedy | Complete | COMPLETE | T3-QU-0067 | QAG |

Notes:
- 1465: 28/5: Late because of delay to approval of SIT Non Functional approach. Re-planned to align to v4. To go to June QAG for baseline date change. 24/6: Approved at QAG on 20/6
- 1467: 28/5: Late because of delay to approval of SIT Non Functional approach. Re-planned to align to v4. 24/6: Approved at QAG on 20/6

| ID | WBS | Task | Type | Duration | Start | Finish | Predecessors | Complete | Remaining | Baseline start | Baseline finish | Baseline duration | Baseline 1 start | Baseline 1 finish | Total slack | Free slack | Constraint | Baseline cost | Responsible | Involved | Task Status | Update Version | MHHS Resource Name | Sched Status | RAG | Milestone ID | Text29 | MHHS Programme Phase |
| --- | --- | --- | --- | --- | --- | --- | --- | --- | --- | --- | --- | --- | --- | --- | --- | --- | --- | --- | --- | --- | --- | --- | --- | --- | --- | --- | --- | --- |
| 1487 | 1.6.1.3.3 | **Qualification Assessment Document Portal** |  | 285d | 2024-02-05 A | 2025-03-07 |  | 59% | 116.67d | 2024-02-05 | 2025-03-07 | 285d |  |  | 32376d |  |  | -0 | N/A | N/A | -131.67 | 5.24 | N/A |  |  |  |  |  |
| 1488 | 1.6.1.3.3.1 | Design Completion |  | 30d | 2024-02-05 A | 2024-03-15 A |  | 100% |  | 2024-02-05 | 2024-03-15 | 30d |  |  |  |  | finish no earlier than 2024-03-15 |  | QAD Portal Dev Team | QAD Portal Dev Team |  | 5.24 | Laura Kennedy | Complete | COMPLETE |  |  |  |
| 1489 | 1.6.1.3.3.2 | Qualification Assessment Document Portal Build |  | 30d | 2024-03-18 A | 2024-04-26 A | 1488 | 100% |  | 2024-03-18 | 2024-04-26 | 30d |  |  |  |  |  |  | QAD Portal Dev Team | QAD Portal Dev Team |  | 5.24 | Laura Kennedy | Complete | COMPLETE |  |  |  |
| 1490 | 1.6.1.3.3.3 | Qualification Assessment Document Internal Testing |  | 20d | 2024-04-29 A | 2024-05-24 A | 1489 | 100% |  | 2024-04-29 | 2024-05-24 | 20d |  |  |  |  |  |  | QAD Portal Dev Team. Code Bodies | QAD Portal Dev Team. Code Bodies |  | 5.24 | Laura Kennedy | Complete | COMPLETE |  |  |  |
| 1491 | 1.6.1.3.3.4 | Qualification Assessment Document Portal Training and Onboarding Material Creation |  | 20d | 2024-05-27 A | 2024-06-21 A | 1490 | 100% |  | 2024-05-27 | 2024-06-21 | 20d |  |  |  |  |  |  | QAD Portal Dev Team | QAD Portal Dev Team |  | 5.24 | Laura Kennedy | Complete | COMPLETE |  |  |  |
| 1492 | 1.6.1.3.3.5 | Qualification Assessment Document Portal Webinar (Date TBC) |  | 1d | 2024-06-18 A | 2024-06-18 A |  | 100% |  | 2024-06-11 | 2024-06-11 | 1d |  |  |  |  | start no earlier than 2024-06-18 |  | QAD Portal Dev Team | QAD Portal Dev Team |  | 5.24 | Laura Kennedy | Complete | COMPLETE |  |  |  |
| 1493 | 1.6.1.3.3.6 | SIT Participant QAD Application Creation in Portal |  | 10d | 2024-08-12 | 2024-08-23 | 1491FS+35d |  |  | 2024-08-12 | 2024-08-23 | 10d |  |  | 32516d | 0d |  |  | Code Bodies | Code Bodies | -38.67 | 5.24 | Laura Kennedy | Overdue Start | RED |  |  |  |
| 1494 | 1.6.1.3.3.7 | Non-SIT LDSO Participant QAD Application Creation in Portal |  | 10d | 2024-08-12 | 2024-08-23 | 1491FS+35d |  |  | 2024-08-12 | 2024-08-23 | 10d |  |  | 32516d | 0d |  |  | Code Bodies | Code Bodies | -38.67 | 5.24 | Laura Kennedy | Overdue Start | RED |  |  |  |
| 1495 | 1.6.1.3.3.8 | QT Wave 1 Participant QAD Application Creation in Portal |  | 10d | 2024-09-23 | 2024-10-04 | 1491FS+65d |  |  | 2024-09-23 | 2024-10-04 | 10d |  |  | 31785d | 0d |  |  | Code Bodies | Code Bodies | 3.33 | 5.24 | Laura Kennedy | Green | GREEN |  |  |  |
| 1496 | 1.6.1.3.3.9 | QT Wave 2 Participant QAD Application Creation in Portal |  | 10d | 2024-10-28 | 2024-11-08 | 1491FS+90d |  |  | 2024-10-28 | 2024-11-08 | 10d |  |  | 31783d | 0d |  |  | Code Bodies | Code Bodies | 38.33 | 5.27 | Laura Kennedy | Green | GREEN |  |  |  |
| 1497 | 1.6.1.3.3.10 | QT Wave 3 Participant QAD Application Creation in Portal |  | 10d | 2024-12-30 | 2025-01-10 | 1491FS+135d |  |  | 2024-12-30 | 2025-01-10 | 10d |  |  | 31784d | 0d |  |  | Code Bodies | Code Bodies | 101.33 | 5.27 | Laura Kennedy | Green | GREEN |  |  |  |
| 1498 | 1.6.1.3.3.11 | QT Wave 4 Participant QAD Application Creation in Portal |  | 10d | 2025-02-24 | 2025-03-07 | 1491FS+175d |  |  | 2025-02-24 | 2025-03-07 | 10d |  |  | 31784d | 0d |  |  | Code Bodies | Code Bodies | 157.33 | 5.27 | Laura Kennedy | Green | GREEN |  |  |  |
| 1499 | 1.6.1.3.3.12 | Update to Qualification Assessment Document Portal post QAD V3 |  | 10d | 2024-08-30 | 2024-09-12 | 1486 |  |  | 2024-08-30 | 2024-09-12 | 10d |  |  | 31949d | 0d |  |  | QAD Portal Dev Team | QAD Portal Dev Team | -20.67 | 5.24 | Laura Kennedy | Green | GREEN |  |  |  |
| 1500 | 1.6.1.3.3.13 | Update to Qualification Assessment Document Portal post QAD V3 Complete | milestone | 0d | 2024-09-12 | 2024-09-12 | 1499 |  |  | 2024-09-12 | 2024-09-12 | 0d |  |  | 31949d | 146d |  |  | QAD Portal Dev Team | QAD Portal Dev Team | -7.29 | 5.25 | Laura Kennedy | Green | GREEN | T3-QU-0084 | QAG |  |
| 1501 | 1.6.2 | **MHHS Qualification - SIT Participants** |  | 225d | 2025-01-06 | 2025-11-14 |  |  |  | 2024-09-02 | 2025-05-30 | 194d | 2024-01-29 | 2024-07-05 | 31803d |  |  | -0 | N/A | N/A | -133.67 | 5.24 | N/A |  |  |  |  | Systems Integration Testing (SIT) |
| 1502 | 1.6.2.1 | Initial QAD Submission Window opens | milestone | 0d | 2025-01-06 | 2025-01-06 | 1493FS+96d |  |  | 2024-09-02 | 2024-09-02 | 0d |  |  | 32516d |  | start no earlier than 2025-01-06 |  | Participants | Participants | 108.71 | 5.24 | Laura Kennedy | Red | RED |  |  |  |
| 1503 | 1.6.2.2 | SIT Participants submit Initial QAD |  | 29d | 2025-01-06 | 2025-02-13 |  |  |  | 2024-09-02 | 2024-10-10 | 29d |  |  | 31803d | 0d | start no earlier than 2025-01-06 |  | Participants | Participants | 108.33 | 5.24 | Laura Kennedy | Red | RED |  |  |  |
| 1504 | 1.6.2.3 | Code Bodies review Initial QAD |  | 36d | 2025-02-14 | 2025-04-04 | 1503 |  |  | 2024-10-11 | 2024-11-29 | 36d |  |  | 31803d | 0d |  |  | Code Bodies | Code Bodies | 147.33 | 5.24 | Laura Kennedy | Red | RED |  |  |  |
| 1505 | 1.6.2.4 | Completion of Code Bodies review of Initial QAD | milestone | 0d | 2025-04-04 | 2025-04-04 | 1504 |  |  | 2024-11-29 | 2024-11-29 | 0d |  |  | 31803d | 0d |  |  | Code Bodies | Code Bodies | 196.71 | 5.24 | Laura Kennedy | Red | RED |  |  |  |
| 1506 | 1.6.2.5 | **MHHS Qualification - SIT MVC Participants** |  | 84d | 2025-04-04 | 2025-07-31 |  |  |  | 2024-11-29 | 2025-02-28 | 64d |  |  | 31778d |  |  |  | N/A | N/A | -154.67 | 5.24 | N/A |  |  |  |  |  |
| 1507 | 1.6.2.5.1 | Final QAD Submission Window (MVC) opens | milestone | 0d | 2025-04-04 | 2025-04-04 | 1504, 1500, 1505 |  |  | 2024-11-29 | 2024-11-29 | 0d |  |  | 31803d | 0d |  |  | Participants | Participants | 196.71 | 5.24 | Laura Kennedy | Red | RED |  |  |  |
| 1508 | 1.6.2.5.2 | SIT MVC Participants submit Final QAD |  | 26d | 2025-04-07 | 2025-05-12 | 1507 |  |  | 2024-12-02 | 2025-01-06 | 26d |  |  | 31803d | 0d |  |  | Participants | Participants | 199.33 | 5.24 | Laura Kennedy | Red | RED |  |  |  |
| 1509 | 1.6.2.5.3 | Completion of Code Bodies review of Final QAD (MVC) |  | 19d | 2025-05-13 | 2025-06-06 | 1508, 1190FF |  |  | 2025-01-07 | 2025-01-31 | 19d |  |  | 31803d | 25d |  |  | Code Bodies | Code Bodies | 235.33 | 5.24 | Laura Kennedy | Red | RED |  |  |  |
| 1510 | 1.6.2.5.4 | QAD Sign Off Deadline (MVC) | milestone | 0d | 2025-07-11 | 2025-07-11 | 1199, 1509 |  |  | 2025-02-07 | 2025-02-07 | 1d |  |  | 31778d | 0d |  |  | Participants | Participants | 294.71 | 5.24 | Laura Kennedy | Red | RED |  |  |  |
| 1511 | 1.6.2.5.5 | REC Code Manager / BSC PAB Approval of Qualification (MVC) | milestone | 0d | 2025-07-31 | 2025-07-31 | 1510FS+14d |  |  | 2025-02-28 | 2025-02-28 | 0d |  |  | 31778d | 0d |  |  | Code Bodies | Code Bodies | 314.71 | 5.25 | Laura Kennedy | Red | RED | T3-QU-0085 | QAG |  |

Notes:
- 1511: 6/8/24: Date at risk from scenario planning activity

| ID | WBS | Task | Type | Duration | Start | Finish | Predecessors | Complete | Remaining | Baseline start | Baseline finish | Baseline duration | Total slack | Free slack | Constraint | Baseline cost | Responsible | Involved | Task Status | Update Version | MHHS Resource Name | Sched Status | RAG | Milestone ID | Text29 |
| --- | --- | --- | --- | --- | --- | --- | --- | --- | --- | --- | --- | --- | --- | --- | --- | --- | --- | --- | --- | --- | --- | --- | --- | --- | --- |
| 1512 | 1.6.2.6 | **MHHS Qualification - SIT Non-MVC Participants** |  | 159d | 2025-04-07 | 2025-11-14 |  |  |  | 2024-12-02 | 2025-05-30 | 129d | 31794d |  |  |  | N/A | N/A | -154.67 | 5.24 | N/A |  |  |  |  |
| 1513 | 1.6.2.6.1 | Final QAD Submission Window (Non-MVC) opens | milestone | 0d | 2025-04-07 | 2025-04-07 | 1505FS+1d |  |  | 2024-12-02 | 2024-12-02 | 0d | 31824d | 0d |  |  | Participants | Participants | 199.71 | 5.24 | Laura Kennedy | Red | RED |  |  |
| 1514 | 1.6.2.6.2 | SIT Non-MVC Participants submit Final QAD |  | 85d | 2025-04-08 | 2025-08-04 | 1513SS |  |  | 2024-12-02 | 2025-03-31 | 86d | 31824d | 0d |  |  | Participants | Participants | 200.33 | 5.24 | Laura Kennedy | Red | RED |  |  |
| 1515 | 1.6.2.6.3 | Completion of Code Bodies review of Final QAD (Non-MVC) |  | 19d | 2025-08-05 | 2025-08-29 | 1514 |  |  | 2025-04-01 | 2025-04-25 | 19d | 31824d | 30d |  |  | Code Bodies | Code Bodies | 319.33 | 5.24 | Laura Kennedy | Red | RED |  |  |
| 1516 | 1.6.2.6.4 | QAD Sign Off Deadline (Non-MVC) |  | 1d | 2025-10-17 | 2025-10-17 | 1515FS+4d, 1221 |  |  | 2025-05-02 | 2025-05-02 | 1d | 31794d | 0d |  |  | Participants | Participants | 392.33 | 5.24 | Laura Kennedy | Red | RED |  |  |
| 1517 | 1.6.2.6.5 | REC Code Manager / BSC PAB Approval of Qualification (Non-MVC) | milestone | 0d | 2025-11-14 | 2025-11-14 | 1516FS+20d |  |  | 2025-05-30 | 2025-05-30 | 0d | 31794d | 0d |  |  | Code Bodies | Code Bodies | 420.71 | 5.25 | Laura Kennedy | Red | RED | T3-QU-0086 | QAG |
| 1518 | 1.6.3 | **MHHS Qualification - Non-SIT LDSO** |  | 149d | 2025-01-06 | 2025-07-31 |  |  |  | 2024-09-02 | 2025-02-07 | 115d | 31815d |  |  | -0 | N/A | N/A | -133.67 | 5.24 | N/A |  |  |  |  |
| 1519 | 1.6.3.1 | Initial QAD Submission window opens | milestone | 0d | 2025-01-06 | 2025-01-06 | 1494FS+96d |  |  | 2024-09-02 | 2024-09-02 | 0d | 32516d |  |  |  | Participants | Participants | 108.71 | 5.24 | Laura Kennedy | Red | RED |  |  |
| 1520 | 1.6.3.2 | Non-SIT LDSO Participants submit initial QAD |  | 29d | 2025-01-06 | 2025-02-13 |  |  |  | 2024-09-02 | 2024-10-10 | 29d | 31815d | 0d | start no earlier than 2025-01-06 |  | Participants | Participants | 108.33 | 5.24 | Laura Kennedy | Red | RED |  |  |
| 1521 | 1.6.3.3 | Non-SIT LDSO QT Participants have submitted their initial QAD | milestone | 0d | 2025-02-13 | 2025-02-13 | 1520 |  |  | 2024-10-10 | 2024-10-10 | 0d | 31815d | 0d |  |  | Participants | Participants | 146.71 | 5.25 | Laura Kennedy | Red | RED | T3-QU-0087 | QAG |
| 1522 | 1.6.3.4 | Code Bodies review of Non-SIT LDSO participants Initial QAD |  | 36d | 2025-02-14 | 2025-04-04 | 1521 |  |  | 2024-10-11 | 2024-11-29 | 36d | 31815d | 0d |  |  | Code Bodies | Code Bodies | 147.33 | 5.24 | Laura Kennedy | Red | RED |  |  |
| 1523 | 1.6.3.5 | Completion of Code Bodies review of Initial QAD | milestone | 0d | 2025-04-04 | 2025-04-04 | 1522 |  |  | 2024-11-29 | 2024-11-29 | 0d | 31815d | 0d |  |  | Code Bodies | Code Bodies | 196.71 | 5.24 | Laura Kennedy | Red | RED |  |  |
| 1524 | 1.6.3.6 | Final QAD Submission window opens | milestone | 0d | 2025-04-07 | 2025-04-07 | 1523FS+1d |  |  | 2024-12-02 | 2024-12-02 | 0d | 31815d | 9d |  |  | Participants | Participants | 199.71 | 5.24 | Laura Kennedy | Red | RED |  |  |
| 1525 | 1.6.3.7 | Non-SIT LDSO Participants submit Final QAD |  | 25d | 2025-04-21 | 2025-05-23 | 1432SS, 1524SS |  |  | 2024-12-02 | 2025-01-06 | 26d | 31806d | 0d |  |  | Participants | Participants | 213.33 | 5.24 | Laura Kennedy | Red | RED |  |  |
| 1526 | 1.6.3.8 | Non-SIT LDSO QT Participants have submitted their final QAD | milestone | 0d | 2025-05-23 | 2025-05-23 | 1525 |  |  | 2025-01-06 | 2025-01-06 | 0d | 31806d | 0d |  |  | Participants | Participants | 245.71 | 5.25 | Laura Kennedy | Red | RED | T3-QU-0088 | QAG |
| 1527 | 1.6.3.9 | Completion of Code Bodies review of the Final QAD |  | 19d | 2025-05-26 | 2025-06-19 | 1526 |  |  | 2025-01-07 | 2025-01-31 | 19d | 31806d | 11d |  |  | Code Bodies | Code Bodies | 248.33 | 5.24 | Laura Kennedy | Red | RED |  |  |
| 1528 | 1.6.3.10 | QAD Sign Off Deadline (Non-SIT LDSOs) | milestone | 0d | 2025-07-11 | 2025-07-11 | 1527FS+5d, 1199 |  |  | 2025-02-07 | 2025-02-07 | 1d | 31795d | 0d |  |  | Participants | Participants | 294.71 | 5.24 | Laura Kennedy | Red | RED |  |  |
| 1529 | 1.6.3.11 | BSC PAB & REC Manager approval of Qualification for Non-SIT LDSOs (Start of Migration for Qualification Participants) | milestone | 0d | 2025-07-31 | 2025-07-31 | 1430, 1528FS+14d |  |  | 2025-02-28 | 2025-02-28 | 0d | 32368d |  |  |  | Non-SIT LDSO | Non-SIT LDSO | 314.71 | 5.24 | Ben Wickins | Red | RED | T2-QU-0500 | QAG (Non-SIT LDSO) |
| 1530 | 1.6.4 | **MHHS Qualification - Qualification Waves** |  | 777d | 2023-12-18 A | 2026-12-08 |  | 29% | 553.75d | 2023-12-18 | 2026-02-27 | 574d | 32015d |  |  | -0 | N/A | N/A | -131.67 | 5.24 | N/A |  |  |  |  |
| 1531 | 1.6.4.1 | **Qualification Wave Prep** |  | 538d | 2023-12-18 A | 2026-01-07 |  | 53% | 250.77d | 2023-12-18 | 2025-07-31 | 424d | 32254d |  |  | -0 | N/A | N/A | -131.67 | 5.24 | N/A |  |  |  |  |
| 1532 | 1.6.4.1.1 | **Non-SIT Supplier and Agent Test Approach and Plan** |  | 119d | 2023-12-18 A | 2024-05-30 A |  | 100% |  | 2023-12-18 | 2024-05-30 | 118d |  |  |  | -0 | N/A | N/A | -133.67 | 5.24 | N/A |  |  |  |  |
| 1533 | 1.6.4.1.1.1 | Draft Non-SIT S&A Test Approach and Plan |  | 50d | 2023-12-18 A | 2024-02-23 A |  | 100% |  | 2023-12-18 | 2024-02-23 | 50d |  |  | finish no earlier than 2024-02-23 |  | Non-SIT S&A QT Test Team | Non-SIT S&A QT Test Team |  | 5.24 | Laura Kennedy | Complete | COMPLETE |  |  |
| 1534 | 1.6.4.1.1.2 | Internal Review of Non-SIT S&A Test Approach and Plan (Code Bodies and MHHSP) |  | 10d | 2024-02-26 A | 2024-03-08 A | 1533 | 100% |  | 2024-02-26 | 2024-03-08 | 10d |  |  |  |  | Code Bodies, SI Team, SRO | Code Bodies, SI Team, SRO |  | 5.24 | Laura Kennedy | Complete | COMPLETE |  |  |
| 1535 | 1.6.4.1.1.3 | Issue Non-SIT S&A Test Approach and Plan for Consultation |  | 15d | 2024-03-18 A | 2024-04-05 A | 1534 | 100% |  | 2024-03-18 | 2024-04-05 | 15d |  |  | start no earlier than 2024-03-18 |  | Participants | Participants |  | 5.24 | Laura Kennedy | Complete | COMPLETE |  |  |
| 1536 | 1.6.4.1.1.4 | Update Non-SIT S&A Test Approach and Plan Post-Consultation |  | 10d | 2024-04-08 A | 2024-04-19 A | 1535 | 100% |  | 2024-04-08 | 2024-04-19 | 10d |  |  |  |  | Non-SIT S&A QT Test Team | Non-SIT S&A QT Test Team |  | 5.24 | Laura Kennedy | Complete | COMPLETE |  |  |
| 1537 | 1.6.4.1.1.5 | QWG Endorsement of Non-SIT S&A Test Approach and Plan |  | 1d | 2024-05-14 A | 2024-05-14 A |  | 100% |  | 2024-05-14 | 2024-05-14 | 1d |  |  | finish no earlier than 2024-05-14 |  | Non-SIT S&A QT Test Team | Non-SIT S&A QT Test Team |  | 5.24 | Laura Kennedy | Complete | COMPLETE |  |  |
| 1538 | 1.6.4.1.1.6 | QAG Approval of Non-SIT S&A Test Approach and Plan | milestone | 0d | 2024-05-23 A | 2024-05-23 A | 1537FS+7d | 100% |  | 2024-05-23 | 2024-05-23 | 0d |  |  |  |  | Non-SIT S&A QT Test Team | Non-SIT S&A QT Test Team |  | 5.25 | Laura Kennedy | Complete | COMPLETE | T3-QU-0089 | QAG |
| 1539 | 1.6.4.1.1.7 | BSC & REC PAB Approval of Non-SIT S&A Test Approach and Plan | milestone | 0d | 2024-05-30 A | 2024-05-30 A | 1538FS+5d | 100% |  | 2024-05-30 | 2024-05-30 | 0d |  |  |  |  | Code Bodies | Code Bodies |  | 5.25 | Laura Kennedy | Complete | COMPLETE | T3-QU-0090 | QAG |

Notes:
- 1517: 6/8/24: Date at risk from scenario planning activity
- 1521: 28/08/24 - Date will be missed because the date for the initial QAD submission window has been moved back to reflect the delay to SIT activities and to provide Programme PPs with more time to prepare. Milestone date change was approved at QAG on 22/08/24, from 10/10/24 to 10/11/24. To go to 19/09/24 QAG for noting.
- 1526: 6/8/24: Date at risk from scenario planning activity
- 1528: 18/09/24 - Adding dependency so the milestone is dependent on SIT LDSO MVC.
- 1529: 13/5: name changed as part of cr47.

| ID | WBS | Task | Type | Duration | Start | Finish | Predecessors | Complete | Baseline start | Baseline finish | Baseline duration | Total slack | Free slack | Constraint | Baseline cost | Responsible | Involved | Task Status | Update Version | MHHS Resource Name | Sched Status | RAG | Milestone ID | Text29 |
| --- | --- | --- | --- | --- | --- | --- | --- | --- | --- | --- | --- | --- | --- | --- | --- | --- | --- | --- | --- | --- | --- | --- | --- | --- |
| 1540 | 1.6.4.1.2 | **QT Test Data Approach and Plan** |  | 64d | 2024-04-19 A | 2024-07-18 A |  | 100% | 2024-04-19 | 2024-07-18 | 64d |  |  |  | -0 | N/A | N/A | -133.67 | 5.24 | N/A |  |  |  |  |
| 1541 | 1.6.4.1.2.1 | QT Test Data Approach agreed as part of the Non-SIT Supplier and Agent Test Approach and Plan | milestone | 0d | 2024-04-19 A | 2024-04-19 A | 1536 | 100% | 2024-04-19 | 2024-04-19 | 0d |  |  |  |  | Non-SIT S&A QT Test Team, Participants | Non-SIT S&A QT Test Team, Participants |  | 5.24 | Laura Kennedy | Complete | COMPLETE |  |  |
| 1542 | 1.6.4.1.2.2 | Draft Test Data Approach and Plan for QT |  | 10d | 2024-05-06 A | 2024-05-17 A | 1541 | 100% | 2024-05-06 | 2024-05-17 | 10d |  |  |  |  | Non-SIT S&A QT Test Team | Non-SIT S&A QT Test Team |  | 5.24 | Laura Kennedy | Complete | COMPLETE |  |  |
| 1543 | 1.6.4.1.2.3 | Internal Review (Code Bodies and MHHSP) of QT Test Data Approach and Plan |  | 15d | 2024-05-20 A | 2024-06-07 A | 1542 | 100% | 2024-05-20 | 2024-05-31 | 10d |  |  |  |  | Code Bodies, SI Team, SRO | Code Bodies, SI Team, SRO |  | 5.24 | Laura Kennedy | Complete | COMPLETE |  |  |
| 1544 | 1.6.4.1.2.4 | Issue QT Test Data Approach and Plan for Industry Consultation |  | 10d | 2024-06-10 A | 2024-06-21 A | 1543 | 100% | 2024-06-03 | 2024-06-14 | 10d |  |  |  |  | Participants | Participants |  | 5.24 | Laura Kennedy | Complete | COMPLETE |  |  |
| 1545 | 1.6.4.1.2.5 | Update QT Test Approach and Plan Post Industry Consultation |  | 5d | 2024-06-24 A | 2024-06-28 A | 1544 | 100% | 2024-06-17 | 2024-06-28 | 10d |  |  |  |  | Non-SIT S&A QT Team | Non-SIT S&A QT Team |  | 5.24 | Laura Kennedy | Complete | COMPLETE |  |  |
| 1546 | 1.6.4.1.2.6 | QWG Endorsement of Test Data Approach and Plan |  | 1d | 2024-07-09 A | 2024-07-09 A | 1545FS+6d | 100% | 2024-07-09 | 2024-07-09 | 1d |  |  |  |  | Non-SIT S&A QT Test Team | Non-SIT S&A QT Test Team |  | 5.24 | Laura Kennedy | Complete | COMPLETE |  |  |
| 1547 | 1.6.4.1.2.7 | QAG Approval of QT Test Data Approach and Plan | milestone | 0d | 2024-07-18 A | 2024-07-18 A | 1546FS+7d | 100% | 2024-07-18 | 2024-07-18 | 0d |  |  |  |  | Non-SIT S&A QT Test Team | Non-SIT S&A QT Test Team |  | 5.29 | Laura Kennedy | Complete | COMPLETE | T3-QU-0091 | QAG |
| 1548 | 1.6.4.1.3 | **QT Functional Test Scenarios and Test Cases** |  | 59d | 2024-03-04 A | 2024-05-23 A |  | 100% | 2024-03-04 | 2024-05-23 | 59d |  |  |  | -0 | N/A | N/A | -133.67 | 5.24 | N/A |  |  |  |  |
| 1549 | 1.6.4.1.3.1 | Draft Test Scenarios and Test Case list - Batch 1 |  | 10d | 2024-03-04 A | 2024-03-15 A |  | 100% | 2024-03-04 | 2024-03-15 | 10d |  |  | finish no earlier than 2024-03-15 |  | Non-SIT S&A QT Test Team, Code Bodies | Non-SIT S&A QT Test Team, Code Bodies |  | 5.24 | Laura Kennedy | Complete | COMPLETE |  |  |
| 1550 | 1.6.4.1.3.2 | Issue Batch 1 for Consultation |  | 15d | 2024-03-18 A | 2024-04-05 A | 1549 | 100% | 2024-03-18 | 2024-04-05 | 15d |  |  | start no earlier than 2024-03-18 |  | Participants | Participants |  | 5.24 | Laura Kennedy | Complete | COMPLETE |  |  |
| 1551 | 1.6.4.1.3.3 | Gap analysis against QT Requirements |  | 8d | 2024-03-18 A | 2024-03-27 A | 1549 | 100% | 2024-03-18 | 2024-03-27 | 8d |  |  |  |  | Non-SIT S&A QT Test Team | Non-SIT S&A QT Test Team |  | 5.24 | Laura Kennedy | Complete | COMPLETE |  |  |
| 1552 | 1.6.4.1.3.4 | Update Test Scenarios and Test Case list - Batch 2 |  | 6d | 2024-03-28 A | 2024-04-04 A | 1551 | 100% | 2024-03-28 | 2024-04-04 | 6d |  |  |  |  | Non-SIT S&A QT Test Team, Code Bodies | Non-SIT S&A QT Test Team, Code Bodies |  | 5.24 | Laura Kennedy | Complete | COMPLETE |  |  |
| 1553 | 1.6.4.1.3.5 | Issue Batch 2 for consultation |  | 10d | 2024-04-05 A | 2024-04-18 A | 1552 | 100% | 2024-04-05 | 2024-04-18 | 10d |  |  |  |  | Participants | Participants |  | 5.24 | Laura Kennedy | Complete | COMPLETE |  |  |
| 1554 | 1.6.4.1.3.6 | Update Batch 2 post consultation |  | 10d | 2024-04-19 A | 2024-05-02 A | 1553 | 100% | 2024-04-19 | 2024-05-02 | 10d |  |  |  |  | Non-SIT S&A QT Test Team, Code Bodies | Non-SIT S&A QT Test Team, Code Bodies |  | 5.24 | Laura Kennedy | Complete | COMPLETE |  |  |
| 1555 | 1.6.4.1.3.7 | QWG Endorsement of Batch 1 and 2 |  | 1d | 2024-05-14 A | 2024-05-14 A |  | 100% | 2024-05-14 | 2024-05-14 | 1d |  |  | finish no earlier than 2024-05-14 |  | Non-SIT S&A QT Test Team | Non-SIT S&A QT Test Team, Code Bodies, Participants |  | 5.24 | Laura Kennedy | Complete | COMPLETE |  |  |
| 1556 | 1.6.4.1.3.8 | QAG Approval of QT Functional Test Scenarios and Test Cases Batches 1 and 2 | milestone | 0d | 2024-05-23 A | 2024-05-23 A | 1555FS+7d | 100% | 2024-05-23 | 2024-05-23 | 0d |  |  |  |  | Non-SIT S&A QT Test Team | Non-SIT S&A QT Test Team, Code Bodies, Participants |  | 5.25 | Laura Kennedy | Complete | COMPLETE | T3-QU-0092 | QAG |
| 1557 | 1.6.4.1.4 | **QT Migration Test Scenarios and Test Cases** |  | 54d | 2024-05-06 A | 2024-07-18 A |  | 100% | 2024-05-06 | 2024-07-18 | 54d |  |  |  |  | N/A | N/A |  | 5.25 | N/A |  |  |  |  |
| 1558 | 1.6.4.1.4.1 | Draft Test Scenarios and Test Case list - Batch 1 |  | 20d | 2024-05-06 A | 2024-05-31 A | 893FS+12d | 100% | 2024-05-06 | 2024-05-31 | 20d |  |  |  |  | Non-SIT S&A QT Test Team, Code Bodies | Non-SIT S&A QT Test Team, Code Bodies |  | 5.25 | Laura Kennedy | Complete | COMPLETE |  |  |
| 1559 | 1.6.4.1.4.2 | Issue Batch 1 for Consultation |  | 10d | 2024-06-03 A | 2024-06-14 A | 1558 | 100% | 2024-06-03 | 2024-06-14 | 10d |  |  |  |  | Participants | Participants |  | 5.25 | Laura Kennedy | Complete | COMPLETE |  |  |
| 1560 | 1.6.4.1.4.3 | Update Batch 1 Post Consultation |  | 10d | 2024-06-17 A | 2024-06-28 A | 1559 | 100% | 2024-06-17 | 2024-06-28 | 10d |  |  |  |  | Non-SIT S&A QT Test Team | Non-SIT S&A QT Test Team |  | 5.25 | Laura Kennedy | Complete | COMPLETE |  |  |
| 1561 | 1.6.4.1.4.4 | QWG Endorsement of Batch 1 | milestone | 0d | 2024-07-09 A | 2024-07-09 A | 1560FS+7d | 100% | 2024-07-09 | 2024-07-09 | 0d |  |  |  |  | Non-SIT S&A QT Test Team | Non-SIT S&A QT Test Team, Code Bodies, Participants |  | 5.25 | Laura Kennedy | Complete | COMPLETE |  |  |
| 1562 | 1.6.4.1.4.5 | QAG Approval of QT Migration Test Scenarios and Test Cases Batches 1 | milestone | 0d | 2024-07-18 A | 2024-07-18 A | 1561FS+7d | 100% | 2024-07-18 | 2024-07-18 | 0d |  |  |  |  | Non-SIT S&A QT Test Team | Non-SIT S&A QT Test Team, Code Bodies, Participants |  | 5.29 | Laura Kennedy | Complete | COMPLETE | T3-QU-0119 | QAG |
| 1563 | 1.6.4.1.5 | **QT Non-Functional Test Scenarios and Test Cases** |  | 61d | 2024-09-20 | 2024-12-13 |  |  | 2024-07-22 | 2024-09-19 | 43d | 32518d |  |  |  | N/A | N/A |  | 5.25 | N/A |  |  |  |  |
| 1564 | 1.6.4.1.5.1 | Draft Test Scenarios and Test Case list - Batch 2 |  | 27d | 2024-09-20 | 2024-10-28 | 950FS+2d, 944FS+2d |  | 2024-07-22 | 2024-08-02 | 10d | 32518d | 0d |  |  | Non-SIT S&A QT Test Team, Code Bodies | Non-SIT S&A QT Test Team, Code Bodies | 0.33 | 5.25 | Laura Kennedy | Red | RED |  |  |
| 1565 | 1.6.4.1.5.2 | Issue Batch 2 for Consultation |  | 10d | 2024-10-29 | 2024-11-11 | 1564 |  | 2024-08-05 | 2024-08-16 | 10d | 32518d | 0d |  |  | Participants | Participants | 39.33 | 5.25 | Laura Kennedy | Red | RED |  |  |
| 1566 | 1.6.4.1.5.3 | Update Batch 2 Post Consultation |  | 10d | 2024-11-12 | 2024-11-25 | 1565 |  | 2024-08-19 | 2024-08-30 | 10d | 32518d | 0d |  |  | Non-SIT S&A QT Test Team | Non-SIT S&A QT Test Team | 53.33 | 5.25 | Laura Kennedy | Red | RED |  |  |
| 1567 | 1.6.4.1.5.4 | QWG Endorsement of Batch 2 | milestone | 0d | 2024-12-04 | 2024-12-04 | 1566FS+7d, 1467 |  | 2024-09-10 | 2024-09-10 | 0d | 32518d | 0d |  |  | Non-SIT S&A QT Test Team | Non-SIT S&A QT Test Team, Code Bodies, Participants | 75.71 | 5.25 | Laura Kennedy | Red | RED |  |  |
| 1568 | 1.6.4.1.5.5 | QAG Approval of QT Non-Functional Test Scenarios and Test Cases Batch 2 | milestone | 0d | 2024-12-13 | 2024-12-13 | 1567FS+7d |  | 2024-09-19 | 2024-09-19 | 0d | 32518d | 13d |  |  | Non-SIT S&A QT Test Team | Non-SIT S&A QT Test Team, Code Bodies, Participants | 84.71 | 5.27 | Laura Kennedy | Red | RED | T3-QU-0120 | QAG |

Notes:
- 1568: Date will be missed because of SIT Non-Functional/Operational Test Scenario Approval dates. QT Test Scenarios which reuse SIT Scenarios are unable to be approved until SIT Scenarios are approved. Review scope of SIT NF/Operational to understand whether all themes impact QT, work with SIT team to increase parallelisation of activities where possible. On track to meet forecast date. Update to baseline date to be requested at QAG on 19/09. / Notes (2): work with SIT team to increase parallelisation of activities where possible.

| ID | WBS | Task | Type | Duration | Start | Finish | Predecessors | Complete | Remaining | Baseline start | Baseline finish | Baseline duration | Total slack | Free slack | Constraint | Baseline cost | Responsible | Involved | Update Version | MHHS Resource Name | Task Status | Sched Status | RAG | Milestone ID | Text29 |
| --- | --- | --- | --- | --- | --- | --- | --- | --- | --- | --- | --- | --- | --- | --- | --- | --- | --- | --- | --- | --- | --- | --- | --- | --- | --- |
| 1569 | 1.6.4.1.6 | **QT Operational Test Scenarios and Test Cases** |  | 82d | 2024-09-10 | 2025-01-01 |  |  |  | 2024-07-22 | 2024-10-17 | 63d | 32505d |  |  |  | N/A | N/A | 5.25 | N/A |  |  |  |  |  |
| 1570 | 1.6.4.1.6.1 | Draft QT Operational Test Cases - Batch 1 |  | 47d | 2024-09-11 | 2024-11-14 | 999FS+2d, 1547 |  |  | 2024-07-22 | 2024-08-02 | 10d | 32505d | 0d |  |  | Non-SIT S&A QT Test Team, Code Bodies | Non-SIT S&A QT Test Team, Code Bodies | 5.25 | Laura Kennedy | -8.67 | Red | RED |  |  |
| 1571 | 1.6.4.1.6.2 | Issue Batch 1 for Consultation |  | 10d | 2024-11-15 | 2024-11-28 | 1570 |  |  | 2024-08-05 | 2024-08-16 | 10d | 32505d | 0d |  |  | Participants | Participants | 5.25 | Laura Kennedy | 56.33 | Red | RED |  |  |
| 1572 | 1.6.4.1.6.3 | Update Batch 1 Post Consultation |  | 10d | 2024-11-29 | 2024-12-12 | 1571 |  |  | 2024-08-19 | 2024-08-30 | 10d | 32505d | 0d |  |  | Non-SIT S&A QT Test Team | Non-SIT S&A QT Test Team | 5.25 | Laura Kennedy | 70.33 | Red | RED |  |  |
| 1573 | 1.6.4.1.6.4 | QWG Endorsement of Batch 1 | milestone | 0d | 2024-12-23 | 2024-12-23 | 1572FS+7d |  |  | 2024-09-10 | 2024-09-10 | 0d | 32505d | 0d |  |  | Non-SIT S&A QT Test Team | Non-SIT S&A QT Test Team, Code Bodies, Participants | 5.25 | Laura Kennedy | 94.71 | Red | RED |  |  |
| 1574 | 1.6.4.1.6.5 | QAG Approval of QT Operational Test Scenarios and Test Cases Batch 1 | milestone | 0d | 2025-01-01 | 2025-01-01 | 1573FS+7d |  |  | 2024-09-19 | 2024-09-19 | 0d | 32505d | 0d |  |  | Non-SIT S&A QT Test Team | Non-SIT S&A QT Test Team, Code Bodies, Participants | 5.27 | Laura Kennedy | 103.71 | Red | RED | T3-QU-0121 | QAG |
| 1575 | 1.6.4.1.6.6 | Draft QT Operational Test Cases - Batch 2 |  | 10d | 2024-09-10 | 2024-09-23 | 1005FS+2d |  |  | 2024-07-22 | 2024-08-02 | 10d | 32543d | 0d |  |  | Non-SIT S&A QT Test Team, Code Bodies | Non-SIT S&A QT Test Team, Code Bodies | 5.25 | Laura Kennedy | -9.67 | Red | RED |  |  |
| 1576 | 1.6.4.1.6.7 | Issue Batch 2 for Consultation |  | 10d | 2024-09-24 | 2024-10-07 | 1575 |  |  | 2024-08-05 | 2024-08-16 | 10d | 32543d | 0d |  |  | Participants | Participants | 5.25 | Laura Kennedy | 4.33 | Red | RED |  |  |
| 1577 | 1.6.4.1.6.8 | Update Batch 2 Post Consultation |  | 10d | 2024-10-08 | 2024-10-21 | 1576 |  |  | 2024-08-19 | 2024-08-30 | 10d | 32543d | 0d |  |  | Non-SIT S&A QT Test Team | Non-SIT S&A QT Test Team | 5.25 | Laura Kennedy | 18.33 | Red | RED |  |  |
| 1578 | 1.6.4.1.6.9 | QWG Endorsement of Batch 2 | milestone | 0d | 2024-10-30 | 2024-10-30 | 1577FS+7d |  |  | 2024-09-10 | 2024-09-10 | 0d | 32543d | 0d |  |  | Non-SIT S&A QT Test Team | Non-SIT S&A QT Test Team, Code Bodies, Participants | 5.25 | Laura Kennedy | 40.71 | Red | RED |  |  |
| 1579 | 1.6.4.1.6.10 | QAG Approval of QT Operational Test Scenarios and Test Cases Batch 2 | milestone | 0d | 2024-11-08 | 2024-11-08 | 1578FS+7d |  |  | 2024-09-19 | 2024-09-19 | 0d | 32543d | 38d |  |  | Non-SIT S&A QT Test Team | Non-SIT S&A QT Test Team, Code Bodies, Participants | 5.27 | Laura Kennedy | 49.71 | Red | RED | T3-QU-0122 | QAG |
| 1580 | 1.6.4.1.7 | **Qualification Testing Framework (Test Stubs and Supporting UI)** |  | 508d | 2024-01-29 A | 2026-01-07 |  | 47% | 267.18d | 2024-01-29 | 2025-07-31 | 394d | 32254d |  |  | -0 | N/A | N/A | 5.27 | N/A | -594.67 |  |  |  |  |
| 1581 | 1.6.4.1.7.1 | Proof of Concept for QTF Completion |  | 45d | 2024-01-29 A | 2024-03-29 A |  | 100% |  | 2024-01-29 | 2024-03-29 | 45d |  |  | start no earlier than 2024-01-22 |  | Non-SIT S&A QT Test Team | Non-SIT S&A QT Test Team | 5.27 | Laura Kennedy |  | Complete | COMPLETE |  |  |
| 1582 | 1.6.4.1.7.2 | Discovery and Mobilisation |  | 25d | 2024-04-01 A | 2024-05-03 A | 1581 | 100% |  | 2024-04-01 | 2024-05-03 | 25d |  |  |  |  | Non-SIT S&A QT Test Team | Non-SIT S&A QT Test Team | 5.27 | Laura Kennedy |  | Complete | COMPLETE |  |  |
| 1583 | 1.6.4.1.7.3 | **Agile DBT of Qualification Testing Framework** |  | 83d | 2024-04-24 A | 2024-08-16 |  | 96% | 3.05d | 2024-04-24 | 2024-08-16 | 83d | 32617d |  |  | -0 | N/A | N/A | 5.27 | N/A |  |  |  |  |  |
| 1584 | 1.6.4.1.7.3.1 | **User Interface (UI)** |  | 48d | 2024-04-24 A | 2024-06-28 A |  | 100% |  | 2024-04-24 | 2024-06-28 | 48d |  |  |  |  | N/A | N/A | 5.27 | N/A | -594.67 |  |  |  |  |
| 1585 | 1.6.4.1.7.3.1.1 | UI Wireframe |  | 48d | 2024-04-24 A | 2024-06-28 A | 1536FS+2d | 100% |  | 2024-04-24 | 2024-06-28 | 48d |  |  |  |  | Non-SIT S&A QT Test Team | Non-SIT S&A QT Test Team | 5.27 | Laura Kennedy |  | Complete | COMPLETE |  |  |
| 1586 | 1.6.4.1.7.3.1.2 | UI Standards |  | 35d | 2024-05-13 A | 2024-06-28 A | 1585SS+13d | 100% |  | 2024-05-13 | 2024-06-28 | 35d |  |  |  |  | Non-SIT S&A QT Test Team | Non-SIT S&A QT Test Team | 5.27 | Laura Kennedy |  | Complete | COMPLETE |  |  |
| 1587 | 1.6.4.1.7.3.1.3 | Elexon Branding Sylesheet |  | 1d | 2024-05-17 A | 2024-05-20 A | 1582FS+10d | 100% |  | 2024-05-17 | 2024-05-20 | 1d |  |  |  |  | Non-SIT S&A QT Test Team | Non-SIT S&A QT Test Team | 5.27 | Laura Kennedy |  | Complete | COMPLETE |  |  |
| 1588 | 1.6.4.1.7.3.1.4 | Elexon Branding QTF Logo |  | 1d | 2024-05-31 A | 2024-06-03 A | 1582FS+20d | 100% |  | 2024-05-31 | 2024-06-03 | 1d |  |  |  |  | Non-SIT S&A QT Test Team | Non-SIT S&A QT Test Team | 5.27 | Laura Kennedy |  | Complete | COMPLETE |  |  |
| 1589 | 1.6.4.1.7.3.2 | **Design, Build, Test** |  | 70d | 2024-05-13 A | 2024-08-16 |  | 95% | 3.47d | 2024-05-13 | 2024-08-16 | 70d | 32617d |  |  |  | N/A | N/A | 5.27 | N/A | -594.67 |  |  |  |  |
| 1590 | 1.6.4.1.7.3.2.1 | Core UI Screens |  | 60d | 2024-05-13 A | 2024-08-02 A | 1586SS | 100% |  | 2024-05-13 | 2024-08-02 | 60d |  |  |  |  | Non-SIT S&A QT Test Team | Non-SIT S&A QT Test Team | 5.27 | Laura Kennedy |  | Complete | COMPLETE |  |  |
| 1591 | 1.6.4.1.7.3.2.2 | Tooling (Trigger Files / Template Generators) |  | 70d | 2024-05-13 A | 2024-08-16 | 1585SS+13d | 83% | 12d | 2024-05-13 | 2024-08-16 | 70d | 32617d | 10d |  |  | Non-SIT S&A QT Test Team | Non-SIT S&A QT Test Team | 5.27 | Laura Kennedy |  | Overdue | RED |  |  |
| 1592 | 1.6.4.1.7.3.2.3 | Database Schema |  | 50d | 2024-05-13 A | 2024-07-19 A | 1585SS+13d | 100% |  | 2024-05-13 | 2024-07-19 | 50d |  |  |  |  | Non-SIT S&A QT Test Team | Non-SIT S&A QT Test Team | 5.27 | Laura Kennedy |  | Complete | COMPLETE |  |  |
| 1593 | 1.6.4.1.7.3.2.4 | Core API's |  | 60d | 2024-05-13 A | 2024-08-02 A | 1585SS+13d | 100% |  | 2024-05-13 | 2024-08-02 | 60d |  |  |  |  | Non-SIT S&A QT Test Team | Non-SIT S&A QT Test Team | 5.27 | Laura Kennedy |  | Complete | COMPLETE |  |  |
| 1594 | 1.6.4.1.7.3.2.5 | DIP (SIT-A) Onboarding for Development inc. Test Stubs |  | 1d | 2024-07-12 A | 2024-07-12 A | 1582FS+49d | 100% |  | 2024-07-12 | 2024-07-12 | 1d |  |  |  |  | Non-SIT S&A QT Test Team, Electralink | Non-SIT S&A QT Test Team, Electralink | 5.27 | Laura Kennedy |  | Complete | COMPLETE |  |  |
| 1595 | 1.6.4.1.7.3.2.6 | DTN Onboarding for Development inc. Test Stubs |  | 1d | 2024-07-15 A | 2024-07-15 A | 1594 | 100% |  | 2024-07-15 | 2024-07-15 | 1d |  |  |  |  | Non-SIT S&A QT Test Team, MHHSP, Avanade | Non-SIT S&A QT Test Team, MHHSP, Avanade | 5.27 | Laura Kennedy |  | Complete | COMPLETE |  |  |
| 1596 | 1.6.4.1.7.4 | QTF Test Cases DBT Refinement, Execution and Results Validation, Defect Management, Error Handling |  | 131d | 2024-07-03 | 2025-01-01 | 1562FF, 1568FF, 1574FF, 1579FF |  |  | 2024-07-15 | 2024-10-31 | 79d | 32505d | 0d |  |  | Non-SIT S&A QT Test Team | Non-SIT S&A QT Test Team | 5.27 | Laura Kennedy | -78.67 | Overdue Start | RED |  |  |

Notes:
- 1569: Impact: QT Test Scenarios which reuse SIT Scenarios are unable to be approved until SIT Scenarios are approved.
- 1570: Action: Review scope of SIT NF/Operational to understand whether all themes impact QT, work with SIT team to increase parallelisation of activities where possible. / Action: 9/7/24: Potential delay as delay from the test side. Does it need to be linked to all 3 or just 1?
- 1574: Date will be missed because of delay to SIT Non-Functional/Operational Test Scenario Approval dates. QT Test Scenarios which reuse SIT Scenarios are unable to be approved until SIT Scenarios are approved. Review scope of SIT NF/Operational to understand whether all themes impact QT, work with SIT team to increase parallelisation of activities where possible. Update to baseline date to be requested at QAG on 19/09. / Notes (2): work with SIT team to increase parallelisation of activities where possible.
- 1579: Date will be missed because of delay to SIT Non-Functional/Operational Test Scenario Approval dates. QT Test Scenarios which reuse SIT Scenarios are unable to be approved until SIT Scenarios are approved. Review scope of SIT NF/Operational to understand whether all themes impact QT, work with SIT team to increase parallelisation of activities where possible. Update to baseline date to be requested at QAG on 19/09.

| ID | WBS | Task | Duration | Start | Finish | Predecessors | Complete | Remaining | Baseline start | Baseline finish | Baseline duration | Total slack | Free slack | Constraint | Baseline cost | Responsible | Involved | Task Status | Update Version | MHHS Resource Name | Sched Status | RAG | Action |
| --- | --- | --- | --- | --- | --- | --- | --- | --- | --- | --- | --- | --- | --- | --- | --- | --- | --- | --- | --- | --- | --- | --- | --- |
| 1597 | 1.6.4.1.7.5 | **Environments** | 202d | 2024-04-15 A | 2025-01-21 |  | 49% | 102.05d | 2024-04-15 | 2024-11-20 | 158d | 32505d |  |  | -0 | N/A | N/A | -594.67 | 5.27 | N/A |  |  |  |
| 1598 | 1.6.4.1.7.5.1 | **Azure Devops** | 120d | 2024-04-15 A | 2024-09-27 |  | 42% | 69.38d | 2024-04-15 | 2024-09-27 | 120d | 31964d |  |  | -0 | N/A | N/A | -594.67 | 5.27 | N/A |  |  |  |
| 1599 | 1.6.4.1.7.5.1.1 | **QFT ADO Development Instance** | 15d | 2024-04-15 A | 2024-05-03 A |  | 100% |  | 2024-04-15 | 2024-05-03 | 15d |  |  |  |  | N/A | N/A | -594.67 | 5.27 | N/A |  |  |  |
| 1600 | 1.6.4.1.7.5.1.1.1 | Elexon Instance Setup for QTF Build | 5d | 2024-04-15 A | 2024-04-19 A | 1582SS+10d | 100% |  | 2024-04-15 | 2024-04-19 | 5d |  |  |  |  | Non-SIT S&A QT Test Team | Non-SIT S&A QT Test Team |  | 5.27 | Laura Kennedy | Complete | COMPLETE |  |
| 1601 | 1.6.4.1.7.5.1.1.2 | Configuration and User Access | 10d | 2024-04-22 A | 2024-05-03 A | 1600 | 100% |  | 2024-04-22 | 2024-05-03 | 10d |  |  |  |  | Non-SIT S&A QT Test Team | Non-SIT S&A QT Test Team |  | 5.27 | Laura Kennedy | Complete | COMPLETE |  |
| 1602 | 1.6.4.1.7.5.1.2 | **MHHSP ADO Instance** | 49d | 2024-07-23 A | 2024-09-27 |  | 24% | 37d | 2024-07-22 | 2024-09-27 | 50d | 31964d |  |  |  | N/A | N/A | -594.67 | 5.27 | N/A | Complete |  |  |
| 1603 | 1.6.4.1.7.5.1.2.1 | MHHSP Instance Setup for QTF Production | 29d | 2024-07-23 A | 2024-08-30 | 1609SS+41d | 41% | 17d | 2024-07-22 | 2024-08-30 | 30d | 31964d | 0d |  |  | MHHSP | MHHSP |  | 5.27 | Laura Kennedy | Green | GREEN |  |
| 1604 | 1.6.4.1.7.5.1.2.2 | Configuration and User Access | 20d | 2024-09-02 | 2024-09-27 | 1603, 1660 |  |  | 2024-09-02 | 2024-09-27 | 20d | 31964d | 175d |  |  | Non-SIT S&A QT Test Team | Non-SIT S&A QT Test Team | -17.67 | 5.27 | Laura Kennedy | Green | GREEN |  |
| 1605 | 1.6.4.1.7.5.2 | **Temporary Development Environment** | 35d | 2024-04-15 A | 2024-05-31 A |  | 100% |  | 2024-04-15 | 2024-05-31 | 35d |  |  |  |  | N/A | N/A | -594.67 | 5.27 | N/A |  |  |  |
| 1606 | 1.6.4.1.7.5.2.1 | Design | 15d | 2024-04-15 A | 2024-05-03 A | 1582SS+10d | 100% |  | 2024-04-15 | 2024-05-03 | 15d |  |  |  |  | Non-SIT S&A QT Test Team | Non-SIT S&A QT Test Team |  | 5.27 | Laura Kennedy | Complete | COMPLETE |  |
| 1607 | 1.6.4.1.7.5.2.2 | Build and Deployment | 20d | 2024-05-06 A | 2024-05-31 A | 1601, 1606 | 100% |  | 2024-05-06 | 2024-05-31 | 20d |  |  |  |  | Non-SIT S&A QT Test Team | Non-SIT S&A QT Test Team |  | 5.27 | Laura Kennedy | Complete | COMPLETE |  |
| 1608 | 1.6.4.1.7.5.3 | **Dev, Test & Prod Environment Requirements + Design** | 105d | 2024-05-27 A | 2024-10-18 |  | 58% | 43.91d | 2024-05-27 | 2024-10-18 | 105d | 32572d |  |  | -0 | N/A | N/A | -594.67 | 5.27 | N/A |  |  |  |
| 1609 | 1.6.4.1.7.5.3.1 | Design (including Security Review) | 70d | 2024-05-27 A | 2024-08-30 | 1582FS+15d | 76% | 17d | 2024-05-27 | 2024-08-30 | 70d | 32607d | 0d |  |  | Non-SIT S&A QT Test Team | Non-SIT S&A QT Test Team |  | 5.27 | Laura Kennedy | Green | GREEN |  |
| 1610 | 1.6.4.1.7.5.3.2 | Hub Deployment | 20d | 2024-06-10 A | 2024-07-05 A | 1609SS+10d | 100% |  | 2024-06-10 | 2024-07-05 | 20d |  |  |  |  | Non-SIT S&A QT Test Team | Non-SIT S&A QT Test Team |  | 5.27 | Laura Kennedy | Complete | COMPLETE |  |
| 1611 | 1.6.4.1.7.5.3.3 | Development Envn. Deployment | 40d | 2024-07-08 A | 2024-08-30 | 1610 | 58% | 17d | 2024-07-08 | 2024-08-30 | 40d | 32558d | 0d |  |  | Non-SIT S&A QT Test Team | Non-SIT S&A QT Test Team |  | 5.27 | Laura Kennedy | Green | GREEN |  |
| 1612 | 1.6.4.1.7.5.3.4 | Test Envn. Deployment | 10d | 2024-09-02 | 2024-09-13 | 1611 |  |  | 2024-09-02 | 2024-09-13 | 10d | 32558d | 0d |  |  | Non-SIT S&A QT Test Team | Non-SIT S&A QT Test Team | -17.67 | 5.27 | Laura Kennedy | Green | GREEN |  |
| 1613 | 1.6.4.1.7.5.3.5 | Production Envn. Deployment | 25d | 2024-09-16 | 2024-10-18 | 1612 |  |  | 2024-09-16 | 2024-10-18 | 25d | 32558d | 53d |  |  | Non-SIT S&A QT Test Team | Non-SIT S&A QT Test Team | -3.67 | 5.27 | Laura Kennedy | Green | GREEN |  |
| 1614 | 1.6.4.1.7.5.4 | **QTF Deployment into Production** | 14d | 2025-01-02 | 2025-01-21 |  |  |  | 2024-11-01 | 2024-11-20 | 14d | 32505d |  |  |  | N/A | N/A | -594.67 | 5.27 | N/A | No BL |  |  |
| 1615 | 1.6.4.1.7.5.4.1 | App Deployment | 1d | 2025-01-02 | 2025-01-02 | 1596, 1613 |  |  | 2024-11-01 | 2024-11-01 | 1d | 32505d | 0d |  |  | Non-SIT S&A QT Test Team | Non-SIT S&A QT Test Team | 104.33 | 5.27 | Laura Kennedy | Red | RED |  |
| 1616 | 1.6.4.1.7.5.4.2 | Smoke Test | 2d | 2025-01-02 | 2025-01-03 | 1615SS |  |  | 2024-11-01 | 2024-11-04 | 2d | 32505d | 0d |  |  | Non-SIT S&A QT Test Team | Non-SIT S&A QT Test Team | 104.33 | 5.27 | Laura Kennedy | Red | RED |  |
| 1617 | 1.6.4.1.7.5.4.3 | PEN Test | 2d | 2025-01-06 | 2025-01-07 | 1616 |  |  | 2024-11-05 | 2024-11-06 | 2d | 32505d | 0d |  |  | Non-SIT S&A QT Test Team | Non-SIT S&A QT Test Team | 108.33 | 5.27 | Laura Kennedy | Red | RED |  |
| 1618 | 1.6.4.1.7.5.4.4 | Regresssion Test | 10d | 2025-01-08 | 2025-01-21 | 1617 |  |  | 2024-11-07 | 2024-11-20 | 10d | 32505d |  |  |  | Non-SIT S&A QT Test Team | Non-SIT S&A QT Test Team | 110.33 | 5.27 | Laura Kennedy | Red | RED |  |
| 1619 | 1.6.4.1.7.5.5 | **DIP Onboarding (UIT)** | 37d | 2024-08-05 | 2024-09-24 |  |  |  | 2024-08-05 | 2024-09-24 | 37d | 32590d |  |  |  | N/A | N/A | -594.67 | 5.27 | N/A |  |  |  |
| 1620 | 1.6.4.1.7.5.5.1 | DIP available for Onboarding | 1d | 2024-08-05 | 2024-08-05 | 1606 |  |  | 2024-08-05 | 2024-08-05 | 1d | 32590d | 0d | start no earlier than 2024-08-05 |  | MHHSP, Avanade | MHHSP, Avanade | -45.67 | 5.27 | Laura Kennedy | Overdue Start | RED | 3/7: Link into UIT ENV |
| 1621 | 1.6.4.1.7.5.5.2 | Qualification Testing for Non-SIT S&A Participants' environments) Ready to start DIP onboarding (incl. certificates and security compliance) | 15d | 2024-08-06 | 2024-08-26 | 1620 |  |  | 2024-08-06 | 2024-08-26 | 15d | 32590d | 0d |  |  | MHHSP, Avanade | MHHSP, Avanade | -44.67 | 5.27 | Laura Kennedy | Overdue Start | GREEN |  |
| 1622 | 1.6.4.1.7.5.5.3 | Non-SIT S&A QTF Environments Connection Confirmed to UIT Environment | 1d | 2024-08-27 | 2024-08-27 | 1621 |  |  | 2024-08-27 | 2024-08-27 | 1d | 32590d | 0d |  |  | Non-SIT S&A QT Test Team | Non-SIT S&A QT Test Team | -23.67 | 5.27 | Laura Kennedy | Green | GREEN |  |
| 1623 | 1.6.4.1.7.5.5.4 | DIP UIT Test Stubs | 20d | 2024-08-28 | 2024-09-24 | 1622 |  |  | 2024-08-28 | 2024-09-24 | 20d | 32590d |  |  |  | Non-SIT S&A QT Test Team | Non-SIT S&A QT Test Team, Avanade | -22.67 | 5.27 |  | Green | GREEN |  |

| ID | WBS | Task | Duration | Start | Finish | Predecessors | Complete | Remaining | Baseline start | Baseline finish | Baseline duration | Total slack | Free slack | Constraint | Baseline cost | Responsible | Involved | Task Status | Update Version | MHHS Resource Name | Sched Status | RAG |
| --- | --- | --- | --- | --- | --- | --- | --- | --- | --- | --- | --- | --- | --- | --- | --- | --- | --- | --- | --- | --- | --- | --- |
| 1624 | 1.6.4.1.7.5.6 | **DTN Onboarding** | 95d | 2024-05-20 A | 2024-09-27 |  | 47% | 50.21d | 2024-05-20 | 2024-09-27 | 95d | 32587d |  |  | -0 | N/A | N/A | -594.67 | 5.27 | N/A |  |  |
| 1625 | 1.6.4.1.7.5.6.1 | DTN Request Raised for Onboarding | 25d | 2024-05-20 A | 2024-06-21 A | 1606FS+10d | 100% |  | 2024-05-20 | 2024-06-21 | 25d |  |  |  |  | Non-SIT S&A QT Test Team | Non-SIT S&A QT Test Team |  | 5.27 | Laura Kennedy | Complete | COMPLETE |
| 1626 | 1.6.4.1.7.5.6.2 | Setup, configuration of New Host and Test Flags | 5d | 2024-06-24 A | 2024-06-28 A | 1625 | 100% |  | 2024-06-24 | 2024-06-28 | 5d |  |  |  |  | Electralink | Electralink |  | 5.27 | Laura Kennedy | Complete | COMPLETE |
| 1627 | 1.6.4.1.7.5.6.3 | New VPN Connection | 30d | 2024-08-05 A | 2024-09-13 | 1626FS+25d | 10% | 27d | 2024-08-05 | 2024-09-13 | 30d | 32587d | 0d |  |  | QT Test Team | QT Test Team |  | 5.30 | Laura Kennedy | Green | GREEN |
| 1628 | 1.6.4.1.7.5.6.4 | DTN Test Stubs | 10d | 2024-09-16 | 2024-09-27 | 1627 |  |  | 2024-09-16 | 2024-09-27 | 10d | 32587d |  |  |  | Non-SIT S&A QT Test Team | Non-SIT S&A QT Test Team | -3.67 | 5.27 | Laura Kennedy | Green | GREEN |
| 1629 | 1.6.4.1.7.6 | **Test Data (MPANs, DIP Messages, Settlement, Consumption, Reference)** | 413d | 2024-06-10 A | 2026-01-07 |  | 14% | 355.68d | 2024-06-10 | 2025-07-31 | 299d | 32254d |  |  | -0 | N/A | N/A | -385.67 | 5.27 | N/A |  |  |
| 1630 | 1.6.4.1.7.6.1 | Sample MPAN Data + Attributes from Suppliers | 15d | 2024-06-10 A | 2024-06-28 A | 1543 | 100% |  | 2024-06-10 | 2024-06-28 | 15d |  |  |  |  | Participants | Participants |  | 5.27 | Laura Kennedy | Complete | COMPLETE |
| 1631 | 1.6.4.1.7.6.2 | Test Data Templates and generator tools ready | 30d | 2024-06-24 A | 2024-08-02 | 1591SS+20d, 1630FF+25d | 93% | 2d | 2024-06-24 | 2024-08-02 | 30d | 32627d |  |  |  | Non-SIT S&A QT Test Team | Non-SIT S&A QT Test Team |  | 5.27 | Laura Kennedy | Overdue | RED |
| 1632 | 1.6.4.1.7.6.3 | **Industry Standing Data (ISD)** | 33d | 2024-07-26 A | 2024-09-10 |  | 6% | 31.17d | 2024-07-26 | 2024-09-10 | 33d | 32600d |  |  | -0 | N/A | N/A | -594.67 | 5.27 | N/A |  |  |
| 1633 | 1.6.4.1.7.6.3.1 | Dependant on Receiving ISD Agreed Source Data from Helix | 1d | 2024-07-26 A | 2024-07-26 A |  | 100% |  | 2024-07-26 | 2024-07-26 | 1d |  |  | start no earlier than 2024-07-26 |  | Helix | Helix |  | 5.27 | Laura Kennedy | Complete | COMPLETE |
| 1634 | 1.6.4.1.7.6.3.2 | First View of Migrated ISD Data | 1d | 2024-08-19 | 2024-08-19 | 1633 |  |  | 2024-08-19 | 2024-08-19 | 1d | 32600d | 0d | start no earlier than 2024-08-19 |  |  |  | -31.67 | 5.28 | Laura Kennedy | Overdue Start | RED |
| 1635 | 1.6.4.1.7.6.3.3 | Final Cycle 3 Migrated ISD Data | 1d | 2024-08-20 | 2024-08-20 | 1634 |  |  | 2024-08-20 | 2024-08-20 | 1d | 32600d | 0d |  |  |  |  | -30.67 | 5.28 | Laura Kennedy | Overdue Start | RED |
| 1636 | 1.6.4.1.7.6.3.4 | Create ISD Template inc. DIP ID | 5d | 2024-08-21 | 2024-08-27 | 1635 |  |  | 2024-08-21 | 2024-08-27 | 5d | 32600d | 0d |  |  | Non-SIT S&A QT Test Team | Non-SIT S&A QT Test Team | -29.67 | 5.27 | Laura Kennedy | Overdue Start | GREEN |
| 1637 | 1.6.4.1.7.6.3.5 | Publish Qualification ISD | 10d | 2024-08-28 | 2024-09-10 | 1636 |  |  | 2024-08-28 | 2024-09-10 | 10d | 32600d |  |  |  | Non-SIT S&A QT Test Team | Non-SIT S&A QT Test Team | -22.67 | 5.27 | Laura Kennedy | Green | GREEN |
| 1638 | 1.6.4.1.7.6.4 | **Wave 1 Test Data** | 46d | 2025-05-12 | 2025-07-14 |  |  |  | 2024-11-29 | 2025-01-31 | 46d | 31783d |  |  |  | N/A | N/A | -596.67 | 5.27 | N/A |  |  |
| 1639 | 1.6.4.1.7.6.4.1 | Test Data Request + Templates Completed | 16d | 2025-05-12 | 2025-06-02 | 1682 |  |  | 2024-11-29 | 2024-12-20 | 16d | 31783d | 0d |  |  | Participants | Participants | 234.33 | 5.27 | Laura Kennedy | Red | RED |
| 1640 | 1.6.4.1.7.6.4.2 | Test Data Generated | 10d | 2025-06-03 | 2025-06-16 | 1639 |  |  | 2024-12-23 | 2025-01-03 | 10d | 31783d | 0d |  |  | Non-SIT S&A QT Test Team | Non-SIT S&A QT Test Team | 256.33 | 5.27 | Laura Kennedy | Red | RED |
| 1641 | 1.6.4.1.7.6.4.3 | Test Data Loaded into QP Systems | 20d | 2025-06-17 | 2025-07-14 | 1640 |  |  | 2025-01-06 | 2025-01-31 | 20d | 31783d | 0d |  |  | Participants | Participants | 270.33 | 5.27 | Laura Kennedy | Red | RED |
| 1642 | 1.6.4.1.7.6.4.4 | Test Data Loaded into QTF + ADO | 20d | 2025-06-17 | 2025-07-14 | 1640 |  |  | 2025-01-06 | 2025-01-31 | 20d | 31783d | 0d |  |  | Non-SIT S&A QT Test Team | Non-SIT S&A QT Test Team | 270.33 | 5.27 | Laura Kennedy | Red | RED |
| 1643 | 1.6.4.1.7.6.5 | **Wave 2 Test Data** | 42d | 2025-07-07 | 2025-09-02 |  |  |  | 2025-01-31 | 2025-03-31 | 42d | 31787d |  |  |  | N/A | N/A | -596.67 | 5.27 | N/A |  |  |
| 1644 | 1.6.4.1.7.6.5.1 | Test Data Request + Templates Completed | 16d | 2025-07-07 | 2025-07-28 | 1712 |  |  | 2025-01-31 | 2025-02-21 | 16d | 31787d | 0d |  |  | Participants | Participants | 290.33 | 5.27 | Laura Kennedy | Red | RED |
| 1645 | 1.6.4.1.7.6.5.2 | Test Data Generated | 10d | 2025-07-29 | 2025-08-11 | 1644 |  |  | 2025-02-24 | 2025-03-07 | 10d | 31787d | 0d |  |  | Non-SIT S&A QT Test Team | Non-SIT S&A QT Test Team | 312.33 | 5.27 | Laura Kennedy | Red | RED |
| 1646 | 1.6.4.1.7.6.5.3 | Test Data Loaded into QP Systems | 16d | 2025-08-12 | 2025-09-02 | 1645 |  |  | 2025-03-10 | 2025-03-31 | 16d | 31787d | 4d |  |  | Participants | Participants | 326.33 | 5.27 | Laura Kennedy | Red | RED |
| 1647 | 1.6.4.1.7.6.5.4 | Test Data Loaded into QTF + ADO | 16d | 2025-08-12 | 2025-09-02 | 1645 |  |  | 2025-03-10 | 2025-03-31 | 16d | 31787d | 4d |  |  | Non-SIT S&A QT Test Team | Non-SIT S&A QT Test Team | 326.33 | 5.27 | Laura Kennedy | Red | RED |

Notes:
- 1631: Action: 6/8/24: To be split into 2 tasks - jordan awaiting update. Successor?
- 1634: Action: 6/8/24: Will have to reflect the start of the new maintenence window

| ID | WBS | Task | Type | Duration | Start | Finish | Predecessors | Complete | Remaining | Baseline start | Baseline finish | Baseline duration | Total slack | Free slack | Constraint | Baseline cost | Responsible | Involved | Task Status | Update Version | MHHS Resource Name | Sched Status | RAG | Milestone ID | Text29 |
| --- | --- | --- | --- | --- | --- | --- | --- | --- | --- | --- | --- | --- | --- | --- | --- | --- | --- | --- | --- | --- | --- | --- | --- | --- | --- |
| 1648 | 1.6.4.1.7.6.6 | **Wave 3 Test Data** |  | 45d | 2025-09-08 | 2025-11-07 |  |  |  | 2025-03-31 | 2025-05-30 | 45d | 31783d |  |  |  | N/A | N/A | -596.67 | 5.27 | N/A |  |  |  |  |
| 1649 | 1.6.4.1.7.6.6.1 | Test Data Request + Templates Completed |  | 15d | 2025-09-08 | 2025-09-26 | 1742 |  |  | 2025-03-31 | 2025-04-18 | 15d | 31783d | 0d |  |  | Participants | Participants | 353.33 | 5.27 | Laura Kennedy | Red | RED |  |  |
| 1650 | 1.6.4.1.7.6.6.2 | Test Data Generated |  | 10d | 2025-09-29 | 2025-10-10 | 1649 |  |  | 2025-04-21 | 2025-05-02 | 10d | 31783d | 0d |  |  | Non-SIT S&A QT Test Team | Non-SIT S&A QT Test Team | 374.33 | 5.27 | Laura Kennedy | Red | RED |  |  |
| 1651 | 1.6.4.1.7.6.6.3 | Test Data Loaded into QP Systems |  | 20d | 2025-10-13 | 2025-11-07 | 1650 |  |  | 2025-05-05 | 2025-05-30 | 20d | 31783d | 0d |  |  | Participants | Participants | 388.33 | 5.27 | Laura Kennedy | Red | RED |  |  |
| 1652 | 1.6.4.1.7.6.6.4 | Test Data Loaded into QTF + ADO |  | 20d | 2025-10-13 | 2025-11-07 | 1650 |  |  | 2025-05-05 | 2025-05-30 | 20d | 31783d | 0d |  |  | Non-SIT S&A QT Test Team | Non-SIT S&A QT Test Team | 388.33 | 5.27 | Laura Kennedy | Red | RED |  |  |
| 1653 | 1.6.4.1.7.6.7 | **Wave 4 Test Data** |  | 45d | 2025-11-06 | 2026-01-07 |  |  |  | 2025-05-30 | 2025-07-31 | 45d | 31784d |  |  |  | N/A | N/A | -596.67 | 5.27 | N/A |  |  |  |  |
| 1654 | 1.6.4.1.7.6.7.1 | Test Data Request + Templates Completed |  | 15d | 2025-11-06 | 2025-11-26 | 1772 |  |  | 2025-05-30 | 2025-06-19 | 15d | 31784d | 0d |  |  | Participants | Participants | 412.33 | 5.27 | Laura Kennedy | Red | RED |  |  |
| 1655 | 1.6.4.1.7.6.7.2 | Test Data Generated |  | 10d | 2025-11-27 | 2025-12-10 | 1654 |  |  | 2025-06-20 | 2025-07-03 | 10d | 31784d | 0d |  |  | Non-SIT S&A QT Test Team | Non-SIT S&A QT Test Team | 433.33 | 5.27 | Laura Kennedy | Red | RED |  |  |
| 1656 | 1.6.4.1.7.6.7.3 | Test Data Loaded into QP Systems |  | 20d | 2025-12-11 | 2026-01-07 | 1655 |  |  | 2025-07-04 | 2025-07-31 | 20d | 31784d | 2d |  |  | Participants | Participants | 447.33 | 5.27 | Laura Kennedy | Red | RED |  |  |
| 1657 | 1.6.4.1.7.6.7.4 | Test Data Loaded into QTF + ADO |  | 20d | 2025-12-11 | 2026-01-07 | 1655 |  |  | 2025-07-04 | 2025-07-31 | 20d | 31784d | 2d |  |  | Non-SIT S&A QT Test Team | Non-SIT S&A QT Test Team | 447.33 | 5.27 | Laura Kennedy | Red | RED |  |  |
| 1658 | 1.6.4.1.7.7 | **Governance** |  | 130d | 2024-07-01 A | 2024-12-27 |  | 29% | 92.67d | 2024-07-01 | 2024-12-27 | 130d | 32522d |  |  |  | N/A | N/A | -594.67 | 5.27 | N/A |  |  |  |  |
| 1659 | 1.6.4.1.7.7.1 | Onboarding Strategy and Develop Training Requirements & Materials Inc. Day in the Life |  | 65d | 2024-07-01 A | 2024-09-27 | 1585 | 43% | 37d | 2024-07-01 | 2024-09-27 | 65d | 32587d | 0d |  |  | Non-SIT S&A QT Test Team | Non-SIT S&A QT Test Team |  | 5.27 | Laura Kennedy | Green | GREEN |  |  |
| 1660 | 1.6.4.1.7.7.2 | Design Approach & Set-Up ADO Tool for Test & Defect Management Tool |  | 45d | 2024-07-01 A | 2024-08-30 | 1659SS | 62% | 17d | 2024-07-01 | 2024-08-30 | 45d | 31964d | 0d |  |  | Non-SIT S&A QT Test Team | Non-SIT S&A QT Test Team |  | 5.27 | Laura Kennedy | Green | GREEN |  |  |
| 1661 | 1.6.4.1.7.7.3 | Knowledge Transfer, Training, Demonstrations, Documentation, Governance |  | 85d | 2024-09-02 | 2024-12-27 | 1659SS+45d |  |  | 2024-09-02 | 2024-12-27 | 85d | 31924d | 0d |  |  | Non-SIT S&A QT Test Team | Non-SIT S&A QT Test Team | -17.67 | 5.27 | Laura Kennedy | Green | GREEN |  |  |
| 1662 | 1.6.4.1.7.8 | Qualification Testing Wave Readiness Confirmed | milestone | 0d | 2024-12-27 | 2024-12-27 | 1661 |  |  | 2025-01-23 | 2025-01-23 | 0d | 31924d | 141d |  |  | Non-SIT S&A QT Test Team | Non-SIT S&A QT Test Team, Code Bodies | 98.71 | 5.25 | Laura Kennedy | Green | GREEN | T3-QU-0117 | QAG |
| 1663 | 1.6.4.1.8 | **Wave Allocation** |  | 129d | 2024-01-02 A | 2024-06-28 A |  | 100% |  | 2024-01-02 | 2024-06-28 | 128d |  |  |  | -0 | N/A | N/A | -133.67 | 5.24 | N/A |  |  |  |  |
| 1664 | 1.6.4.1.8.1 | Draft Pre-Qualification Submission (PQS) document |  | 20d | 2024-01-02 A | 2024-01-29 A |  | 100% |  | 2024-01-02 | 2024-01-29 | 20d |  |  | finish no earlier than 2024-01-26 |  | Code Bodies | Code Bodies |  | 5.24 | Laura Kennedy | Complete | COMPLETE |  |  |
| 1665 | 1.6.4.1.8.2 | Publish PQS document |  | 1d | 2024-01-31 A | 2024-01-31 A |  | 100% |  | 2024-01-31 | 2024-01-31 | 1d |  |  | start no earlier than 2024-01-31 |  | Code Bodies | Code Bodies |  | 5.24 | Laura Kennedy | Complete | COMPLETE |  |  |
| 1666 | 1.6.4.1.8.3 | PQS Submission window |  | 60d | 2024-02-05 A | 2024-04-26 A |  | 100% |  | 2024-02-05 | 2024-04-26 | 60d |  |  | start no earlier than 2024-02-05 |  | Participants | Participants |  | 5.24 | Laura Kennedy | Complete | COMPLETE |  |  |
| 1667 | 1.6.4.1.8.4 | Pre-Qualification Submission and PIT Test Plan Deadline for Submission​ | milestone | 0d | 2024-04-26 A | 2024-04-26 A | 1666 | 100% |  | 2024-04-26 | 2024-04-26 | 0d |  |  |  |  | Participants | Participants |  | 5.25 | Laura Kennedy | Complete | COMPLETE | T3-QU-0118 | QAG |
| 1668 | 1.6.4.1.8.5 | PQS Review by Code Bodies |  | 25d | 2024-04-29 A | 2024-05-31 A | 1666, 1667 | 100% |  | 2024-04-29 | 2024-05-31 | 25d |  |  |  |  | Code Bodies | Code Bodies |  | 5.24 | Laura Kennedy | Complete | COMPLETE |  |  |
| 1669 | 1.6.4.1.8.6 | Draft Wave Allocations |  | 15d | 2024-06-03 A | 2024-06-21 A | 1668 | 100% |  | 2024-06-03 | 2024-06-21 | 15d |  |  |  |  | Code Bodies | Code Bodies |  | 5.24 | Laura Kennedy | Complete | COMPLETE |  |  |
| 1670 | 1.6.4.1.8.7 | Confirmation of participant Qualification Wave allocation | milestone | 0d | 2024-06-28 A | 2024-06-28 A | 1669FS+5d | 100% |  | 2024-06-28 | 2024-06-28 | 0d |  |  |  |  | Code Bodies | Code Bodies |  | 5.28 | Laura Kennedy | Complete | COMPLETE | T3-QU-0012 | QAG |
| 1671 | 1.6.4.2 | **Qualification Wave 1** |  | 240d | 2025-03-21 | 2026-02-20 |  |  |  | 2024-10-14 | 2025-08-29 | 229d | 31783d |  |  | -0 | N/A | N/A | -133.67 | 5.24 | N/A |  |  |  |  |
| 1672 | 1.6.4.2.1 | **Qualification Wave 1 QAD Prep** |  | 79d | 2025-03-21 | 2025-07-10 |  |  |  | 2024-10-14 | 2025-01-31 | 80d | 31785d |  |  | -0 | N/A | N/A | -152.67 | 5.24 | N/A |  |  |  |  |
| 1673 | 1.6.4.2.1.1 | Initial QAD Submission window opens | milestone | 0d | 2025-03-21 | 2025-03-21 | 1670, 1495FS+120d |  |  | 2024-10-14 | 2024-10-14 | 0d | 31785d | 0d |  |  | Participants | Participants | 182.71 | 5.24 | Laura Kennedy | Red | RED |  |  |
| 1674 | 1.6.4.2.1.2 | Qualification Wave 1 Participants Submit Initial QAD |  | 49d | 2025-03-24 | 2025-05-29 | 1673 |  |  | 2024-10-14 | 2024-12-20 | 50d | 31785d | 0d |  |  | Participants | Participants | 185.33 | 5.24 | Laura Kennedy | Red | RED |  |  |
| 1675 | 1.6.4.2.1.3 | Qualification Wave 1 Participants have submitted their initial QAD | milestone | 0d | 2025-05-29 | 2025-05-29 | 1674 |  |  | 2024-12-20 | 2024-12-20 | 0d | 31785d | 0d |  |  | Participants | Participants | 251.71 | 5.25 | Laura Kennedy | Red | RED | T3-QU-0094 | QAG |
| 1676 | 1.6.4.2.1.4 | Code Bodies review of Wave 1 Participants Initial QAD |  | 30d | 2025-05-30 | 2025-07-10 | 1674, 1675 |  |  | 2024-12-23 | 2025-01-31 | 30d | 31785d | 0d |  |  | Code Bodies | Code Bodies | 252.33 | 5.24 | Laura Kennedy | Red | RED |  |  |
| 1677 | 1.6.4.2.1.5 | Completion of Code Bodies review of Initial QAD | milestone | 0d | 2025-07-10 | 2025-07-10 | 1676 |  |  | 2025-01-31 | 2025-01-31 | 0d | 31785d | 1d |  |  | Code Bodies | Code Bodies | 293.71 | 5.24 | Laura Kennedy | Red | RED |  |  |

| ID | WBS | Task | Type | Duration | Start | Finish | Predecessors | Baseline start | Baseline finish | Baseline duration | Total slack | Free slack | Constraint | Baseline cost | Responsible | Involved | Task Status | Update Version | MHHS Resource Name | Sched Status | RAG | Milestone ID | Text29 |
| --- | --- | --- | --- | --- | --- | --- | --- | --- | --- | --- | --- | --- | --- | --- | --- | --- | --- | --- | --- | --- | --- | --- | --- |
| 1678 | 1.6.4.2.2 | **Qualification Wave 1 Test Prep** |  | 60d | 2025-04-14 | 2025-07-04 |  | 2024-11-01 | 2025-01-24 | 60d | 31789d |  |  | -0 | N/A | N/A | -555.67 | 5.24 | N/A |  |  |  |  |
| 1679 | 1.6.4.2.2.1 | Confirmation from Qualification Wave 1 Participants that DIP onboarding has commenced | milestone | 0d | 2025-04-14 | 2025-04-14 |  | 2024-11-01 | 2024-11-01 | 0d | 31809d | 0d | start no earlier than 2025-04-14 |  | Participants | Participants | 206.33 | 5.24 | Laura Kennedy | Red | RED | T3-QU-0017 | QAG |
| 1680 | 1.6.4.2.2.2 | Qualification Wave 1 Participants DIP Onboarding Window |  | 35d | 2025-04-14 | 2025-05-30 | 1679 | 2024-11-04 | 2024-12-20 | 35d | 31809d | 0d |  |  | Participants | Participants | 206.33 | 5.24 | Laura Kennedy | Red | RED |  |  |
| 1681 | 1.6.4.2.2.3 | Confirmation from Qualification Wave 1 Participants that DIP onboarding has completed | milestone | 0d | 2025-05-30 | 2025-05-30 | 1680 | 2024-12-20 | 2024-12-20 | 0d | 31809d | 25d |  |  | Participants | Participants | 252.71 | 5.24 | Laura Kennedy | Red | RED |  |  |
| 1682 | 1.6.4.2.2.4 | Qualification Wave 1 Participants' to provide status of PIT completion and submit QT Test Plan | milestone | 0d | 2025-05-12 | 2025-05-12 |  | 2024-11-29 | 2024-11-29 | 0d | 31783d | 0d | start no earlier than 2025-05-12 |  | Participants | Participants | 234.33 | 5.25 | Laura Kennedy | Red | RED | T3-QU-0095 | QAG |
| 1683 | 1.6.4.2.2.5 | Review of Participants' PIT Status and QT Test Plan |  | 15d | 2025-05-12 | 2025-05-30 | 1682 | 2024-12-02 | 2024-12-20 | 15d | 31809d | 0d |  |  | Code Bodies, Non-SIT S&A QT Test Team | Code Bodies, Non-SIT S&A QT Test Team | 234.33 | 5.24 | Laura Kennedy | Red | RED |  |  |
| 1684 | 1.6.4.2.2.6 | Qualification Test Plans for Wave 1 Participants approved | milestone | 0d | 2025-05-30 | 2025-05-30 | 1683 | 2024-12-20 | 2024-12-20 | 0d | 31809d | 25d |  |  | Non-SIT S&A QT Test Team | Non-SIT S&A QT Test Team | 252.71 | 5.24 | Laura Kennedy | Red | RED | T3-QU-0016 | QAG |
| 1685 | 1.6.4.2.2.7 | Qualification Wave 1 Participants have submitted PIT Test Completion Report and evidence for QT Entry | milestone | 0d | 2025-06-02 | 2025-06-02 |  | 2024-12-20 | 2024-12-20 | 0d | 31784d | 0d | start no earlier than 2025-06-02 |  | Participants | Participants | 255.33 | 5.25 | Laura Kennedy | Red | RED | T3-QU-0096 | QAG |
| 1686 | 1.6.4.2.2.8 | Review of Participants PIT Test Completion Report |  | 25d | 2025-06-02 | 2025-07-04 | 1685 | 2024-12-23 | 2025-01-24 | 25d | 31784d | 0d |  |  | Code Bodies, Non-SIT S&A QT Test Team | Code Bodies, Non-SIT S&A QT Test Team | 255.33 | 5.24 | Laura Kennedy | Red | RED |  |  |
| 1687 | 1.6.4.2.2.9 | Onboarding to QTF & ADO |  | 25d | 2025-06-02 | 2025-07-04 | 1686SS, 1604 | 2024-12-23 | 2025-01-24 | 25d | 31789d | 6d |  |  | Code Bodies, Non-SIT S&A QT Test Team | Code Bodies, Non-SIT S&A QT Test Team | 255.33 | 5.25 | Laura Kennedy | Red | RED |  |  |
| 1688 | 1.6.4.2.3 | **Qualification Wave 1 QT Execution** |  | 100d | 2025-07-07 | 2025-11-21 |  | 2025-01-27 | 2025-06-13 | 100d | 31784d |  |  | -0 | N/A | N/A | -152.67 | 5.24 | N/A |  |  |  |  |
| 1689 | 1.6.4.2.3.1 | Review Entry Criteria Evidence for each Wave 1 Participant |  | 5d | 2025-07-07 | 2025-07-11 | 1677FF, 1681, 1684, 1686 | 2025-01-27 | 2025-01-31 | 5d | 31784d | 1d |  |  | Non-SIT S&A QT Test Team | Non-SIT S&A QT Test Team | 290.33 | 5.24 | Laura Kennedy | Red | RED |  |  |
| 1690 | 1.6.4.2.3.2 | Qualification Wave 1 Participant Test Readiness Confirmed | milestone | 0d | 2025-07-14 | 2025-07-14 | 1676, 1677, 1689FF, 1641, 1642 | 2025-01-31 | 2025-01-31 | 0d | 31783d | 0d |  |  | Non-SIT S&A QT Test Team | Non-SIT S&A QT Test Team | 297.71 | 5.24 | Laura Kennedy | Red | RED | T3-QU-0027 | QAG |
| 1691 | 1.6.4.2.3.3 | Qualification Wave 1 QT Execution Start | milestone | 0d | 2025-07-14 | 2025-07-14 | 1690, 1662, 1687, 1125 | 2025-02-03 | 2025-02-03 | 0d | 31783d | 0d | start no earlier than 2025-07-14 |  | Participants | Participants | 297.71 | 5.24 | Laura Kennedy | Red | RED | T3-QU-0028 | QAG |
| 1692 | 1.6.4.2.3.4 | Qualification Wave 1 QT Execution Window |  | 95d | 2025-07-14 | 2025-11-21 | 1691FS-1d | 2025-02-03 | 2025-06-13 | 95d | 31788d | 0d |  |  | Participants | Participants | 297.33 | 5.24 | Laura Kennedy | Red | RED |  |  |
| 1693 | 1.6.4.2.3.5 | Qualification Wave 1 QT Projected Execution End | milestone | 0d | 2025-11-21 | 2025-11-21 | 1692 | 2025-06-13 | 2025-06-13 | 0d | 31788d | 5d |  |  | Participants | Participants | 427.71 | 5.24 | Laura Kennedy | Red | RED | T3-QU-0054 | QAG |
| 1694 | 1.6.4.2.4 | **Qualification Wave 1 Exit** |  | 159d | 2025-07-14 | 2026-02-20 |  | 2025-02-03 | 2025-08-29 | 149d? | 31783d |  |  | -0 | N/A | N/A | -152.67 | 5.24 | N/A |  |  |  |  |
| 1695 | 1.6.4.2.4.1 | Final QAD Submission window opens | milestone | 0d | 2025-07-14 | 2025-07-14 | 1691 | 2025-02-03 | 2025-02-03 | 0d | 31783d | 0d |  |  | Participants | Participants | 297.71 | 5.24 | Laura Kennedy | Red | RED |  |  |
| 1696 | 1.6.4.2.4.2 | Qualification Wave 1 Participants submit their Final QAD |  | 99d | 2025-07-15 | 2025-11-28 | 1695 | 2025-02-03 | 2025-06-20 | 100d | 31783d | 0d |  |  | Participants | Participants | 298.33 | 5.24 | Laura Kennedy | Red | RED |  |  |
| 1697 | 1.6.4.2.4.3 | Qualification Wave 1 Participants have submitted their final QAD | milestone | 0d | 2025-11-28 | 2025-11-28 | 1696, 1693 | 2025-06-20 | 2025-06-20 | 0d | 31783d | 0d |  |  | Participants | Participants | 434.71 | 5.25 | Laura Kennedy | Red | RED | T3-QU-0097 | QAG |
| 1698 | 1.6.4.2.4.4 | Completion of Code Bodies review of Final QAD |  | 30d | 2025-12-01 | 2026-01-09 | 1696, 1697 | 2025-06-23 | 2025-07-18 | 20d | 31783d | 0d |  |  | Code Bodies | Code Bodies | 437.33 | 5.24 | Laura Kennedy | Red | RED |  |  |
| 1699 | 1.6.4.2.4.5 | QAD Sign Off deadline |  | 1d | 2026-01-22 | 2026-01-22 | 1698FS+8d | 2025-07-31 | 2025-07-31 | 1d | 31783d | 0d |  |  | Participants | Participants | 489.33 | 5.24 | Laura Kennedy | Red | RED |  |  |
| 1700 | 1.6.4.2.4.6 | Qualification Wave 1 Participants Qualification approved by BSC PAB and REC Manager | milestone | 0d | 2026-02-20 | 2026-02-20 | 1699FS+21d | 2025-08-29 | 2025-08-29 | 0d | 31783d | 0d |  |  | Code Bodies | Code Bodies | 518.71 | 5.24 | Laura Kennedy | Red | RED | T2-QU-0150 | QAG |
| 1701 | 1.6.4.3 | **Qualification Wave 2** |  | 249d | 2025-04-25 | 2026-04-09 |  | 2024-11-18 | 2025-10-31 | 249d | 31783d |  |  | -0 | N/A | N/A | -133.67 | 5.24 | N/A |  |  |  |  |
| 1702 | 1.6.4.3.1 | **Qualification Wave 2 QAD Prep** |  | 95d | 2025-04-25 | 2025-09-05 |  | 2024-11-18 | 2025-03-31 | 96d | 31783d |  |  | -0 | N/A | N/A | -154.67 | 5.24 | N/A |  |  |  |  |
| 1703 | 1.6.4.3.1.1 | Initial QAD Submission window opens | milestone | 0d | 2025-04-25 | 2025-04-25 | 1496FS+120d | 2024-11-18 | 2024-11-18 | 0d | 31783d | 0d |  |  | Participants | Participants | 217.71 | 5.24 | Laura Kennedy | Red | RED |  |  |
| 1704 | 1.6.4.3.1.2 | Qualification Wave 2 Participants Submit Initial QAD |  | 69d | 2025-04-28 | 2025-07-31 | 1703 | 2024-11-18 | 2025-02-21 | 70d | 31783d | 0d |  |  | Participants | Participants | 220.33 | 5.24 | Laura Kennedy | Red | RED |  |  |
| 1705 | 1.6.4.3.1.3 | Qualification Wave 2 Participants have submitted their initial QAD | milestone | 0d | 2025-07-31 | 2025-07-31 | 1704 | 2025-02-21 | 2025-02-21 | 0d | 31783d | 0d |  |  | Participants | Participants | 314.71 | 5.25 | Laura Kennedy | Red | RED | T3-QU-0098 | QAG |
| 1706 | 1.6.4.3.1.4 | Code Bodies review of Wave 2 Participants' Initial QAD |  | 26d | 2025-08-01 | 2025-09-05 | 1705 | 2025-02-24 | 2025-03-31 | 26d | 31783d | 0d |  |  | Code Bodies | Code Bodies | 315.33 | 5.24 | Laura Kennedy | Red | RED |  |  |
| 1707 | 1.6.4.3.1.5 | Completion of Code Bodies review of Initial QAD | milestone | 0d | 2025-09-05 | 2025-09-05 | 1706 | 2025-03-31 | 2025-03-31 | 0d | 31783d | 0d |  |  | Code Bodies | Code Bodies | 350.71 | 5.24 | Laura Kennedy | Red | RED |  |  |

Notes:
- 1691: 16/09/24 - Date updated to 14/07/25, in line with recalibration planning.

| ID | WBS | Task | Type | Duration | Start | Finish | Predecessors | Baseline start | Baseline finish | Baseline duration | Total slack | Free slack | Constraint | Baseline cost | Responsible | Involved | Task Status | Update Version | MHHS Resource Name | Sched Status | RAG | Milestone ID | Text29 |
| --- | --- | --- | --- | --- | --- | --- | --- | --- | --- | --- | --- | --- | --- | --- | --- | --- | --- | --- | --- | --- | --- | --- | --- |
| 1708 | 1.6.4.3.2 | **Qualification Wave 2 Test Prep** |  | 60d | 2025-06-09 | 2025-08-29 |  | 2025-01-06 | 2025-03-28 | 60d | 31789d |  |  | -0 | N/A | N/A | -555.67 | 5.24 | N/A |  |  |  |  |
| 1709 | 1.6.4.3.2.1 | Confirmation from Qualification Wave 2 Participants that DIP Onboarding has commenced | milestone | 0d | 2025-06-09 | 2025-06-09 |  | 2025-01-06 | 2025-01-06 | 0d | 31808d | 0d | start no earlier than 2025-06-09 |  | Participants | Participants | 262.33 | 5.24 | Laura Kennedy | Red | RED | T3-QU-0021 | QAG |
| 1710 | 1.6.4.3.2.2 | Qualification Wave 2 Participants DIP Onboarding Window |  | 35d | 2025-06-09 | 2025-07-25 | 1709 | 2025-01-06 | 2025-02-28 | 40d | 31808d | 0d |  |  | Participants | Participants | 262.33 | 5.24 | Laura Kennedy | Red | RED |  |  |
| 1711 | 1.6.4.3.2.3 | Confirmation from Qualificiation Wave 2 Participants that DIP onboarding has completed | milestone | 0d | 2025-07-25 | 2025-07-25 | 1710 | 2025-02-28 | 2025-02-28 | 0d | 31808d | 25d |  |  | Participants | Participants | 308.71 | 5.24 | Laura Kennedy | Red | RED |  |  |
| 1712 | 1.6.4.3.2.4 | Qualification Wave 2 Participants' to provide status of PIT completion and submit QT Test Plan | milestone | 0d | 2025-07-07 | 2025-07-07 |  | 2025-01-31 | 2025-01-31 | 0d | 31787d | 0d | start no earlier than 2025-07-07 |  | Participants | Participants | 290.33 | 5.25 | Laura Kennedy | Red | RED | T3-QU-0099 | QAG |
| 1713 | 1.6.4.3.2.5 | Review of Participants' PIT Status and QT Test Plan |  | 15d | 2025-07-07 | 2025-07-25 | 1712 | 2025-02-03 | 2025-02-21 | 15d | 31808d | 0d | start no earlier than 2025-07-07 |  | Code Bodies, Non-SIT S&A QT Test Team | Code Bodies, Non-SIT S&A QT Test Team | 290.33 | 5.24 | Laura Kennedy | Red | RED |  |  |
| 1714 | 1.6.4.3.2.6 | Qualification Test Plans for Wave 2 Participants approved | milestone | 0d | 2025-07-25 | 2025-07-25 | 1713 | 2025-02-21 | 2025-02-21 | 0d | 31808d | 25d | start no earlier than 2025-07-25 |  | Non-SIT S&A QT Test Team | Non-SIT S&A QT Test Team | 308.71 | 5.24 | Laura Kennedy | Red | RED | T3-QU-0020 | QAG |
| 1715 | 1.6.4.3.2.7 | Qualification Wave 2 Participants have submitted PIT Test Completion Report and evidence for QT entry | milestone | 0d | 2025-07-28 | 2025-07-28 |  | 2025-02-21 | 2025-02-21 | 0d | 31783d | 0d | start no earlier than 2025-07-28 |  | Participants | Participants | 311.33 | 5.25 | Laura Kennedy | Red | RED | T3-QU-0100 | QAG |
| 1716 | 1.6.4.3.2.8 | Review of Participants' PIT Test Completion Report |  | 25d | 2025-07-28 | 2025-08-29 | 1715 | 2025-02-24 | 2025-03-28 | 25d | 31783d | 0d |  |  | Code Bodies, Non-SIT S&A QT Test Team | Code Bodies, Non-SIT S&A QT Test Team | 311.33 | 5.24 | Laura Kennedy | Red | RED |  |  |
| 1717 | 1.6.4.3.2.9 | Onboarding to QTF & ADO |  | 25d | 2025-07-28 | 2025-08-29 | 1716SS | 2025-02-24 | 2025-03-28 | 25d | 31789d | 6d |  |  | Code Bodies, Non-SIT S&A QT Test Team | Code Bodies, Non-SIT S&A QT Test Team | 311.33 | 5.25 | Laura Kennedy | Red | RED |  |  |
| 1718 | 1.6.4.3.3 | **Qualification Wave 2 QT Execution** |  | 98d | 2025-09-01 | 2026-01-14 |  | 2025-03-25 | 2025-08-08 | 99d | 31783d |  |  | -0 | N/A | N/A | -154.67 | 5.24 | N/A |  |  |  |  |
| 1719 | 1.6.4.3.3.1 | Review Entry Criteria Evidence for each Wave 2 Participant |  | 5d | 2025-09-01 | 2025-09-05 | 1707FF, 1711, 1714, 1716 | 2025-03-25 | 2025-03-31 | 5d | 31783d | 0d |  |  | Non-SIT S&A QT Test Team | Non-SIT S&A QT Test Team | 346.33 | 5.24 | Laura Kennedy | Red | RED |  |  |
| 1720 | 1.6.4.3.3.2 | Qualification Wave 2 Participant Test Readiness Confirmed | milestone | 0d | 2025-09-08 | 2025-09-08 | 1719FS+1d, 1707, 1646, 1647 | 2025-03-31 | 2025-03-31 | 0d | 31783d | 0d |  |  | Non-SIT S&A QT Test Team | Non-SIT S&A QT Test Team | 353.71 | 5.24 | Laura Kennedy | Red | RED | T3-QU-0033 | QAG |
| 1721 | 1.6.4.3.3.3 | Qualification Wave 2 Execution Start | milestone | 0d | 2025-09-08 | 2025-09-08 | 1720, 1717 | 2025-04-01 | 2025-04-01 | 0d | 31783d | 0d |  |  | Participants | Participants | 353.71 | 5.24 | Laura Kennedy | Red | RED | T3-QU-0034 | QAG |
| 1722 | 1.6.4.3.3.4 | Qualification Wave 2 QT Execution Window |  | 93d | 2025-09-08 | 2026-01-14 | 1721SS-1d | 2025-04-01 | 2025-08-08 | 94d | 31789d | 0d |  |  | Participants | Participants | 353.33 | 5.24 | Laura Kennedy | Red | RED |  |  |
| 1723 | 1.6.4.3.3.5 | Qualfication Wave 2 QT Execution End | milestone | 0d | 2026-01-14 | 2026-01-14 | 1722 | 2025-08-08 | 2025-08-08 | 0d | 31789d | 6d |  |  | Participants | Participants | 481.71 | 5.24 | Laura Kennedy | Red | RED | T3-QU-0055 | QAG |
| 1724 | 1.6.4.3.4 | **Qualification Wave 2 Exit** |  | 153d | 2025-09-08 | 2026-04-09 |  | 2025-04-01 | 2025-10-31 | 153d | 31783d |  |  | -0 | N/A | N/A | -154.67 | 5.24 | N/A |  |  |  |  |
| 1725 | 1.6.4.3.4.1 | Final QAD Submission window opens | milestone | 0d | 2025-09-08 | 2025-09-08 | 1721 | 2025-04-01 | 2025-04-01 | 0d | 31783d | 0d |  |  | Participants | Participants | 353.71 | 5.24 | Laura Kennedy | Red | RED |  |  |
| 1726 | 1.6.4.3.4.2 | Qualification Wave 2 Participants submit their Final QAD |  | 98d | 2025-09-09 | 2026-01-22 | 1725 | 2025-04-01 | 2025-08-15 | 99d | 31783d | 0d |  |  | Participants | Participants | 354.33 | 5.24 | Laura Kennedy | Red | RED |  |  |
| 1727 | 1.6.4.3.4.3 | Qualification Wave 2 Participants have submitted their final QAD | milestone | 0d | 2026-01-22 | 2026-01-22 | 1726, 1723 | 2025-08-15 | 2025-08-15 | 0d | 31783d | 0d |  |  | Participants | Participants | 489.71 | 5.25 | Laura Kennedy | Red | RED | T3-QU-0101 | QAG |
| 1728 | 1.6.4.3.4.4 | Completion of Code Bodies review of Final QAD |  | 27d | 2026-01-23 | 2026-03-02 | 1727 | 2025-08-18 | 2025-09-23 | 27d | 31783d | 0d |  |  | Code Bodies | Code Bodies | 490.33 | 5.24 | Laura Kennedy | Red | RED |  |  |
| 1729 | 1.6.4.3.4.5 | QAD Sign Off deadline |  | 1d | 2026-03-09 | 2026-03-09 | 1728FS+4d | 2025-09-30 | 2025-09-30 | 1d | 31783d | 0d |  |  | Participants | Participants | 535.33 | 5.24 | Laura Kennedy | Red | RED |  |  |
| 1730 | 1.6.4.3.4.6 | Qualification Wave 2 Participants Qualification approved by BSC PAB and REC Manager | milestone | 0d | 2026-04-09 | 2026-04-09 | 1729FS+23d | 2025-10-31 | 2025-10-31 | 0d | 31783d | 0d |  |  | Code Bodies | Code Bodies | 566.71 | 5.24 | Laura Kennedy | Red | RED | T2-QU-0200 | QAG |
| 1731 | 1.6.4.4 | **Qualification Wave 3** |  | 239d | 2025-06-27 | 2026-05-28 |  | 2025-01-20 | 2025-12-19 | 239d | 90d |  |  | -0 | N/A | N/A | -133.67 | 5.24 | N/A |  |  |  |  |
| 1732 | 1.6.4.4.1 | **Qualification Wave 3 QAD Prep** |  | 94d | 2025-06-27 | 2025-11-06 |  | 2025-01-20 | 2025-05-30 | 95d | 31784d |  |  | -0 | N/A | N/A | -154.67 | 5.24 | N/A |  |  |  |  |
| 1733 | 1.6.4.4.1.1 | Initial QAD Submission window opens | milestone | 0d | 2025-06-27 | 2025-06-27 | 1497FS+120d | 2025-01-20 | 2025-01-20 | 0d | 31784d | 0d |  |  | Participants | Participants | 280.71 | 5.24 | Laura Kennedy | Red | RED |  |  |
| 1734 | 1.6.4.4.1.2 | Qualification Wave 3 Participants Submit Initial QAD |  | 64d | 2025-06-30 | 2025-09-25 | 1733 | 2025-01-20 | 2025-04-18 | 65d | 31784d | 0d |  |  | Participants | Participants | 283.33 | 5.24 | Laura Kennedy | Red | RED |  |  |
| 1735 | 1.6.4.4.1.3 | Qualification Wave 3 Participants have submitted their initial QAD | milestone | 0d | 2025-09-25 | 2025-09-25 | 1734 | 2025-04-18 | 2025-04-18 | 0d | 31784d | 0d |  |  | Participants | Participants | 370.71 | 5.25 | Laura Kennedy | Red | RED | T3-QU-0102 | QAG |
| 1736 | 1.6.4.4.1.4 | Code Bodies review of Wave 3 Participants' Initial QAD |  | 30d | 2025-09-26 | 2025-11-06 | 1735 | 2025-04-21 | 2025-05-30 | 30d | 31784d | 0d |  |  | Code Bodies | Code Bodies | 371.33 | 5.24 | Laura Kennedy | Red | RED |  |  |
| 1737 | 1.6.4.4.1.5 | Completion of Code Bodies review of Initial QAD | milestone | 0d | 2025-11-06 | 2025-11-06 | 1736 | 2025-05-30 | 2025-05-30 | 0d | 31784d | 1d |  |  | Code Bodies | Code Bodies | 412.71 | 5.24 | Laura Kennedy | Red | RED |  |  |

Notes:
- 1721: 6/8/24: Date at risk from scenario planning activity
- 1730: 14/5: Baseline and name updated after cr48 approval at psg on 1/5

| ID | WBS | Task | Type | Duration | Start | Finish | Predecessors | Baseline start | Baseline finish | Baseline duration | Total slack | Free slack | Constraint | Baseline cost | Responsible | Involved | Task Status | Update Version | MHHS Resource Name | Sched Status | RAG | Milestone ID | Text29 |
| --- | --- | --- | --- | --- | --- | --- | --- | --- | --- | --- | --- | --- | --- | --- | --- | --- | --- | --- | --- | --- | --- | --- | --- |
| 1738 | 1.6.4.4.2 | **Qualification Wave 3 Test Prep** |  | 65d | 2025-08-04 | 2025-10-31 |  | 2025-03-03 | 2025-05-30 | 65d | 31808d |  |  | -0 | N/A | N/A | -555.67 | 5.24 | N/A |  |  |  |  |
| 1739 | 1.6.4.4.2.1 | Qualification Wave 3 Participants' have started DIP Onboarding | milestone | 0d | 2025-08-04 | 2025-08-04 |  | 2025-03-03 | 2025-03-03 | 0d | 31813d | 0d | start no earlier than 2025-08-04 |  | Participants | Participants | 318.33 | 5.24 | Laura Kennedy | Red | RED | T3-QU-0025 | QAG |
| 1740 | 1.6.4.4.2.2 | Qualification Wave 3 Participants DIP Onboarding window |  | 35d | 2025-08-04 | 2025-09-19 | 1739 | 2025-03-03 | 2025-04-25 | 40d | 31813d | 0d | start no earlier than 2025-08-04 |  | Participants | Participants | 318.33 | 5.24 | Laura Kennedy | Red | RED |  |  |
| 1741 | 1.6.4.4.2.3 | Confirmation from Qualification Wave 3 Participants that DIP onboarding has completed | milestone | 0d | 2025-09-22 | 2025-09-22 | 1740 | 2025-04-25 | 2025-04-25 | 0d | 31813d | 30d | start no earlier than 2025-09-22 |  | Participants | Participants | 367.33 | 5.24 | Laura Kennedy | Red | RED |  |  |
| 1742 | 1.6.4.4.2.4 | Qualification Wave 3 Participants' to provide status of PIT completion and submit QT Test Plan | milestone | 0d | 2025-09-08 | 2025-09-08 |  | 2025-03-31 | 2025-03-31 | 0d | 31783d | 0d | start no earlier than 2025-09-08 |  | Participants | Participants | 353.33 | 5.25 | Laura Kennedy | Red | RED | T3-QU-0103 | QAG |
| 1743 | 1.6.4.4.2.5 | Review of Participants' PIT Status and QT Test Plan |  | 15d | 2025-09-08 | 2025-09-26 | 1742 | 2025-03-31 | 2025-04-18 | 15d | 32327d | 0d | start no earlier than 2025-09-08 |  | Code Bodies, Non-SIT S&A QT Test Team | Code Bodies, Non-SIT S&A QT Test Team | 353.33 | 5.24 | Laura Kennedy | Red | RED |  |  |
| 1744 | 1.6.4.4.2.6 | Qualification Test Plans for Wave 3 Participants approved | milestone | 0d | 2025-09-26 | 2025-09-26 | 1743 | 2025-04-18 | 2025-04-18 | 0d | 32327d |  | start no earlier than 2025-09-26 |  | Non-SIT S&A QT Test Team | Non-SIT S&A QT Test Team | 371.71 | 5.24 | Laura Kennedy | Red | RED | T3-QU-0024 | QAG |
| 1745 | 1.6.4.4.2.7 | Qualification Wave 3 Participants have submitted PIT Test Completion Report and evidence for QT Entry | milestone | 0d | 2025-09-29 | 2025-09-29 |  | 2025-04-18 | 2025-04-18 | 0d | 31783d | 0d | start no earlier than 2025-09-29 |  | Participants | Participants | 374.33 | 5.25 | Laura Kennedy | Red | RED | T3-QU-0104 | QAG |
| 1746 | 1.6.4.4.2.8 | Review of Participants' PIT Test Completion Report |  | 25d | 2025-09-29 | 2025-10-31 | 1745 | 2025-04-21 | 2025-05-30 | 30d | 31783d | 0d | start no earlier than 2025-09-29 |  | Code Bodies, Non-SIT S&A QT Test Team | Code Bodies, Non-SIT S&A QT Test Team | 374.33 | 5.24 | Laura Kennedy | Red | RED |  |  |
| 1747 | 1.6.4.4.2.9 | Onboarding to QTF & ADO |  | 25d | 2025-09-29 | 2025-10-31 | 1746SS | 2025-04-21 | 2025-05-30 | 30d | 31783d | 0d | finish no earlier than 2025-10-31 |  |  |  | 374.33 | 5.24 | Laura Kennedy | Red | RED |  |  |
| 1748 | 1.6.4.4.3 | **Qualification Wave 3 QT Execution** |  | 102d | 2025-11-03 | 2026-03-24 |  | 2025-05-26 | 2025-10-10 | 100d |  |  |  | -0 | N/A | N/A | -154.67 | 5.24 | N/A |  |  |  |  |
| 1749 | 1.6.4.4.3.1 | Review Entry Criteria Evidence for each Wave 3 Participant |  | 5d | 2025-11-03 | 2025-11-07 | 1741, 1737FF, 1747 | 2025-05-26 | 2025-05-30 | 5d | 31783d | 0d | start no earlier than 2025-11-03 |  | Non-SIT S&A QT Test Team | Non-SIT S&A QT Test Team | 409.33 | 5.24 | Laura Kennedy | Red | RED |  |  |
| 1750 | 1.6.4.4.3.2 | Qualification Wave 3 Participant Test Readiness confirmed | milestone | 0d | 2025-11-10 | 2025-11-10 | 1741, 1749, 1651, 1652 | 2025-05-30 | 2025-05-30 | 0d | 31783d | 0d | start no earlier than 2025-11-10 |  | Non-SIT S&A QT Test Team | Non-SIT S&A QT Test Team | 416.33 | 5.24 | Laura Kennedy | Red | RED | T3-QU-0038 | QAG |
| 1751 | 1.6.4.4.3.3 | Qualification Wave 3 Execution Start | milestone | 0d | 2025-11-10 | 2025-11-10 | 1750, 1747 | 2025-06-02 | 2025-06-02 | 0d | 31783d | 0d | start no earlier than 2025-11-03 |  | Participants | Participants | 416.33 | 5.24 | Laura Kennedy | Red | RED | T3-QU-0039 | QAG |
| 1752 | 1.6.4.4.3.4 | Qualification Wave 3 QT Execution Window |  | 96d | 2025-11-10 | 2026-03-23 | 1749, 1751 | 2025-06-02 | 2025-10-10 | 95d | 31786d | 0d |  |  | Participants | Participants | 416.33 | 5.24 | Laura Kennedy | Red | RED |  |  |
| 1753 | 1.6.4.4.3.5 | Qualification Wave 3 Projected Execution End | milestone | 0d | 2026-03-23 | 2026-03-23 | 1752 | 2025-10-10 | 2025-10-10 | 0d | 31786d | 3d |  |  | Participants | Participants | 549.71 | 5.24 | Laura Kennedy | Red | RED | T3-QU-0056 | QAG |
| 1754 | 1.6.4.4.4 | **Qualification Wave 3 Exit** |  | 144d | 2025-11-10 | 2026-05-28 |  | 2025-06-02 | 2025-12-19 | 144d | 31783d |  |  | -0 | N/A | N/A | -154.67 | 5.24 | N/A |  |  |  |  |
| 1755 | 1.6.4.4.4.1 | Final QAD Submission window opens | milestone | 0d | 2025-11-10 | 2025-11-10 | 1751 | 2025-06-02 | 2025-06-02 | 0d | 31783d | 0d |  |  | Participants | Participants | 416.33 | 5.24 | Laura Kennedy | Red | RED |  |  |
| 1756 | 1.6.4.4.4.2 | Qualification Wave 3 Participants submit their Final QAD |  | 99d | 2025-11-10 | 2026-03-26 | 1755 | 2025-06-02 | 2025-10-17 | 100d | 31783d | 0d |  |  | Participants | Participants | 416.33 | 5.24 | Laura Kennedy | Red | RED |  |  |
| 1757 | 1.6.4.4.4.3 | Qualification Wave 3 Participants have submitted their Final QAD | milestone | 0d | 2026-03-26 | 2026-03-26 | 1756, 1753 | 2025-10-17 | 2025-10-17 | 0d | 31783d | 0d |  |  | Participants | Participants | 552.71 | 5.25 | Laura Kennedy | Red | RED | T3-QU-0105 | QAG |
| 1758 | 1.6.4.4.4.4 | Completion of Code Bodies review of Final QAD |  | 20d | 2026-03-27 | 2026-04-23 | 1757 | 2025-10-20 | 2025-11-14 | 20d | 31783d | 0d |  |  | Code Bodies | Code Bodies | 553.33 | 5.24 | Laura Kennedy | Red | RED |  |  |
| 1759 | 1.6.4.4.4.5 | QAD Sign Off deadline |  | 1d | 2026-04-30 | 2026-04-30 | 1758FS+4d | 2025-11-21 | 2025-11-21 | 1d | 31783d | 0d |  |  | Participants | Participants | 587.33 | 5.24 | Laura Kennedy | Red | RED |  |  |
| 1760 | 1.6.4.4.4.6 | Qualification Wave 3 Participants Qualification approved by BSC PAB and REC Manager | milestone | 0d | 2026-05-28 | 2026-05-28 | 1759FS+20d | 2025-12-19 | 2025-12-19 | 0d | 31783d | 0d |  |  | Code Bodies | Code Bodies | 615.71 | 5.24 | Laura Kennedy | Red | RED | T2-QU-0250 | QAG |
| 1761 | 1.6.4.5 | **Qualification Wave 4** |  | 337d | 2025-08-22 | 2026-12-08 |  | 2025-03-17 | 2026-02-27 | 249d | 31784d |  |  | -0 | N/A | N/A | -133.67 | 5.24 | N/A |  |  |  |  |
| 1762 | 1.6.4.5.1 | **Qualification Wave 4 QAD Prep** |  | 98d | 2025-08-22 | 2026-01-07 |  | 2025-03-17 | 2025-07-31 | 99d | 31784d |  |  | -0 | N/A | N/A | -155.67 | 5.24 | N/A |  |  |  |  |
| 1763 | 1.6.4.5.1.1 | Initial QAD Submission window opens | milestone | 0d | 2025-08-22 | 2025-08-22 | 1498FS+120d | 2025-03-17 | 2025-03-17 | 0d | 31784d | 0d |  |  | Participants | Participants | 336.71 | 5.24 | Laura Kennedy | Red | RED |  |  |
| 1764 | 1.6.4.5.1.2 | Qualification Wave 4 Participants Submit Initial QAD |  | 69d | 2025-08-25 | 2025-11-27 | 1763 | 2025-03-17 | 2025-06-20 | 70d | 31784d | 0d |  |  | Participants | Participants | 339.33 | 5.24 | Laura Kennedy | Red | RED |  |  |
| 1765 | 1.6.4.5.1.3 | Qualification Wave 4 Participants have submitted their Initial QAD | milestone | 0d | 2025-11-27 | 2025-11-27 | 1764 | 2025-06-20 | 2025-06-20 | 0d | 31784d | 0d |  |  | Participants | Participants | 433.71 | 5.25 | Laura Kennedy | Red | RED | T3-QU-0106 | QAG |
| 1766 | 1.6.4.5.1.4 | Code Bodies review of Wave 4 Participants' Initial QAD |  | 29d | 2025-11-28 | 2026-01-07 | 1765 | 2025-06-23 | 2025-07-31 | 29d | 31784d | 0d |  |  | Code Bodies | Code Bodies | 434.33 | 5.24 | Laura Kennedy | Red | RED |  |  |
| 1767 | 1.6.4.5.1.5 | Completion of Code Bodies review of Initial QAD | milestone | 0d | 2026-01-07 | 2026-01-07 | 1766 | 2025-07-31 | 2025-07-31 | 0d | 31784d | 2d |  |  | Code Bodies | Code Bodies | 474.71 | 5.24 | Laura Kennedy | Red | RED |  |  |

Notes:
- 1751: 6/8/24: Date at risk from scenario planning activity
- 1760: 14/5: Baseline and name updated after cr48 approval at psg on 1/5

| ID | WBS | Task | Type | Duration | Start | Finish | Predecessors | Baseline start | Baseline finish | Baseline duration | Baseline 1 start | Baseline 1 finish | Total slack | Free slack | Constraint | Baseline cost | Responsible | Involved | Task Status | Update Version | MHHS Resource Name | Sched Status | RAG | Milestone ID | Text29 | MHHS Programme Phase | Tier |
| --- | --- | --- | --- | --- | --- | --- | --- | --- | --- | --- | --- | --- | --- | --- | --- | --- | --- | --- | --- | --- | --- | --- | --- | --- | --- | --- | --- |
| 1768 | 1.6.4.5.2 | **Qualification Wave 4 Test Prep** |  | 55d | 2025-10-06 | 2025-12-19 |  | 2025-05-01 | 2025-08-01 | 67d |  |  | 31797d |  |  | -0 | N/A | N/A | -555.67 | 5.24 | N/A |  |  |  |  |  |  |
| 1769 | 1.6.4.5.2.1 | Confirmation from Qualification 4 Participants that DIP Onboarding has commenced | milestone | 0d | 2025-10-06 | 2025-10-06 |  | 2025-05-01 | 2025-05-01 | 0d |  |  | 31812d | 0d | start no earlier than 2025-10-06 |  | Participants | Participants | 381.33 | 5.24 | Laura Kennedy | Red | RED | T3-QU-0031 | QAG |  |  |
| 1770 | 1.6.4.5.2.2 | Qualification Wave 4 Participants DIP Onboarding Window |  | 35d | 2025-10-06 | 2025-11-21 | 1769 | 2025-05-01 | 2025-06-27 | 42d |  |  | 31812d | 0d |  |  | Participants | Participants | 381.33 | 5.24 | Laura Kennedy | Red | RED |  |  |  |  |
| 1771 | 1.6.4.5.2.3 | Confirmation from Qualification Wave 4 Participants that DIP onboarding has completed | milestone | 0d | 2025-11-21 | 2025-11-21 | 1770 | 2025-06-27 | 2025-06-27 | 0d |  |  | 31812d | 30d |  |  | Participants | Participants | 427.71 | 5.24 | Laura Kennedy | Red | RED |  |  |  |  |
| 1772 | 1.6.4.5.2.4 | Qualification Wave 4 Participants' to provide status of PIT completion and submit QT Test Plan | milestone | 0d | 2025-11-06 | 2025-11-06 |  | 2025-05-30 | 2025-05-30 | 0d |  |  | 31784d | 0d | start no earlier than 2025-11-06 |  | Participants | Participants | 412.33 | 5.25 | Laura Kennedy | Red | RED | T3-QU-0107 | QAG |  |  |
| 1773 | 1.6.4.5.2.5 | Review of Participants' PIT Status and QT Test Plan |  | 15d | 2025-11-06 | 2025-11-26 | 1772 | 2025-05-30 | 2025-06-20 | 16d |  |  | 31797d | 0d |  |  | Code Bodies, Non-SIT S&A QT Test Team | Code Bodies, Non-SIT S&A QT Test Team | 412.33 | 5.24 | Laura Kennedy | Red | RED |  |  |  |  |
| 1774 | 1.6.4.5.2.6 | Qualification Test Plans for Qualification Wave 4 Participants approved | milestone | 0d | 2025-11-26 | 2025-11-26 | 1773 | 2025-06-20 | 2025-06-20 | 0d |  |  | 31797d | 0d | start no earlier than 2025-11-26 |  | Non-SIT S&A QT Test Team | Non-SIT S&A QT Test Team | 432.71 | 5.24 | Laura Kennedy | Red | RED | T3-QU-0030 | QAG |  |  |
| 1775 | 1.6.4.5.2.7 | Qualification Wave 4 Participants have submitted PIT Test Completion Report and evidence for QT entry | milestone | 0d | 2025-11-27 | 2025-11-27 | 1774 | 2025-06-20 | 2025-06-20 | 0d |  |  | 31797d | 0d | start no earlier than 2025-11-27 |  | Participants | Participants | 433.33 | 5.25 | Laura Kennedy | Red | RED | T3-QU-0108 | QAG |  |  |
| 1776 | 1.6.4.5.2.8 | Review of Participants' PIT Test Completion Report |  | 17d | 2025-11-27 | 2025-12-19 | 1775 | 2025-06-20 | 2025-07-31 | 30d |  |  | 31797d | 0d |  |  | Code Bodies, Non-SIT S&A QT Test Team | Code Bodies, Non-SIT S&A QT Test Team | 433.33 | 5.24 | Laura Kennedy | Red | RED |  |  |  |  |
| 1777 | 1.6.4.5.2.9 | Onboarding to QTF & ADO |  | 17d | 2025-11-27 | 2025-12-19 | 1776SS | 2025-06-23 | 2025-08-01 | 30d |  |  | 31797d | 15d | start no earlier than 2025-11-24 |  | Code Bodies, Non-SIT S&A QT Test Team | Code Bodies, Non-SIT S&A QT Test Team | 433.33 | 5.25 | Laura Kennedy | Red | RED |  |  |  |  |
| 1778 | 1.6.4.5.3 | **Qualification Wave 4 QT Execution** |  | 100d | 2026-01-05 | 2026-05-22 |  | 2025-07-25 | 2025-12-12 | 101d |  |  | 31782d |  |  | -0 | N/A | N/A | -155.67 | 5.24 | N/A |  |  |  |  |  |  |
| 1779 | 1.6.4.5.3.1 | Review Entry Criteria Evidence for each Wave 4 Participant |  | 5d | 2026-01-05 | 2026-01-09 | 1767FF, 1771 | 2025-07-25 | 2025-07-31 | 5d |  |  | 31782d | 0d | start no earlier than 2026-01-05 |  | Non-SIT S&A QT Test Team | Non-SIT S&A QT Test Team | 472.33 | 5.24 | Laura Kennedy | Red | RED |  |  |  |  |
| 1780 | 1.6.4.5.3.2 | Qualification Wave 4 Participant Test Readiness Confirmed | milestone | 0d | 2026-01-12 | 2026-01-12 | 1771, 1779, 1656, 1657 | 2025-07-31 | 2025-07-31 | 0d |  |  | 31782d | 0d | start no earlier than 2026-01-12 |  | Non-SIT S&A QT Test Team | Non-SIT S&A QT Test Team | 479.33 | 5.24 | Laura Kennedy | Red | RED | T3-QU-0043 | QAG |  |  |
| 1781 | 1.6.4.5.3.3 | Qualification Wave 4 QT Execution Start | milestone | 0d | 2026-01-12 | 2026-01-12 | 1780, 1777 | 2025-08-01 | 2025-08-01 | 0d |  |  | 31782d | 0d | start no earlier than 2026-01-07 |  | Participants | Participants | 479.33 | 5.24 | Laura Kennedy | Red | RED | T3-QU-0044 | QAG |  |  |
| 1782 | 1.6.4.5.3.4 | Qualification Wave 4 QT Execution Window |  | 95d | 2026-01-12 | 2026-05-22 | 1781, 1779 | 2025-08-01 | 2025-12-12 | 96d |  |  | 31787d | 0d |  |  | Participants | Participants | 479.33 | 5.24 | Laura Kennedy | Red | RED |  |  |  |  |
| 1783 | 1.6.4.5.3.5 | Qualification Wave 4 Projected Execution End | milestone | 0d | 2026-05-22 | 2026-05-22 | 1782 | 2025-12-12 | 2025-12-12 | 0d |  |  | 31787d | 5d |  |  | Participants | Participants | 609.71 | 5.24 | Laura Kennedy | Red | RED | T3-QU-0057 | QAG |  |  |
| 1784 | 1.6.4.5.4 | **Qualification Wave 4 Exit** |  | 145d | 2026-01-12 | 2026-07-31 |  | 2025-08-01 | 2026-02-27 | 150d |  |  | 31782d |  |  | -0 | N/A | N/A | -155.67 | 5.24 | N/A |  |  |  |  |  |  |
| 1785 | 1.6.4.5.4.1 | Final QAD Submission window opens | milestone | 0d | 2026-01-12 | 2026-01-12 | 1781 | 2025-08-01 | 2025-08-01 | 0d |  |  | 31782d | 0d |  |  | Participants | Participants | 479.33 | 5.24 | Laura Kennedy | Red | RED |  |  |  |  |
| 1786 | 1.6.4.5.4.2 | Qualification Wave 4 Participants submit their Final QAD |  | 100d | 2026-01-12 | 2026-05-29 | 1785 | 2025-08-01 | 2025-12-19 | 101d |  |  | 31782d | 0d |  |  | Participants | Participants | 479.33 | 5.24 | Laura Kennedy | Red | RED |  |  |  |  |
| 1787 | 1.6.4.5.4.3 | Qualification Wave 4 Participants have submitted their Final QAD | milestone | 0d | 2026-05-29 | 2026-05-29 | 1786, 1783 | 2025-12-19 | 2025-12-19 | 0d |  |  | 31782d | 0d |  |  | Participants | Participants | 616.71 | 5.25 | Laura Kennedy | Red | RED | T3-QU-0109 | QAG |  |  |
| 1788 | 1.6.4.5.4.4 | Completion of Code Bodies review of Final QAD |  | 20d | 2026-06-01 | 2026-06-26 | 1787 | 2025-12-22 | 2026-01-23 | 25d |  |  | 31782d | 0d |  |  | Code Bodies | Code Bodies | 619.33 | 5.24 | Laura Kennedy | Red | RED |  |  |  |  |
| 1789 | 1.6.4.5.4.5 | QAD Sign Off deadline |  | 1d | 2026-07-03 | 2026-07-03 | 1788FS+4d | 2026-01-30 | 2026-01-30 | 1d |  |  | 31782d | 0d |  |  | Participants | Participants | 651.33 | 5.24 | Laura Kennedy | Red | RED |  |  |  |  |
| 1790 | 1.6.4.5.4.6 | Qualification Wave 4 Participants Qualification approved by BSC PAB and REC Manager | milestone | 0d | 2026-07-31 | 2026-07-31 | 1789FS+20d | 2026-02-27 | 2026-02-27 | 0d |  |  | 31782d | 0d |  |  | Code Bodies | Code Bodies | 679.71 | 5.24 | Laura Kennedy | Red | RED | T2-QU-0300 | QAG |  |  |
| 1791 | 1.6.4.5.5 | **Qualification Tier 1 Milestone** |  | 66d | 2026-09-07 | 2026-12-08 |  |  |  |  |  |  | 32015d |  |  |  |  |  | -686.67 |  |  | Overdue Start | RED |  |  |  |  |
| 1792 | 1.6.4.5.5.1 | All suppliers must be able to access MPANs under the new TOM (M14) | milestone | 0d | 2026-09-07 | 2026-09-07 | 1790FS+26d | 2026-03-16 | 2026-03-16 | 0d | 2026-03-16 | 2026-03-16 | 32015d | 0d | start no earlier than 2026-03-12 |  | CPT | CPT | 717.71 | 5.0 | CPT | Red | RED | T1-MI-5000 | PSG | Migration | T1 |
| 1793 | 1.6.4.5.5.2 | All suppliers must be able to access MPANs under the new TOM (M14*) - Late Exit | milestone | 0d | 2026-12-08 | 2026-12-08 | 1792FS+66d | 2026-06-16 | 2026-06-16 | 0d | 2026-06-16 | 2026-06-16 | 32015d |  |  |  | CPT | CPT | 809.71 | 5.0 | CPT | Red | RED | T1-MI-5500 | PSG | Migration | T1 |

Notes:
- 1781: 6/8/24: Date at risk from scenario planning activity
- 1790: 14/5: Baseline and name updated after cr48 approval at psg on 1/5
- 1792: Text3: All suppliers must be able to accept MPANs under the new TOM (one way gate)
- 1793: Text3: All suppliers must be able to accept MPANs under the new TOM (one way gate)

| ID | WBS | Task | Type | Duration | Start | Finish | Predecessors | Complete | Remaining | Baseline start | Baseline finish | Baseline duration | Baseline 1 start | Baseline 1 finish | Total slack | Constraint | Baseline cost | Responsible | Involved | MHHS Resource Name | MHHS Programme Phase | Update Version | Sched Status | RAG | Task Status | Artefact ID | Milestone ID | Text29 | Tier |
| --- | --- | --- | --- | --- | --- | --- | --- | --- | --- | --- | --- | --- | --- | --- | --- | --- | --- | --- | --- | --- | --- | --- | --- | --- | --- | --- | --- | --- | --- |
| 1794 | 1.7 | **REGULATORY** |  | 793d | 2022-10-31 A | 2025-11-12 |  | 93% | 52.41d | 2022-10-31 | 2025-06-06 | 680d | 2022-10-31 | 2025-03-07 | 32294d |  | -0 | N/A | N/A | N/A | Regulatory |  |  |  |  |  |  |  |  |
| 1795 | 1.7.1 | **Baseline MHHS Code Changes** |  | 475d | 2022-10-31 A | 2024-08-23 A |  | 100% |  | 2022-10-31 | 2024-08-23 | 475d | 2022-10-31 | 2024-08-23 |  |  | -0 | N/A | N/A | N/A | Regulatory | 5.0 |  |  |  |  |  |  |  |
| 1796 | 1.7.1.1 | **Preparation and planning** |  | 35d | 2022-10-31 A | 2022-12-16 A |  | 100% |  | 2022-10-31 | 2022-12-16 | 35d | 2022-10-31 | 2022-12-16 |  |  |  | N/A | N/A | N/A | Regulatory | 5.0 |  |  |  |  |  |  |  |
| 1797 | 1.7.1.1.1 | Impact assessment of Programme design on codes to determine required changes |  | 20d | 2022-10-31 A | 2022-11-25 A | 48 | 100% |  | 2022-10-31 | 2022-11-25 | 20d | 2022-10-31 | 2022-11-25 |  |  |  | Code Bodies,SRO Code Drafters | Code Drafting PM | Andrew Margan | Regulatory | 5.0 | Complete | COMPLETE |  |  |  |  |  |
| 1798 | 1.7.1.1.2 | Become 'code draft ready' |  | 35d | 2022-10-31 A | 2022-12-16 A |  | 100% |  | 2022-10-31 | 2022-12-16 | 35d | 2022-10-31 | 2022-12-16 |  |  |  | Code Bodies,SRO Code Drafters | Code Drafting PM | Andrew Margan | Regulatory | 5.0 | Complete | COMPLETE |  |  |  |  |  |
| 1799 | 1.7.1.1.3 | Soft start drafting where possible |  | 35d | 2022-10-31 A | 2022-12-16 A |  | 100% |  | 2022-10-31 | 2022-12-16 | 35d | 2022-10-31 | 2022-12-16 |  |  |  | Code Bodies,SRO Code Drafters | Code Drafting PM | Andrew Margan | Regulatory | 5.0 | Complete | COMPLETE |  |  |  |  |  |
| 1800 | 1.7.1.2 | **Code drafting** |  | 443d | 2022-12-12 A | 2024-08-21 A |  | 100% |  | 2022-12-12 | 2024-08-23 | 445d | 2022-12-12 | 2024-08-23 |  |  | -0 | N/A | N/A | N/A | Regulatory | 5.0 |  |  | M6 |  |  |  |  |
| 1801 | 1.7.1.2.1 | **Data Services (BSC driven)** |  | 118d | 2022-12-12 A | 2023-05-24 A |  | 100% |  | 2022-12-12 | 2023-05-24 | 118d | 2022-12-12 | 2023-05-24 |  |  |  | N/A | N/A | N/A | Regulatory | 5.0 |  |  | M6 |  |  |  |  |
| 1802 | 1.7.1.2.1.1 | Pre Code Drafting activities |  | 5d | 2022-12-12 A | 2022-12-16 A |  | 100% |  | 2022-12-12 | 2022-12-16 | 5d | 2022-12-12 | 2022-12-16 |  | start no earlier than 2022-12-12 |  | Code Drafting PM |  | Andrew Margan | Regulatory | 5.0 | Complete | COMPLETE |  |  |  |  |  |
| 1803 | 1.7.1.2.1.2 | Code and subsidiary document drafting takes place offline |  | 19d | 2023-01-03 A | 2023-01-27 A | 1802FS+11d | 100% |  | 2023-01-03 | 2023-01-27 | 19d | 2023-01-03 | 2023-01-27 |  |  |  | Code Bodies,SRO Design | Code Drafting PM | Andrew Margan | Regulatory | 5.0 | Complete | COMPLETE |  |  |  |  |  |
| 1804 | 1.7.1.2.1.3 | Internal review and cross-checking of drafting across code drafters |  | 11d | 2023-01-30 A | 2023-02-13 A | 1803 | 100% |  | 2023-01-30 | 2023-02-13 | 11d | 2023-01-30 | 2023-02-13 |  |  |  | Code Bodies,SRO Design | Code Drafting PM | Andrew Margan | Regulatory | 5.0 | Complete | COMPLETE |  |  |  |  |  |
| 1805 | 1.7.1.2.1.4 | External industry review via consultation |  | 20d | 2023-02-14 A | 2023-03-13 A | 1804 | 100% |  | 2023-02-14 | 2023-03-13 | 20d | 2023-02-14 | 2023-03-13 |  |  |  | PP | Code Drafting PM | Andrew Margan | Regulatory | 5.0 | Complete | COMPLETE |  |  |  |  |  |
| 1806 | 1.7.1.2.1.5 | Triage and action comments |  | 19d | 2023-03-10 A | 2023-04-05 A | 1805FS-2d | 100% |  | 2023-03-10 | 2023-04-05 | 19d | 2023-03-10 | 2023-04-05 |  |  |  | Code Bodies,SRO Design | Code Drafting PM | Andrew Margan | Regulatory | 5.0 | Complete | COMPLETE |  |  |  |  |  |
| 1807 | 1.7.1.2.1.6 | CDWG review |  | 30d | 2023-04-06 A | 2023-05-17 A | 1806 | 100% |  | 2023-04-06 | 2023-05-17 | 30d | 2023-04-06 | 2023-05-17 |  |  |  | PP | Code Drafting PM | Andrew Margan | Regulatory | 5.0 | Complete | COMPLETE |  |  |  |  |  |
| 1808 | 1.7.1.2.1.7 | CCAG review |  | 5d | 2023-05-18 A | 2023-05-24 A | 1807 | 100% |  | 2023-05-18 | 2023-05-24 | 5d | 2023-05-18 | 2023-05-24 |  |  |  | PP |  | Andrew Margan | Regulatory | 5.0 | Complete | COMPLETE |  |  |  |  |  |
| 1809 | 1.7.1.2.1.8 | Code drafting for Data Services topic area approved | milestone | 0d | 2023-05-24 A | 2023-05-24 A | 1808 | 100% |  | 2023-05-24 | 2023-05-24 | 0d | 2023-05-24 | 2023-05-24 |  |  |  | PP | Code Drafting PM | Andrew Margan | Regulatory | 5.0 | Complete | COMPLETE |  | MHHS-ART060 | T2-RE-0100 | CCAG | T2 |
| 1810 | 1.7.1.2.2 | **Metering (REC driven)** |  | 118d | 2022-12-12 A | 2023-05-24 A |  | 100% |  | 2022-12-12 | 2023-05-24 | 118d | 2022-12-12 | 2023-05-24 |  |  |  | N/A | N/A | N/A | Regulatory | 5.0 |  |  | M6 |  |  |  |  |
| 1811 | 1.7.1.2.2.1 | Pre Code Drafting activities |  | 5d | 2022-12-12 A | 2022-12-16 A | 1802SS | 100% |  | 2022-12-12 | 2022-12-16 | 5d | 2022-12-12 | 2022-12-16 |  |  |  | Code Drafting PM |  | Andrew Margan | Regulatory | 5.0 | Complete | COMPLETE |  |  |  |  |  |
| 1812 | 1.7.1.2.2.2 | Code and subsidiary document drafting takes place offline |  | 19d | 2023-01-03 A | 2023-01-27 A | 1811FS+11d | 100% |  | 2023-01-03 | 2023-01-27 | 19d | 2023-01-03 | 2023-01-27 |  |  |  | Code Bodies,SRO Design | Code Drafting PM | Andrew Margan | Regulatory | 5.0 | Complete | COMPLETE |  |  |  |  |  |
| 1813 | 1.7.1.2.2.3 | Internal review and cross-checking of drafting across code drafters |  | 11d | 2023-01-30 A | 2023-02-13 A | 1812 | 100% |  | 2023-01-30 | 2023-02-13 | 11d | 2023-01-30 | 2023-02-13 |  |  |  | Code Bodies,SRO Design | Code Drafting PM | Andrew Margan | Regulatory | 5.0 | Complete | COMPLETE |  |  |  |  |  |
| 1814 | 1.7.1.2.2.4 | External industry review via consultation |  | 20d | 2023-02-14 A | 2023-03-13 A | 1813 | 100% |  | 2023-02-14 | 2023-03-13 | 20d | 2023-02-14 | 2023-03-13 |  |  |  | PP | Code Drafting PM | Andrew Margan | Regulatory | 5.0 | Complete | COMPLETE |  |  |  |  |  |
| 1815 | 1.7.1.2.2.5 | Triage and action comments |  | 19d | 2023-03-10 A | 2023-04-05 A | 1814FS-2d | 100% |  | 2023-03-10 | 2023-04-05 | 19d | 2023-03-10 | 2023-04-05 |  |  |  | Code Bodies,SRO Design | Code Drafting PM | Andrew Margan | Regulatory | 5.0 | Complete | COMPLETE |  |  |  |  |  |
| 1816 | 1.7.1.2.2.6 | CDWG review |  | 30d | 2023-04-06 A | 2023-05-17 A | 1815 | 100% |  | 2023-04-06 | 2023-05-17 | 30d | 2023-04-06 | 2023-05-17 |  |  |  | PP | Code Drafting PM | Andrew Margan | Regulatory | 5.0 | Complete | COMPLETE |  |  |  |  |  |
| 1817 | 1.7.1.2.2.7 | CCAG review |  | 5d | 2023-05-18 A | 2023-05-24 A | 1816 | 100% |  | 2023-05-18 | 2023-05-24 | 5d | 2023-05-18 | 2023-05-24 |  |  |  | PP |  | Andrew Margan | Regulatory | 5.0 | Complete | COMPLETE |  |  |  |  |  |
| 1818 | 1.7.1.2.2.8 | Code drafting for Metering topic area approved | milestone | 0d | 2023-05-24 A | 2023-05-24 A | 1817 | 100% |  | 2023-05-24 | 2023-05-24 | 0d | 2023-05-24 | 2023-05-24 |  |  |  | PP | Code Drafting PM | Andrew Margan | Regulatory | 5.0 | Complete | COMPLETE |  | MHHS-ART060 | T2-RE-0150 | CCAG | T2 |

| ID | WBS | Task | Type | Duration | Start | Finish | Predecessors | Complete | Baseline start | Baseline finish | Baseline duration | Baseline 1 start | Baseline 1 finish | Constraint | Responsible | Involved | Task Status | Update Version | MHHS Resource Name | MHHS Programme Phase | Sched Status | RAG | Artefact ID | Milestone ID | Text29 | Tier |
| --- | --- | --- | --- | --- | --- | --- | --- | --- | --- | --- | --- | --- | --- | --- | --- | --- | --- | --- | --- | --- | --- | --- | --- | --- | --- | --- |
| 1819 | 1.7.1.2.3 | **BSC Central Services (BSC driven)** |  | 156d | 2023-02-22 A | 2023-09-27 A |  | 100% | 2023-02-22 | 2023-09-27 | 156d | 2023-02-22 | 2023-09-14 |  | N/A | N/A | M6 | 5.0 | N/A | Regulatory |  |  |  |  |  |  |
| 1820 | 1.7.1.2.3.1 | Pre Code Drafting activities |  | 5d | 2023-02-22 A | 2023-02-28 A | 1821SS-5d | 100% | 2023-02-22 | 2023-02-28 | 5d | 2023-02-22 | 2023-02-28 |  | Code Drafting PM |  |  | 5.0 | Andrew Margan | Regulatory | Complete | COMPLETE |  |  |  |  |
| 1821 | 1.7.1.2.3.2 | Code Drafting (offline) |  | 80d | 2023-03-01 A | 2023-06-20 A | 1805SS | 100% | 2023-03-01 | 2023-06-20 | 80d | 2023-03-01 | 2023-06-20 | must start on 2023-03-01 | Code Bodies,SRO Design | Code Drafting PM |  | 5.0 | Andrew Margan | Regulatory | Complete | COMPLETE |  |  |  |  |
| 1822 | 1.7.1.2.3.3 | Internal review and cross-checking of drafting across code drafters |  | 70d | 2023-03-15 A | 2023-06-20 A | 1821SS+10d | 100% | 2023-03-15 | 2023-06-20 | 70d | 2023-03-15 | 2023-06-20 |  | Code Bodies,SRO Design | Code Drafting PM |  | 5.0 | Andrew Margan | Regulatory | Complete | COMPLETE |  |  |  |  |
| 1823 | 1.7.1.2.3.4 | External industry review via consultation |  | 15d | 2023-06-21 A | 2023-07-11 A | 1822 | 100% | 2023-06-21 | 2023-07-11 | 15d | 2023-06-21 | 2023-07-11 |  | PP | Code Drafting PM |  | 5.0 | Andrew Margan | Regulatory | Complete | COMPLETE |  |  |  |  |
| 1824 | 1.7.1.2.3.5 | Triage and action comments |  | 19d | 2023-07-10 A | 2023-08-03 A | 1823FS-2d | 100% | 2023-07-10 | 2023-08-03 | 19d | 2023-07-10 | 2023-08-03 |  | Code Bodies,SRO Design | Code Drafting PM |  | 5.0 | Andrew Margan | Regulatory | Complete | COMPLETE |  |  |  |  |
| 1825 | 1.7.1.2.3.6 | CDWG review |  | 28d | 2023-08-04 A | 2023-09-12 A | 1824 | 100% | 2023-08-04 | 2023-09-12 | 28d | 2023-08-04 | 2023-09-07 |  | PP | Code Drafting PM |  | 5.0 | Andrew Margan | Regulatory | Complete | COMPLETE |  |  |  |  |
| 1826 | 1.7.1.2.3.7 | CCAG review |  | 11d | 2023-09-13 A | 2023-09-27 A | 1825 | 100% | 2023-09-13 | 2023-09-27 | 11d | 2023-09-08 | 2023-09-14 |  | PP |  |  | 5.0 | Andrew Margan | Regulatory | Complete | COMPLETE |  |  |  |  |
| 1827 | 1.7.1.2.3.8 | Code drafting for BSC Central Services topic area approved | milestone | 0d | 2023-09-27 A | 2023-09-27 A | 1826 | 100% | 2023-09-27 | 2023-09-27 | 0d | 2023-09-14 | 2023-09-14 |  | PP | Code Drafting PM |  | 5.0 | Andrew Margan | Regulatory | Complete | COMPLETE | MHHS-ART060 | T2-RE-0200 | CCAG | T2 |
| 1828 | 1.7.1.2.4 | **Registration (BSC & REC driven)** |  | 131d | 2023-02-22 A | 2023-08-23 A |  | 100% | 2023-02-22 | 2023-08-23 | 131d | 2023-02-22 | 2023-08-23 |  | N/A | N/A | M6 | 5.0 | N/A | Regulatory |  |  |  |  |  |  |
| 1829 | 1.7.1.2.4.1 | Pre Code Drafting activities |  | 5d | 2023-02-22 A | 2023-02-28 A | 1830SS-5d | 100% | 2023-02-22 | 2023-02-28 | 5d | 2023-02-22 | 2023-02-28 |  | Code Drafting PM |  |  | 5.0 | Andrew Margan | Regulatory | Complete | COMPLETE |  |  |  |  |
| 1830 | 1.7.1.2.4.2 | Code Drafting (offline) |  | 65d | 2023-03-01 A | 2023-05-30 A | 1804, 1813 | 100% | 2023-03-01 | 2023-05-30 | 65d | 2023-03-01 | 2023-05-30 | must start on 2023-03-01 | Code Bodies,SRO Design | Code Drafting PM |  | 5.0 | Andrew Margan | Regulatory | Complete | COMPLETE |  |  |  |  |
| 1831 | 1.7.1.2.4.3 | Internal review and cross-checking of drafting across code drafters |  | 55d | 2023-03-15 A | 2023-05-30 A | 1830SS+10d | 100% | 2023-03-15 | 2023-05-30 | 55d | 2023-03-15 | 2023-05-30 |  | Code Bodies,SRO Design | Code Drafting PM |  | 5.0 | Andrew Margan | Regulatory | Complete | COMPLETE |  |  |  |  |
| 1832 | 1.7.1.2.4.4 | External industry review via consultation |  | 15d | 2023-05-31 A | 2023-06-20 A | 1831 | 100% | 2023-05-31 | 2023-06-20 | 15d | 2023-05-31 | 2023-06-20 |  | PP | Code Drafting PM |  | 5.0 | Andrew Margan | Regulatory | Complete | COMPLETE |  |  |  |  |
| 1833 | 1.7.1.2.4.5 | Triage and action comments |  | 19d | 2023-06-19 A | 2023-07-13 A | 1832FS-2d | 100% | 2023-06-19 | 2023-07-13 | 19d | 2023-06-19 | 2023-07-13 |  | Code Bodies,SRO Design | Code Drafting PM |  | 5.0 | Andrew Margan | Regulatory | Complete | COMPLETE |  |  |  |  |
| 1834 | 1.7.1.2.4.6 | CDWG review |  | 18d | 2023-07-14 A | 2023-08-08 A | 1833 | 100% | 2023-07-14 | 2023-08-08 | 18d | 2023-07-14 | 2023-08-16 |  | PP | Code Drafting PM |  | 5.0 | Andrew Margan | Regulatory | Complete | COMPLETE |  |  |  |  |
| 1835 | 1.7.1.2.4.7 | CCAG review |  | 11d | 2023-08-09 A | 2023-08-23 A | 1834 | 100% | 2023-08-09 | 2023-08-23 | 11d | 2023-08-17 | 2023-08-23 |  | PP |  |  | 5.0 | Andrew Margan | Regulatory | Complete | COMPLETE |  |  |  |  |
| 1836 | 1.7.1.2.4.8 | Code drafting for Registration topic area approved | milestone | 0d | 2023-08-23 A | 2023-08-23 A | 1835 | 100% | 2023-08-23 | 2023-08-23 | 0d | 2023-08-23 | 2023-08-23 |  | PP | Code Drafting PM |  | 5.0 | Andrew Margan | Regulatory | Complete | COMPLETE | MHHS-ART060 | T2-RE-0250 | CCAG | T2 |
| 1837 | 1.7.1.2.5 | **Governance and Qualification (BSC & REC driven)** |  | 130d | 2023-05-25 A | 2023-11-22 A |  | 100% | 2023-05-25 | 2023-11-22 | 130d | 2023-05-25 | 2023-11-13 |  | N/A | N/A | M6 | 5.0 | N/A | Regulatory |  |  |  |  |  |  |
| 1838 | 1.7.1.2.5.1 | Pre Code Drafting activities |  | 5d | 2023-05-25 A | 2023-05-31 A | 1839SS-5d | 100% | 2023-05-25 | 2023-05-31 | 5d | 2023-05-25 | 2023-05-31 |  | Code Drafting PM |  |  | 5.0 | Andrew Margan | Regulatory | Complete | COMPLETE |  |  |  |  |
| 1839 | 1.7.1.2.5.2 | Code Drafting (offline) |  | 55d | 2023-06-01 A | 2023-08-16 A | 1832SS+1d | 100% | 2023-06-01 | 2023-08-16 | 55d | 2023-06-01 | 2023-08-16 |  | Code Bodies,SRO Design | Code Drafting PM |  | 5.0 | Andrew Margan | Regulatory | Complete | COMPLETE |  |  |  |  |
| 1840 | 1.7.1.2.5.3 | Internal review and cross-checking of drafting across code drafters |  | 45d | 2023-06-15 A | 2023-08-16 A | 1839SS+10d | 100% | 2023-06-15 | 2023-08-16 | 45d | 2023-06-15 | 2023-08-16 |  | Code Bodies,SRO Design | Code Drafting PM |  | 5.0 | Andrew Margan | Regulatory | Complete | COMPLETE |  |  |  |  |
| 1841 | 1.7.1.2.5.4 | External industry review via consultation |  | 15d | 2023-08-18 A | 2023-09-07 A | 1840FS+1d | 100% | 2023-08-18 | 2023-09-07 | 15d | 2023-08-18 | 2023-09-07 |  | PP | Code Drafting PM |  | 5.0 | Andrew Margan | Regulatory | Complete | COMPLETE |  |  |  |  |
| 1842 | 1.7.1.2.5.5 | Triage and action comments |  | 19d | 2023-09-06 A | 2023-10-02 A | 1841FS-2d | 100% | 2023-09-06 | 2023-10-02 | 19d | 2023-09-06 | 2023-10-02 |  | Code Bodies,SRO Design | Code Drafting PM |  | 5.0 | Andrew Margan | Regulatory | Complete | COMPLETE |  |  |  |  |
| 1843 | 1.7.1.2.5.6 | CDWG review |  | 31d | 2023-10-03 A | 2023-11-14 A | 1842 | 100% | 2023-10-03 | 2023-11-14 | 31d | 2023-10-03 | 2023-11-06 |  | PP | Code Drafting PM |  | 5.0 | Andrew Margan | Regulatory | Complete | COMPLETE |  |  |  |  |
| 1844 | 1.7.1.2.5.7 | CCAG review |  | 6d | 2023-11-15 A | 2023-11-22 A | 1843 | 100% | 2023-11-15 | 2023-11-22 | 6d | 2023-11-07 | 2023-11-13 |  | PP |  |  | 5.0 | Andrew Margan | Regulatory | Complete | COMPLETE |  |  |  |  |
| 1845 | 1.7.1.2.5.8 | Code drafting for Governance and Qualification topic areas approved | milestone | 0d | 2023-11-22 A | 2023-11-22 A | 1844 | 100% | 2023-11-22 | 2023-11-22 | 0d | 2023-11-13 | 2023-11-13 |  | PP | Code Drafting PM |  | 5.12 | Andrew Margan | Regulatory | Complete | COMPLETE | MHHS-ART060 | T3-RE-0300 | CCAG | T2 |

Notes:
- 1845: 10/10 - CH - Agreed at PSG on 4/10 to downgrade from T2 to T3

| ID | WBS | Task | Type | Duration | Start | Finish | Predecessors | Complete | Baseline start | Baseline finish | Baseline duration | Baseline 1 start | Baseline 1 finish | Constraint | Baseline cost | Responsible | Involved | Task Status | Update Version | MHHS Resource Name | MHHS Programme Phase | Sched Status | RAG | Artefact ID | Milestone ID | Text29 | Tier |
| --- | --- | --- | --- | --- | --- | --- | --- | --- | --- | --- | --- | --- | --- | --- | --- | --- | --- | --- | --- | --- | --- | --- | --- | --- | --- | --- | --- |
| 1846 | 1.7.1.2.6 | **Interfaces / Data Specification (REC driven)** |  | 174d | 2023-05-25 A | 2024-01-23 A |  | 100% | 2023-05-25 | 2024-01-24 | 175d | 2023-05-25 | 2023-11-13 |  |  | N/A | N/A | M6 | 5.2 | N/A | Regulatory |  |  |  |  |  |  |
| 1847 | 1.7.1.2.6.1 | Pre Code Drafting activities |  | 5d | 2023-05-25 A | 2023-05-31 A | 1848SS-5d | 100% | 2023-05-25 | 2023-05-31 | 5d | 2023-05-25 | 2023-05-31 |  |  | Code Drafting PM |  |  | 5.0 | Andrew Margan | Regulatory | Complete | COMPLETE |  |  |  |  |
| 1848 | 1.7.1.2.6.2 | Code Drafting (offline) |  | 94d | 2023-06-01 A | 2023-10-10 A | 1832SS+1d | 100% | 2023-06-01 | 2023-10-10 | 94d | 2023-06-01 | 2023-08-16 |  |  | Code Bodies,SRO Design | Code Drafting PM |  | 5.2 | Andrew Margan | Regulatory | Complete | COMPLETE |  |  |  |  |
| 1849 | 1.7.1.2.6.3 | Internal review and cross-checking of drafting across code drafters |  | 84d | 2023-06-15 A | 2023-10-10 A | 1848SS+10d | 100% | 2023-06-15 | 2023-10-10 | 84d | 2023-06-15 | 2023-08-16 |  |  | Code Bodies,SRO Design | Code Drafting PM |  | 5.2 | Andrew Margan | Regulatory | Complete | COMPLETE |  |  |  |  |
| 1850 | 1.7.1.2.6.4 | External industry review via consultation |  | 15d | 2023-10-11 A | 2023-10-31 A | 1849 | 100% | 2023-10-11 | 2023-10-31 | 15d | 2023-08-18 | 2023-09-07 |  |  | PP | Code Drafting PM |  | 5.2 | Andrew Margan | Regulatory | Complete | COMPLETE |  |  |  |  |
| 1851 | 1.7.1.2.6.5 | Triage and action comments |  | 20d | 2023-10-30 A | 2023-11-24 A | 1850FS-2d | 100% | 2023-10-30 | 2023-11-24 | 20d | 2023-09-06 | 2023-10-02 |  |  | Code Bodies,SRO Design | Code Drafting PM |  | 5.2 | Andrew Margan | Regulatory | Complete | COMPLETE |  |  |  |  |
| 1852 | 1.7.1.2.6.6 | CDWG review |  | 37d | 2023-11-27 A | 2024-01-16 A | 1851 | 100% | 2023-11-27 | 2024-01-09 | 32d | 2023-10-03 | 2023-11-06 |  |  | PP | Code Drafting PM |  | 5.2 | Andrew Margan | Regulatory | Complete | COMPLETE |  |  |  |  |
| 1853 | 1.7.1.2.6.7 | CCAG review |  | 5d | 2024-01-17 A | 2024-01-23 A | 1852 | 100% | 2024-01-10 | 2024-01-24 | 11d | 2023-11-07 | 2023-11-13 |  |  | PP | Code Drafting PM |  | 5.2 | Andrew Margan | Regulatory | Complete | COMPLETE |  |  |  |  |
| 1854 | 1.7.1.2.6.8 | Code drafting for Interfaces / Data Specification topic areas approved | milestone | 0d | 2024-01-23 A | 2024-01-23 A | 1853 | 100% | 2024-01-24 | 2024-01-24 | 0d | 2023-11-13 | 2023-11-13 |  |  | PP | Code Drafting PM |  | 5.16 | Andrew Margan | Regulatory | Complete | COMPLETE | MHHS-ART060 | T3-RE-0350 | CCAG | T2 |
| 1855 | 1.7.1.2.7 | **Migration (BSC & REC driven)** |  | 130d | 2023-05-25 A | 2023-11-22 A |  | 100% | 2023-05-25 | 2023-11-22 | 130d | 2023-05-25 | 2023-11-13 |  |  | N/A | N/A | M6 | 5.0 | N/A | Regulatory |  |  |  |  |  |  |
| 1856 | 1.7.1.2.7.1 | Pre Code Drafting activities |  | 5d | 2023-05-25 A | 2023-05-31 A | 1857SS-5d | 100% | 2023-05-25 | 2023-05-31 | 5d | 2023-05-25 | 2023-05-31 |  |  | Code Drafting PM |  |  | 5.0 | Andrew Margan | Regulatory | Complete | COMPLETE |  |  |  |  |
| 1857 | 1.7.1.2.7.2 | Code Drafting (offline) |  | 55d | 2023-06-01 A | 2023-08-16 A | 1832SS+1d | 100% | 2023-06-01 | 2023-08-16 | 55d | 2023-06-01 | 2023-08-16 |  |  | Code Bodies,SRO Design | Code Drafting PM |  | 5.0 | Andrew Margan | Regulatory | Complete | COMPLETE |  |  |  |  |
| 1858 | 1.7.1.2.7.3 | Internal review and cross-checking of drafting across code drafters |  | 45d | 2023-06-15 A | 2023-08-16 A | 1857SS+10d | 100% | 2023-06-15 | 2023-08-16 | 45d | 2023-06-15 | 2023-08-16 |  |  | Code Bodies,SRO Design | Code Drafting PM |  | 5.0 | Andrew Margan | Regulatory | Complete | COMPLETE |  |  |  |  |
| 1859 | 1.7.1.2.7.4 | External industry review via consultation |  | 15d | 2023-08-18 A | 2023-09-07 A | 1858FS+1d | 100% | 2023-08-18 | 2023-09-07 | 15d | 2023-08-18 | 2023-09-07 |  |  | PP | Code Drafting PM |  | 5.0 | Andrew Margan | Regulatory | Complete | COMPLETE |  |  |  |  |
| 1860 | 1.7.1.2.7.5 | Triage and action comments |  | 19d | 2023-09-06 A | 2023-10-02 A | 1859FS-2d | 100% | 2023-09-06 | 2023-10-02 | 19d | 2023-09-06 | 2023-10-02 |  |  | Code Bodies,SRO Design | Code Drafting PM |  | 5.0 | Andrew Margan | Regulatory | Complete | COMPLETE |  |  |  |  |
| 1861 | 1.7.1.2.7.6 | CDWG review |  | 31d | 2023-10-03 A | 2023-11-14 A | 1860 | 100% | 2023-10-03 | 2023-11-14 | 31d | 2023-10-03 | 2023-11-06 |  |  | PP | Code Drafting PM |  | 5.0 | Andrew Margan | Regulatory | Complete | COMPLETE |  |  |  |  |
| 1862 | 1.7.1.2.7.7 | CCAG review |  | 6d | 2023-11-15 A | 2023-11-22 A | 1861 | 100% | 2023-11-15 | 2023-11-22 | 6d | 2023-11-07 | 2023-11-13 |  |  | PP | Code Drafting PM |  | 5.0 | Andrew Margan | Regulatory | Complete | COMPLETE |  |  |  |  |
| 1863 | 1.7.1.2.7.8 | Code drafting for Migration topic area approved | milestone | 0d | 2023-11-22 A | 2023-11-22 A | 1862 | 100% | 2023-11-22 | 2023-11-22 | 0d | 2023-11-13 | 2023-11-13 |  |  | PP | Code Drafting PM |  | 5.12 | Andrew Margan | Regulatory | Complete | COMPLETE | MHHS-ART060 | T3-RE-0400 | CCAG | T2 |
| 1864 | 1.7.1.2.8 | **Consequential Code Change** |  | 109d | 2023-10-11 A | 2024-03-11 A |  | 100% | 2023-10-11 | 2024-03-08 | 108d | 2023-08-18 | 2024-03-08 |  | -0 | N/A | N/A |  | 5.0 | N/A | Regulatory |  |  |  |  |  |  |
| 1865 | 1.7.1.2.8.1 | External industry review via consultation - drop 1 (DCUSA) |  | 15d | 2023-10-11 A | 2023-10-31 A | 1871SS | 100% | 2023-10-11 | 2023-10-31 | 15d | 2023-08-18 | 2023-09-07 |  |  | Code Bodies | PP |  | 5.2 | Andrew Margan | Regulatory | Complete | COMPLETE |  |  |  |  |
| 1866 | 1.7.1.2.8.2 | External industry review via consultation - drop 2 (Elexon) |  | 16d | 2024-02-19 A | 2024-03-11 A | 1881SS | 100% | 2024-02-19 | 2024-03-08 | 15d | 2023-10-16 | 2023-11-03 | start no earlier than 2024-02-19 |  | Code Bodies | PP |  | 5.2 | Andrew Margan | Regulatory | Complete | COMPLETE |  |  |  |  |
| 1867 | 1.7.1.2.9 | **Transition Text (all codes)** |  | 118d | 2023-08-11 A | 2024-01-23 A |  | 100% | 2023-08-11 | 2024-01-24 | 119d | 2023-08-11 | 2024-01-25 |  |  | N/A | N/A | M6 | 5.2 | N/A | Regulatory |  |  |  |  |  |  |
| 1868 | 1.7.1.2.9.1 | Pre Code Drafting activities |  | 8d | 2023-08-11 A | 2023-08-22 A | 1869SS-5d | 100% | 2023-08-11 | 2023-08-22 | 8d | 2023-08-11 | 2023-08-17 |  |  | Code Drafting PM |  |  | 5.0 | Andrew Margan | Regulatory | Complete | COMPLETE |  |  |  |  |
| 1869 | 1.7.1.2.9.2 | Code Drafting (offline) |  | 38d | 2023-08-18 A | 2023-10-10 A | 1859SS | 100% | 2023-08-18 | 2023-10-10 | 38d | 2023-08-18 | 2023-10-12 |  |  | Code Bodies,SRO Design | Code Drafting PM |  | 5.2 | Andrew Margan | Regulatory | Complete | COMPLETE |  |  |  |  |
| 1870 | 1.7.1.2.9.3 | Internal review and cross-checking of drafting across code drafters |  | 28d | 2023-09-01 A | 2023-10-10 A | 1869SS+10d | 100% | 2023-09-01 | 2023-10-10 | 28d | 2023-09-01 | 2023-10-12 |  |  | Code Bodies,SRO Design | Code Drafting PM |  | 5.2 | Andrew Margan | Regulatory | Complete | COMPLETE |  |  |  |  |
| 1871 | 1.7.1.2.9.4 | External industry review via consultation |  | 15d | 2023-10-11 A | 2023-10-31 A | 1870 | 100% | 2023-10-11 | 2023-10-31 | 15d | 2023-10-16 | 2023-11-03 |  |  | PP | Code Drafting PM |  | 5.2 | Andrew Margan | Regulatory | Complete | COMPLETE |  |  |  |  |
| 1872 | 1.7.1.2.9.5 | Triage and action comments |  | 20d | 2023-10-30 A | 2023-11-24 A | 1871FS-2d | 100% | 2023-10-30 | 2023-11-24 | 20d | 2023-11-02 | 2023-11-21 |  |  | Code Bodies,SRO Design | Code Drafting PM |  | 5.2 | Andrew Margan | Regulatory | Complete | COMPLETE |  |  |  |  |
| 1873 | 1.7.1.2.9.6 | CDWG review |  | 37d | 2023-11-27 A | 2024-01-16 A | 1872 | 100% | 2023-11-27 | 2024-01-16 | 37d | 2023-11-22 | 2024-01-17 |  |  | PP | Code Drafting PM |  | 5.2 | Andrew Margan | Regulatory | Complete | COMPLETE |  |  |  |  |
| 1874 | 1.7.1.2.9.7 | CCAG review |  | 5d | 2024-01-17 A | 2024-01-23 A | 1873 | 100% | 2024-01-17 | 2024-01-24 | 6d | 2024-01-18 | 2024-01-25 |  |  | PP | Code Drafting PM |  | 5.2 | Andrew Margan | Regulatory | Complete | COMPLETE |  |  |  |  |
| 1875 | 1.7.1.2.9.8 | Code drafting for Transition Text topic area approved | milestone | 0d | 2024-01-23 A | 2024-01-23 A | 1874 | 100% | 2024-01-24 | 2024-01-24 | 0d | 2024-01-25 | 2024-01-25 |  |  | PP | Code Drafting PM |  | 5.16 | Andrew Margan | Regulatory | Complete | COMPLETE | MHHS-ART060 | T3-RE-0450 | CCAG | T2 |

Notes:
- 1854: 10/10 - CH - Agreed at PSG on 4/10 to downgrade from T2 to T3
- 1863: 31/07/23 - Changed date to 22/11/23 from 13/11/23 after approval from CCAG on 28/6/23. 10/10 - CH - Agreed at PSG on 4/10 to downgrade from T2 to T3
- 1865: Review of drop schedule and scope is being undertaken with CCAG.
- 1866: Review of drop schedule and scope is being undertaken with CCAG.
- 1869: Guidance: 14/8/23 - RECCo transition drafting activity is expected to take the full 38 days, noting BSE co-drafting will be expected to take approx. 21 days
- 1875: 10/10 - CH - Agreed at PSG on 4/10 to downgrade from T2 to T3

| ID | WBS | Task | Type | Duration | Start | Finish | Predecessors | Complete | Remaining | Baseline start | Baseline finish | Baseline duration | Baseline 1 start | Baseline 1 finish | Total slack | Free slack | Baseline cost | Responsible | Involved | Task Status | Update Version | MHHS Resource Name | MHHS Programme Phase | Sched Status | RAG | Artefact ID | Milestone ID | Text29 | Tier |
| --- | --- | --- | --- | --- | --- | --- | --- | --- | --- | --- | --- | --- | --- | --- | --- | --- | --- | --- | --- | --- | --- | --- | --- | --- | --- | --- | --- | --- | --- |
| 1876 | 1.7.1.2.10 | **Final Code Drafting (mop-up) (all codes)** |  | 199d | 2023-08-18 A | 2024-05-22 A |  | 100% |  | 2023-08-18 | 2024-05-22 | 199d | 2023-08-18 | 2024-05-13 |  |  |  | N/A | N/A | M6 | 5.0 | N/A | Regulatory |  |  |  |  |  |  |
| 1877 | 1.7.1.2.10.1 | Forward look and confirm remaining plan |  | 15d | 2023-08-18 A | 2023-09-07 A | 1869SS | 100% |  | 2023-08-18 | 2023-09-07 | 15d | 2023-08-18 | 2023-09-07 |  |  |  | Code Drafting PM |  |  | 5.0 | Andrew Margan | Regulatory | Complete | COMPLETE |  |  |  |  |
| 1878 | 1.7.1.2.10.2 | Identify remaining or additional areas of code (e.g. consequential change requirements) to be completed |  | 15d | 2023-08-18 A | 2023-09-07 A | 1877SS | 100% |  | 2023-08-18 | 2023-09-07 | 15d | 2023-08-18 | 2023-09-07 |  |  |  | Code Bodies,SRO Design | Code Drafting PM |  | 5.0 | Andrew Margan | Regulatory | Complete | COMPLETE |  |  |  |  |
| 1879 | 1.7.1.2.10.3 | Code Drafting (offline) Interim Consultation (1) |  | 60d | 2023-09-08 A | 2023-11-30 A | 1878 | 100% |  | 2023-09-08 | 2023-11-30 | 60d | 2023-09-08 | 2024-02-15 |  |  |  | Code Bodies,SRO Design | Code Drafting PM |  | 5.0 | Andrew Margan | Regulatory | Complete | COMPLETE |  |  |  |  |
| 1880 | 1.7.1.2.10.4 | Internal review and cross-checking of drafting across code drafters Interim Consultation (1) |  | 50d | 2023-09-22 A | 2023-11-30 A | 1879SS+10d | 100% |  | 2023-09-22 | 2023-11-30 | 50d | 2023-09-22 | 2024-02-15 |  |  |  | Code Bodies,SRO Design | Code Drafting PM |  | 5.0 | Andrew Margan | Regulatory | Complete | COMPLETE |  |  |  |  |
| 1881 | 1.7.1.2.10.5 | External industry review via consultation Interim Consultation (1) |  | 23d | 2023-12-01 A | 2024-01-02 A | 1880 | 100% |  | 2023-12-01 | 2024-01-02 | 23d | 2024-02-19 | 2024-03-08 |  |  |  | PP | Code Drafting PM |  | 5.0 | Andrew Margan | Regulatory | Complete | COMPLETE |  |  |  |  |
| 1882 | 1.7.1.2.10.6 | Code Drafting (offline) Final Consultation (2) |  | 55d | 2023-12-01 A | 2024-02-15 A | 1880 | 100% |  | 2023-12-01 | 2024-02-15 | 55d | 2023-09-08 | 2024-02-15 |  |  |  | Code Bodies,SRO Design | Code Drafting PM |  | 5.0 | Andrew Margan | Regulatory | Complete | COMPLETE |  |  |  |  |
| 1883 | 1.7.1.2.10.7 | Internal review and cross-checking of drafting across code drafters Final Consultation (2) |  | 45d | 2023-12-15 A | 2024-02-15 A | 1882SS+10d | 100% |  | 2023-12-15 | 2024-02-15 | 45d | 2023-09-22 | 2024-02-15 |  |  |  | Code Bodies,SRO Design | Code Drafting PM |  | 5.0 | Andrew Margan | Regulatory | Complete | COMPLETE |  |  |  |  |
| 1884 | 1.7.1.2.10.8 | External industry review via consultation Final Consultation (2) |  | 16d | 2024-02-19 A | 2024-03-11 A | 1883FS+1d | 100% |  | 2024-02-19 | 2024-03-08 | 15d | 2024-02-19 | 2024-03-08 |  |  |  | PP | Code Drafting PM |  | 5.0 | Andrew Margan | Regulatory | Complete | COMPLETE |  |  |  |  |
| 1885 | 1.7.1.2.10.9 | Triage and action comments |  | 18d | 2024-03-11 A | 2024-04-03 A | 1884FS-1d | 100% |  | 2024-03-07 | 2024-04-01 | 18d | 2024-03-07 | 2024-04-03 |  |  |  | Code Bodies,SRO Design | Code Drafting PM |  | 5.0 | Andrew Margan | Regulatory | Complete | COMPLETE |  |  |  |  |
| 1886 | 1.7.1.2.10.10 | CDWG review |  | 29d | 2024-04-04 A | 2024-05-14 A | 1885 | 100% |  | 2024-04-02 | 2024-05-14 | 31d | 2024-04-04 | 2024-05-03 |  |  |  | PP | Code Drafting PM |  | 5.0 | Andrew Margan | Regulatory | Complete | COMPLETE |  |  |  |  |
| 1887 | 1.7.1.2.10.11 | CCAG review |  | 6d | 2024-05-15 A | 2024-05-22 A | 1886 | 100% |  | 2024-05-15 | 2024-05-22 | 6d | 2024-05-06 | 2024-05-13 |  |  |  | PP | Code Drafting PM |  | 5.0 | Andrew Margan | Regulatory | Complete | COMPLETE |  |  |  |  |
| 1888 | 1.7.1.2.10.12 | Final code drafting (mop-up) approved | milestone | 0d | 2024-05-22 A | 2024-05-22 A | 1887 | 100% |  | 2024-05-22 | 2024-05-22 | 0d | 2024-05-13 | 2024-05-13 |  |  |  | PP | Code Drafting PM |  | 5.25 | Andrew Margan | Regulatory | Complete | COMPLETE | MHHS-ART060 | T3-RE-0500 | CCAG | T2 |
| 1889 | 1.7.1.2.11 | **Final code review, consistency check and approval** |  | 100d | 2024-04-04 A | 2024-08-21 A |  | 100% |  | 2024-04-04 | 2024-08-23 | 102d | 2024-05-06 | 2024-08-23 |  |  | -0 | N/A | N/A | M6 | 5.0 | N/A | Regulatory |  |  |  |  |  |  |
| 1890 | 1.7.1.2.11.1 | Gap analysis of final code against design artefacts (reverse process to code drafting) |  | 38d | 2024-04-04 A | 2024-05-27 A | 1886SS | 100% |  | 2024-04-04 | 2024-05-27 | 38d | 2024-05-06 | 2024-05-17 |  |  |  | Code Bodies,SRO Design | Code Drafting PM |  | 5.0 | Andrew Margan | Regulatory | Complete | COMPLETE |  |  |  |  |
| 1891 | 1.7.1.2.11.2 | Outputs of gap analysis actioned offline |  | 11d | 2024-05-28 A | 2024-06-11 A | 1890 | 100% |  | 2024-05-28 | 2024-06-11 | 11d | 2024-05-20 | 2024-06-07 |  |  |  | Code Bodies,SRO Design | Code Drafting PM |  | 5.0 | Andrew Margan | Regulatory | Complete | COMPLETE |  |  |  |  |
| 1892 | 1.7.1.2.11.3 | Final documentation collated for final consultation |  | 8d | 2024-06-12 A | 2024-06-21 A | 1891 | 100% |  | 2024-06-12 | 2024-06-24 | 9d | 2024-06-10 | 2024-06-13 |  |  |  | Code Drafting PM | Code Bodies,SRO Design |  | 5.23 | Andrew Margan | Regulatory | Complete | COMPLETE |  |  |  |  |
| 1893 | 1.7.1.2.11.4 | External industry review via consultation |  | 15d | 2024-06-24 A | 2024-07-12 A | 1892 | 100% |  | 2024-06-24 | 2024-07-19 | 20d | 2024-06-14 | 2024-07-04 |  |  |  | PP | Code Drafting PM |  | 5.0 | Andrew Margan | Regulatory | Complete | COMPLETE |  |  |  |  |
| 1894 | 1.7.1.2.11.5 | Triage and action comments |  | 10d | 2024-07-15 A | 2024-07-26 A | 1893 | 100% |  | 2024-07-18 | 2024-08-05 | 13d | 2024-07-03 | 2024-07-19 |  |  |  | Code Bodies,SRO Design | Code Drafting PM |  | 5.0 | Andrew Margan | Regulatory | Complete | COMPLETE |  |  |  |  |
| 1895 | 1.7.1.2.11.6 | Final CDWG review |  | 8d | 2024-08-02 A | 2024-08-13 A | 1894FS+4d | 100% |  | 2024-08-06 | 2024-08-13 | 6d | 2024-07-22 | 2024-08-16 |  |  |  | PP | Code Drafting PM |  | 5.0 | Andrew Margan | Regulatory | Complete | COMPLETE |  |  |  |  |
| 1896 | 1.7.1.2.11.7 | Final CCAG review |  | 6d | 2024-08-14 A | 2024-08-21 A | 1895 | 100% |  | 2024-08-14 | 2024-08-23 | 8d | 2024-08-19 | 2024-08-23 |  |  |  | PP | Code Drafting PM |  | 5.0 | Andrew Margan | Regulatory | Complete | COMPLETE |  |  |  |  |
| 1897 | 1.7.1.2.11.8 | CCAG recommend final code to PSG for baselining | milestone | 0d | 2024-08-21 A | 2024-08-21 A | 1896 | 100% |  | 2024-08-23 | 2024-08-23 | 0d | 2024-08-23 | 2024-08-23 |  |  |  | PP | Code Drafting PM |  | 5.9 | Andrew Margan | Regulatory | Complete | COMPLETE | MHHS-ART060 | T3-RE-0550 | CCAG | T2 |
| 1898 | 1.7.1.3 | Code changes baselined (M6) | milestone | 0d | 2024-08-23 A | 2024-08-23 A | 1896FS+2d, 1888, 1875, 1863, 1854, 1845, 1836, 1827, 1818, 1809 | 100% |  | 2024-08-23 | 2024-08-23 | 0d | 2024-08-23 | 2024-08-23 |  |  |  | CPT | PP |  | 5.0 | Andrew Margan | Regulatory | Complete | COMPLETE | MHHS-ART012 | T1-RE-1000 | PSG | T1 |
| 1899 | 1.7.2 | **Ofgem preparation and enactment of SCR powers** |  | 225d | 2024-02-05 A | 2024-12-13 |  | 71% | 65.25d | 2024-02-05 | 2024-12-13 | 225d | 2024-01-26 | 2024-11-12 | 32532d |  | -0 | N/A | N/A | M7 | 5.0 | N/A | Regulatory |  |  |  |  |  |  |
| 1900 | 1.7.2.1 | **Preparation and enactment of SCR Powers** |  | 223d | 2024-02-05 A | 2024-12-11 |  | 72% | 63.28d | 2024-02-05 | 2024-12-11 | 223d | 2024-01-26 | 2024-11-11 | 32469d |  | -0 | N/A | N/A |  | 5.0 | N/A | Regulatory |  |  |  |  |  |  |
| 1901 | 1.7.2.1.1 | Ofgem to keep Ofgem legal informed of process followed and nature of Code drafting to ensure that prepared for SCR go/no go decision |  | 101d | 2024-02-05 A | 2024-06-24 A | 1902SF | 100% |  | 2024-02-05 | 2024-06-25 | 101d | 2024-01-26 | 2024-06-14 |  |  |  | Ofgem | Code Bodies |  | 5.0 | Andrew Margan | Regulatory | Complete | COMPLETE |  |  |  |  |
| 1902 | 1.7.2.1.2 | OFGEM Legal to review Code Artefacts deliver policy intent and process followed and confirm that SCR powers are appropriate to use rather than SMAP - SCR go/no go |  | 14d | 2024-06-24 A | 2024-07-11 A | 1893SS | 100% |  | 2024-06-24 | 2024-07-12 | 15d | 2024-06-14 | 2024-07-04 |  |  |  | Ofgem | Code Bodies |  | 5.0 | Andrew Margan | Regulatory | Complete | COMPLETE |  |  |  |  |
| 1903 | 1.7.2.1.3 | Code Bodies to draft MOD proposal forms |  | 20d | 2024-07-12 A | 2024-08-08 A | 1902 | 100% |  | 2024-07-15 | 2024-08-09 | 20d | 2024-07-05 | 2024-08-01 |  |  |  | Code Bodies | Ofgem |  | 5.0 | Andrew Margan | Regulatory | Complete | COMPLETE |  |  |  |  |
| 1904 | 1.7.2.1.4 | Ofgem discuss and agree code mod timetable with code bodies (and MHHSP in relation to the dates for expected decisions) |  | 20d | 2024-07-12 A | 2024-08-08 A | 1902 | 100% |  | 2024-07-15 | 2024-08-09 | 20d | 2024-07-05 | 2024-08-01 |  |  |  | Ofgem | Code Bodies |  | 5.0 | Andrew Margan | Regulatory | Complete | COMPLETE |  |  |  |  |
| 1905 | 1.7.2.1.5 | Ofgem to publish each Direction to each code body specifying the timetable for each modification |  | 1d | 2024-08-28 A | 2024-08-28 A | 1904FS+13d | 100% |  | 2024-08-28 | 2024-08-28 | 1d | 2024-08-28 | 2024-08-28 |  |  |  | Ofgem | Code Bodies |  | 5.0 | Andrew Margan | Regulatory | Complete | COMPLETE |  |  |  |  |
| 1906 | 1.7.2.1.6 | Formally submit (by separate email) Modification Proposal Forms and legal texts to each code body |  | 1d | 2024-08-28 A | 2024-08-28 A | 1904FS+13d | 100% |  | 2024-08-28 | 2024-08-28 | 1d | 2024-08-28 | 2024-08-28 |  |  |  | Ofgem | Code Bodies |  | 5.0 | Andrew Margan | Regulatory | Complete | COMPLETE |  |  |  |  |
| 1907 | 1.7.2.1.7 | Each Code Body publishes and issues Modification Proposal Forms |  | 3d | 2024-08-29 A | 2024-09-02 A | 1906, 1905 | 100% |  | 2024-08-29 | 2024-09-02 | 3d | 2024-08-29 | 2024-09-02 |  |  |  | Code Bodies | Ofgem |  | 5.0 | Andrew Margan | Regulatory | Complete | COMPLETE |  |  |  |  |
| 1908 | 1.7.2.1.8 | Each Code Body sends Modification Proposal Forms to Panel to approve Mod to go to consultation |  | 10d | 2024-09-03 A | 2024-09-16 | 1907 | 33% | 6.7d | 2024-09-03 | 2024-09-16 | 10d | 2024-09-03 | 2024-09-16 | 32469d | 0d |  | Code Bodies | Ofgem |  | 5.0 | Andrew Margan | Regulatory | Green | AMBER |  |  |  |  |
| 1909 | 1.7.2.1.9 | Modification Proposal approved by Panel for Consultation |  | 1d | 2024-09-17 | 2024-09-17 | 1908 |  |  | 2024-09-17 | 2024-09-17 | 1d | 2024-09-17 | 2024-09-17 | 32469d | 0d |  | Code Bodies | Ofgem | -2.67 | 5.0 | Andrew Margan | Regulatory | Green | AMBER |  |  |  |  |
| 1910 | 1.7.2.1.10 | Draft Modification Report issued for consultation |  | 1d | 2024-09-18 | 2024-09-18 | 1909 |  |  | 2024-09-18 | 2024-09-18 | 1d | 2024-09-18 | 2024-09-18 | 32469d | 0d |  | Code Bodies | Ofgem | -1.67 | 5.0 | Andrew Margan | Regulatory | Green | AMBER |  |  |  |  |
| 1911 | 1.7.2.1.11 | Consultation Close-out for representations |  | 15d | 2024-09-19 | 2024-10-09 | 1910 |  |  | 2024-09-19 | 2024-10-09 | 15d | 2024-09-19 | 2024-10-09 | 32469d | 0d |  | Code Bodies | Ofgem | -0.67 | 5.0 | Andrew Margan | Regulatory | Green | GREEN |  |  |  |  |
| 1912 | 1.7.2.1.12 | Each Code Body reviews consultation response and drafts Modification Report |  | 10d | 2024-10-10 | 2024-10-23 | 1911 |  |  | 2024-10-10 | 2024-10-23 | 10d | 2024-10-10 | 2024-10-23 | 32469d | 0d |  | Code Bodies | Ofgem | 20.33 | 5.0 | Andrew Margan | Regulatory | Green | GREEN |  |  |  |  |
| 1913 | 1.7.2.1.13 | Final Modification Report sent to Panel for decision with recommendation to approve |  | 1d | 2024-10-24 | 2024-10-24 | 1912 |  |  | 2024-10-24 | 2024-10-24 | 1d | 2024-10-24 | 2024-10-24 | 32469d | 0d |  | Code Bodies | Ofgem | 34.33 | 5.0 | Andrew Margan | Regulatory | Green | GREEN |  |  |  |  |
| 1914 | 1.7.2.1.14 | Modification Panel decision |  | 1d | 2024-11-07 | 2024-11-07 | 1913FS+9d |  |  | 2024-11-07 | 2024-11-07 | 1d | 2024-11-07 | 2024-11-07 | 32469d | 0d |  | Code Bodies | Ofgem | 48.33 | 5.0 | Andrew Margan | Regulatory | Green | GREEN |  |  |  |  |
| 1915 | 1.7.2.1.15 | Code Bodies Submit Final Modification/Change Reports |  | 1d | 2024-11-08 | 2024-11-08 | 1914 |  |  | 2024-11-08 | 2024-11-08 | 1d |  |  | 32469d | 0d |  | Code Bodies | Ofgem | 49.33 | 5.31 | Andrew Margan |  | Green | GREEN |  |  |  |  |
| 1916 | 1.7.2.1.16 | Ofgem Reviews Final Modification/Change Reports |  | 10d | 2024-11-11 | 2024-11-22 | 1915 |  |  | 2024-11-11 | 2024-11-22 | 10d |  |  | 32469d | 0d |  | Ofgem | Code Bodies | 52.33 | 5.31 | Andrew Margan |  | Green | GREEN |  |  |  |  |
| 1917 | 1.7.2.1.17 | Ofgem Drafts Decision/Direction Letters |  | 17d | 2024-11-18 | 2024-12-10 | 1916SS+5d |  |  | 2024-11-18 | 2024-12-10 | 17d |  |  | 32469d | 0d |  | Ofgem | Code Bodies | 59.33 | 5.31 | Andrew Margan |  | Green | GREEN |  |  |  |  |
| 1918 | 1.7.2.1.18 | Ofgem Internally Signs Off the Decision/Direction Letters and Sends Them to the Code Bodies |  | 1d | 2024-12-11 | 2024-12-11 | 1917 |  |  | 2024-12-11 | 2024-12-11 | 1d |  |  | 32469d | 0d |  | Ofgem | Code Bodies | 82.33 | 5.31 | Andrew Margan |  | Green | GREEN |  |  |  |  |
| 1919 | 1.7.2.2 | Ofgem decisions on M6 baselined code modification proposals (M7) | milestone | 0d | 2024-12-11 | 2024-12-11 | 1898, 1918 |  |  | 2024-12-11 | 2024-12-11 | 0d | 2024-11-11 | 2024-11-11 | 32469d | 0d |  | CPT | PP | 82.71 | 5.31 | Andrew Margan | Regulatory | Green | GREEN | MHHS-ART012 | T2-RE-0600 | CCAG | T2 |
| 1920 | 1.7.2.3 | Ofgem Publishes the Decisions/Directions |  | 2d | 2024-12-12 | 2024-12-13 | 1919 |  |  | 2024-12-12 | 2024-12-13 | 2d |  |  | 32532d |  |  | Ofgem | Code Bodies | 83.33 | 5.31 | Andrew Margan |  | Green | GREEN |  |  |  |  |

Notes:
- 1888: 10/10 - CH - Agreed at PSG on 4/10 to downgrade from T2 to T3
- 1897: 10/10 - CH - Agreed at PSG on 4/10 to downgrade from T2 to T3
- 1898: CCAG will approve the code text to go to Ofgem on 23/8/24. PSG will then ratify the milestone at PSG on 2/9/24
- 1908: 16/09/24 - Modifications sent to Panel. Individual CB meeting cycle not aligned to the plan, but no concerns or delays expected to Consultation Close-out (6460).
- 1909: 16/09/24 - Modifications sent to Panel. Individual CB meeting cycle not aligned to the plan, but no concerns or delays expected to Consultation Close-out (6460).
- 1910: 16/09/24 - Modifications sent to Panel. Individual CB meeting cycle not aligned to the plan, but no concerns or delays expected to Consultation Close-out (6460).
- 1919: Guidance: 5/8/25 - CR no52 and going to PSG on 7/8/24. 21/8/24: Milestone name and date change approved at psg on 7/8/24

| ID | WBS | Task | Type | Duration | Start | Finish | Predecessors | Complete | Remaining | Baseline start | Baseline finish | Baseline duration | Baseline 1 start | Baseline 1 finish | Total slack | Free slack | Constraint | Baseline cost | Responsible | Involved | Task Status | Update Version | MHHS Resource Name | MHHS Programme Phase | Sched Status | RAG | Artefact ID | Milestone ID | Text29 | Tier | Text3 |
| --- | --- | --- | --- | --- | --- | --- | --- | --- | --- | --- | --- | --- | --- | --- | --- | --- | --- | --- | --- | --- | --- | --- | --- | --- | --- | --- | --- | --- | --- | --- | --- |
| 1921 | 1.7.3 | **Deliver MHHS Code Changes** |  | 262d | 2024-11-12 | 2025-11-12 |  |  |  | 2024-11-12 | 2025-06-06 | 149d | 2024-11-12 | 2025-03-07 | 32294d |  |  |  | N/A | N/A | M8 | 5.0 | N/A | Regulatory |  |  |  |  |  |  |  |
| 1922 | 1.7.3.1 | **Releases** |  | 262d | 2024-11-12 | 2025-11-12 |  |  |  | 2024-11-12 | 2025-06-06 | 149d | 2024-11-12 | 2025-03-07 | 32294d |  |  |  | N/A | N/A |  | 5.0 | N/A | Regulatory |  |  |  |  |  |  |  |
| 1923 | 1.7.3.1.1 | Impacted codes make resourcing provisions and prepare to implement new Code via internal code body change processes |  | 78d | 2024-11-12 | 2025-02-27 |  |  |  | 2024-11-12 | 2025-02-27 | 78d | 2024-11-12 | 2025-02-27 | 32478d |  | start no earlier than 2024-11-12 |  | Code Bodies |  | 53.33 | 5.0 | Andrew Margan | Regulatory | Green | GREEN |  |  |  |  |  |
| 1924 | 1.7.3.1.2 | **Main Code Release** |  | 71d | 2025-08-06 | 2025-11-12 |  |  |  | 2025-02-28 | 2025-06-06 | 71d | 2025-02-28 | 2025-03-07 | 32294d |  |  |  | N/A | N/A |  | 5.0 | N/A | Regulatory |  |  |  |  |  |  |  |
| 1925 | 1.7.3.1.2.1 | Release preparation (e.g. preparing release documentation) |  | 6d | 2025-08-06 | 2025-08-13 | 1926SF |  |  | 2025-02-28 | 2025-03-07 | 5d | 2025-02-28 | 2025-03-07 | 32359d |  |  |  | Code Bodies |  | 320.33 | 5.0 | Andrew Margan | Regulatory | Red | RED |  |  |  |  |  |
| 1926 | 1.7.3.1.2.2 | Implement new code on day of code release | milestone | 0d | 2025-08-13 | 2025-08-13 | 1927SF |  |  | 2025-03-07 | 2025-03-07 | 1d | 2025-03-07 | 2025-03-07 | 32359d | 0d |  |  | Code Bodies |  | 327.71 | 5.0 | Andrew Margan | Regulatory | Red | RED |  |  |  |  |  |
| 1927 | 1.7.3.1.2.3 | Code changes delivered (M8) | milestone | 0d | 2025-08-13 | 2025-08-13 | 1919, 1898, 1317SS |  |  | 2025-03-07 | 2025-03-07 | 0d | 2025-03-07 | 2025-03-07 | 32294d | 0d |  |  | CPT | Code Bodies,PP | 327.71 | 5.0 | Andrew Margan | Regulatory | Red | RED | MHHS-ART060 | T2-RE-0650 | CCAG | T2 |  |
| 1928 | 1.7.3.1.2.4 | Code changes delivered (M8*) late exit | milestone | 0d | 2025-11-12 | 2025-11-12 | 1927FS+65d |  |  | 2025-06-06 | 2025-06-06 | 0d |  |  | 32294d |  |  |  | CPT | Code Bodies,PP | 418.71 | 5.1 | Andrew Margan | Regulatory | Red | RED | MHHS-ART060 | T2-RE-0700 | CCAG | T2 |  |
| 1929 | 1.7.4 | **External Programme Dependency Management** |  | 38d | 2023-12-01 A | 2024-01-24 A |  | 100% |  | 2023-12-01 | 2024-01-24 | 38d | 2023-09-08 | 2024-01-24 |  |  |  |  | N/A | N/A |  | 5.0 | N/A | Regulatory |  |  |  |  |  |  |  |
| 1930 | 1.7.4.1 | **DCP397** |  | 38d | 2023-12-01 A | 2024-01-24 A |  | 100% |  | 2023-12-01 | 2024-01-24 | 38d | 2023-09-08 | 2024-01-24 |  |  |  |  | N/A | N/A |  | 5.0 | N/A | Regulatory |  |  |  |  |  |  |  |
| 1931 | 1.7.4.1.1 | Ensure DCP397 drafting included in mop-up code drafting activity (link to mop-up) |  | 20d | 2023-12-01 A | 2023-12-28 A | 1882SS, 1879SS | 100% |  | 2023-12-01 | 2023-12-28 | 20d | 2023-09-08 | 2023-10-05 |  |  |  |  | CPT | Code Bodies,SRO Design, Code Drafting PM |  | 5.0 | Andrew Margan | Regulatory | Complete | COMPLETE |  |  |  |  |  |
| 1932 | 1.7.4.1.2 | Implementation of DCP397 | milestone | 0d | 2024-01-24 A | 2024-01-24 A |  | 100% |  | 2024-01-24 | 2024-01-24 | 0d | 2024-01-24 | 2024-01-24 |  |  | start no earlier than 2024-01-24 |  | Code Bodies |  |  | 5.0 | Andrew Margan | Regulatory | Complete | COMPLETE |  |  |  |  |  |
| 1933 | 1.8 | **MIGRATION** |  | 1207d | 2022-10-31 A | 2027-06-15 |  | 35% | 783.84d | 2022-10-31 | 2027-01-05 | 1092d | 2022-10-31 | 2027-01-05 | 31880d |  |  | -0 | N/A | N/A |  |  | N/A | Migration |  |  |  |  |  |  | 1 Oct 2024 - 31 Oct 2025 |
| 1934 | 1.8.1 | Migration Period Plan Review 1 Completed | milestone, inactive | 0d | 2025-01-31 | 2025-01-31 |  |  |  | 2025-01-31 | 2025-01-31 | 0d | 2025-01-31 | 2025-01-31 | 32497d |  | finish no earlier than 2025-01-31 |  | SRO | PP,IPA | 133.71 | 5.28 | Simon chidwick | Migration |  | GREEN |  | T3-MI-0016 | MCAG (Migration) | T3 |  |
| 1935 | 1.8.2 | **Regulatory Governance** |  | 198d | 2024-04-01 A | 2025-01-01 |  | 47% | 105d | 2024-04-01 | 2024-11-27 | 173d |  |  | 32519d |  |  | -0 | N/A | N/A |  | 5.28 | N/A |  |  |  |  |  |  |  |  |
| 1936 | 1.8.2.1 | Incentive Mods Created |  | 110d | 2024-04-01 A | 2024-08-30 |  | 85% | 17d | 2024-04-01 | 2024-07-26 | 85d |  |  | 32519d | 0d | start no earlier than 2024-04-01 |  | SRO Migration | SRO Migration,Code Bodies,PP |  | 5.28 | Simon chidwick |  | Red | RED |  |  |  |  |  |
| 1937 | 1.8.2.2 | Incentives Implemented |  | 88d | 2024-09-02 | 2025-01-01 | 1936 |  |  | 2024-07-29 | 2024-11-27 | 88d |  |  | 32519d |  | start no earlier than 2024-07-02 |  | Code Bodies | Code Bodies,SRO Migration | -17.67 | 5.28 | Simon chidwick |  | Red | RED |  |  |  |  |  |
| 1938 | 1.8.3 | **Migration Framework Agreed and Implemented** |  | 256d | 2024-02-01 A | 2025-01-23 |  | 62% | 97.34d | 2024-02-01 | 2024-11-26 | 214d |  |  | 32415d |  |  | -0 | N/A | N/A |  | 5.28 | N/A |  |  |  |  |  |  |  |  |
| 1939 | 1.8.3.1 | **Consultation 1 - Schedule** |  | 70d | 2024-02-01 A | 2024-05-08 A |  | 100% |  | 2024-02-01 | 2024-05-08 | 70d |  |  |  |  |  |  | N/A | N/A |  | 5.28 | N/A |  |  |  |  |  |  |  |  |
| 1940 | 1.8.3.1.1 | Prepare Artefacts for Consultation |  | 33d | 2024-02-01 A | 2024-03-18 A |  | 100% |  | 2024-02-01 | 2024-03-18 | 33d |  |  |  |  |  |  |  |  |  | 5.28 | Simon chidwick |  | Complete | COMPLETE |  |  |  |  |  |
| 1941 | 1.8.3.1.2 | Industry Consultation |  | 16d | 2024-03-18 A | 2024-04-08 A |  | 100% |  | 2024-03-18 | 2024-04-08 | 16d |  |  |  |  |  |  |  |  |  | 5.28 | Simon chidwick |  | Complete | COMPLETE |  |  |  |  |  |
| 1942 | 1.8.3.1.3 | Triage and Action Comments |  | 10d | 2024-04-08 A | 2024-04-19 A |  | 100% |  | 2024-04-08 | 2024-04-19 | 10d |  |  |  |  |  |  |  |  |  | 5.28 | Simon chidwick |  | Complete | COMPLETE |  |  |  |  |  |
| 1943 | 1.8.3.1.4 | Industry Assurance Review |  | 6d | 2024-04-19 A | 2024-04-26 A |  | 100% |  | 2024-04-19 | 2024-04-26 | 6d |  |  |  |  |  |  |  |  |  | 5.28 | Simon chidwick |  | Complete | COMPLETE |  |  |  |  |  |
| 1944 | 1.8.3.1.5 | MWG Recommendation |  | 1d | 2024-04-26 A | 2024-04-26 A |  | 100% |  | 2024-04-26 | 2024-04-26 | 1d |  |  |  |  |  |  |  |  |  | 5.28 | Simon chidwick |  | Complete | COMPLETE |  |  |  |  |  |
| 1945 | 1.8.3.1.6 | MCAG Interim Approval Artefacts |  | 1d | 2024-05-08 A | 2024-05-08 A |  | 100% |  | 2024-05-08 | 2024-05-08 | 1d |  |  |  |  |  |  |  |  |  | 5.28 | Simon chidwick |  | Complete | COMPLETE |  |  |  |  |  |

Notes:
- 1934: 2/7: To go to July MCAG for removal because milestone no longer reflects the delivery of the migration approach / Action: 11/7/24: MI-0016 warren is saying he wants another think about before going to MCAG so can you hold off doing anything official with that one please?

| ID | WBS | Task | Type | Duration | Start | Finish | Predecessors | Complete | Remaining | Baseline start | Baseline finish | Baseline duration | Total slack | Free slack | Baseline cost | Responsible | Involved | Update Version | MHHS Resource Name | Sched Status | RAG | Milestone ID | Text29 | Task Status |
| --- | --- | --- | --- | --- | --- | --- | --- | --- | --- | --- | --- | --- | --- | --- | --- | --- | --- | --- | --- | --- | --- | --- | --- | --- |
| 1946 | 1.8.3.2 | **Consultation 2 - Control** |  | 79d | 2024-04-08 A | 2024-07-25 A |  | 100% |  | 2024-04-08 | 2024-07-25 | 79d |  |  | -0 | N/A | N/A | 5.28 | N/A |  |  |  |  |  |
| 1947 | 1.8.3.2.1 | Prepare Artefacts for Consultation |  | 49d | 2024-04-08 A | 2024-06-13 A |  | 100% |  | 2024-04-08 | 2024-06-13 | 49d |  |  |  |  |  | 5.28 | Simon chidwick | Complete | COMPLETE |  |  |  |
| 1948 | 1.8.3.2.2 | Industry Consultation |  | 11d | 2024-06-14 A | 2024-06-28 A | 1947 | 100% |  | 2024-06-14 | 2024-06-28 | 11d |  |  |  |  |  | 5.28 | Simon chidwick | Complete | COMPLETE |  |  |  |
| 1949 | 1.8.3.2.3 | Triage and Action Comments |  | 9d | 2024-07-01 A | 2024-07-11 A | 1948 | 100% |  | 2024-07-01 | 2024-07-11 | 9d |  |  |  | SRO Migration | SRO Migration | 5.28 | Simon chidwick | Complete | COMPLETE |  |  |  |
| 1950 | 1.8.3.2.4 | Industry Assurance Review |  | 5d | 2024-07-12 A | 2024-07-18 A | 1949 | 100% |  | 2024-07-12 | 2024-07-18 | 5d |  |  |  | PP | PP,SRO Migration | 5.28 | Simon chidwick | Complete | COMPLETE |  |  |  |
| 1951 | 1.8.3.2.5 | MWG Recommendation | milestone | 0d | 2024-07-18 A | 2024-07-18 A | 1950 | 100% |  | 2024-07-18 | 2024-07-18 | 0d |  |  |  | PP | PP,SRO Migration | 5.28 | Simon chidwick | Complete | COMPLETE |  |  |  |
| 1952 | 1.8.3.2.6 | Consultation 2 - Control - MCAG Approval of Interim Artefacts | milestone | 0d | 2024-07-25 A | 2024-07-25 A | 1951FS+5d | 100% |  | 2024-07-25 | 2024-07-25 | 0d |  |  |  | PP | PP,SRO Migration | 5.30 | Simon chidwick | Complete | COMPLETE | T3-MI-0037 | MCAG (Migration) |  |
| 1953 | 1.8.3.3 | **Consultation 3 - Parameters** |  | 143d | 2024-07-09 A | 2025-01-23 |  | 18% | 117.21d | 2024-07-09 | 2024-10-22 | 76d | 32415d |  | -0 | N/A | N/A | 5.28 | N/A |  |  |  |  |  |
| 1954 | 1.8.3.3.1 | Prepare Artefacts (9) for Consultation |  | 95d | 2024-07-09 A | 2024-11-18 | 1961SS+6d | 23% | 73d | 2024-07-09 | 2024-08-27 | 36d | 32415d | 0d |  | SRO Migration | SRO Migration | 5.28 | Simon chidwick | Red | RED |  |  |  |
| 1955 | 1.8.3.3.2 | Industry Consultation |  | 10d | 2024-11-19 | 2024-12-02 | 1954 |  |  | 2024-08-28 | 2024-09-10 | 10d | 32415d | 0d |  | PP | PP,SRO Migration | 5.28 | Simon chidwick | Red | RED |  |  | 60.33 |
| 1956 | 1.8.3.3.3 | Triage and Action Comments |  | 10d | 2024-12-03 | 2024-12-16 | 1955 |  |  | 2024-09-11 | 2024-09-24 | 10d | 32415d | 0d |  | SRO Migration | SRO Migration | 5.28 | Simon chidwick | Red | RED |  |  | 74.33 |
| 1957 | 1.8.3.3.4 | Industry Assurance Review |  | 7d | 2024-12-17 | 2024-12-25 | 1956 |  |  | 2024-09-25 | 2024-10-03 | 7d | 32415d | 0d |  | PP | PP,SRO Migration | 5.28 | Simon chidwick | Red | RED |  |  | 88.33 |
| 1958 | 1.8.3.3.5 | MWG Recommendation | milestone | 0d | 2025-01-06 | 2025-01-06 | 1957FS+8d |  |  | 2024-10-03 | 2024-10-03 | 0d | 32415d | 0d |  | PP | PP,SRO Migration | 5.28 | Simon chidwick | Red | RED |  |  | 108.71 |
| 1959 | 1.8.3.3.6 | MCAG Approval of Migration Framework Artefacts (Baselined) | milestone | 0d | 2025-01-23 | 2025-01-23 | 1962, 1958FS+13d |  |  | 2024-10-22 | 2024-10-22 | 0d | 32415d | 0d |  | PP | PP,SRO Migration | 5.30 | Simon chidwick | Red | RED | T3-MI-0017 | MCAG (Migration) | 125.71 |
| 1960 | 1.8.4 | **Migration Schedule Agreed and Maintained** |  | 415d | 2024-07-01 A | 2026-01-30 |  | 14% | 357.48d | 2024-07-01 | 2025-04-15 | 207d | 32237d |  | -0 | N/A | N/A | 5.28 | N/A |  |  |  |  |  |
| 1961 | 1.8.4.1 | Indicative Envelopes Issued |  | 23d | 2024-07-01 A | 2024-07-31 A | 1945FS+37d | 100% |  | 2024-07-01 | 2024-07-31 | 23d |  |  |  | SRO Migration | SRO Migration,PP | 5.28 | Simon chidwick | Complete | COMPLETE |  |  |  |
| 1962 | 1.8.4.2 | Supplier Submissions |  | 45d | 2024-08-01 A | 2024-10-02 | 1961, 1952 | 11% | 40d | 2024-08-01 | 2024-10-02 | 45d | 32295d | 0d |  | PP | SRO Migration,PP | 5.28 | Simon chidwick | Green | GREEN |  |  |  |
| 1963 | 1.8.4.3 | Team Assess Responses |  | 10d | 2024-10-03 | 2024-10-16 | 1962 |  |  | 2024-10-03 | 2024-10-16 | 10d | 32295d | 0d |  | SRO Migration | SRO Migration | 5.28 | Simon chidwick | Green | GREEN |  |  | 13.33 |
| 1964 | 1.8.4.4 | Discuss and Agree Approach with Participants where necessary |  | 4d | 2024-10-17 | 2024-10-22 | 1963 |  |  | 2024-10-17 | 2024-10-22 | 4d | 32295d | 58d |  | SRO Migration | SRO Migration,PP | 5.28 | Simon chidwick | Green | GREEN |  |  | 27.33 |
| 1965 | 1.8.4.5 | V1.0 of Migration Schedule Baseline Approved at MCAG | milestone | 0d | 2025-01-10 | 2025-01-10 | 1974, 1964 |  |  | 2024-10-22 | 2024-10-22 | 0d | 32237d | 0d |  | PP | SRO Migration,PP | 5.30 | Simon chidwick | Red | RED | T3-MI-0039 | MCAG (Migration) | 112.71 |
| 1966 | 1.8.4.6 | Sprint Planning (Cycle 1) |  | 40d | 2025-06-16 | 2025-08-08 | 1965FS+110d |  |  | 2024-11-20 | 2024-12-17 | 20d | 32237d | 0d |  | SRO Migration | SRO Migration,PP | 5.28 | Simon chidwick | Red | RED |  |  | 269.33 |
| 1967 | 1.8.4.7 | Sprint Planning (Cycle 2) |  | 40d | 2025-09-15 | 2025-11-07 | 1966FS+25d |  |  | 2025-01-22 | 2025-02-18 | 20d | 32237d | 0d |  | SRO Migration | SRO Migration,PP | 5.28 | Simon chidwick | Red | RED |  |  | 360.33 |
| 1968 | 1.8.4.8 | Sprint Planning (Cycle 3) |  | 40d | 2025-12-08 | 2026-01-30 | 1967FS+20d, 1982 |  |  | 2025-03-20 | 2025-04-15 | 19d | 32237d |  |  | SRO Migration | SRO Migration,PP | 5.28 | Simon chidwick | Red | RED |  |  | 444.33 |
| 1969 | 1.8.5 | **Migration Control Centre Tooling** |  | 242d | 2024-05-09 A | 2025-04-11 |  | 30% | 168.46d | 2024-05-09 | 2025-01-17 | 182d | 32406d |  |  | N/A | N/A | 5.28 | N/A |  |  |  |  |  |
| 1970 | 1.8.5.1 | Data Source Definition |  | 120d | 2024-05-09 A | 2024-10-23 | 1945 | 46% | 65d | 2024-05-09 | 2024-07-31 | 60d | 32237d | 0d |  | SRO Migration | SRO Migration | 5.28 | Simon chidwick | Red | RED |  |  |  |
| 1971 | 1.8.5.2 | Scheduling and Data Requirements |  | 120d | 2024-05-09 A | 2024-10-23 | 1945 | 46% | 65d | 2024-05-09 | 2024-07-31 | 60d | 32237d | 0d |  | SRO Migration | SRO Migration | 5.28 | Simon chidwick | Red | RED |  |  |  |
| 1972 | 1.8.5.3 | Tool Phase 1 |  | 11d | 2024-10-24 | 2024-11-07 | 1971, 1970 |  |  | 2024-08-01 | 2024-08-15 | 11d | 32237d | 0d |  | SRO Migration | SRO Migration | 5.28 | Simon chidwick | Red | RED |  |  | 34.33 |
| 1973 | 1.8.5.4 | Data Requirements |  | 21d | 2024-11-08 | 2024-12-06 | 1945, 1972 |  |  | 2024-08-16 | 2024-09-13 | 21d | 32237d | 0d |  | SRO Migration | SRO Migration | 5.28 | Simon chidwick | Red | RED |  |  | 49.33 |
| 1974 | 1.8.5.5 | Tool Phase 2 |  | 25d | 2024-12-09 | 2025-01-10 | 1973 |  |  | 2024-09-16 | 2024-10-18 | 25d | 32237d | 0d |  | SRO Migration | SRO Migration | 5.28 | Simon chidwick | Red | RED |  |  | 80.33 |
| 1975 | 1.8.5.6 | Data Source Provision |  | 7d | 2025-01-13 | 2025-01-21 | 1974 |  |  | 2024-10-21 | 2024-10-29 | 7d | 32406d | 0d |  | SRO Migration | SRO Migration | 5.28 | Simon chidwick | Red | RED |  |  | 115.33 |
| 1976 | 1.8.5.7 | Tool - Internal and External Testing |  | 58d | 2025-01-22 | 2025-04-11 | 1975 |  |  | 2024-10-30 | 2025-01-17 | 58d | 32406d | 0d |  | SRO Migration | SRO Migration,PP | 5.28 | Simon chidwick | Red | RED |  |  | 124.33 |

Notes:
- 1952: New milestone added to reflect updated delivery approach for migration. To go to July MCAG for approval / Guidance: 25/7/24: New Milestone approved at MCAG on 25/7/24
- 1959: It is expected that baseline date will need to be changed. This is due to a combination of the changes coming out of MWG for Consultation 3 being very minimal for the original release date of 28th August and not warranting an industry consultation, coupled with the reassessment of activity that has highlighted that it would be better to wait to align Consultation 3 with any changes that result from the current Supplier Migration Submission process, rather than issue a consultation before that process had completed and the MCC has digested the plans, and then have to issue yet further consultations. ~Current thinking is that the consultation 3 would be issued in November and approved (and therefore the framework baselined) in December/January / Guidance: 25/7/24: Milestone name and date change approved at MCAG on 25/7/24. Date from 2/8/24 to 22/10/24. Name from 'Migration Processes & Procedures approved' to 'MCAG Approval of Migration Framework Artefacts (Baselined)’
- 1965: On Track. / Guidance: 25/7/24: New Milestone approved at MCAG on 25/7/24
- 1968: Action: 8/7/24: Successor was on M10 (1861 id903) - I removed as it was moving the date out
- 1972: Action: 9/7/24: To be expanded once clarified
- 1973: Action: 9/7/24: To be expanded once clarified
- 1974: Action: 9/7/24: To be expanded once clarified
- 1975: Action: 9/7/24: To be expanded once clarified
- 1976: Action: 9/7/24: To be expanded once clarified

| ID | WBS | Task | Type | Duration | Start | Finish | Predecessors | Complete | Remaining | Baseline start | Baseline finish | Baseline duration | Baseline 1 start | Baseline 1 finish | Total slack | Free slack | Baseline cost | Responsible | Involved | Update Version | MHHS Resource Name | Sched Status | RAG | Task Status | MHHS Programme Phase | Artefact ID | Milestone ID | Text29 | Tier |
| --- | --- | --- | --- | --- | --- | --- | --- | --- | --- | --- | --- | --- | --- | --- | --- | --- | --- | --- | --- | --- | --- | --- | --- | --- | --- | --- | --- | --- | --- |
| 1977 | 1.8.6 | **Migration Control Centre Mobilised and Ready** |  | 185d | 2024-07-30 A | 2025-04-14 |  | 1% | 182.8d | 2024-07-31 | 2025-02-03 | 134d |  |  | 32406d |  |  | N/A | N/A | 5.28 | N/A |  |  |  |  |  |  |  |  |
| 1978 | 1.8.6.1 | Migration Control Centre TOM Definition |  | 65d | 2024-07-30 A | 2024-10-28 | 1952FS+2d | 3% | 63d | 2024-07-31 | 2024-09-09 | 29d |  |  | 32420d | 0d |  | SRO Migration | SRO Migration | 5.28 | Simon chidwick | Red | RED |  |  |  |  |  |  |
| 1979 | 1.8.6.2 | Access to Data |  | 25d | 2024-11-04 | 2024-12-06 | 1978FS+4d |  |  | 2024-09-16 | 2024-10-18 | 25d |  |  | 32420d | 0d |  | SRO Migration | SRO Migration | 5.28 | Simon chidwick | Red | RED | 45.33 |  |  |  |  |  |
| 1980 | 1.8.6.3 | Migration Control Centre Delegation of Authority |  | 12d | 2024-12-24 | 2025-01-08 | 1979FS+11d |  |  | 2024-11-04 | 2024-11-19 | 12d |  |  | 32420d | 0d |  | SRO Migration | SRO Migration | 5.28 | Simon chidwick | Red | RED | 95.33 |  |  |  |  |  |
| 1981 | 1.8.6.4 | Recruit and Train |  | 65d | 2024-12-24 | 2025-03-24 | 1980SS |  |  | 2024-11-04 | 2025-01-31 | 65d |  |  | 32420d | 14d |  | SRO Migration | SRO Migration | 5.28 | Simon chidwick | Red | RED | 95.33 |  |  |  |  |  |
| 1982 | 1.8.6.5 | Dress Rehearsal |  | 1d | 2025-04-14 | 2025-04-14 | 1976, 1981, 1986, 1987 |  |  | 2025-02-03 | 2025-02-03 | 1d |  |  | 32406d | 169d |  | SRO Migration | SRO Migration | 5.28 | Simon chidwick | Red | RED | 206.33 |  |  |  |  |  |
| 1983 | 1.8.7 | **PP's Prepared for Migration** |  | 196d | 2024-07-01 A | 2025-03-31 |  | 23% | 150.77d | 2024-07-01 | 2025-01-30 | 154d |  |  | 32415d |  | -0 | N/A | N/A | 5.28 | N/A |  |  |  |  |  |  |  |  |
| 1984 | 1.8.7.1 | Prep for Envelope Webinar |  | 26d | 2024-07-01 A | 2024-08-05 A | 1961SS | 100% |  | 2024-07-01 | 2024-08-05 | 26d |  |  |  |  |  | SRO Migration | SRO Migration | 5.28 | Simon chidwick | Complete | COMPLETE |  |  |  |  |  |  |
| 1985 | 1.8.7.2 | Envelope/Submission Webinar |  | 1d | 2024-08-05 A | 2024-08-05 A | 1984FF | 100% |  | 2024-08-05 | 2024-08-05 | 1d |  |  |  |  |  | SRO Migration | SRO Migration,PP | 5.28 | Simon chidwick | Complete | COMPLETE |  |  |  |  |  |  |
| 1986 | 1.8.7.3 | Guides Creation |  | 45d | 2025-01-28 | 2025-03-31 | 1959FS+2d |  |  | 2024-11-29 | 2025-01-30 | 45d |  |  | 32415d | 9d |  | SRO Migration | SRO Migration,PP | 5.28 | Simon chidwick | Red | RED | 130.33 |  |  |  |  |  |
| 1987 | 1.8.7.4 | Support Channels |  | 45d | 2025-01-28 | 2025-03-31 | 1959FS+2d |  |  | 2024-11-29 | 2025-01-30 | 45d |  |  | 32415d | 9d |  | SRO Migration | SRO Migration,PP | 5.28 | Simon chidwick | Red | RED | 130.33 |  |  |  |  |  |
| 1988 | 1.8.8 | **Migration Artefact Development and Publication** |  | 743d | 2022-10-31 A | 2025-09-03 |  | 78% | 161.06d | 2022-10-31 | 2025-04-04 | 635d | 2022-10-31 | 2025-04-04 | 32344d |  | -0 | N/A | N/A | 5.0 | N/A |  |  |  | Migration |  |  |  |  |
| 1989 | 1.8.8.1 | **Migration Approach** |  | 28d | 2022-10-31 A | 2022-12-07 A |  | 100% |  | 2022-10-31 | 2022-12-07 | 28d | 2022-10-31 | 2022-12-07 |  |  |  | N/A | N/A | 5.0 | N/A |  |  |  | Migration |  |  |  |  |
| 1990 | 1.8.8.1.1 | Option analysis (via MWG and PPIR) and recommendation |  | 23d | 2022-10-31 A | 2022-11-30 A |  | 100% |  | 2022-10-31 | 2022-11-30 | 23d | 2022-10-31 | 2022-11-30 |  |  |  | PP | SI Migration | 5.0 | John Wiggins,Matthew Breen | Complete | COMPLETE |  | Migration |  |  |  |  |
| 1991 | 1.8.8.1.2 | Migration Approach approved | milestone | 0d | 2022-12-07 A | 2022-12-07 A | 1990FS+5d | 100% |  | 2022-12-07 | 2022-12-07 | 0d | 2022-12-07 | 2022-12-07 |  |  |  | SI Migration | PP,IPA | 5.0 | John Wiggins,Matthew Breen | Complete | COMPLETE |  | Migration | MHHS-DEL770 | T3-MI-0010 | PSG | T3 |
| 1992 | 1.8.8.2 | **Migration Design** |  | 100d | 2022-11-14 A | 2023-03-31 A |  | 100% |  | 2022-11-14 | 2023-03-31 | 100d | 2022-11-14 | 2023-03-31 |  |  |  | N/A | N/A | 5.0 | N/A |  |  |  | Migration |  |  |  |  |
| 1993 | 1.8.8.2.1 | Review and update existing design artefacts and socialise with participants ahead of MDSG |  | 10d | 2022-11-14 A | 2022-11-25 A |  | 100% |  | 2022-11-14 | 2022-11-25 | 10d | 2022-11-14 | 2022-11-25 |  |  |  | SI Migration | SRO Design,CPT | 5.0 | John Wiggins,Matthew Breen | Complete | COMPLETE |  | Migration |  |  |  |  |
| 1994 | 1.8.8.2.2 | Develop design artefacts and supporting technical documents in line with MDSG |  | 53d | 2022-11-30 A | 2023-02-10 A | 1993FS+2d | 100% |  | 2022-11-30 | 2023-02-10 | 53d | 2022-11-30 | 2023-02-10 |  |  |  | SI Migration | PP,SRO Function,CPT | 5.0 | John Wiggins,Matthew Breen | Complete | COMPLETE |  | Migration |  |  |  |  |
| 1995 | 1.8.8.2.3 | Migration design artefacts issued for consultation | milestone | 0d | 2023-02-13 A | 2023-02-13 A | 1994FS+1d | 100% |  | 2023-02-13 | 2023-02-13 | 0d | 2023-02-13 | 2023-02-13 |  |  |  | SI Migration | PP,SRO Function,CPT | 5.0 | John Wiggins,Matthew Breen | Complete | COMPLETE |  | Migration |  | T3-MI-0011 | DAG | T3 |
| 1996 | 1.8.8.2.4 | Industry consultation |  | 5d | 2023-02-14 A | 2023-02-20 A | 1995SS | 100% |  | 2023-02-14 | 2023-02-20 | 5d | 2023-02-14 | 2023-02-20 |  |  |  | PP | SI Migration | 5.0 | John Wiggins,Matthew Breen | Complete | COMPLETE |  | Migration |  |  |  |  |
| 1997 | 1.8.8.2.5 | Review consultation feedback, address comments and update artefacts |  | 5d | 2023-02-21 A | 2023-02-27 A | 1996 | 100% |  | 2023-02-21 | 2023-02-27 | 5d | 2023-02-21 | 2023-02-27 |  |  |  | SI Migration | PP | 5.0 | John Wiggins,Matthew Breen | Complete | COMPLETE |  | Migration |  |  |  |  |
| 1998 | 1.8.8.2.6 | Internal artefact review and comms preparation |  | 3d | 2023-02-28 A | 2023-03-02 A | 1997 | 100% |  | 2023-02-28 | 2023-03-02 | 3d | 2023-02-28 | 2023-03-02 |  |  |  | SI Migration | SRO Function | 5.0 | John Wiggins,Matthew Breen | Complete | COMPLETE |  | Migration |  |  |  |  |
| 1999 | 1.8.8.2.7 | Updated Migration Design artefacts issued to PPs for assurance review | milestone | 0d | 2023-03-03 A | 2023-03-03 A | 1998FS+1d | 100% |  | 2023-03-03 | 2023-03-03 | 0d | 2023-03-03 | 2023-03-03 |  |  |  | SI Migration | PP | 5.0 | John Wiggins,Matthew Breen | Complete | COMPLETE |  | Migration |  | T3-MI-0013 | DAG | T3 |
| 2000 | 1.8.8.2.8 | Final Migration Design artefacts walkthrough with PPs | milestone | 0d | 2023-03-22 A | 2023-03-22 A | 1999FS+13d | 100% |  | 2023-03-22 | 2023-03-22 | 0d | 2023-03-22 | 2023-03-22 |  |  |  | SI Migration | PP | 5.0 | John Wiggins,Matthew Breen | Complete | COMPLETE |  | Migration |  |  |  |  |
| 2001 | 1.8.8.2.9 | Migration Design approved | milestone | 0d | 2023-03-31 A | 2023-03-31 A | 2000FS+7d | 100% |  | 2023-03-31 | 2023-03-31 | 0d | 2023-03-31 | 2023-03-31 |  |  |  | SI Migration | PP,SRO Function,CPT | 5.0 | John Wiggins,Matthew Breen | Complete | COMPLETE |  | Migration |  | T2-MI-0050 | DAG | T2 |

| ID | WBS | Task | Type | Duration | Start | Finish | Predecessors | Complete | Baseline start | Baseline finish | Baseline duration | Baseline 1 start | Baseline 1 finish | Baseline cost | Responsible | Involved | Update Version | MHHS Resource Name | MHHS Programme Phase | Sched Status | RAG | Milestone ID | Text29 | Tier | Guidance |
| --- | --- | --- | --- | --- | --- | --- | --- | --- | --- | --- | --- | --- | --- | --- | --- | --- | --- | --- | --- | --- | --- | --- | --- | --- | --- |
| 2002 | 1.8.8.3 | **Transition Design** |  | 186d | 2023-03-01 A | 2023-11-15 A |  | 100% | 2023-03-01 | 2023-11-15 | 186d | 2023-03-01 | 2023-08-03 | -0 | N/A | N/A | 5.0 | N/A | Migration |  |  |  |  |  |  |
| 2003 | 1.8.8.3.1 | **Tranche 1** |  | 56d | 2023-03-01 A | 2023-05-17 A |  | 100% | 2023-03-01 | 2023-05-17 | 56d | 2023-03-01 | 2023-05-17 |  | N/A | N/A | 5.0 | N/A | Migration |  |  |  |  |  |  |
| 2004 | 1.8.8.3.1.1 | Develop design artefacts and supporting technical details with participants |  | 50d | 2023-03-01 A | 2023-05-09 A |  | 100% | 2023-03-01 | 2023-05-09 | 50d | 2023-03-01 | 2023-05-09 |  | SI Design | PP | 5.0 | Andrew Margan | Migration | Complete | COMPLETE |  |  |  |  |
| 2005 | 1.8.8.3.1.2 | Issue Material for DAG approval |  | 1d | 2023-05-10 A | 2023-05-10 A | 2004 | 100% | 2023-05-10 | 2023-05-10 | 1d | 2023-05-10 | 2023-05-10 |  | PP | SI Design | 5.0 | Andrew Margan | Migration | Complete | COMPLETE |  |  |  |  |
| 2006 | 1.8.8.3.1.3 | Tranche 1 Transition Design approved | milestone | 0d | 2023-05-17 A | 2023-05-17 A | 2005FS+5d | 100% | 2023-05-17 | 2023-05-17 | 0d | 2023-05-17 | 2023-05-17 |  | SI Design | PP | 5.0 | Andrew Margan | Migration | Complete | COMPLETE | T2-DB-0150 | DAG | T2 |  |
| 2007 | 1.8.8.3.2 | **Tranche 2** |  | 130d | 2023-05-18 A | 2023-11-15 A |  | 100% | 2023-05-18 | 2023-11-15 | 130d | 2023-05-18 | 2023-08-03 | -0 | N/A | N/A | 5.0 | N/A | Migration |  |  |  |  |  |  |
| 2008 | 1.8.8.3.2.1 | Develop Initial design artefacts and supporting technical details |  | 76d | 2023-05-18 A | 2023-08-31 A | 2006 | 100% | 2023-05-18 | 2023-08-31 | 76d | 2023-05-18 | 2023-07-26 |  | SRO | PP, CPT, SRO Design | 5.5 | Andrew Margan | Migration | Complete | COMPLETE |  |  |  |  |
| 2009 | 1.8.8.3.2.2 | Communicate Initial Design Artefacts with Industry (MTDSG) |  | 1d | 2023-09-01 A | 2023-09-01 A | 2008 | 100% | 2023-09-01 | 2023-09-01 | 1d |  |  |  | SRO | PP, CPT, SRO Design | 5.5 | Andrew Margan | Migration | Complete | COMPLETE |  |  |  |  |
| 2010 | 1.8.8.3.2.3 | Host MTDSG |  | 1d | 2023-09-11 A | 2023-09-11 A | 2009FS+5d | 100% | 2023-09-11 | 2023-09-11 | 1d |  |  |  | SRO | PP, CPT, SRO Design | 5.5 | Andrew Margan | Migration | Complete | COMPLETE |  |  |  |  |
| 2011 | 1.8.8.3.2.4 | Process MTDSG Feedback and Amend Design Artefacts |  | 4d | 2023-09-12 A | 2023-09-15 A | 2010 | 100% | 2023-09-12 | 2023-09-15 | 4d |  |  |  | SRO | PP, CPT, SRO Design | 5.5 | Andrew Margan | Migration | Complete | COMPLETE |  |  |  |  |
| 2012 | 1.8.8.3.2.5 | Communicate Amended Design Artefacts with Industry |  | 1d | 2023-09-15 A | 2023-09-15 A | 2011FF | 100% | 2023-09-15 | 2023-09-15 | 1d |  |  |  | SRO | PP, CPT, SRO Design | 5.5 | Andrew Margan | Migration | Complete | COMPLETE |  |  |  |  |
| 2013 | 1.8.8.3.2.6 | Host MTDSG |  | 1d | 2023-09-26 A | 2023-09-26 A | 2012FS+6d | 100% | 2023-09-26 | 2023-09-26 | 1d |  |  |  | SRO | PP, CPT, SRO Design | 5.5 | Andrew Margan | Migration | Complete | COMPLETE |  |  |  |  |
| 2014 | 1.8.8.3.2.7 | Make Final Amendments to Design Artefact |  | 5d | 2023-09-27 A | 2023-10-03 A | 2013 | 100% | 2023-09-27 | 2023-10-03 | 5d |  |  |  | SRO | PP, CPT, SRO Design | 5.5 | Andrew Margan | Migration | Complete | COMPLETE |  |  |  |  |
| 2015 | 1.8.8.3.2.8 | Request DAG Consultation |  | 1d | 2023-10-04 A | 2023-10-04 A | 2014 | 100% | 2023-10-04 | 2023-10-04 | 1d |  |  |  | SRO | PP, CPT, SRO Design | 5.5 | Andrew Margan | Migration | Complete | COMPLETE |  |  |  |  |
| 2016 | 1.8.8.3.2.9 | Consultation Period |  | 11d | 2023-10-04 A | 2023-10-18 A | 2015SS | 100% | 2023-10-04 | 2023-10-18 | 11d |  |  |  | SRO | PP, CPT, SRO Design | 5.5 | Andrew Margan | Migration | Complete | COMPLETE |  |  |  |  |
| 2017 | 1.8.8.3.2.10 | Action Consultation Comments |  | 5d | 2023-10-19 A | 2023-10-25 A | 2016 | 100% | 2023-10-19 | 2023-10-25 | 5d |  |  |  | SRO | PP, CPT, SRO Design | 5.5 | Andrew Margan | Migration | Complete | COMPLETE |  |  |  |  |
| 2018 | 1.8.8.3.2.11 | Post Consultation Industry Assurance |  | 5d | 2023-10-26 A | 2023-11-01 A | 2017 | 100% | 2023-10-26 | 2023-11-01 | 5d |  |  |  | SRO | PP, CPT, SRO Design | 5.5 | Andrew Margan | Migration | Complete | COMPLETE |  |  |  |  |
| 2019 | 1.8.8.3.2.12 | Request DAG Approval |  | 1d | 2023-11-01 A | 2023-11-01 A | 2018FF | 100% | 2023-11-01 | 2023-11-01 | 1d |  |  |  | SRO | PP, CPT, SRO Design | 5.5 | Andrew Margan | Migration | Complete | COMPLETE |  |  |  |  |
| 2020 | 1.8.8.3.2.13 | DAG Transition Design Approved |  | 1d | 2023-11-08 A | 2023-11-08 A | 2019FS+4d | 100% | 2023-11-08 | 2023-11-08 | 1d |  |  |  | SRO | PP, CPT, SRO Design | 5.5 | Andrew Margan | Migration | Complete | COMPLETE |  |  |  |  |
| 2021 | 1.8.8.3.2.14 | Update Transition Design Admin |  | 5d | 2023-11-09 A | 2023-11-15 A | 2020 | 100% | 2023-11-09 | 2023-11-15 | 5d |  |  |  | SRO | PP, CPT, SRO Design | 5.5 | Andrew Margan | Migration | Complete | COMPLETE |  |  |  |  |
| 2022 | 1.8.8.3.2.15 | Tranche 2 Transition Design Baselined | milestone | 0d | 2023-11-15 A | 2023-11-15 A | 2021 | 100% | 2023-11-15 | 2023-11-15 | 0d | 2023-08-03 | 2023-08-03 |  | SRO | PP, CPT, SRO Design | 5.12 | Andrew Margan | Migration | Complete | COMPLETE | T2-DB-0250 | DAG | T2 | 14/8 - Date aligns with DAG |
| 2023 | 1.8.8.4 | **Data Assessment Report** |  | 61d | 2022-12-06 A | 2023-02-28 A |  | 100% | 2022-12-06 | 2023-02-28 | 61d | 2022-12-06 | 2023-02-28 |  | N/A | N/A | 5.0 | N/A | Migration |  |  |  |  |  |  |
| 2024 | 1.8.8.4.1 | Develop document with MWG |  | 49d | 2022-12-06 A | 2023-02-10 A |  | 100% | 2022-12-06 | 2023-02-10 | 49d | 2022-12-06 | 2023-02-10 |  | SI Migration |  | 5.0 | John Wiggins,Matthew Breen | Migration | Complete | COMPLETE |  |  |  |  |
| 2025 | 1.8.8.4.2 | Artefact review (via TMAG) and updates |  | 25d | 2023-01-18 A | 2023-02-21 A | 2024FS-18d | 100% | 2023-01-18 | 2023-02-21 | 25d | 2023-01-18 | 2023-02-21 |  | PP | IPA,SI Migration | 5.0 | John Wiggins,Matthew Breen | Migration | Complete | COMPLETE |  |  |  |  |
| 2026 | 1.8.8.4.3 | Data Assessment Report approved | milestone | 0d | 2023-02-28 A | 2023-02-28 A | 2025FS+5d | 100% | 2023-02-28 | 2023-02-28 | 0d | 2023-02-28 | 2023-02-28 |  | SI Migration | PP,IPA | 5.0 | John Wiggins,Matthew Breen | Migration | Complete | COMPLETE | T3-MI-0012 | MCAG | T3 |  |

Notes:
- 2022: 14/8 - Milestone aligned to 5 days after DAG approval, to update comms and admin on collaboration base. CR number to be added. 15/9 - Rebaseline approved at DAG on 13/9/23 / Action: 2/8/23 - needs to be replanned to 15//11/23. AM to raise CR as T2 milestone

| ID | WBS | Task | Type | Duration | Start | Finish | Predecessors | Complete | Remaining | Baseline start | Baseline finish | Baseline duration | Baseline 1 start | Baseline 1 finish | Total slack | Free slack | Constraint | Baseline cost | Responsible | Involved | Update Version | MHHS Resource Name | MHHS Programme Phase | Sched Status | RAG | Milestone ID | Text29 | Tier | Task Status | Guidance |
| --- | --- | --- | --- | --- | --- | --- | --- | --- | --- | --- | --- | --- | --- | --- | --- | --- | --- | --- | --- | --- | --- | --- | --- | --- | --- | --- | --- | --- | --- | --- |
| 2027 | 1.8.8.5 | **Migration, Cutover & Data Strategy (incl. Migration Entry Criteria)** |  | 102d | 2022-12-08 A | 2023-04-28 A |  | 100% |  | 2022-12-08 | 2023-04-28 | 102d | 2022-12-08 | 2023-04-28 |  |  |  |  | N/A | N/A | 5.0 | N/A | Migration |  |  |  |  |  |  |  |
| 2028 | 1.8.8.5.1 | Develop document with MWG |  | 67d | 2022-12-08 A | 2023-03-10 A | 1991 | 100% |  | 2022-12-08 | 2023-03-10 | 67d | 2022-12-08 | 2023-03-10 |  |  |  |  | SI Migration | PP | 5.0 | John Wiggins,Matthew Breen | Migration | Complete | COMPLETE |  |  |  |  |  |
| 2029 | 1.8.8.5.2 | Artefact review (via TMAG) and updates |  | 28d | 2023-03-15 A | 2023-04-21 A | 2028FS+2d | 100% |  | 2023-03-15 | 2023-04-21 | 28d | 2023-03-15 | 2023-04-21 |  |  |  |  | PP | SI Migration | 5.0 | John Wiggins,Matthew Breen | Migration | Complete | COMPLETE |  |  |  |  |  |
| 2030 | 1.8.8.5.3 | Migration, Cutover & Data Strategy approved | milestone | 0d | 2023-04-28 A | 2023-04-28 A | 2029FF+5d | 100% |  | 2023-04-28 | 2023-04-28 | 0d | 2023-04-28 | 2023-04-28 |  |  |  |  | SI Migration | PP | 5.0 | John Wiggins,Matthew Breen | Migration | Complete | COMPLETE | T3-MI-0014 | MCAG | T3 |  |  |
| 2031 | 1.8.8.6 | **Data Cleanse Plan** |  | 655d | 2023-03-02 A | 2025-09-03 |  | 63% | 245.22d | 2023-03-02 | 2025-04-04 | 547d | 2023-03-02 | 2025-04-04 | 32344d |  |  | -0 | N/A | N/A | 5.0 | N/A | Migration |  |  |  |  |  |  |  |
| 2032 | 1.8.8.6.1 | Develop document with MWG |  | 50d | 2023-03-02 A | 2023-05-10 A |  | 100% |  | 2023-03-02 | 2023-05-10 | 50d | 2023-03-02 | 2023-05-10 |  |  |  |  | SI Migration | PP | 5.0 | John Wiggins,Matthew Breen | Migration | Complete | COMPLETE |  |  |  |  |  |
| 2033 | 1.8.8.6.2 | Artefact review (via TMAG) and updates |  | 20d | 2023-05-11 A | 2023-06-07 A | 2032 | 100% |  | 2023-05-11 | 2023-06-07 | 20d | 2023-05-11 | 2023-06-07 |  |  |  |  | PP | SI Migration,IPA | 5.0 | John Wiggins,Matthew Breen | Migration | Complete | COMPLETE |  |  |  |  |  |
| 2034 | 1.8.8.6.3 | Data Cleanse Plan approved | milestone | 0d | 2023-07-19 A | 2023-07-19 A | 2033FS+30d | 100% |  | 2023-07-19 | 2023-07-19 | 0d | 2023-06-14 | 2023-06-14 |  |  |  |  | SI Migration | PP | 5.0 | John Wiggins,Matthew Breen | Migration | Complete | COMPLETE | T3-MI-0020 | MCAG | T3 |  |  |
| 2035 | 1.8.8.6.4 | Monitor Programme Participant adherence to Data Cleanse Plan |  | 467d | 2023-06-15 A | 2025-03-28 | 2034 | 64% | 167d | 2023-06-15 | 2025-03-28 | 467d | 2023-06-15 | 2025-03-28 | 32457d |  |  |  | SI Migration | PP | 5.0 | Matthew Breen | Migration | Green | GREEN |  |  |  |  |  |
| 2036 | 1.8.8.6.5 | **MTDs** |  | 120d | 2024-08-16 A | 2025-01-31 |  | 8% | 111d | 2024-08-16 | 2024-12-23 | 91d |  |  | 32497d |  |  | -0 | N/A | N/A | 5.4 | N/A | Migration |  |  |  |  |  |  |  |
| 2037 | 1.8.8.6.5.1 | **ESME ID** |  | 90d | 2024-08-16 A | 2024-12-20 |  |  | 90d | 2024-08-16 | 2024-12-20 | 90d |  |  | 32527d |  |  | -0 | N/A | N/A | 5.4 | N/A | Migration |  |  |  |  |  |  |  |
| 2038 | 1.8.8.6.5.1.1 | DCC to extract ESME ID and share with LDSO | milestone | 0d | 2024-08-16 A | 2024-08-16 A | 2034FS+282d | 100% |  | 2024-08-16 | 2024-08-16 | 0d |  |  |  |  |  |  | DCC/SI |  | 5.5 | Matthew Breen | Migration | Complete | COMPLETE | T3-MI-0024 | MCAG (Transition) | T3 |  |  |
| 2039 | 1.8.8.6.5.1.2 | LDSO ‘full refresh’ between their Registration Service and the EES (ESME ID) |  | 16d | 2024-10-21 | 2024-11-11 | 2038FS+45d |  |  | 2024-10-21 | 2024-11-11 | 0d |  |  | 32527d | 0d |  |  | LDSO/EES |  | 5.5 | Matthew Breen | Migration | Green | GREEN | T3-MI-0025 | MCAG (Transition) | T3 | 31.33 |  |
| 2040 | 1.8.8.6.5.1.3 | Suppliers complete investigation of exceptions and resolution of exceptions |  | 1d | 2024-12-20 | 2024-12-20 | 2039FS+28d |  |  | 2024-12-20 | 2024-12-20 | 1d |  |  | 32527d | 0d |  |  | Supplier |  | 5.4 | Matthew Breen | Migration | Green | GREEN |  |  |  | 91.33 |  |
| 2041 | 1.8.8.6.5.1.4 | ESME ID Complete | milestone | 0d | 2024-12-20 | 2024-12-20 | 2040 |  |  | 2024-12-20 | 2024-12-20 | 0d |  |  | 32527d |  |  |  |  |  | 5.4 | Matthew Breen | Migration | Green | GREEN |  |  |  | 91.71 |  |
| 2042 | 1.8.8.6.5.2 | **Meter Location and Number of Displayed Register Digits** |  | 101d | 2024-09-13 A | 2025-01-31 |  | 13% | 87.83d | 2024-08-16 | 2024-12-23 | 91d |  |  | 32497d |  |  |  | N/A | N/A | 5.4 | N/A | Migration |  |  |  |  |  |  |  |
| 2043 | 1.8.8.6.5.2.1 | MEM to extract data and share with LDSO |  | 6d | 2024-09-13 A | 2024-09-20 | 2034FS+301d | 50% | 3d | 2024-08-16 | 2024-08-16 | 1d |  |  | 32497d | 0d |  |  | MEM/SI |  | 5.4 | Matthew Breen | Migration | Red | RED |  |  |  |  |  |
| 2044 | 1.8.8.6.5.2.2 | LDSO ‘full refresh’ between their Registration Service and the EES (Meter Location and Number of Displayed Register Digits) |  | 16d | 2024-10-28 | 2024-11-18 | 2043FS+25d |  |  | 2024-09-27 | 2024-09-27 | 0d |  |  | 32497d | 0d |  |  | LDSO /EES |  | 5.5 | Matthew Breen | Migration | Red | RED | T3-MI-0026 | MCAG (Transition) | T3 | 38.33 |  |
| 2045 | 1.8.8.6.5.2.3 | Suppliers complete investigation of exceptions and resolution of exceptions |  | 1d | 2025-01-31 | 2025-01-31 | 2044FS+53d |  |  | 2024-12-20 | 2024-12-20 | 1d |  |  | 32497d | 0d |  |  | Supplier |  | 5.4 | Matthew Breen | Migration | Red | RED |  |  |  | 133.33 |  |
| 2046 | 1.8.8.6.5.2.4 | Meter Location and Number of Displayed Register Digits Complete | milestone | 0d | 2025-01-31 | 2025-01-31 | 2045 |  |  | 2024-12-23 | 2024-12-23 | 0d |  |  | 32497d |  |  |  |  |  | 5.4 | Matthew Breen | Migration | Red | RED |  |  |  | 133.71 |  |
| 2047 | 1.8.8.6.6 | **Registration Data** |  | 259d | 2024-09-06 A | 2025-09-03 |  | 5% | 246.67d | 2024-09-06 | 2025-03-31 | 147d |  |  | 32344d |  |  |  | N/A | N/A | 5.4 | N/A | Migration |  |  |  |  |  |  |  |
| 2048 | 1.8.8.6.6.1 | **Connection Type** |  | 47d | 2024-09-06 A | 2024-11-11 |  | 6% | 44.24d | 2024-09-06 | 2024-09-27 | 16d |  |  | 32556d |  |  |  | N/A | N/A | 5.4 | N/A | Migration |  |  |  |  |  |  |  |
| 2049 | 1.8.8.6.6.1.1 | Automated Population of Connection Type for Measurement Classes ‘B’, ‘D’, ‘F’ & ‘G’ | milestone | 0d | 2024-10-04 | 2024-10-04 | 2034FS+317d |  |  | 2024-09-13 | 2024-09-13 | 0d |  |  | 32582d | 26d | start no earlier than 2024-09-13 |  | LDSO |  | 5.5 | Matthew Breen | Migration | Red | RED | T3-MI-0027 | MCAG (Transition) | T3 | 14.71 |  |
| 2050 | 1.8.8.6.6.1.2 | BAU Population of Connection Type for Site Specific LLFCs within Measurement Classes ‘C’ & ‘E’ | milestone | 0d | 2024-10-04 | 2024-10-04 | 2034FS+317d |  |  | 2024-09-13 | 2024-09-13 | 0d |  |  | 32582d | 26d |  |  | LDSO |  | 5.5 | Matthew Breen | Migration | Red | RED | T3-MI-0028 | MCAG (Transition) | T3 | 14.71 |  |
| 2051 | 1.8.8.6.6.1.3 | Automated Population of Connection Type for Smart Meters within Measurement Class ‘A’ | milestone | 0d | 2024-10-04 | 2024-10-04 | 2034FS+317d |  |  | 2024-09-13 | 2024-09-13 | 0d |  |  | 32582d | 26d |  |  | LDSO |  | 5.5 | Matthew Breen | Migration | Red | RED | T3-MI-0029 | MCAG (Transition) | T3 | 14.71 |  |
| 2052 | 1.8.8.6.6.1.4 | Population of Connection Type for Traditional and Advanced Meters within Measurement Class ‘A’ |  | 1d | 2024-09-06 A | 2024-09-06 A | 2034FS+296d | 100% |  | 2024-09-06 | 2024-09-06 | 1d |  |  |  |  |  |  | Suppliers |  | 5.4 | Matthew Breen | Migration | Complete | COMPLETE |  |  |  |  |  |
| 2053 | 1.8.8.6.6.1.5 | Automated Population of Null Connection Type | milestone | 0d | 2024-10-04 | 2024-10-04 | 2034FS+317d |  |  | 2024-09-13 | 2024-09-13 | 0d |  |  | 32582d | 26d |  |  | LDSO |  | 5.5 | Matthew Breen | Migration | Red | RED | T3-MI-0030 | MCAG (Transition) | T3 | 14.71 |  |
| 2054 | 1.8.8.6.6.1.6 | Full MPAN refresh to ESS |  | 16d | 2024-10-21 | 2024-11-11 | 2034FS+327d |  |  | 2024-09-27 | 2024-09-27 | 1d |  |  | 32556d | 0d |  |  | LDSO/EES |  | 5.4 | Matthew Breen | Migration | Red | RED |  |  |  | 31.33 | Actually takes place on 29/9/24 which is a Sunday |
| 2055 | 1.8.8.6.6.1.7 | Connection Type Complete | milestone | 0d | 2024-11-11 | 2024-11-11 | 2049, 2050, 2051, 2052, 2053, 2054 |  |  | 2024-09-27 | 2024-09-27 | 0d |  |  | 32556d |  |  |  |  |  | 5.4 | Matthew Breen | Migration | Red | RED |  |  |  | 52.71 |  |

Notes:
- 2036: 27/7 - CH added in with Matthew Breen
- 2037: 27/7 - CH added in with Matthew Breen
- 2038: 27/7 - CH added in with Matthew Breen
- 2039: 2/8/24: Date missed because Meter Location and Number of Displayed Register Digits has been delayed due to additional data validation activities. This will delay some of the data migration activities. To go to August MCAG for date change approval
- 2040: 27/7 - CH added in with Matthew Breen
- 2041: 27/7 - CH added in with Matthew Breen / Action: 2/8/24: is date right as different to baseline? Why was it 23rd?
- 2042: 27/7 - CH added in with Matthew Breen
- 2043: 27/7 - CH added in with Matthew Breen
- 2044: Date missed due to additional data validation activities for Meter Location and Number of Displayed Register Digits. This will cause a delay to some of the other data migration activities. To go to August MCAG for date change approval
- 2045: 27/7 - CH added in with Matthew Breen
- 2046: 27/7 - CH added in with Matthew Breen
- 2047: 27/7 - CH added in with Matthew Breen
- 2048: 27/7 - CH added in with Matthew Breen
- 2052: 27/7 - CH added in with Matthew Breen
- 2054: 27/7 - CH added in with Matthew Breen
- 2055: 27/7 - CH added in with Matthew Breen

| ID | WBS | Task | Type | Duration | Start | Finish | Predecessors | Complete | Remaining | Baseline start | Baseline finish | Baseline duration | Baseline 1 start | Baseline 1 finish | Total slack | Free slack | Constraint | Baseline cost | Responsible | Involved | Update Version | MHHS Resource Name | MHHS Programme Phase | Guidance | Task Status | Sched Status | RAG | Milestone ID | Text29 | Tier |
| --- | --- | --- | --- | --- | --- | --- | --- | --- | --- | --- | --- | --- | --- | --- | --- | --- | --- | --- | --- | --- | --- | --- | --- | --- | --- | --- | --- | --- | --- | --- |
| 2056 | 1.8.8.6.6.2 | **Domestic Premises Indicator** |  | 19d | 2025-08-08 | 2025-09-03 |  |  |  | 2025-03-07 | 2025-03-31 | 17d |  |  | 32344d |  |  |  | N/A | N/A | 5.4 | N/A | Migration |  |  |  |  |  |  |  |
| 2057 | 1.8.8.6.6.2.1 | The DCC to extract Domestic Premises Indicator from the CSS and provide a file to each LDSO and EES. |  | 2d | 2025-08-08 | 2025-08-11 |  |  |  | 2025-03-07 | 2025-03-07 | 1d |  |  | 32344d | 0d | start no earlier than 2025-08-08 |  | DCC |  | 5.4 | Matthew Breen | Migration | 27/7 - needs to end on date of M10 7/3/25 | 322.33 | Red | RED |  |  |  |
| 2058 | 1.8.8.6.6.2.2 | Each LDSO notifies the DCC of any exceptions |  | 1d | 2025-08-12 | 2025-08-12 | 2057 |  |  | 2025-03-07 | 2025-03-07 | 1d |  |  | 32344d | 0d |  |  | LDSO |  | 5.4 | Matthew Breen | Migration | 27/7 - needs to end on date of M10 7/3/25 | 326.33 | Red | RED |  |  |  |
| 2059 | 1.8.8.6.6.2.3 | Each LDSO and DCC completes investigation and resolution of exceptions |  | 1d | 2025-09-03 | 2025-09-03 | 2057FS+15d, 2058FS+15d |  |  | 2025-03-31 | 2025-03-31 | 1d |  |  | 32344d | 0d |  |  | LDSO / DCC |  | 5.4 | Matthew Breen | Migration | 27/7 Needs to take place approx. 1 month after M10 | 348.33 | Red | RED |  |  |  |
| 2060 | 1.8.8.6.6.2.4 | Domestic Premises Indicator Complete | milestone | 0d | 2025-09-03 | 2025-09-03 | 2059 |  |  | 2025-03-31 | 2025-03-31 | 0d |  |  | 32344d |  |  |  |  |  | 5.4 | Matthew Breen | Migration |  | 348.71 | Red | RED |  |  |  |
| 2061 | 1.8.8.6.7 | **Export / Import MPANs** |  | 151d | 2024-03-22 A | 2024-10-18 |  | 67% | 50.33d | 2024-03-22 | 2024-10-18 | 151d |  |  | 32572d |  |  |  | N/A | N/A | 5.4 | N/A | Migration |  |  |  |  |  |  |  |
| 2062 | 1.8.8.6.7.1 | **Linking of Export / Import MPANS** |  | 151d | 2024-03-22 A | 2024-10-18 |  | 67% | 50.33d | 2024-03-22 | 2024-10-18 | 151d |  |  | 32572d |  |  |  | N/A | N/A | 5.4 | N/A | Migration |  |  |  |  |  |  |  |
| 2063 | 1.8.8.6.7.1.1 | LDSO utilises BAU processing (DB05s) to populate each import/export association |  | 1d | 2024-03-22 A | 2024-03-22 A | 2034FS+176d | 100% |  | 2024-03-22 | 2024-03-22 | 1d |  |  |  |  |  |  | LDSO |  | 5.4 | Matthew Breen | Migration |  |  | Complete | COMPLETE |  |  |  |
| 2064 | 1.8.8.6.7.1.2 | Each LDSO notifies the Registered Supplier of any exceptions |  | 1d | 2024-04-19 A | 2024-04-19 A | 2063FS+19d | 100% |  | 2024-04-19 | 2024-04-19 | 1d |  |  |  |  |  |  | LDSO |  | 5.4 | Matthew Breen | Migration |  |  | Complete | COMPLETE |  |  |  |
| 2065 | 1.8.8.6.7.1.3 | Each Supplier completes investigation and resolution of exceptions |  | 1d | 2024-08-23 | 2024-08-23 | 2064FS+89d |  |  | 2024-08-23 | 2024-08-23 | 1d |  |  | 32572d | 0d |  |  | Supplier |  | 5.4 | Matthew Breen | Migration |  | -27.67 | Overdue Start | RED |  |  |  |
| 2066 | 1.8.8.6.7.1.4 | Each LDSO has linked al relevant import/export MPANS | milestone | 0d | 2024-10-18 | 2024-10-18 | 2065FS+40d |  |  | 2024-10-18 | 2024-10-18 | 0d |  |  | 32572d | 0d |  |  | LDSO |  | 5.5 | Matthew Breen | Migration |  | 28.71 | Green | GREEN | T3-MI-0031 | MCAG (Transition) | T3 |
| 2067 | 1.8.8.6.7.1.5 | Linking of Export / Import MPANS Complete | milestone | 0d | 2024-10-18 | 2024-10-18 | 2066 |  |  | 2024-10-18 | 2024-10-18 | 0d |  |  | 32572d |  |  |  |  |  | 5.4 | Matthew Breen | Migration |  | 28.71 | Green | GREEN |  |  |  |
| 2068 | 1.8.8.6.8 | Pre-migration data cleanse complete | milestone | 0d | 2025-08-13 | 2025-08-13 |  |  |  | 2025-04-04 | 2025-04-04 | 0d | 2025-04-04 | 2025-04-04 | 32360d |  | start no earlier than 2025-08-13 |  | SI Migration | PP | 5.0 | Matthew Breen | Migration |  | 327.33 | Red | RED | T2-MI-0450 | MCAG (Transition) | T2 |
| 2069 | 1.8.9 | **Migration Period Planning** |  | 367d | 2023-07-03 A | 2024-11-26 |  | 83% | 61.71d | 2023-07-03 | 2026-10-05 | 851d | 2023-07-03 | 2026-10-05 | 32421d |  |  | -0 | N/A | N/A | 5.0 | N/A | Migration |  | M10 |  |  |  |  |  |
| 2070 | 1.8.9.1 | **Migration Implementation Plan (incl. Migration Exit Criteria)** |  | 367d | 2023-07-03 A | 2024-11-26 |  | 83% | 61.71d | 2023-07-03 | 2026-10-05 | 851d | 2023-07-03 | 2026-10-05 | 32421d |  |  | -0 | N/A | N/A | 5.0 | N/A | Migration |  |  |  |  |  |  |  |
| 2071 | 1.8.9.1.1 | **Migration Threshold Volumes** |  | 101d | 2023-07-03 A | 2023-11-20 A |  | 100% |  | 2023-07-03 | 2023-11-15 | 98d | 2023-07-03 | 2023-08-31 |  |  |  | -0 | N/A | N/A | 5.0 | N/A | Migration |  |  |  |  |  |  |  |
| 2072 | 1.8.9.1.1.1 | Threshold volumes reviewed by MWG |  | 54d | 2023-07-03 A | 2023-09-14 A |  | 100% |  | 2023-07-03 | 2023-09-14 | 54d | 2023-07-03 | 2023-07-28 |  |  |  |  | SI Migration | PP | 5.6 | John Wiggins,Matthew Breen | Migration |  |  | Complete | COMPLETE |  |  |  |
| 2073 | 1.8.9.1.1.2 | Artefact review (via TMAG) and updates |  | 47d | 2023-09-15 A | 2023-11-20 A | 2072 | 100% |  | 2023-09-15 | 2023-11-15 | 44d | 2023-07-31 | 2023-08-31 |  |  |  |  | PP | SI Migration | 5.9 | John Wiggins,Matthew Breen | Migration |  |  | Complete | COMPLETE |  |  |  |
| 2074 | 1.8.9.1.1.3 | Threshold volumes approved at TMAG | milestone | 0d | 2023-11-20 A | 2023-11-20 A | 2073 | 100% |  | 2023-11-15 | 2023-11-15 | 0d | 2023-08-31 | 2023-08-31 |  |  |  |  | SI Migration | PP | 5.12 | John Wiggins,Matthew Breen | Migration |  |  | Complete | COMPLETE | T3-MI-0021 | SITAG | T3 |
| 2075 | 1.8.9.1.2 | **Define acceptance criteria for M15** |  | 78d | 2023-09-04 A | 2023-12-20 A |  | 100% |  | 2023-09-04 | 2023-12-20 | 78d | 2023-09-04 | 2023-11-30 |  |  |  | -0 | N/A | N/A | 5.0 | N/A | Migration |  |  |  |  |  |  |  |
| 2076 | 1.8.9.1.2.1 | Review acceptance criteria and reporting requirements with MWG |  | 49d | 2023-09-04 A | 2023-11-09 A |  | 100% |  | 2023-09-04 | 2023-10-27 | 40d | 2023-09-04 | 2023-10-27 |  |  | start no earlier than 2023-09-04 |  | SI Migration |  | 5.0 | John Wiggins,Matthew Breen | Migration |  |  | Complete | COMPLETE |  |  |  |
| 2077 | 1.8.9.1.2.2 | Artefact review (via TMAG) and updates |  | 29d | 2023-11-10 A | 2023-12-20 A | 2076 | 100% |  | 2023-11-10 | 2023-12-20 | 29d | 2023-10-30 | 2023-11-30 |  |  | start no earlier than 2023-10-30 |  | PP | SI Migration | 5.0 | John Wiggins,Matthew Breen | Migration |  |  | Complete | COMPLETE |  |  |  |
| 2078 | 1.8.9.1.2.3 | Acceptance criteria for M15 agreed at TMAG | milestone | 0d | 2023-12-20 A | 2023-12-20 A | 2077 | 100% |  | 2023-12-20 | 2023-12-20 | 0d | 2023-11-30 | 2023-11-30 |  |  | finish no earlier than 2023-11-30 |  | SI Migration |  | 5.14 | John Wiggins,Matthew Breen | Migration |  |  | Complete | COMPLETE | T3-MI-0022 | SITAG | T3 |
| 2079 | 1.8.9.1.3 | **M10/M11 cut-over plan** |  | 119d | 2023-12-21 A | 2024-06-04 A |  | 100% |  | 2023-12-21 | 2024-06-04 | 119d | 2024-01-01 | 2024-05-31 |  |  |  | -0 | N/A | N/A | 5.16 | N/A | Migration |  |  |  |  |  |  |  |
| 2080 | 1.8.9.1.3.1 | Draft Document |  | 84d | 2023-12-21 A | 2024-04-16 A | 2078 | 100% |  | 2023-12-21 | 2024-04-16 | 84d |  |  |  |  |  |  | SI Transition | SI Transition,PP,SRO | 5.16 | Matthew Breen | Migration |  |  | Complete | COMPLETE |  |  |  |
| 2081 | 1.8.9.1.3.2 | Share Document with SRO |  | 1d | 2024-04-17 A | 2024-04-17 A | 2080 | 100% |  | 2024-04-17 | 2024-04-17 | 1d |  |  |  |  |  |  | SI Transition | SI Transition,PP,SRO | 5.16 | Matthew Breen | Migration |  |  | Complete | COMPLETE |  |  |  |
| 2082 | 1.8.9.1.3.3 | Industry Consultation |  | 11d | 2024-04-23 A | 2024-05-07 A | 2081FS+3d | 100% |  | 2024-04-23 | 2024-05-07 | 11d |  |  |  |  |  |  | SI Transition | SI Transition,PP,SRO | 5.16 | Matthew Breen | Migration |  |  | Complete | COMPLETE |  |  |  |
| 2083 | 1.8.9.1.3.4 | Assurance Meeting |  | 1d | 2024-05-21 A | 2024-05-21 A | 2082FS+9d | 100% |  | 2024-05-14 | 2024-05-14 | 1d |  |  |  |  |  |  | SI Transition | SI Transition,PP,SRO | 5.16 | Matthew Breen | Migration |  |  | Complete | COMPLETE |  |  |  |
| 2084 | 1.8.9.1.3.5 | MCAG Approval of M10/M11 Cut-over Plan | milestone | 0d | 2024-06-04 A | 2024-06-04 A | 2083FS+10d | 100% |  | 2024-06-04 | 2024-06-04 | 0d | 2024-05-31 | 2024-05-31 |  |  |  |  | SI Transition | SI Transition,PP,SRO | 5.26 | Matthew Breen | Migration |  |  | Complete | COMPLETE | T3-MI-0023 | MCAG | T3 |

Notes:
- 2056: 27/7 - CH added in with Matthew Breen
- 2057: 27/7 - CH added in with Matthew Breen
- 2058: 27/7 - CH added in with Matthew Breen
- 2059: 27/7 - CH added in with Matthew Breen
- 2060: 27/7 - CH added in with Matthew Breen
- 2061: 27/7 - CH added in with Matthew Breen
- 2062: 27/7 - CH added in with Matthew Breen
- 2063: 27/7 - CH added in with Matthew Breen
- 2064: 27/7 - CH added in with Matthew Breen
- 2065: 27/7 - CH added in with Matthew Breen
- 2066: On track
- 2067: 27/7 - CH added in with Matthew Breen
- 2073: 7/11 - Red because date of TMAG chnaged
- 2074: Red as plan was to approve at extraordinary TMAG on 8/11, however regular TMAG taking place on 15/11 so deferred approval to this date. To go to TMAG for date change. Approved for date change at TMAG on 23/10/23. 7/11 - Red because date of TMAG changed
- 2078: 17/10 - Red because initial date was not aligned to a TMAG. On track to delivery by 20/12. To go to 20/11/23 TMAG for approval to change date. 20/11 - Date rebaselined. 20/12 - Approved at TMAG on 20/12
- 2084: 27/2 - Approved at MCAG on 27/2/24. 30/4: To go to 8th Red MCAG for rebaselining because MCAG is being rescheduled. 8/5 - Approved date change at MCAG on 8/5/24

| ID | WBS | Task | Type | Duration | Start | Finish | Predecessors | Complete | Remaining | Baseline start | Baseline finish | Baseline duration | Baseline 1 start | Baseline 1 finish | Total slack | Free slack | Constraint | Baseline cost | Responsible | Involved | Update Version | MHHS Resource Name | MHHS Programme Phase | Sched Status | RAG | Task Status | Milestone ID | Text29 | Tier | Action |
| --- | --- | --- | --- | --- | --- | --- | --- | --- | --- | --- | --- | --- | --- | --- | --- | --- | --- | --- | --- | --- | --- | --- | --- | --- | --- | --- | --- | --- | --- | --- |
| 2085 | 1.8.9.1.4 | **M16 Methodology** |  | 85d | 2024-07-31 A | 2024-11-26 |  | 10% | 76.9d | 2024-07-31 | 2024-11-26 | 85d | 2023-10-02 | 2024-04-26 | 32421d |  |  | -0 | N/A | N/A | 5.0 | N/A | Migration |  |  |  |  |  |  |  |
| 2086 | 1.8.9.1.4.1 | Draft Document |  | 50d | 2024-07-31 A | 2024-10-08 |  | 12% | 44d | 2024-07-31 | 2024-10-08 | 50d | 2023-10-02 | 2023-12-29 | 32421d | 0d |  |  | SI Transition | SI Transition,PP,SRO | 5.26 | Matthew Breen | Migration | Green | RED |  |  |  |  |  |
| 2087 | 1.8.9.1.4.2 | Share Document with SRO |  | 1d | 2024-10-09 | 2024-10-09 | 2086 |  |  | 2024-10-09 | 2024-10-09 | 1d | 2024-01-01 | 2024-01-26 | 32421d | 0d |  |  | SI Transition | SI Transition,PP,SRO | 5.26 | Matthew Breen | Migration | Green | RED | 19.33 |  |  |  |  |
| 2088 | 1.8.9.1.4.3 | Industry Consultation |  | 11d | 2024-10-15 | 2024-10-29 | 2087FS+3d |  |  | 2024-10-15 | 2024-10-29 | 11d | 2024-01-29 | 2024-03-29 | 32421d | 0d |  |  | SI Transition | SI Transition,PP,SRO | 5.26 | Matthew Breen | Migration | Green | RED | 25.33 |  |  |  |  |
| 2089 | 1.8.9.1.4.4 | Assurance Meeting |  | 1d | 2024-11-12 | 2024-11-12 | 2088FS+9d |  |  | 2024-11-12 | 2024-11-12 | 1d | 2024-04-01 | 2024-04-26 | 32421d | 0d |  |  | SI Transition | SI Transition,PP,SRO | 5.26 | Matthew Breen | Migration | Green | RED | 53.33 |  |  |  |  |
| 2090 | 1.8.9.1.4.5 | M16 methodology approved | milestone | 0d | 2024-11-26 | 2024-11-26 | 2089FS+10d |  |  | 2024-11-26 | 2024-11-26 | 0d | 2024-04-26 | 2024-04-26 | 32421d | 643d |  |  | SI Transition | SI Transition,PP,SRO | 5.26 | Matthew Breen | Migration | Green | RED | 67.71 | T3-MI-0500 | MCAG (Transition) | T2 |  |
| 2091 | 1.8.10 | **Preparation for Cutover to Live** |  | 748d | 2022-10-31 A | 2025-09-10 |  |  | 748d | 2024-06-28 | 2025-04-04 | 201d | 2025-02-07 | 2025-04-04 | 32339d |  |  | -0 | N/A | N/A | 5.27 | N/A | Migration |  |  |  |  |  |  |  |
| 2092 | 1.8.10.1 | **Central Systems Prepare for Cutover to Live** |  | 730d | 2022-10-31 A | 2025-08-15 |  |  | 730d | 2024-06-28 | 2025-03-14 | 186d | 2025-02-07 | 2025-03-07 | 32357d |  |  | -0 | N/A | N/A | 5.27 | N/A | Migration |  |  | M13 |  |  |  |  |
| 2093 | 1.8.10.1.1 | DCC (Functionality available June 2024) | milestone | 0d | 2024-06-28 A | 2024-06-28 A |  | 100% |  | 2024-06-28 | 2024-06-28 | 0d |  |  |  |  | start no earlier than 2024-06-28 |  | DCC |  | 5.27 | Matthew Breen |  | Complete | COMPLETE |  |  |  |  |  |
| 2094 | 1.8.10.1.2 | **Development of Comms Approach and Declaration Guidance** |  | 79d | 2025-03-03 | 2025-06-19 |  |  |  | 2024-10-01 | 2025-01-17 | 79d |  |  | 31817d |  |  |  | N/A | N/A | 5.28 | N/A |  |  |  | 95.33 |  |  |  |  |
| 2095 | 1.8.10.1.2.1 | Draft Cutover Comms Approach |  | 59d | 2025-03-03 | 2025-05-22 |  |  |  | 2024-10-01 | 2024-12-20 | 59d |  |  | 31817d | 0d | start no earlier than 2025-03-03 |  | SI Transition | SI Transition | 5.28 | Matthew Breen |  | Red | RED | 164.33 |  |  |  |  |
| 2096 | 1.8.10.1.2.2 | Draft Cutover Comms Approach shared | milestone | 0d | 2025-05-22 | 2025-05-22 | 2095 |  |  | 2024-12-20 | 2024-12-20 | 0d |  |  | 31817d | 0d |  |  | SI Transition | SI Transition | 5.28 | Matthew Breen |  | Red | RED | 244.71 |  |  |  |  |
| 2097 | 1.8.10.1.2.3 | Development of Implementation Group |  | 59d | 2025-03-03 | 2025-05-22 |  |  |  | 2024-10-01 | 2024-12-20 | 59d |  |  | 31817d | 0d | start no earlier than 2025-03-03 |  | SI Transition | SI Transition | 5.28 | Matthew Breen |  | Red | RED | 164.33 |  |  |  |  |
| 2098 | 1.8.10.1.2.4 | Implementation Group Established | milestone | 0d | 2025-05-22 | 2025-05-22 | 2097 |  |  | 2024-12-20 | 2024-12-20 | 0d |  |  | 31817d | 0d |  |  | SI Transition | SI Transition | 5.28 | Matthew Breen |  | Red | RED | 244.71 |  |  |  |  |
| 2099 | 1.8.10.1.2.5 | Finalised Cutover Comms Approach shared | milestone | 0d | 2025-06-19 | 2025-06-19 | 2096FS+20d, 2098FS+20d |  |  | 2025-01-17 | 2025-01-17 | 0d |  |  | 31817d | 39d |  |  | SI Transition | SI Transition | 5.28 | Matthew Breen |  | Red | RED | 272.71 |  |  |  |  |
| 2100 | 1.8.10.1.3 | **Development of Cutover Plan requirements with Participants** |  | 113d | 2025-03-03 | 2025-08-06 |  |  |  | 2024-10-01 | 2024-12-20 | 59d |  |  | 31783d |  |  |  | N/A | N/A | 5.28 | N/A |  |  |  | -605.67 |  |  |  |  |
| 2101 | 1.8.10.1.3.1 | Development of SIT Participant Cutover Plans |  | 59d | 2025-03-03 | 2025-05-22 |  |  |  | 2024-10-01 | 2024-12-20 | 59d |  |  | 31783d | 0d | start no earlier than 2025-03-03 |  | SI Transition | SI Transition | 5.28 | Matthew Breen |  | Red | RED | 164.33 |  |  |  |  |
| 2102 | 1.8.10.1.3.2 | SIT Participant Cutover Plans Ready | milestone | 0d | 2025-05-22 | 2025-05-22 | 2101 |  |  | 2024-12-20 | 2024-12-20 | 0d |  |  | 31783d | 0d |  |  | SI Transition | SI Transition | 5.28 | Matthew Breen |  | Red | RED | 244.71 |  |  |  |  |
| 2103 | 1.8.10.1.3.3 | Programme SIT Participant Cutover Plan Assurance |  | 44d | 2025-06-06 | 2025-08-06 | 2102FS+10d |  |  | 2025-01-06 | 2025-03-06 | 44d |  |  | 31783d | 5d |  |  | SI Transition | SI Transition | 5.28 | Matthew Breen |  | Red | RED | 259.33 |  |  |  |  |
| 2104 | 1.8.10.1.4 | **M10/M11 Cutover Activities** |  | 730d | 2022-10-31 | 2025-08-15 |  |  |  | 2025-02-21 | 2025-03-14 | 15d |  |  | 32357d |  |  | -0 |  |  | 5.27 |  |  |  |  | -608.67 |  |  |  |  |
| 2105 | 1.8.10.1.4.1 | Production DIP Portal (DIP Deployment) | milestone | 0d | 2025-07-25 | 2025-07-25 | 1199FS+10d |  |  | 2025-02-21 | 2025-02-21 | 0d |  |  | 31786d | 8d |  |  | Elexon,DIP Manager | Elexon,DIP Manager, SI Transition | 5.27 | Matthew Breen |  | Red | RED | 308.71 |  |  |  |  |
| 2106 | 1.8.10.1.4.2 | Production Certificates (DIP Deployment) | milestone | 0d | 2025-07-25 | 2025-07-25 | 1199FS+10d |  |  | 2025-02-21 | 2025-02-21 | 0d |  |  | 31786d | 8d |  |  | Elexon,DIP Manager | Elexon,DIP Manager, SI Transition | 5.27 | Matthew Breen |  | Red | RED | 308.71 |  |  |  |  |
| 2107 | 1.8.10.1.4.3 | Completion of the MHHS Data Cleanse | milestone | 0d | 2025-08-13 | 2025-08-13 | 1317 |  |  | 2025-02-26 | 2025-02-26 | 0d |  |  | 32359d |  |  |  | PP,DCC,SI Transition | PP,DCC,SI Transition | 5.27 | Matthew Breen |  | Red | RED | 327.71 |  |  |  |  |
| 2108 | 1.8.10.1.4.4 | Market-wide Participant MHHS Supporting Functionality Ready - Confirmation from Code Bodies | milestone | 0d | 2025-03-03 | 2025-03-03 | 2001FS+501d |  |  | 2025-03-03 | 2025-03-03 | 0d |  |  | 32476d |  |  |  | Code Bodies | Code Bodies,SI Transition | 5.27 | Matthew Breen |  | Green | GREEN | 164.71 |  |  |  |  |
| 2109 | 1.8.10.1.4.5 | Market-wide Participant MHHS Supporting Functionality Ready | milestone | 0d | 2025-08-04 | 2025-08-04 | 1317FS-8d |  |  | 2025-03-07 | 2025-03-07 | 0d |  |  | 32367d |  |  |  | PP | PP,SI Transition | 5.27 | Matthew Breen |  | Red | RED | 318.33 |  |  |  |  |
| 2110 | 1.8.10.1.4.6 | Elexon Central Services Deployment | milestone | 0d | 2025-08-08 | 2025-08-08 | 2129 |  |  | 2025-03-07 | 2025-03-07 | 0d |  |  | 31778d | 0d |  |  | DIP Manager,Elexon | DIP Manager,Elexon,SI Transition | 5.27 | Matthew Breen |  | Red | RED | 322.71 |  |  |  |  |
| 2111 | 1.8.10.1.4.7 | Service Management Go-Live | milestone | 0d | 2025-08-08 | 2025-08-08 | 2129 |  |  | 2025-03-07 | 2025-03-07 | 0d |  |  | 31778d | 0d |  |  | Elexon | Elexon,SI Transition | 5.27 | Matthew Breen |  | Red | RED | 322.71 |  |  |  |  |
| 2112 | 1.8.10.1.4.8 | Data Transfer Service (DTS) New Functionality Deployment | milestone | 0d | 2025-08-08 | 2025-08-08 | 2129 |  |  | 2025-03-07 | 2025-03-07 | 0d |  |  | 31778d | 0d |  |  | Code Bodies,Electralink | Code Bodies,SI Transition | 5.27 | Matthew Breen |  | Red | RED | 322.71 |  |  |  |  |
| 2113 | 1.8.10.1.4.9 | Electricity Enquiry Service (EES) Deployment | milestone | 0d | 2025-08-08 | 2025-08-08 | 2129 |  |  | 2025-03-07 | 2025-03-07 | 0d |  |  | 31778d | 0d |  |  | Code Bodies | Code Bodies,SI Transition | 5.27 | Matthew Breen |  | Red | RED | 322.71 |  |  |  |  |
| 2114 | 1.8.10.1.4.10 | MPRS, UMSO Role, LDSO Role Operational | milestone | 0d | 2025-08-08 | 2025-08-08 | 2129 |  |  | 2025-03-07 | 2025-03-07 | 0d |  |  | 31778d | 0d |  |  | PP | SI Transition,PP | 5.27 | Matthew Breen |  | Red | RED | 322.71 |  |  |  |  |
| 2115 | 1.8.10.1.4.11 | Population of Domestic Premises Indicator | milestone | 0d | 2025-08-08 | 2025-08-08 | 2129 |  |  | 2025-03-07 | 2025-03-07 | 0d |  |  | 31778d | 0d |  |  | PP,DCC,SI Transition | PP,DCC,SI Transition | 5.27 | Matthew Breen |  | Red | RED | 322.71 |  |  |  |  |
| 2116 | 1.8.10.1.4.12 | Population of Market Segment | milestone | 0d | 2025-08-08 | 2025-08-08 | 2129 |  |  | 2025-03-07 | 2025-03-07 | 0d |  |  | 31778d | 0d |  |  | PP,SI Transition | PP,SI Transition | 5.27 | Matthew Breen |  | Red | RED | 322.71 |  |  |  |  |
| 2117 | 1.8.10.1.4.13 | Early Life Support Implemented | milestone | 0d | 2025-08-08 | 2025-08-08 | 2129 |  |  | 2025-03-07 | 2025-03-07 | 0d |  |  | 31781d | 3d |  |  | SI Transition,Elexon,Central Services | SI Transition,Elexon,Central Services | 5.27 | Matthew Breen |  | Red | RED | 322.71 |  |  |  |  |
| 2118 | 1.8.10.1.4.14 | MCC Tested and Ready to Operate | milestone | 0d | 2022-10-31 | 2022-10-31 |  |  |  | 2025-03-07 | 2025-03-07 | 0d |  |  | 32496d | 0d |  |  | SI Migration | SI Migration | 5.27 | Matthew Breen |  | Overdue Start | GREEN | -689.67 |  |  |  | 1/7: To link into migration/service activation |
| 2119 | 1.8.10.1.4.15 | MCC Operational | milestone | 0d | 2022-10-31 | 2022-10-31 | 2118 |  |  | 2025-03-07 | 2025-03-07 | 0d |  |  | 32506d | 728d |  |  | SI Migration | SI Migration | 5.27 | Matthew Breen |  | Overdue Start | GREEN | -689.67 |  |  |  | 1/7: To link into migration/service activation |
| 2120 | 1.8.4.1.4 | Central Systems live and Codes designated at 00:00 | milestone | 0d | 2025-08-11 | 2025-08-11 | 2110FS+1d, 2111FS+1d, 2112FS+1d, 2113FS+1d, 2114FS+1d, 2115FS+1d, 2116FS+1d, 2093FS+1d |  |  | 2025-03-07 | 2025-03-07 | 0d |  |  | 31778d | 0d |  |  | SI Transition | SI Transition | 5.30 | Matthew Breen |  | Red | RED | 325.71 | T3-MI-0034 | MCAG (Transition) |  |  |
| 2121 | 1.8.10.1.4.17 | SIT Participant Qualification - The final date by which participant qualification status can be confirmed for participants to be ready for the start of Migration at M11. | milestone | 0d | 2025-08-15 | 2025-08-15 | 1199FS+25d |  |  | 2025-03-14 | 2025-03-14 | 0d |  |  | 31789d | 11d |  |  | PP,Code Bodies,BSC PAB | SI Transition,PP,Code Bodies,BSC PAB | 5.27 | Matthew Breen |  | Red | RED | 329.71 |  |  |  |  |

Notes:
- 2090: 27/8/24: Milestone to to to MCAG on 24/9 be renamed because the m15/m16 cutover plan is being combined with the m15/16 cut over plan. Name will change from m16 methodology approved to M15 and M16 Cutover plan and M16 Success Criteria
- 2120: 6/8/24: Forecast date updated to correctly reflect the cutover plan which was approved in June. To go to August MCAG for date change approval / Guidance: 25/7/24: New Milestone approved at MCAG on 25/7/24. It was initially approved at MCAG on 4/6 but didn't follow the usual process so addded to July MCAG for noting

| ID | WBS | Task | Type | Duration | Start | Finish | Predecessors | Baseline start | Baseline finish | Baseline duration | Total slack | Free slack | Constraint | Baseline cost | Responsible | Involved | Task Status | Update Version | MHHS Resource Name | Sched Status | RAG | Milestone ID | Text29 |
| --- | --- | --- | --- | --- | --- | --- | --- | --- | --- | --- | --- | --- | --- | --- | --- | --- | --- | --- | --- | --- | --- | --- | --- |
| 2122 | 1.8.10.2 | **Cutover Governance M10** |  | 11d | 2025-07-30 | 2025-08-13 |  | 2025-02-26 | 2025-04-04 | 27d | 31782d |  |  |  | N/A | N/A | -595.67 | 5.27 | N/A |  |  |  |  |
| 2123 | 1.8.10.2.1 | Confirmation that Pre-migration Data Cleanse Activities have successfully taken place | milestone | 0d | 2025-07-30 | 2025-07-30 |  | 2025-02-26 | 2025-02-26 | 0d | 31784d | 6d | start no earlier than 2025-07-30 |  | PP | SI Transition,PP | 313.33 | 5.27 | Matthew Breen | Red | RED |  |  |
| 2124 | 1.8.10.2.2 | Confirmation of Qualification Status for SIT MVC | milestone | 0d | 2025-08-04 | 2025-08-04 | 1199FS+16d | 2025-03-03 | 2025-03-03 | 0d | 31778d | 0d |  |  | SIT MVC,Code Bodies | SI Transition,SIT MVC,Code Bodies | 318.71 | 5.27 | Matthew Breen | Red | RED |  |  |
| 2125 | 1.8.10.2.3 | Confirmation of Qualification Status for Non-SIT LDSOs | milestone | 0d | 2025-08-04 | 2025-08-04 | 2129FS-5d | 2025-03-03 | 2025-03-03 | 0d | 32367d |  |  |  | PP,Code Bodies | SI Transition,PP,Code Bodies | 318.33 | 5.27 | Matthew Breen | Red | RED |  |  |
| 2126 | 1.8.10.2.4 | Confirmation of Qualification Status of at least one Supplier and their contracted Agents | milestone | 0d | 2025-08-04 | 2025-08-04 | 2124 | 2025-03-03 | 2025-03-03 | 0d | 31778d | 0d |  |  | S&A Qualification | SI Transition,S&A Qualification | 318.71 | 5.27 | Matthew Breen | Red | RED |  |  |
| 2127 | 1.8.10.2.5 | Declaration from all Central Services and LDSOs that they are in a position to move forwards | milestone | 0d | 2025-08-04 | 2025-08-04 | 2129FS-5d | 2025-03-03 | 2025-03-03 | 0d | 32367d |  |  |  | DIP Manager,Elexon,PP,Code Bodies | SI Transition,DIP Manager,Elexon,PP,Code Bodies | 318.33 | 5.27 | Matthew Breen | Red | RED |  |  |
| 2128 | 1.8.10.2.6 | TORWG (Recommendation from TORWG that the Programme should enter M10) | milestone | 0d | 2025-08-06 | 2025-08-06 | 2123, 2124FS+2d, 2126FS+2d, 2105, 2106, 2211 | 2025-03-05 | 2025-03-05 | 0d | 31778d | 0d |  |  | SI Transition | SI Transition | 320.71 | 5.27 | Matthew Breen | Red | RED |  |  |
| 2129 | 1.8.4.1.4 | MCAG (Confirm that the Programme can Enter M10) | milestone | 0d | 2025-08-08 | 2025-08-08 | 2128FS+2d, 2217 | 2025-03-07 | 2025-03-07 | 0d | 31778d | 0d |  |  | SI Migration | SI Transition,SI Migration | 322.71 | 5.30 | Matthew Breen | Red | RED | T3-MI-0035 | MCAG (Transition) |
| 2130 | 1.8.10.2.8 | Self-Declaration from all Central Services and LDSOs that Cutover activities have been successfully carried out | milestone | 0d | 2025-08-11 | 2025-08-11 | 2129FS+1d | 2025-03-10 | 2025-03-10 | 0d | 31778d | 0d |  |  | PP,DCC,Code Bodies | SI Transition,PP,DCC,Code Bodies | 325.71 | 5.27 | Matthew Breen | Red | RED |  |  |
| 2131 | 1.8.10.2.9 | Confirmation that DIP and ECS have been deployed, Service management is active, ISD has been populated | milestone | 0d | 2025-08-11 | 2025-08-11 | 2129FS+1d | 2025-03-10 | 2025-03-10 | 0d | 31778d | 0d |  |  | Elexon,DIP Manager | SI Transition,Elexon,DIP Manager | 325.71 | 5.27 | Matthew Breen | Red | RED |  |  |
| 2132 | 1.8.10.2.10 | Self-Declarations against all M10 Data Cleanse Activities | milestone | 0d | 2025-08-11 | 2025-08-11 | 2129FS+1d | 2025-03-10 | 2025-03-10 | 0d | 31778d | 0d |  |  | PP | SI Transition,PP | 325.71 | 5.27 | Matthew Breen | Red | RED |  |  |
| 2133 | 1.8.10.2.11 | IF-047 has been sent | milestone | 0d | 2025-08-11 | 2025-08-11 | 2129FS+1d | 2025-03-10 | 2025-03-10 | 0d | 31778d | 0d |  |  | ECS | SI Transition,ECS | 325.71 | 5.27 | Matthew Breen | Red | RED |  |  |
| 2134 | 1.8.10.2.12 | Recommendation from TORWG that PSG should approve M10 | milestone | 0d | 2025-08-12 | 2025-08-12 | 2130FS+1d, 2131FS+1d, 2132FS+1d, 2133FS+1d, 2215 | 2025-03-11 | 2025-03-11 | 0d | 31778d | 0d |  |  | SI Transition | SI Transition | 326.71 | 5.27 | Matthew Breen | Red | RED |  |  |
| 2135 | 1.8.10.2.13 | PSG (OFGEM and PSG to Approve That Conditions of M10 and M13 Have Been Met) | milestone | 0d | 2025-08-13 | 2025-08-13 | 2134FS+1d | 2025-03-12 | 2025-03-12 | 0d | 31778d | 0d |  |  | SI Transition,Ofgem | SI Transition,Ofgem | 327.71 | 5.27 | Matthew Breen | Red | RED |  |  |
| 2136 | 1.8.10.3 | **Cutover Governance M11** |  | 19d | 2025-08-15 | 2025-09-10 |  |  |  |  | 31778d |  |  |  |  |  | -687.67 |  |  | Overdue Start | RED |  |  |
| 2137 | 1.8.10.3.1 | Confirmation of Qualified Parties from Code Bodies |  | 11d | 2025-08-15 | 2025-08-29 | 2135FS+1d | 2025-03-14 | 2025-03-28 | 11d | 31778d | 0d |  |  | Code Bodies,SIT Participants | SI Transition,Code Bodies,SIT Participants | 329.33 | 5.27 | Matthew Breen | Red | RED |  |  |
| 2138 | 1.8.10.3.2 | Self-Declaration that MHHS Functionality will be deployed to Production by Qualified parties | milestone | 0d | 2025-08-29 | 2025-08-29 | 2135FS+12d | 2025-03-28 | 2025-03-28 | 0d | 31778d | 0d |  |  | PP | SI Transition,PP | 343.71 | 5.27 | Matthew Breen | Red | RED |  |  |
| 2139 | 1.8.10.3.3 | Production Service Activation Activities have taken place | milestone | 0d | 2025-08-29 | 2025-08-29 | 2135FS+12d | 2025-03-28 | 2025-03-28 | 0d | 31778d | 0d |  |  | PP | SI Transition,PP | 343.71 | 5.27 | Matthew Breen | Red | RED |  |  |
| 2140 | 1.8.10.3.4 | TORWG (Confirmation of Qualified Parties from TORWG) | milestone | 0d | 2025-09-01 | 2025-09-01 | 2137FS+1d, 2138FS+1d, 2139FS+1d, 2121, 2212, 2216 | 2025-03-31 | 2025-03-31 | 0d | 31778d | 0d |  |  | SI Transition | SI Transition | 346.71 | 5.27 | Matthew Breen | Red | RED |  |  |
| 2141 | 1.8.10.3.5 | MCAG (Provide recommendation to PSG on M11 decision) | milestone | 0d | 2025-09-05 | 2025-09-05 | 2140FS+4d | 2025-04-02 | 2025-04-02 | 0d | 31778d | 0d |  |  | SI Migration | SI Transition,SI Migration | 350.71 | 5.30 | Matthew Breen | Red | RED | T3-MI-0036 | MCAG (Transition) |
| 2142 | 1.8.10.3.6 | PSG (OFGEM and PSG Decision to Confirm M11 and M12) | milestone | 0d | 2025-09-10 | 2025-09-10 | 2141FS+3d | 2025-04-04 | 2025-04-04 | 0d | 31778d | 0d |  |  | SI Transition | SI Transition | 355.71 | 5.27 | Matthew Breen | Red | RED |  |  |
| 2143 | 1.8.11 | **UMS / Advanced Migration** |  | 392d | 2025-09-11 | 2027-03-12 |  | 2025-04-04 | 2026-10-02 | 391d | 31783d |  |  | -0 | N/A | N/A | -555.67 | 5.24 | N/A |  |  |  |  |
| 2144 | 1.8.11.1 | SIT MVC UMS / Advanced Migration |  | 391d | 2025-09-11 | 2027-03-11 | 2217, 2173 | 2025-04-04 | 2026-10-02 | 391d | 31784d | 0d |  |  |  |  | 356.33 | 5.24 |  | Red | RED |  |  |
| 2145 | 1.8.11.2 | SIT Non-MVC UMS / Advanced Migration |  | 326d | 2025-11-27 | 2027-02-25 | 2238 | 2025-07-04 | 2026-10-02 | 326d | 31794d | 12d |  |  |  |  | 433.33 | 5.24 |  | Red | RED |  |  |
| 2146 | 1.8.11.3 | Wave 1 UMS / Advanced Migration |  | 251d | 2026-03-27 | 2027-03-12 | 2254 | 2025-10-03 | 2026-10-02 | 261d | 31783d | 1d |  |  |  |  | 553.33 | 5.24 |  | Red | RED |  |  |
| 2147 | 1.8.11.4 | Wave 2 UMS / Advanced Migration |  | 217d | 2026-05-14 | 2027-03-12 | 2278 | 2025-12-05 | 2026-10-02 | 216d | 31783d | 1d |  |  |  |  | 601.33 | 5.24 |  | Red | RED |  |  |
| 2148 | 1.8.11.5 | Wave 3 UMS / Advanced Migration |  | 182d | 2026-07-02 | 2027-03-12 | 2302 | 2026-01-23 | 2026-10-02 | 181d | 31783d | 1d |  |  |  |  | 650.33 | 5.24 |  | Red | RED |  |  |
| 2149 | 1.8.11.6 | Wave 4 UMS / Advanced Migration |  | 136d | 2026-09-04 | 2027-03-12 | 2326 | 2026-04-03 | 2026-10-02 | 131d | 31783d | 1d |  |  |  |  | 714.33 | 5.24 |  | Red | RED |  |  |

Notes:
- 2129: 18/6: New T3 milestone agreed at MCAG on 4/6/24 / Guidance: 25/7/24: New Milestone approved at MCAG on 25/7/24. It was initially approved at MCAG on 4/6 but didn't follow the usual process so addded to July MCAG for noting
- 2139: Guidance: 12/8/24: Think this is covered in Service activation prep section below
- 2141: 18/6: New T3 milestone agreed at MCAG on 4/6/24 / Guidance: 25/7/24: New Milestone approved at MCAG on 25/7/24. It was initially approved at MCAG on 4/6 but didn't follow the usual process so addded to July MCAG for noting
- 2146: Guidance: 12/8/24: Made start no earlier, because shorter service actiobal was allowing this to start earlier than the date that had been set

| ID | WBS | Task | Type | Duration | Start | Finish | Predecessors | Complete | Remaining | Baseline start | Baseline finish | Baseline duration | Baseline 1 start | Baseline 1 finish | Total slack | Free slack | Constraint | Baseline cost | Responsible | Involved | Task Status | Update Version | MHHS Resource Name | Sched Status | RAG | MHHS Programme Phase | Milestone ID | Text29 | Tier | Text3 |
| --- | --- | --- | --- | --- | --- | --- | --- | --- | --- | --- | --- | --- | --- | --- | --- | --- | --- | --- | --- | --- | --- | --- | --- | --- | --- | --- | --- | --- | --- | --- |
| 2150 | 1.8.12 | **Smart / Non-Smart Migration** |  | 392d | 2025-09-11 | 2027-03-12 |  |  |  | 2025-04-04 | 2026-10-02 | 391d |  |  | 31783d |  |  | -0 | N/A | N/A | -555.67 | 5.24 | N/A |  |  |  |  |  |  |  |
| 2151 | 1.8.12.1 | SIT MVC Smart / Non-Smart Migration |  | 391d | 2025-09-11 | 2027-03-11 | 2217, 2173 |  |  | 2025-04-04 | 2026-10-02 | 391d |  |  | 31784d | 0d |  |  |  |  | 356.33 | 5.24 |  | Red | RED |  |  |  |  |  |
| 2152 | 1.8.12.2 | SIT Non-MVC Smart / Non-Smart Migration |  | 326d | 2025-11-27 | 2027-02-25 | 2238 |  |  | 2025-07-04 | 2026-10-02 | 326d |  |  | 31794d | 12d |  |  |  |  | 433.33 | 5.24 |  | Red | RED |  |  |  |  |  |
| 2153 | 1.8.12.3 | Wave 1 Smart / Non-Smart Migration |  | 251d | 2026-03-27 | 2027-03-12 | 2254 |  |  | 2025-10-03 | 2026-10-02 | 261d |  |  | 31783d | 1d | start no earlier than 2025-10-03 |  |  |  | 553.33 | 5.24 |  | Red | RED |  |  |  |  |  |
| 2154 | 1.8.12.4 | Wave 2 Smart / Non-Smart Migration |  | 217d | 2026-05-14 | 2027-03-12 | 2278 |  |  | 2025-12-05 | 2026-10-02 | 216d |  |  | 31783d | 1d |  |  |  |  | 601.33 | 5.24 |  | Red | RED |  |  |  |  |  |
| 2155 | 1.8.12.5 | Wave 3 Smart / Non-Smart Migration |  | 182d | 2026-07-02 | 2027-03-12 | 2302 |  |  | 2026-01-23 | 2026-10-02 | 181d |  |  | 31783d | 1d |  |  |  |  | 650.33 | 5.24 |  | Red | RED |  |  |  |  |  |
| 2156 | 1.8.12.6 | Wave 4 Smart / Non-Smart Migration |  | 136d | 2026-09-04 | 2027-03-12 | 2326 |  |  | 2026-04-03 | 2026-10-02 | 131d |  |  | 31782d | 0d |  |  |  |  | 714.33 | 5.24 |  | Red | RED |  |  |  |  |  |
| 2157 | 1.8.13 | **External Programme Dependency Management** |  | 713d | 2022-10-31 A | 2025-07-23 |  | 66% | 244.19d | 2022-10-31 | 2025-12-30 | 827d | 2022-10-31 | 2025-07-01 | 32374d |  |  | -0 | N/A | N/A |  | 5.0 | N/A |  |  | Migration |  |  |  |  |
| 2158 | 1.8.13.1 | **BSC Mod P432 & REC CP R0015** |  | 392d | 2022-10-31 A | 2024-04-30 A |  | 100% |  | 2022-10-31 | 2025-12-30 | 827d | 2022-10-31 | 2025-07-01 |  |  |  | -0 | N/A | N/A |  | 5.0 | N/A |  |  | Migration |  |  |  |  |
| 2159 | 1.8.13.1.1 | MHHSP engagement with BSCCo until Ofgem decision |  | 316d | 2022-10-31 A | 2024-01-15 A |  | 100% |  | 2022-10-31 | 2024-05-10 | 400d | 2022-10-31 | 2022-12-30 |  |  |  |  | CPT,SRO Function | Code Bodies |  | 5.0 | MHHS Programme | Complete | COMPLETE | Migration |  |  |  |  |
| 2160 | 1.8.13.1.2 | Monitor progress and await implementation date |  | 76d | 2024-01-16 A | 2024-04-30 A | 2159 | 100% |  | 2023-07-03 | 2025-12-30 | 652d | 2023-01-02 | 2025-07-01 |  |  |  |  | CPT,SRO Function | Code Bodies |  | 5.0 | MHHS Programme | Complete | COMPLETE | Migration |  |  |  |  |
| 2161 | 1.8.13.2 | **BSC Mod P434** |  | 713d | 2022-10-31 A | 2025-07-23 |  | 57% | 310d | 2022-10-31 | 2025-07-23 | 713d | 2022-10-31 | 2025-07-01 | 32374d |  |  |  | N/A | N/A |  | 5.0 | N/A |  |  | Migration |  |  |  |  |
| 2162 | 1.8.13.2.1 | MHHSP engagement with BSCCo until Ofgem decision |  | 61d | 2022-10-31 A | 2023-01-23 A |  | 100% |  | 2022-10-31 | 2023-01-23 | 61d | 2022-10-31 | 2022-12-30 |  |  |  |  | CPT,SRO Function | Code Bodies |  | 5.0 | MHHS Programme | Complete | COMPLETE | Migration |  |  |  |  |
| 2163 | 1.8.13.2.2 | Monitor progress and await implementation date |  | 652d | 2023-01-24 A | 2025-07-23 | 2162 | 52% | 310d | 2023-01-24 | 2025-07-23 | 652d | 2023-01-02 | 2025-07-01 | 32374d |  |  |  | CPT,SRO Function | Code Bodies |  | 5.0 | MHHS Programme | Green | GREEN | Migration |  |  |  |  |
| 2164 | 1.8.13.3 | **Elexon System Capacity Upgrade** |  | 697d | 2022-10-31 A | 2025-07-01 |  | 58% | 294d | 2022-10-31 | 2025-07-01 | 697d | 2022-10-31 | 2025-07-01 | 32390d |  |  |  | N/A | N/A |  | 5.0 | N/A |  |  | Migration |  |  |  |  |
| 2165 | 1.8.13.3.1 | Monitor progress to implementation |  | 697d | 2022-10-31 A | 2025-07-01 |  | 58% | 294d | 2022-10-31 | 2025-07-01 | 697d | 2022-10-31 | 2025-07-01 | 32390d | 0d |  |  | SI Migration | PP |  | 5.0 | MHHS Programme | Green | GREEN | Migration |  |  |  |  |
| 2166 | 1.8.13.3.2 | Implementation date | milestone | 0d | 2025-07-01 | 2025-07-01 | 2165 |  |  | 2025-07-01 | 2025-07-01 | 0d | 2025-07-01 | 2025-07-01 | 32390d |  |  |  | PP | SI Migration | 284.71 | 5.0 | MHHS Programme | Green | GREEN | Migration |  |  |  |  |
| 2167 | 1.8.13.4 | **DCC System Capacity Upgrade** |  | 25d | 2025-06-16 | 2025-07-18 |  |  |  | 2025-01-13 | 2025-02-14 | 25d | 2025-01-13 | 2025-02-14 | 32377d |  |  |  | N/A | N/A |  | 5.0 | N/A |  |  | Migration |  |  |  |  |
| 2168 | 1.8.13.4.1 | Assurance of DCC capacity upgrade to ensure suitability to support migration |  | 20d | 2025-06-16 | 2025-07-11 | 1317FF-23d |  |  | 2025-01-13 | 2025-02-07 | 20d | 2025-01-13 | 2025-02-07 | 32377d | 0d |  |  | SI Migration | PP | 269.33 | 5.0 | MHHS Programme | Red | RED | Migration |  |  |  |  |
| 2169 | 1.8.13.4.2 | DCC Capacity Upgrade Operational | milestone | 0d | 2025-07-18 | 2025-07-18 | 2168FS+5d |  |  | 2025-02-14 | 2025-02-14 | 0d | 2025-02-14 | 2025-02-14 | 32377d |  |  |  | PP | SI Migration,IPA | 301.71 | 5.0 | MHHS Programme | Red | RED | Migration | T2-MI-0350 | MCAG | T2 |  |
| 2170 | 1.8.14 | **Migration - Tier 1 Milestones** |  | 479d | 2025-08-13 | 2027-06-15 |  |  |  | 2025-03-07 | 2027-01-05 | 477d | 2025-03-07 | 2027-01-05 | 31798d |  |  |  | N/A | N/A |  | 5.0 | N/A |  |  | Migration |  |  |  |  |
| 2171 | 1.8.14.1 | Load Shaping Service switched on (M13) | milestone | 0d | 2025-08-13 | 2025-08-13 | 1317 |  |  | 2025-03-07 | 2025-03-07 | 0d | 2025-03-07 | 2025-03-07 | 31798d | 0d |  |  | CPT | CPT | 327.71 | 5.0 | CPT | Red | RED | Migration | T1-MI-2000 | PSG | T1 | Load Shaping Service switched on |
| 2172 | 1.8.14.2 | Load Shaping Service switched on (M13*) - Late Exit | milestone | 0d | 2025-11-12 | 2025-11-12 | 2171FS+65d |  |  | 2025-06-06 | 2025-06-06 | 0d | 2025-06-06 | 2025-06-06 | 32294d |  |  |  | CPT | CPT | 418.71 | 5.0 | CPT | Red | RED | Migration | T2-MI-2500 | PSG | T1 | Load Shaping Service switched on |
| 2173 | 1.8.14.3 | Start of 18-month migration for UMS / Advanced (M11) | milestone | 0d | 2025-09-10 | 2025-09-10 | 2171, 2141, 2142, 2217, 1317FS+20d |  |  | 2025-04-04 | 2025-04-04 | 0d | 2025-04-04 | 2025-04-04 | 31778d | 0d |  |  | CPT | CPT | 355.71 | 5.0 | CPT | Red | RED | Migration | T1-MI-3000 | PSG | T1 | Start of 1 year migration for UMS / Advanced |
| 2174 | 1.8.14.4 | Start of 18-month migration for UMS / Advanced (M11*) - Late Exit | milestone | 0d | 2025-12-10 | 2025-12-10 | 2173FS+65d |  |  | 2025-07-04 | 2025-07-04 | 0d | 2025-07-04 | 2025-07-04 | 32274d |  |  |  | CPT | CPT | 446.71 | 5.0 | CPT | Red | RED | Migration | T2-MI-3500 | PSG | T1 | Start of 1 year migration for UMS / Advanced |
| 2175 | 1.8.14.5 | Start of 18-month migration for Smart / Non-smart (M12) | milestone | 0d | 2025-09-10 | 2025-09-10 | 2171, 1317FS+20d |  |  | 2025-04-04 | 2025-04-04 | 0d | 2025-04-04 | 2025-04-04 | 32274d | 0d |  |  | CPT | CPT | 355.71 | 5.0 | CPT | Red | RED | Migration | T1-MI-4000 | PSG | T1 | Start of 1 year migration for Smart / Non-smart |
| 2176 | 1.8.14.6 | Start of 18-month migration for Smart / Non-smart (M12*) - Late Exit | milestone | 0d | 2025-12-10 | 2025-12-10 | 2175FS+65d |  |  | 2025-07-04 | 2025-07-04 | 0d | 2025-07-04 | 2025-07-04 | 32274d |  |  |  | CPT | CPT | 446.71 | 5.0 | CPT | Red | RED | Migration | T2-MI-4500 | PSG | T1 | Start of 1 year migration for Smart / Non-smart |
| 2177 | 1.8.14.7 | Full transition complete (M15) | milestone | 0d | 2027-03-15 | 2027-03-15 | 2144, 2145, 2146, 2147, 2148, 2149, 2151, 2152, 2153, 2154, 2155, 2156FS+1d |  |  | 2026-10-05 | 2026-10-05 | 0d | 2026-10-05 | 2026-10-05 | 31782d | 0d |  |  | CPT | CPT | 906.71 | 5.0 | CPT | Red | RED | Migration | T1-MI-6000 | PSG | T1 | Full transition complete |
| 2178 | 1.8.14.8 | Full transition complete (M15*) - Late Exit | milestone | 0d | 2027-06-15 | 2027-06-15 | 2177FS+66d |  |  | 2027-01-05 | 2027-01-05 | 0d | 2027-01-05 | 2027-01-05 | 31880d |  |  |  | CPT | CPT | 998.71 | 5.0 | CPT | Red | RED | Migration | T2-MI-6500 | PSG | T1 | Full transition complete |

Notes:
- 2153: Guidance: 12/8/24: Made start no earlier, because shorter service actiobal was allowing this to start earlier than the date that had been set

| ID | WBS | Task | Type | Duration | Start | Finish | Predecessors | Complete | Remaining | Baseline start | Baseline finish | Baseline duration | Baseline 1 start | Baseline 1 finish | Total slack | Free slack | Constraint | Baseline cost | Responsible | Involved | MHHS Resource Name | MHHS Programme Phase | Update Version | Sched Status | RAG | Milestone ID | Text29 | Tier | Task Status | Notes (2) |
| --- | --- | --- | --- | --- | --- | --- | --- | --- | --- | --- | --- | --- | --- | --- | --- | --- | --- | --- | --- | --- | --- | --- | --- | --- | --- | --- | --- | --- | --- | --- |
| 2179 | 1.9 | **BUSINESS & OPERATIONAL READINESS** |  | 33087d? | 2022-10-31 A | 2149-08-26 |  | 6% | 31233.9d? | 2023-09-19 | 2027-05-28 | 964d | 2023-03-01 | 2026-12-07 | 0d |  |  | -0 | N/A | N/A | N/A | Business & Operational Readiness |  |  |  |  |  |  |  |  |
| 2180 | 1.9.1 | **Service Management** |  | 953d | 2023-09-19 A | 2027-05-13 |  | 26% | 706.12d | 2023-09-19 | 2026-12-07 | 840d | 2023-03-01 | 2026-12-07 | 31903d |  |  | -0 | N/A | N/A | N/A | Business & Operational Readiness | 5.0 |  |  |  |  |  |  |  |
| 2181 | 1.9.1.1 | **Service Management Strategy** |  | 116d | 2023-09-19 A | 2024-02-27 A |  | 100% |  | 2023-09-19 | 2024-02-27 | 116d | 2023-03-01 | 2023-05-31 |  |  |  | -0 | N/A | N/A | N/A | Business & Operational Readiness | 5.0 |  |  |  |  |  |  |  |
| 2182 | 1.9.1.1.1 | Develop document with relevant participants (incl. review of the design baseline to ensure service management arrangements are in place across the solution architecture) |  | 84d | 2023-09-19 A | 2024-01-12 A |  | 100% |  | 2023-09-19 | 2024-01-12 | 84d | 2023-03-01 | 2023-04-28 |  |  | start no earlier than 2023-09-19 |  | SI Design |  | Matthew Breen | Business & Operational Readiness | 5.0 | Complete | COMPLETE |  |  |  |  |  |
| 2183 | 1.9.1.1.2 | Artefact review (via relevant Advisory Group) and updates |  | 31d | 2024-01-15 A | 2024-02-26 A | 2182 | 100% |  | 2024-01-15 | 2024-02-26 | 31d | 2023-05-01 | 2023-05-24 |  |  |  |  | PP | SI Design,IPA | Matthew Breen | Business & Operational Readiness | 5.0 | Complete | COMPLETE |  |  |  |  |  |
| 2184 | 1.9.1.1.3 | Service Management Strategy approved | milestone | 0d | 2024-02-27 A | 2024-02-27 A | 2183FS+1d | 100% |  | 2024-02-27 | 2024-02-27 | 0d | 2023-05-31 | 2023-05-31 |  |  |  |  | SI Design | PP | Matthew Breen | Business & Operational Readiness | 5.16 | Complete | COMPLETE | T3-BC-0010 | MCAG | T3 |  |  |
| 2185 | 1.9.1.2 | **Early Life Support Model** |  | 110d | 2024-02-28 A | 2024-07-30 |  | 82% | 20.23d | 2024-02-28 | 2024-07-30 | 110d |  |  | 32630d |  |  | -0 | N/A | N/A | N/A | Business & Operational Readiness | 5.16 |  |  |  |  |  | -441.67 |  |
| 2186 | 1.9.1.2.1 | Draft Document |  | 74d | 2024-02-28 A | 2024-06-10 | 2184 | 96% | 3d | 2024-02-28 | 2024-06-10 | 74d |  |  | 32640d | 0d |  |  | SI Transition | SI Transition,PP,SRO | Matthew Breen | Business & Operational Readiness | 5.24 | Overdue | RED |  |  |  |  |  |
| 2187 | 1.9.1.2.2 | Share document with SRO |  | 1d | 2024-06-11 | 2024-06-11 | 2186 |  |  | 2024-06-11 | 2024-06-11 | 1d |  |  | 32640d | 0d |  |  | SI Transition | SI Transition,PP,SRO | Matthew Breen | Business & Operational Readiness | 5.24 | Overdue Start | RED |  |  |  | -100.67 |  |
| 2188 | 1.9.1.2.3 | Industry Consultation |  | 11d | 2024-06-18 | 2024-07-02 | 2187FS+4d |  |  | 2024-06-18 | 2024-07-02 | 11d |  |  | 32640d | 0d |  |  | SI Transition | SI Transition,PP,SRO | Matthew Breen | Business & Operational Readiness | 5.24 | Overdue Start | RED |  |  |  | -93.67 |  |
| 2189 | 1.9.1.2.4 | Assurance Meeting |  | 1d | 2024-07-16 | 2024-07-16 | 2188FS+9d |  |  | 2024-07-16 | 2024-07-16 | 1d |  |  | 32640d |  |  |  | SI Transition | SI Transition,PP,SRO | Matthew Breen | Business & Operational Readiness | 5.24 | Overdue Start | RED |  |  |  | -65.67 |  |
| 2190 | 1.9.1.2.5 | MCAG Approval of Early Life Support Model | milestone | 0d | 2024-07-30 A | 2024-07-30 A | 2189FS+10d | 100% |  | 2024-07-30 | 2024-07-30 | 0d |  |  |  |  |  |  | SI Transition | PP,SRO,SI Transition | Matthew Breen | Business & Operational Readiness | 5.24 | Complete | COMPLETE | T3-MI-0033 | MCAG (Transition) |  |  | been held with the Code Bodies at the end of August |
| 2191 | 1.9.1.3 | **Service Management Arrangements Implementation** |  | 456d | 2025-08-14 | 2027-05-13 |  |  |  | 2025-03-13 | 2026-12-07 | 453d | 2025-03-10 | 2026-12-07 | 31903d |  |  | -0 | N/A | N/A | N/A | Business & Operational Readiness | 5.0 |  |  |  |  |  |  |  |
| 2192 | 1.9.1.3.1 | Hypercare post M10 |  | 80d | 2025-08-14 | 2025-12-03 | 1317 |  |  | 2025-03-13 | 2025-07-02 | 80d | 2025-03-10 | 2025-06-27 | 32279d |  |  |  | SI Design | PP | Claire Silk | Business & Operational Readiness | 5.0 | Red | RED |  |  |  | 328.33 |  |
| 2193 | 1.9.1.3.2 | Monitor Elexon implementation of Service Management arrangements |  | 436d | 2025-09-11 | 2027-05-13 | 2144SS, 2151SS |  |  | 2025-04-07 | 2026-12-07 | 436d | 2025-04-07 | 2026-12-07 | 31903d |  |  |  | PP | SI Design | Claire Silk | Business & Operational Readiness | 5.0 | Red | RED |  |  |  | 356.33 |  |
| 2194 | 1.9.2 | **Service Activation** |  | 1004d? | 2022-10-31 | 2026-09-03 |  |  |  | 2025-02-24 | 2026-04-02 | 289d |  |  | 32083d |  |  | -0 | N/A | N/A | N/A |  | 5.24 |  |  |  |  |  | -555.67 |  |
| 2195 | 1.9.2.1 | **SIT MVC** |  | 726d? | 2022-10-31 | 2025-08-11 |  |  |  |  |  |  |  |  | 32361d |  |  |  |  |  |  |  | 5.31 | Overdue Start | RED |  |  |  | -650.67 |  |
| 2196 | 1.9.2.1.1 | **SIT MVC Service Activation Preparation Tasks** |  | 20d | 2025-02-03 | 2025-02-28 |  |  |  |  |  |  |  |  | 31907d |  |  |  |  |  |  |  | 5.31 |  |  |  |  |  |  |  |
| 2197 | 1.9.2.1.1.1 | Identify operational resources |  | 5d | 2025-02-03 | 2025-02-07 |  |  |  |  |  |  |  |  | 32492d |  | finish no earlier than 2025-02-07 |  |  |  |  |  | 5.31 | No BL | GREEN |  |  |  | 136.33 |  |
| 2198 | 1.9.2.1.1.2 | Define and approve operational support model |  | 5d | 2025-02-10 | 2025-02-14 |  |  |  |  |  |  |  |  | 32487d |  | finish no earlier than 2025-02-14 |  |  |  |  |  | 5.31 | No BL | GREEN |  |  |  | 143.33 |  |
| 2199 | 1.9.2.1.1.3 | Confirm SA Training completed |  | 10d | 2025-02-10 | 2025-02-21 |  |  |  |  |  |  |  |  | 32482d |  | finish no earlier than 2025-02-21 |  |  |  |  |  | 5.31 | No BL | GREEN |  |  |  | 143.33 |  |
| 2200 | 1.9.2.1.1.4 | Participant Engagement / Communications |  | 15d | 2025-02-10 | 2025-02-28 |  |  |  |  |  |  |  |  | 32477d |  | finish no earlier than 2025-02-28 |  |  |  |  |  | 5.31 | No BL | GREEN |  |  |  | 143.33 |  |
| 2201 | 1.9.2.1.1.5 | Internal Communications |  | 15d | 2025-02-10 | 2025-02-28 |  |  |  |  |  |  |  |  | 32477d |  | finish no earlier than 2025-02-28 |  |  |  |  |  | 5.31 | No BL | GREEN |  |  |  | 143.33 |  |
| 2202 | 1.9.2.1.1.6 | Validate User Access |  | 5d | 2025-02-17 | 2025-02-21 |  |  |  |  |  |  |  |  | 32482d |  | finish no earlier than 2025-02-21 |  |  |  |  |  | 5.31 | No BL | GREEN |  |  |  | 150.33 |  |
| 2203 | 1.9.2.1.1.7 | Target Systems and Environments Ready |  | 3d | 2025-02-20 | 2025-02-24 |  |  |  |  |  |  |  |  | 32481d |  | finish no earlier than 2025-02-24 |  | HELIX |  |  |  | 5.31 | No BL | GREEN |  |  |  | 153.33 |  |
| 2204 | 1.9.2.1.1.8 | Provide opeartional resources with LWIs |  | 5d | 2025-02-17 | 2025-02-21 |  |  |  |  |  |  |  |  | 32482d |  | finish no earlier than 2025-02-21 |  |  |  |  |  | 5.31 | No BL | GREEN |  |  |  | 150.33 |  |
| 2205 | 1.9.2.1.1.9 | Business Readiness Governance Approval |  | 3d | 2025-02-17 | 2025-02-19 |  |  |  |  |  |  |  |  | 32484d |  | finish no earlier than 2025-02-19 |  |  |  |  |  | 5.31 | No BL | GREEN |  |  |  | 150.33 |  |
| 2206 | 1.9.2.1.1.10 | SIT MVC Service Activation Preparation Tasks Complete | milestone | 0d | 2025-02-28 | 2025-02-28 |  |  |  |  |  |  |  |  | 31887d | 109d | finish no earlier than 2025-02-28 |  |  |  |  |  | 5.31 | No BL | GREEN |  |  |  | 161.71 |  |
| 2207 | 1.9.2.1.2 | MHHSP Confirms SIT MVC PPs MHHS Enabled |  | 1d | 2022-10-31 | 2022-10-31 | 2118 |  |  |  |  |  |  |  | 32496d | 718d |  |  |  |  |  |  | 5.28 | Overdue Start | RED |  |  |  | -689.67 |  |

Notes:
- 2184: 17/1 - Baseline change approved at TMAG to change date from 21/2/24 to 27/2/24. Changed because MCAG has been scheduled for 27/2/24. Approved at TMAG on 7/1/24
- 2190: Date has been missed because of late input from Code-Bodies. This input has now been received and we are looking to finalise the document and schedule the industry consultation and then confirm an updated baseline date. Baseline date to be approved at September MCAG.
- 2192: 10/5: Detail to be added when available
- 2193: 10/5: Detail to be added when available
- 2194: 8/7/24: Likely Servce action will be on a pp by pp basis
- 2207: 8/7/24: For M11 need mcc enabled - need confirmation suppliers agree to being mhhs enabled

| ID | WBS | Task | Type | Duration | Start | Finish | Predecessors | Total slack | Free slack | Constraint | Update Version | Task Status | Sched Status | RAG | Involved |
| --- | --- | --- | --- | --- | --- | --- | --- | --- | --- | --- | --- | --- | --- | --- | --- |
| 2208 | 1.9.2.1.3 | **SIT MVC Service Activation Implementation** |  | 7d? | 2025-08-01 | 2025-08-11 |  | 31778d |  |  | 5.31 |  |  |  |  |
| 2209 | 1.9.2.1.3.1 | Add EDF to DIP |  | 1d | 2025-08-01 | 2025-08-01 | 1511SS, 2207, 2206 | 31778d | 0d |  | 5.31 | 315.33 | No BL | GREEN |  |
| 2210 | 1.9.2.1.3.2 | DIP Promoted to Production |  | 1d? | 2025-08-04 | 2025-08-04 | 2209 | 31778d | 0d |  |  | 318.33 | No BL | GREEN |  |
| 2211 | 1.9.2.1.3.3 | SIT LDSOs Create Certificates and Test Connectivity |  | 1d? | 2025-08-05 | 2025-08-05 | 2210 | 31779d | 1d |  |  | 319.33 | No BL | GREEN |  |
| 2212 | 1.9.2.1.3.4 | SIT MVC S&As Create Certificates and Test Connectivity |  | 1d? | 2025-08-05 | 2025-08-05 | 2210 | 31797d | 19d |  |  | 319.33 | No BL | GREEN |  |
| 2213 | 1.9.2.1.3.5 | Create M16 in Customer Solution |  | 2d | 2025-08-05 | 2025-08-06 | 2210 | 31778d | 0d | finish no earlier than 2025-03-07 | 5.31 | 319.33 | No BL | GREEN |  |
| 2214 | 1.9.2.1.3.6 | Publish ISD |  | 2d | 2025-08-07 | 2025-08-08 | 2213 | 31778d | 0d | finish no earlier than 2025-03-07 | 5.31 | 321.33 | No BL | GREEN |  |
| 2215 | 1.9.2.1.3.7 | SIT LDSOs to update systems with ISD |  | 1d? | 2025-08-11 | 2025-08-11 | 2214 | 31779d | 1d |  |  | 325.33 | No BL | GREEN |  |
| 2216 | 1.9.2.1.3.8 | SIT MVC S&As to update systems with ISD |  | 1d? | 2025-08-11 | 2025-08-11 | 2214 | 31793d | 15d |  |  | 325.33 | No BL | GREEN |  |
| 2217 | 1.9.2.1.3.9 | SIT MVC Service Activation Implementation Complete | milestone | 0d | 2025-08-08 | 2025-08-08 | 2214 | 31778d | 0d | finish no earlier than 2025-03-07 | 5.31 | 322.71 | No BL | GREEN |  |
| 2218 | 1.9.2.1.4 | **SIT MVC Service Activation Implementation MDD** |  | 14d | 2025-03-06 | 2025-03-25 |  | 32460d |  |  | 5.31 |  |  |  |  |
| 2219 | 1.9.2.1.4.1 | MDD Manual Load |  | 7d | 2025-03-06 | 2025-03-14 |  | 32467d |  | finish no earlier than 2025-03-14 | 5.31 | 167.33 | No BL | GREEN |  |
| 2220 | 1.9.2.1.4.2 | MDD Update |  | 8d | 2025-03-14 | 2025-03-25 |  | 32460d |  | finish no earlier than 2025-03-25 | 5.31 | 175.33 | No BL | GREEN |  |
| 2221 | 1.9.2.1.4.3 | SIT MVC Service Activation Implementation MDD Complete | milestone | 0d | 2025-03-25 | 2025-03-25 |  | 32460d |  | finish no earlier than 2025-03-25 | 5.31 | 186.71 | No BL | GREEN |  |
| 2222 | 1.9.2.1.5 | **SIT MVC Service Activation Hypercare** |  | 18d | 2025-03-03 | 2025-03-26 |  | 32459d |  |  | 5.31 |  |  |  |  |
| 2223 | 1.9.2.1.5.1 | Service & Process Monitoring |  | 18d | 2025-03-03 | 2025-03-26 |  | 32459d |  | finish no earlier than 2025-03-26 | 5.31 | 164.33 | No BL | GREEN |  |
| 2224 | 1.9.2.1.5.2 | Daily Reporting |  | 18d | 2025-03-03 | 2025-03-26 |  | 32459d |  | finish no earlier than 2025-03-26 | 5.31 | 164.33 | No BL | GREEN |  |
| 2225 | 1.9.2.1.5.3 | Issue Management |  | 18d | 2025-03-03 | 2025-03-26 |  | 32459d |  | finish no earlier than 2025-03-26 | 5.31 | 164.33 | No BL | GREEN |  |
| 2226 | 1.9.2.1.5.4 | SA Hypercare Close Down Activities |  | 18d | 2025-03-03 | 2025-03-26 |  | 32459d |  | finish no earlier than 2025-03-26 | 5.31 | 164.33 | No BL | GREEN |  |
| 2227 | 1.9.2.1.5.5 | Handover to MHHSP |  | 3d | 2025-03-21 | 2025-03-25 |  | 32460d |  | finish no earlier than 2025-03-25 | 5.31 | 182.33 | No BL | GREEN | MHHSP |
| 2228 | 1.9.2.1.5.6 | SIT MVC Service Activation Hypercare Complete | milestone | 0d | 2025-03-25 | 2025-03-25 |  | 32460d |  | finish no earlier than 2025-03-25 | 5.31 | 186.71 | No BL | GREEN |  |
| 2229 | 1.9.2.2 | **SIT Non-MVC** |  | 803d | 2022-10-31 | 2025-11-26 |  | 32284d |  |  | 5.31 | -650.67 | Overdue Start | RED |  |
| 2230 | 1.9.2.2.1 | **SIT Non-MVC Service Activation Preparation Tasks** |  | 1d | 2022-10-31 | 2022-10-31 |  | 32588d |  |  | 5.31 | -651.67 | Overdue Start | RED |  |
| 2231 | 1.9.2.2.1.1 | Helix Preparatory Activities Complete | milestone | 0d | 2022-10-31 | 2022-10-31 |  | 33087d |  |  | 5.29 | -689.67 | Overdue Start | RED |  |
| 2232 | 1.9.2.2.1.2 | MHHSP Confirms SIT Non-MVC PPs MHHS Enabled |  | 1d | 2022-10-31 | 2022-10-31 |  | 32588d | 794d |  | 5.28 | -689.67 | Overdue Start | RED |  |

Notes:
- 2213: 18/09/24 - This milestone is consistent with the Service Activation Verison 2.0 Process Map.
- 2227: Action: 12/8/24: Why is ths a dep into us?
- 2231: Action: 12/8/24: Emailed helix to clarify what needs to go in the prep section and if hypercare is required
- 2232: 8/7/24: Confirm Predecessors

| ID | WBS | Task | Type | Duration | Start | Finish | Predecessors | Baseline start | Baseline finish | Baseline duration | Total slack | Free slack | Constraint | Update Version | Task Status | Sched Status | RAG | Involved |
| --- | --- | --- | --- | --- | --- | --- | --- | --- | --- | --- | --- | --- | --- | --- | --- | --- | --- | --- |
| 2233 | 1.9.2.2.2 | **SIT Non-MVC Service Activation Implementation** |  | 8d | 2025-11-17 | 2025-11-26 |  |  |  |  | 31794d |  |  | 5.31 |  |  |  |  |
| 2234 | 1.9.2.2.2.1 | Add EDF to DIP |  | 2d | 2025-11-17 | 2025-11-18 | 1517SS, 2232 |  |  |  | 31794d | 0d | finish no earlier than 2025-06-04 | 5.31 | 423.33 | No BL | GREEN |  |
| 2235 | 1.9.2.2.2.2 | DIP Promoted to Production |  | 2d | 2025-11-19 | 2025-11-20 | 2234 |  |  |  | 31794d | 0d | finish no earlier than 2025-06-05 | 5.31 | 425.33 | No BL | GREEN |  |
| 2236 | 1.9.2.2.2.3 | Create M16 in Customer Solution |  | 2d | 2025-11-21 | 2025-11-24 | 2235 |  |  |  | 31794d | 0d | finish no earlier than 2025-06-06 | 5.31 | 427.33 | No BL | GREEN |  |
| 2237 | 1.9.2.2.2.4 | Publish ISD |  | 2d | 2025-11-25 | 2025-11-26 | 2236 |  |  |  | 31794d | 0d | finish no earlier than 2025-06-06 | 5.31 | 431.33 | No BL | GREEN |  |
| 2238 | 1.9.2.2.2.5 | SIT Non-MVC Service Activation Implementation Complete | milestone | 0d | 2025-11-26 | 2025-11-26 | 2237 |  |  |  | 31794d | 0d | finish no earlier than 2025-06-06 | 5.31 | 432.71 | No BL | GREEN |  |
| 2239 | 1.9.2.2.3 | **SIT Non-MVC Service Activation Implementation MDD** |  | 14d | 2025-06-05 | 2025-06-24 |  |  |  |  | 32395d |  |  | 5.31 |  |  |  |  |
| 2240 | 1.9.2.2.3.1 | MDD Manual Load |  | 7d | 2025-06-05 | 2025-06-13 |  |  |  |  | 32402d |  | finish no earlier than 2025-06-13 | 5.31 | 258.33 | No BL | GREEN |  |
| 2241 | 1.9.2.2.3.2 | MDD Update |  | 8d | 2025-06-13 | 2025-06-24 |  |  |  |  | 32395d |  | finish no earlier than 2025-06-24 | 5.31 | 266.33 | No BL | GREEN |  |
| 2242 | 1.9.2.2.3.3 | SIT Non-MVC Service Activation Implementation MDD Complete | milestone | 0d | 2025-06-24 | 2025-06-24 |  |  |  |  | 32395d |  | finish no earlier than 2025-06-24 | 5.31 | 277.71 | No BL | GREEN |  |
| 2243 | 1.9.2.2.4 | **Non-SIT MVC Service Activation Hypercare** |  | 19d | 2025-06-02 | 2025-06-26 |  |  |  |  | 32393d |  |  | 5.31 |  |  |  |  |
| 2244 | 1.9.2.2.4.1 | Service& Process Monitoring |  | 18d | 2025-06-02 | 2025-06-25 |  |  |  |  | 32394d |  | finish no earlier than 2025-06-25 | 5.31 | 255.33 | No BL | GREEN |  |
| 2245 | 1.9.2.2.4.2 | Daily Reporting |  | 18d | 2025-06-02 | 2025-06-25 |  |  |  |  | 32394d |  | finish no earlier than 2025-06-25 | 5.31 | 255.33 | No BL | GREEN |  |
| 2246 | 1.9.2.2.4.3 | Issue Management |  | 18d | 2025-06-02 | 2025-06-25 |  |  |  |  | 32394d |  | finish no earlier than 2025-06-25 | 5.31 | 255.33 | No BL | GREEN |  |
| 2247 | 1.9.2.2.4.4 | SA Hypercare Close Down Activities |  | 18d | 2025-06-02 | 2025-06-25 |  |  |  |  | 32394d |  | finish no earlier than 2025-06-25 | 5.31 | 255.33 | No BL | GREEN |  |
| 2248 | 1.9.2.2.4.5 | Handover to MHHSP |  | 4d | 2025-06-23 | 2025-06-26 |  |  |  |  | 32393d |  | finish no earlier than 2025-06-26 | 5.31 | 276.33 | No BL | GREEN | MHHSP |
| 2249 | 1.9.2.2.4.6 | Non-SIT MVC Service Activation Hypercare Complete (M) | milestone | 0d | 2025-06-25 | 2025-06-25 |  |  |  |  | 32394d |  | finish no earlier than 2025-06-25 | 5.31 | 278.71 | No BL | GREEN |  |
| 2250 | 1.9.2.3 | **Wave 1** |  | 889d | 2022-10-31 | 2026-03-26 |  |  |  |  | 32198d |  |  | 5.31 | -650.67 | Overdue Start | RED |  |
| 2251 | 1.9.2.3.1 | **SIT Non-MVC Service Activation Preparation Tasks** |  | 889d | 2022-10-31 | 2026-03-26 |  |  |  |  | 32198d |  |  | 5.31 | -651.67 | Overdue Start | RED |  |
| 2252 | 1.9.2.3.1.1 | Helix Preparatory Activities Complete | milestone | 0d | 2022-10-31 | 2022-10-31 |  |  |  |  | 33087d |  |  | 5.29 | -689.67 | Overdue Start | RED |  |
| 2253 | 1.9.2.3.1.2 | MHHSP Confirms Wave 1 PPs MHHS Enabled |  | 1d | 2022-10-31 | 2022-10-31 |  |  |  |  | 32647d | 864d |  | 5.28 | -689.67 | Overdue Start | RED |  |
| 2254 | 1.9.2.3.1.3 | Wave 1 Service Activation |  | 24d | 2026-02-23 | 2026-03-26 | 1700, 2253 | 2025-08-29 | 2025-10-02 | 25d | 31783d | 0d |  | 5.24 | 521.33 | Red | RED |  |
| 2255 | 1.9.2.3.2 | **Wave 1 - Service Activation Implementation** |  | 5d | 2025-09-01 | 2025-09-05 |  |  |  |  | 32342d |  |  | 5.31 |  |  |  |  |
| 2256 | 1.9.2.3.2.1 | MHHSP Enabled Confirmation |  | 2d | 2025-09-01 | 2025-09-02 |  |  |  |  | 32345d |  | finish no earlier than 2025-09-02 | 5.31 | 346.33 | No BL | GREEN |  |
| 2257 | 1.9.2.3.2.2 | PAB Approval |  | 2d | 2025-09-01 | 2025-09-02 |  |  |  |  | 32345d |  | finish no earlier than 2025-09-02 | 5.31 | 346.33 | No BL | GREEN |  |
| 2258 | 1.9.2.3.2.3 | Add EDF to DIP |  | 2d | 2025-09-02 | 2025-09-03 |  |  |  |  | 32344d |  | finish no earlier than 2025-09-03 | 5.31 | 347.33 | No BL | GREEN |  |
| 2259 | 1.9.2.3.2.4 | DIP Promoted to Production |  | 2d | 2025-09-03 | 2025-09-04 |  |  |  |  | 32343d |  | finish no earlier than 2025-09-04 | 5.31 | 348.33 | No BL | GREEN |  |
| 2260 | 1.9.2.3.2.5 | Create M16 in Customer Solution |  | 2d | 2025-09-04 | 2025-09-05 |  |  |  |  | 32342d |  | finish no earlier than 2025-09-05 | 5.31 | 349.33 | No BL | GREEN |  |
| 2261 | 1.9.2.3.2.6 | Publish ISD |  | 2d | 2025-09-04 | 2025-09-05 |  |  |  |  | 32342d |  | finish no earlier than 2025-09-05 | 5.31 | 349.33 | No BL | GREEN |  |
| 2262 | 1.9.2.3.2.7 | Wave 1 - Service Activation Implementation Complete (M) | milestone | 0d | 2025-09-05 | 2025-09-05 |  |  |  |  | 32342d |  | finish no earlier than 2025-09-05 | 5.31 | 350.71 | No BL | GREEN |  |

Notes:
- 2252: Action: 12/8/24: Emailed helix to clarify what needs to go in the prep section and if hypercare is required
- 2253: 8/7/24: Confirm Predecessors

| ID | WBS | Task | Type | Duration | Start | Finish | Predecessors | Baseline start | Baseline finish | Baseline duration | Total slack | Free slack | Constraint | Update Version | Task Status | Sched Status | RAG | Text3 |
| --- | --- | --- | --- | --- | --- | --- | --- | --- | --- | --- | --- | --- | --- | --- | --- | --- | --- | --- |
| 2263 | 1.9.2.3.3 | **Wave 1 - Service Activation Implementation MDD** |  | 10d | 2025-09-04 | 2025-09-17 |  |  |  |  | 32334d |  |  | 5.31 |  |  |  |  |
| 2264 | 1.9.2.3.3.1 | MDD Manual Load |  | 5d | 2025-09-04 | 2025-09-10 |  |  |  |  | 32339d |  | finish no earlier than 2025-09-10 | 5.31 | 349.33 | No BL | GREEN |  |
| 2265 | 1.9.2.3.3.2 | MDD Update |  | 6d | 2025-09-10 | 2025-09-17 |  |  |  |  | 32334d |  | finish no earlier than 2025-09-17 | 5.31 | 355.33 | No BL | GREEN |  |
| 2266 | 1.9.2.3.3.3 | Wave 1 - Service Activation Implementation MDD Complete (M) | milestone | 0d | 2025-09-17 | 2025-09-17 |  |  |  |  | 32334d |  | finish no earlier than 2025-09-17 | 5.31 | 362.71 | No BL | GREEN |  |
| 2267 | 1.9.2.3.4 | **Wave 1 - Service Activation Hypercare** |  | 754d | 2022-10-31 | 2025-09-18 |  |  |  |  | 32333d |  |  | 5.31 |  |  |  |  |
| 2268 | 1.9.2.3.4.1 | Service& Process Monitoring |  | 14d | 2025-09-01 | 2025-09-18 |  |  |  |  | 32333d |  | finish no earlier than 2025-09-18 | 5.31 | 346.33 | No BL | GREEN |  |
| 2269 | 1.9.2.3.4.2 | Daily Reporting |  | 14d | 2025-09-01 | 2025-09-18 |  |  |  |  | 32333d |  | finish no earlier than 2025-09-18 | 5.31 | 346.33 | No BL | GREEN |  |
| 2270 | 1.9.2.3.4.3 | Issue Management |  | 14d | 2025-09-01 | 2025-09-18 |  |  |  |  | 32333d |  | finish no earlier than 2025-09-18 | 5.31 | 346.33 | No BL | GREEN |  |
| 2271 | 1.9.2.3.4.4 | SA Hypercare Close Down Activities |  | 14d | 2025-09-01 | 2025-09-18 |  |  |  |  | 32333d |  | finish no earlier than 2025-09-18 | 5.31 | 346.33 | No BL | GREEN |  |
| 2272 | 1.9.2.3.4.5 | Handover to MHHSP |  | 4d | 2025-09-15 | 2025-09-18 |  |  |  |  | 32333d |  | finish no earlier than 2025-09-18 | 5.31 | 360.33 | No BL | GREEN |  |
| 2273 | 1.9.2.3.4.6 | Non-SIT LDSO Service Activation Hypercare Complete (M) | milestone | 0d | 2022-10-31 | 2022-10-31 |  |  |  |  | 33087d |  |  | 5.31 | -689.67 | Overdue Start | RED | Dates to be confirmed |
| 2274 | 1.9.2.4 | **Wave 2** |  | 923d | 2022-10-31 | 2026-05-13 |  |  |  |  | 32164d |  |  | 5.31 | -650.67 | Overdue Start | RED |  |
| 2275 | 1.9.2.4.1 | **SIT Non-MVC Service Activation Preparation Tasks** |  | 923d | 2022-10-31 | 2026-05-13 |  |  |  |  | 32164d |  |  | 5.31 | -651.67 | Overdue Start | RED |  |
| 2276 | 1.9.2.4.1.1 | Helix Preparatory Activities Complete | milestone | 0d | 2022-10-31 | 2022-10-31 |  |  |  |  | 33087d |  |  | 5.29 | -689.67 | Overdue Start | RED |  |
| 2277 | 1.9.2.4.1.2 | MHHSP Confirms Wave 2 PPs MHHS Enabled |  | 1d | 2022-10-31 | 2022-10-31 |  |  |  |  | 32681d | 898d |  | 5.28 | -689.67 | Overdue Start | RED |  |
| 2278 | 1.9.2.4.1.3 | Wave 2 Service Activation |  | 24d | 2026-04-10 | 2026-05-13 | 1730, 2277 | 2025-10-31 | 2025-12-04 | 25d | 31783d | 0d |  | 5.24 | 567.33 | Red | RED |  |
| 2279 | 1.9.2.4.2 | **Wave 2 - Service Activation Implementation** |  | 5d | 2025-11-03 | 2025-11-07 |  |  |  |  | 32297d |  |  | 5.31 |  |  |  |  |
| 2280 | 1.9.2.4.2.1 | MHHSP Enabled Confirmation |  | 2d | 2025-11-03 | 2025-11-04 |  |  |  |  | 32300d |  | finish no earlier than 2025-11-04 | 5.31 | 409.33 | No BL | GREEN |  |
| 2281 | 1.9.2.4.2.2 | PAB Approval |  | 2d | 2025-11-03 | 2025-11-04 |  |  |  |  | 32300d |  | finish no earlier than 2025-11-04 | 5.31 | 409.33 | No BL | GREEN |  |
| 2282 | 1.9.2.4.2.3 | Add EDF to DIP |  | 2d | 2025-11-04 | 2025-11-05 |  |  |  |  | 32299d |  | finish no earlier than 2025-11-05 | 5.31 | 410.33 | No BL | GREEN |  |
| 2283 | 1.9.2.4.2.4 | DIP Promoted to Production |  | 2d | 2025-11-05 | 2025-11-06 |  |  |  |  | 32298d |  | finish no earlier than 2025-11-06 | 5.31 | 411.33 | No BL | GREEN |  |
| 2284 | 1.9.2.4.2.5 | Create M16 in Customer Solution |  | 2d | 2025-11-06 | 2025-11-07 |  |  |  |  | 32297d |  | finish no earlier than 2025-11-07 | 5.31 | 412.33 | No BL | GREEN |  |
| 2285 | 1.9.2.4.2.6 | Publish ISD |  | 2d | 2025-11-06 | 2025-11-07 |  |  |  |  | 32297d |  | finish no earlier than 2025-11-07 | 5.31 | 412.33 | No BL | GREEN |  |
| 2286 | 1.9.2.4.2.7 | Wave 2 - Service Activation Implementation Complete (M) | milestone | 0d | 2025-11-07 | 2025-11-07 |  |  |  |  | 32297d |  | finish no earlier than 2025-11-07 | 5.31 | 413.71 | No BL | GREEN |  |

Notes:
- 2276: Action: 12/8/24: Emailed helix to clarify what needs to go in the prep section and if hypercare is required
- 2277: 8/7/24: Confirm Predecessors

| ID | WBS | Task | Type | Duration | Start | Finish | Predecessors | Baseline start | Baseline finish | Baseline duration | Total slack | Free slack | Constraint | Update Version | Task Status | Sched Status | RAG | Involved |
| --- | --- | --- | --- | --- | --- | --- | --- | --- | --- | --- | --- | --- | --- | --- | --- | --- | --- | --- |
| 2287 | 1.9.2.4.3 | **Wave 2 - Service Activation Implementation MDD** |  | 10d | 2025-11-06 | 2025-11-19 |  |  |  |  | 32289d |  |  | 5.31 |  |  |  |  |
| 2288 | 1.9.2.4.3.1 | MDD Manual Load |  | 5d | 2025-11-06 | 2025-11-12 |  |  |  |  | 32294d |  | finish no earlier than 2025-11-12 | 5.31 | 412.33 | No BL | GREEN |  |
| 2289 | 1.9.2.4.3.2 | MDD Update |  | 6d | 2025-11-12 | 2025-11-19 |  |  |  |  | 32289d |  | finish no earlier than 2025-11-19 | 5.31 | 418.33 | No BL | GREEN |  |
| 2290 | 1.9.2.4.3.3 | Wave 2 - Service Activation Implementation MDD Complete (M) | milestone | 0d | 2025-11-19 | 2025-11-19 |  |  |  |  | 32289d |  | finish no earlier than 2025-11-19 | 5.31 | 425.71 | No BL | GREEN |  |
| 2291 | 1.9.2.4.4 | **Wave 2 - Service Activation Hypercare** |  | 14d | 2025-11-03 | 2025-11-20 |  |  |  |  | 32288d |  |  | 5.31 |  |  |  |  |
| 2292 | 1.9.2.4.4.1 | Service& Process Monitoring |  | 14d | 2025-11-03 | 2025-11-20 |  |  |  |  | 32288d |  | finish no earlier than 2025-11-20 | 5.31 | 409.33 | No BL | GREEN |  |
| 2293 | 1.9.2.4.4.2 | Daily Reporting |  | 14d | 2025-11-03 | 2025-11-20 |  |  |  |  | 32288d |  | finish no earlier than 2025-11-20 | 5.31 | 409.33 | No BL | GREEN |  |
| 2294 | 1.9.2.4.4.3 | Issue Management |  | 14d | 2025-11-03 | 2025-11-20 |  |  |  |  | 32288d |  | finish no earlier than 2025-11-20 | 5.31 | 409.33 | No BL | GREEN |  |
| 2295 | 1.9.2.4.4.4 | SA Hypercare Close Down Activities |  | 14d | 2025-11-03 | 2025-11-20 |  |  |  |  | 32288d |  | finish no earlier than 2025-11-20 | 5.31 | 409.33 | No BL | GREEN |  |
| 2296 | 1.9.2.4.4.5 | Handover to MHHSP |  | 4d | 2025-11-17 | 2025-11-20 |  |  |  |  | 32288d |  | finish no earlier than 2025-11-20 | 5.31 | 423.33 | No BL | GREEN | MHHSP |
| 2297 | 1.9.2.4.4.6 | Wave 2 - Service Activation Hypercare Complete (M) | milestone | 0d | 2025-11-19 | 2025-11-19 |  |  |  |  | 32289d |  | finish no earlier than 2025-11-19 | 5.31 | 425.71 | No BL | GREEN |  |
| 2298 | 1.9.2.5 | **Wave 3** |  | 958d | 2022-10-31 | 2026-07-01 |  |  |  |  | 32129d |  |  | 5.31 | -650.67 | Overdue Start | RED |  |
| 2299 | 1.9.2.5.1 | **SIT Non-MVC Service Activation Preparation Tasks** |  | 958d | 2022-10-31 | 2026-07-01 |  |  |  |  | 32129d |  |  | 5.31 | -651.67 | Overdue Start | RED |  |
| 2300 | 1.9.2.5.1.1 | Helix Preparatory Activities Complete | milestone | 0d | 2022-10-31 | 2022-10-31 |  |  |  |  | 33087d |  |  | 5.29 | -689.67 | Overdue Start | RED |  |
| 2301 | 1.9.2.5.1.2 | MHHSP Confirms Wave 3 PPs MHHS Enabled |  | 1d | 2022-10-31 | 2022-10-31 |  |  |  |  | 32716d | 933d |  | 5.28 | -689.67 | Overdue Start | RED |  |
| 2302 | 1.9.2.5.1.3 | Wave 3 Service Activation |  | 24d | 2026-05-29 | 2026-07-01 | 1760, 2301 | 2025-12-19 | 2026-01-22 | 25d | 31783d | 0d |  | 5.24 | 616.33 | Red | RED |  |
| 2303 | 1.9.2.5.2 | **Wave 3 - Service Activation Implementation** |  | 7d | 2025-12-22 | 2025-12-30 |  |  |  |  | 32260d |  |  | 5.31 |  |  |  |  |
| 2304 | 1.9.2.5.2.1 | MHHSP Enabled Confirmation |  | 2d | 2025-12-22 | 2025-12-23 |  |  |  |  | 32265d |  | finish no earlier than 2025-12-23 | 5.31 | 458.33 | No BL | GREEN |  |
| 2305 | 1.9.2.5.2.2 | PAB Approval |  | 2d | 2025-12-22 | 2025-12-23 |  |  |  |  | 32265d |  | finish no earlier than 2025-12-23 | 5.31 | 458.33 | No BL | GREEN |  |
| 2306 | 1.9.2.5.2.3 | Add EDF to DIP |  | 2d | 2025-12-23 | 2025-12-24 |  |  |  |  | 32264d |  | finish no earlier than 2025-12-24 | 5.31 | 459.33 | No BL | GREEN |  |
| 2307 | 1.9.2.5.2.4 | DIP Promoted to Production |  | 2d | 2025-12-29 | 2025-12-30 |  |  |  |  | 32260d |  | finish no earlier than 2025-12-30 | 5.31 | 465.33 | No BL | GREEN |  |
| 2308 | 1.9.2.5.2.5 | Create M16 in Customer Solution |  | 2d | 2025-12-29 | 2025-12-30 |  |  |  |  | 32260d |  | finish no earlier than 2025-12-30 | 5.31 | 465.33 | No BL | GREEN |  |
| 2309 | 1.9.2.5.2.6 | Publish ISD |  | 2d | 2025-12-29 | 2025-12-30 |  |  |  |  | 32260d |  | finish no earlier than 2025-12-30 | 5.31 | 465.33 | No BL | GREEN |  |
| 2310 | 1.9.2.5.2.7 | Wave 3 - Service Activation Implementation Complete (M) | milestone | 0d | 2025-12-30 | 2025-12-30 |  |  |  |  | 32260d |  | finish no earlier than 2025-12-30 | 5.31 | 466.71 | No BL | GREEN |  |

Notes:
- 2300: Action: 12/8/24: Emailed helix to clarify what needs to go in the prep section and if hypercare is required
- 2301: 8/7/24: Confirm Predecessors

| ID | WBS | Task | Type | Duration | Start | Finish | Predecessors | Baseline start | Baseline finish | Baseline duration | Total slack | Free slack | Constraint | Update Version | Task Status | Sched Status | RAG | Text3 | Involved |
| --- | --- | --- | --- | --- | --- | --- | --- | --- | --- | --- | --- | --- | --- | --- | --- | --- | --- | --- | --- |
| 2311 | 1.9.2.5.3 | **Wave 3 - Service Activation Implementation MDD** |  | 839d | 2022-10-31 | 2026-01-15 |  |  |  |  | 32248d |  |  | 5.31 |  |  |  |  |  |
| 2312 | 1.9.2.5.3.1 | MDD Manual Load |  | 7d | 2025-12-29 | 2026-01-06 |  |  |  |  | 32255d |  | finish no earlier than 2026-01-06 | 5.31 | 465.33 | No BL | GREEN |  |  |
| 2313 | 1.9.2.5.3.2 | MDD Update |  | 269d | 2025-01-06 | 2026-01-15 |  |  |  |  | 32248d |  | finish no earlier than 2026-01-15 | 5.31 | 108.33 | No BL | GREEN |  |  |
| 2314 | 1.9.2.5.3.3 | Wave 3 - Service Activation Implementation MDD Complete (M) | milestone | 0d | 2022-10-31 | 2022-10-31 |  |  |  |  | 33087d |  |  | 5.31 | -689.67 | Overdue Start | RED | Dates to be confirmed |  |
| 2315 | 1.9.2.5.4 | **Wave 3 - Service Activation Hypercare** |  | 840d | 2022-10-31 | 2026-01-16 |  |  |  |  | 32247d |  |  | 5.31 |  |  |  |  |  |
| 2316 | 1.9.2.5.4.1 | Service& Process Monitoring |  | 20d | 2025-12-22 | 2026-01-16 |  |  |  |  | 32247d |  | finish no earlier than 2026-01-16 | 5.31 | 458.33 | No BL | GREEN |  |  |
| 2317 | 1.9.2.5.4.2 | Daily Reporting |  | 20d | 2025-12-22 | 2026-01-16 |  |  |  |  | 32247d |  | finish no earlier than 2026-01-16 | 5.31 | 458.33 | No BL | GREEN |  |  |
| 2318 | 1.9.2.5.4.3 | Issue Management |  | 20d | 2025-12-22 | 2026-01-16 |  |  |  |  | 32247d |  | finish no earlier than 2026-01-16 | 5.31 | 458.33 | No BL | GREEN |  |  |
| 2319 | 1.9.2.5.4.4 | SA Hypercare Close Down Activities |  | 20d | 2025-12-22 | 2026-01-16 |  |  |  |  | 32247d |  | finish no earlier than 2026-01-16 | 5.31 | 458.33 | No BL | GREEN |  |  |
| 2320 | 1.9.2.5.4.5 | Handover to MHHSP |  | 4d | 2026-01-12 | 2026-01-15 |  |  |  |  | 32248d |  | finish no earlier than 2026-01-15 | 5.31 | 479.33 | No BL | GREEN |  | MHHSP |
| 2321 | 1.9.2.5.4.6 | Wave 3 Service Activation Hypercare Complete (M) | milestone | 0d | 2022-10-31 | 2022-10-31 |  |  |  |  | 33087d |  |  | 5.31 | -689.67 | Overdue Start | RED | Date to be confirmed |  |
| 2322 | 1.9.2.6 | **Wave 4** |  | 1004d | 2022-10-31 | 2026-09-03 |  |  |  |  | 32083d |  |  | 5.31 | -650.67 | Overdue Start | RED |  |  |
| 2323 | 1.9.2.6.1 | **SIT Non-MVC Service Activation Preparation Tasks** |  | 1004d | 2022-10-31 | 2026-09-03 |  |  |  |  | 32083d |  |  | 5.31 | -651.67 | Overdue Start | RED |  |  |
| 2324 | 1.9.2.6.1.1 | Helix Preparatory Activities Complete | milestone | 0d | 2022-10-31 | 2022-10-31 |  |  |  |  | 33087d |  |  | 5.29 | -689.67 | Overdue Start | RED |  |  |
| 2325 | 1.9.2.6.1.2 | MHHSP Confirms Wave 4 PPs MHHS Enabled |  | 1d | 2022-10-31 | 2022-10-31 |  |  |  |  | 32761d | 979d |  | 5.28 | -689.67 | Overdue Start | RED |  |  |
| 2326 | 1.9.2.6.1.3 | Wave 4 Service Activation |  | 24d | 2026-08-03 | 2026-09-03 | 1790, 2325 | 2026-02-27 | 2026-04-02 | 25d | 31782d | 0d |  | 5.24 | 682.33 | Red | RED |  |  |
| 2327 | 1.9.2.6.2 | **Wave 4 - Service Activation Implementation** |  | 265d | 2025-03-03 | 2026-03-06 |  |  |  |  | 32212d |  |  | 5.31 |  |  |  |  |  |
| 2328 | 1.9.2.6.2.1 | MHHSP Enabled Confirmation |  | 2d | 2026-03-02 | 2026-03-03 |  |  |  |  | 32215d |  | finish no earlier than 2026-03-03 | 5.31 | 528.33 | No BL | GREEN |  |  |
| 2329 | 1.9.2.6.2.2 | PAB Approval |  | 1d | 2025-03-03 | 2025-03-03 |  |  |  |  | 32476d |  | finish no earlier than 2025-03-03 | 5.31 | 164.33 | No BL | GREEN |  |  |
| 2330 | 1.9.2.6.2.3 | Add EDF to DIP |  | 2d | 2026-03-03 | 2026-03-04 |  |  |  |  | 32214d |  | finish no earlier than 2026-03-04 | 5.31 | 529.33 | No BL | GREEN |  |  |
| 2331 | 1.9.2.6.2.4 | DIP Promoted to Production |  | 2d | 2026-03-04 | 2026-03-05 |  |  |  |  | 32213d |  | finish no earlier than 2026-03-05 | 5.31 | 530.33 | No BL | GREEN |  |  |
| 2332 | 1.9.2.6.2.5 | Create M16 in Customer Solution |  | 2d | 2026-03-05 | 2026-03-06 |  |  |  |  | 32212d |  | finish no earlier than 2026-03-06 | 5.31 | 531.33 | No BL | GREEN |  |  |
| 2333 | 1.9.2.6.2.6 | Publish ISD |  | 2d | 2026-03-05 | 2026-03-06 |  |  |  |  | 32212d |  | finish no earlier than 2026-03-06 | 5.31 | 531.33 | No BL | GREEN |  |  |
| 2334 | 1.9.2.6.2.7 | Wave 4 - Service Activation Implementation Complete (M) | milestone | 0d | 2026-03-06 | 2026-03-06 |  |  |  |  | 32212d |  | finish no earlier than 2026-03-06 | 5.31 | 532.71 | No BL | GREEN |  |  |

Notes:
- 2324: Action: 12/8/24: Emailed helix to clarify what needs to go in the prep section and if hypercare is required
- 2325: 8/7/24: Confirm Predecessors

| ID | WBS | Task | Type | Duration | Start | Finish | Predecessors | Baseline start | Baseline finish | Baseline duration | Total slack | Free slack | Constraint | Update Version | Task Status | Sched Status | RAG | Involved | Responsible |
| --- | --- | --- | --- | --- | --- | --- | --- | --- | --- | --- | --- | --- | --- | --- | --- | --- | --- | --- | --- |
| 2335 | 1.9.2.6.3 | **Wave 4 - Service Activation Implementation MDD** |  | 15d | 2026-03-06 | 2026-03-26 |  |  |  |  | 32198d |  |  | 5.31 |  |  |  |  |  |
| 2336 | 1.9.2.6.3.1 | MDD Manual Load |  | 7d | 2026-03-06 | 2026-03-16 |  |  |  |  | 32206d |  | finish no earlier than 2026-03-16 | 5.31 | 532.33 | No BL | GREEN |  |  |
| 2337 | 1.9.2.6.3.2 | MDD Update |  | 9d | 2026-03-16 | 2026-03-26 |  |  |  |  | 32198d |  | finish no earlier than 2026-03-26 | 5.31 | 542.33 | No BL | GREEN |  |  |
| 2338 | 1.9.2.6.3.3 | Wave 4 - Service Activation Implementation MDD Complete | milestone | 0d | 2026-03-25 | 2026-03-25 |  |  |  |  | 32199d |  | finish no earlier than 2026-03-25 | 5.31 | 551.71 | No BL | GREEN |  |  |
| 2339 | 1.9.2.6.4 | **Wave 4 - Service Activation Hypercare** |  | 19d | 2026-03-02 | 2026-03-26 |  |  |  |  | 32198d |  |  | 5.31 |  |  |  |  |  |
| 2340 | 1.9.2.6.4.1 | Service& Process Monitoring |  | 19d | 2026-03-02 | 2026-03-26 |  |  |  |  | 32198d |  | finish no earlier than 2026-03-26 | 5.31 | 528.33 | No BL | GREEN |  |  |
| 2341 | 1.9.2.6.4.2 | Daily Reporting |  | 19d | 2026-03-02 | 2026-03-26 |  |  |  |  | 32198d |  | finish no earlier than 2026-03-26 | 5.31 | 528.33 | No BL | GREEN |  |  |
| 2342 | 1.9.2.6.4.3 | Issue Management |  | 19d | 2026-03-02 | 2026-03-26 |  |  |  |  | 32198d |  | finish no earlier than 2026-03-26 | 5.31 | 528.33 | No BL | GREEN |  |  |
| 2343 | 1.9.2.6.4.4 | SA Hypercare Close Down Activities |  | 19d | 2026-03-02 | 2026-03-26 |  |  |  |  | 32198d |  | finish no earlier than 2026-03-26 | 5.31 | 528.33 | No BL | GREEN |  |  |
| 2344 | 1.9.2.6.4.5 | Handover to MHHSP |  | 4d | 2026-03-02 | 2026-03-05 |  |  |  |  | 32213d |  | finish no earlier than 2026-03-05 | 5.31 | 528.33 | No BL | GREEN | MHHSP |  |
| 2345 | 1.9.2.6.4.6 | Wave 4 - Service Activation Hypercare Complete (M) | milestone | 0d | 2026-03-25 | 2026-03-25 |  |  |  |  | 32199d |  | finish no earlier than 2026-03-25 | 5.31 | 551.71 | No BL | GREEN |  |  |
| 2346 | 1.9.2.7 | **Non-SIT LDSO** |  | 725d | 2022-10-31 | 2025-08-08 |  |  |  |  | 32362d |  |  | 5.31 | -650.67 | Overdue Start | RED |  |  |
| 2347 | 1.9.2.7.1 | **Non-SIT LDSO Service Activation Data Loading** |  | 176d | 2024-06-07 | 2025-02-07 |  |  |  |  | 32492d |  |  | 5.31 |  |  |  |  |  |
| 2348 | 1.9.2.7.1.1 | Define pre Non-SIT LDSO upfront activities |  | 7d | 2024-06-07 | 2024-06-17 |  |  |  |  | 32661d |  | finish no earlier than 2024-06-17 | 5.31 | -104.67 | Overdue Start | RED |  |  |
| 2349 | 1.9.2.7.1.2 | **Execute Non-SIT LDSO Activities** |  | 5d | 2025-02-03 | 2025-02-07 |  |  |  |  | 32492d |  |  | 5.31 |  |  |  |  |  |
| 2350 | 1.9.2.7.1.2.1 | Create Entity Forms in Customer Solution |  | 3d | 2025-02-03 | 2025-02-05 |  |  |  |  | 32494d |  | finish no earlier than 2025-02-05 | 5.31 | 136.33 | No BL | GREEN |  | PMP |
| 2351 | 1.9.2.7.1.2.2 | DIP - Promote to Production Environment |  | 3d | 2025-02-03 | 2025-02-05 |  |  |  |  | 32494d |  | finish no earlier than 2025-02-05 | 5.31 | 136.33 | No BL | GREEN |  | DIP |
| 2352 | 1.9.2.7.1.2.3 | DIP - Enable Technology capabilities for participants |  | 3d | 2025-02-03 | 2025-02-05 |  |  |  |  | 32494d |  | finish no earlier than 2025-02-05 | 5.31 | 136.33 | No BL | GREEN |  | DIP |
| 2353 | 1.9.2.7.1.2.4 | DIP - Add EFD to DIP |  | 3d | 2025-02-03 | 2025-02-05 |  |  |  |  | 32494d |  | finish no earlier than 2025-02-05 | 5.31 | 136.33 | No BL | GREEN |  | DIP |
| 2354 | 1.9.2.7.1.2.5 | ISD - Replicate Entity Forms from CS |  | 2d | 2025-02-06 | 2025-02-07 |  |  |  |  | 32492d |  | finish no earlier than 2025-02-07 | 5.31 | 139.33 | No BL | GREEN |  | HELIX |
| 2355 | 1.9.2.7.1.2.6 | MDD - Load MHHS roles |  | 3d | 2025-02-03 | 2025-02-05 |  |  |  |  | 32494d |  | finish no earlier than 2025-02-05 | 5.31 | 136.33 | No BL | GREEN |  | PMP |
| 2356 | 1.9.2.7.1.3 | Non-SIT LDSO Service Activation Data Loading Completed (M) | milestone | 0d | 2025-02-07 | 2025-02-07 |  |  |  |  | 32492d |  | finish no earlier than 2025-02-07 | 5.31 | 140.71 | No BL | GREEN |  |  |
| 2357 | 1.9.2.7.2 | **SIT Non-MVC Service Activation Preparation Tasks** |  | 725d | 2022-10-31 | 2025-08-08 |  |  |  |  | 32362d |  |  | 5.31 | -651.67 | Overdue Start | RED |  |  |
| 2358 | 1.9.2.7.2.1 | Helix Preparatory Activities Complete | milestone | 0d | 2022-10-31 | 2022-10-31 |  |  |  |  | 33087d |  |  | 5.29 | -689.67 | Overdue Start | RED |  |  |
| 2359 | 1.9.2.7.2.2 | MHHSP Confirms Non-SIT LDSO PPs MHHS Enabled |  | 1d | 2022-10-31 | 2022-10-31 |  |  |  |  | 32499d | 718d |  | 5.28 | -689.67 | Overdue Start | RED |  |  |
| 2360 | 1.9.2.7.2.3 | Non-SIT LDSO Service Activation |  | 6d | 2025-08-01 | 2025-08-08 | 1438, 2359 | 2025-02-24 | 2025-03-06 | 9d | 31781d | 3d |  | 5.24 | 315.33 | Red | RED |  |  |

Notes:
- 2358: Action: 12/8/24: Emailed helix to clarify what needs to go in the prep section and if hypercare is required
- 2359: 8/7/24: Confirm Predecessors

| ID | WBS | Task | Type | Duration | Start | Finish | Predecessors | Baseline start | Baseline finish | Baseline duration | Baseline 1 start | Baseline 1 finish | Total slack | Free slack | Constraint | Baseline cost | Update Version | Responsible | Task Status | Sched Status | RAG | Involved | MHHS Resource Name | MHHS Programme Phase | Artefact ID |
| --- | --- | --- | --- | --- | --- | --- | --- | --- | --- | --- | --- | --- | --- | --- | --- | --- | --- | --- | --- | --- | --- | --- | --- | --- | --- |
| 2361 | 1.9.2.7.3 | **Non-SIT LDSO Service Activation Implementation** |  | 4d | 2025-02-24 | 2025-02-27 |  |  |  |  |  |  | 32478d |  |  |  | 5.31 |  |  |  |  |  |  |  |  |
| 2362 | 1.9.2.7.3.1 | MHHSP Enabled Confirmation |  | 2d | 2025-02-24 | 2025-02-25 |  |  |  |  |  |  | 32480d |  | finish no earlier than 2025-02-25 |  | 5.31 | MHHSP | 157.33 | No BL | GREEN |  |  |  |  |
| 2363 | 1.9.2.7.3.2 | PAB Approval |  | 2d | 2025-02-24 | 2025-02-25 |  |  |  |  |  |  | 32480d |  | finish no earlier than 2025-02-25 |  | 5.31 | QUALF | 157.33 | No BL | GREEN |  |  |  |  |
| 2364 | 1.9.2.7.3.3 | Add EDF to DIP |  | 2d | 2025-02-25 | 2025-02-26 |  |  |  |  |  |  | 32479d |  | finish no earlier than 2025-02-26 |  | 5.31 | DIP | 158.33 | No BL | GREEN |  |  |  |  |
| 2365 | 1.9.2.7.3.4 | DIP Promoted to Production |  | 2d | 2025-02-26 | 2025-02-27 |  |  |  |  |  |  | 32478d |  | finish no earlier than 2025-02-27 |  | 5.31 | DIP | 159.33 | No BL | GREEN |  |  |  |  |
| 2366 | 1.9.2.7.3.5 | Create M16 in Customer Solution |  | 2d | 2025-02-26 | 2025-02-27 |  |  |  |  |  |  | 32478d |  | finish no earlier than 2025-02-27 |  | 5.31 | PMP | 159.33 | No BL | GREEN |  |  |  |  |
| 2367 | 1.9.2.7.3.6 | Publish ISD |  | 2d | 2025-02-26 | 2025-02-27 |  |  |  |  |  |  | 32478d |  | finish no earlier than 2025-02-27 |  | 5.31 |  | 159.33 | No BL | GREEN |  |  |  |  |
| 2368 | 1.9.2.7.3.7 | Non-SIT LDSO Service Activation Implementation Completed (M) | milestone | 0d | 2025-02-27 | 2025-02-27 |  |  |  |  |  |  | 32478d |  | finish no earlier than 2025-02-27 |  | 5.31 |  | 160.71 | No BL | GREEN |  |  |  |  |
| 2369 | 1.9.2.7.4 | **Non-SIT LDSO Service Activation Implementation MDD** |  | 14d | 2025-02-27 | 2025-03-18 |  |  |  |  |  |  | 32465d |  |  |  | 5.31 |  |  |  |  |  |  |  |  |
| 2370 | 1.9.2.7.4.1 | MDD Manual Load |  | 7d | 2025-02-27 | 2025-03-07 |  |  |  |  |  |  | 32472d |  | finish no earlier than 2025-03-07 |  | 5.31 | PMP | 160.33 | No BL | GREEN |  |  |  |  |
| 2371 | 1.9.2.7.4.2 | MDD Update |  | 8d | 2025-03-07 | 2025-03-18 |  |  |  |  |  |  | 32465d |  | finish no earlier than 2025-03-18 |  | 5.31 | PMP | 168.33 | No BL | GREEN |  |  |  |  |
| 2372 | 1.9.2.7.4.3 | Non-SIT LDSO Service Activation Implementation MDD Complete (M) | milestone | 0d | 2025-03-18 | 2025-03-18 |  |  |  |  |  |  | 32465d |  | finish no earlier than 2025-03-18 |  | 5.31 |  | 179.71 | No BL | GREEN |  |  |  |  |
| 2373 | 1.9.2.7.5 | **Non-SIT LDSO Service Activation Hypercare** |  | 18d | 2025-02-24 | 2025-03-19 |  |  |  |  |  |  | 32464d |  |  |  | 5.31 |  |  |  |  |  |  |  |  |
| 2374 | 1.9.2.7.5.1 | **Non-SIT LDSO Service Activation Hypercare Support** |  | 18d | 2025-02-24 | 2025-03-19 |  |  |  |  |  |  | 32464d |  |  |  | 5.31 |  |  |  |  |  |  |  |  |
| 2375 | 1.9.2.7.5.1.1 | Service& Process Monitoring |  | 18d | 2025-02-24 | 2025-03-19 |  |  |  |  |  |  | 32464d |  | finish no earlier than 2025-03-19 |  | 5.31 |  | 157.33 | No BL | GREEN |  |  |  |  |
| 2376 | 1.9.2.7.5.1.2 | Daily Reporting |  | 18d | 2025-02-24 | 2025-03-19 |  |  |  |  |  |  | 32464d |  | finish no earlier than 2025-03-19 |  | 5.31 |  | 157.33 | No BL | GREEN |  |  |  |  |
| 2377 | 1.9.2.7.5.1.3 | Issue Management |  | 18d | 2025-02-24 | 2025-03-19 |  |  |  |  |  |  | 32464d |  | finish no earlier than 2025-03-19 |  | 5.31 |  | 157.33 | No BL | GREEN |  |  |  |  |
| 2378 | 1.9.2.7.5.1.4 | SA Hypercare Close Down Activities |  | 18d | 2025-02-24 | 2025-03-19 |  |  |  |  |  |  | 32464d |  | finish no earlier than 2025-03-19 |  | 5.31 |  | 157.33 | No BL | GREEN |  |  |  |  |
| 2379 | 1.9.2.7.5.1.5 | Handover to MHHSP |  | 3d | 2025-03-14 | 2025-03-18 |  |  |  |  |  |  | 32465d |  | finish no earlier than 2025-03-18 |  | 5.31 |  | 175.33 | No BL | GREEN | MHHSP |  |  |  |
| 2380 | 1.9.2.7.5.1.6 | Non-SIT LDSO Service Activation Hypercare Complete (M) | milestone | 0d | 2025-03-18 | 2025-03-18 |  |  |  |  |  |  | 32465d |  | finish no earlier than 2025-03-18 |  | 5.31 |  | 179.71 | No BL | GREEN |  |  |  |  |
| 2381 | 1.9.3 | **Implement Early Life Support Plan** |  | 45d | 2025-01-06 | 2025-03-07 |  | 2025-01-06 | 2025-03-07 | 45d | 2025-01-06 | 2025-02-28 | 32472d |  |  | -0 | 5.0 | N/A |  |  |  | N/A | N/A | Business & Operational Readiness |  |
| 2382 | 1.9.3.1 | Implement Early Life Support Plan |  | 45d | 2025-01-06 | 2025-03-07 | 2190 | 2025-01-06 | 2025-03-07 | 45d | 2025-02-28 | 2025-02-28 | 32472d |  | start no earlier than 2025-01-06 |  | 5.23 | SI Transition | 108.33 | Green | GREEN | SI Transition,CPT | Matthew Breen | Business & Operational Readiness | MHHS-ART095 |
| 2383 | 1.9.4 | **Business Continuity and Disaster Recovery Plan** |  | 40d | 2025-06-19 | 2025-08-13 |  | 2025-01-13 | 2025-03-07 | 40d | 2025-01-13 | 2025-03-07 | 32359d |  |  |  | 5.0 | N/A |  |  |  | N/A | N/A | Business & Operational Readiness |  |
| 2384 | 1.9.4.1 | Central Parties BCDRs in Place |  | 20d | 2025-06-19 | 2025-07-16 | 1927FS-40d | 2025-01-13 | 2025-02-07 | 20d | 2025-01-13 | 2025-02-07 | 32359d | 0d |  |  | 5.0 | SI Design | 272.33 | Red | RED |  | MHHS Programme | Business & Operational Readiness |  |
| 2385 | 1.9.4.2 | Risk Based Assurance of Cental Party BCDRs |  | 20d | 2025-07-17 | 2025-08-13 | 2384 | 2025-02-10 | 2025-03-07 | 20d | 2025-02-10 | 2025-03-07 | 32359d |  |  |  | 5.0 | PP | 300.33 | Red | RED | SI Design | MHHS Programme | Business & Operational Readiness |  |

| ID | WBS | Task | Type | Duration | Start | Finish | Predecessors | Baseline start | Baseline finish | Baseline duration | Baseline 1 start | Baseline 1 finish | Total slack | Free slack | Constraint | Baseline cost | Responsible | Involved | Action | Update Version | MHHS Resource Name | MHHS Programme Phase | Task Status | Sched Status | RAG | Artefact ID | Milestone ID | Text29 | Tier |
| --- | --- | --- | --- | --- | --- | --- | --- | --- | --- | --- | --- | --- | --- | --- | --- | --- | --- | --- | --- | --- | --- | --- | --- | --- | --- | --- | --- | --- | --- |
| 2386 | 1.9.5 | **Training and Support Materials** |  | 39d | 2025-07-10 | 2025-09-02 |  | 2025-02-03 | 2025-03-28 | 40d | 2025-02-03 | 2025-03-28 | 32345d |  |  |  | N/A | N/A | 10/5: To be reworked with better clarity (LH) | 5.0 | N/A | Business & Operational Readiness |  |  |  |  |  |  |  |
| 2387 | 1.9.5.1 | Develop document |  | 20d | 2025-07-10 | 2025-08-06 | 2175FS-45d | 2025-02-03 | 2025-02-28 | 20d | 2025-02-03 | 2025-02-28 | 32345d | 0d |  |  | SI Migration | CPT |  | 5.0 | PPC | Business & Operational Readiness | 293.33 | Red | RED |  |  |  |  |
| 2388 | 1.9.5.2 | Document review and update |  | 19d | 2025-08-07 | 2025-09-02 | 2387 | 2025-03-03 | 2025-03-28 | 20d | 2025-03-03 | 2025-03-28 | 32345d | 0d |  |  | SI Migration | PMO,CPT,IPA,PP |  | 5.0 | PPC | Business & Operational Readiness | 321.33 | Red | RED |  |  |  |  |
| 2389 | 1.9.5.3 | Training and Support Materials approved | milestone | 0d | 2025-09-02 | 2025-09-02 | 2388 | 2025-03-28 | 2025-03-28 | 0d | 2025-03-28 | 2025-03-28 | 32345d |  |  |  | SI Migration | PMO,CPT |  | 5.0 | PPC | Business & Operational Readiness | 347.71 | Red | RED | MHHS-ART118 |  |  |  |
| 2390 | 1.9.6 | **PP Business Change** |  | 129d | 2025-02-03 | 2025-07-31 |  | 2025-02-03 | 2025-07-31 | 129d | 2025-02-03 | 2025-07-31 | 32368d |  |  |  | N/A | N/A | 10/5: Review with PPC (LH) | 5.0 | N/A | Business & Operational Readiness | M11 |  |  |  |  |  |  |
| 2391 | 1.9.6.1 | Plan stakeholder management |  | 129d | 2025-02-03 | 2025-07-31 |  | 2025-02-03 | 2025-07-31 | 129d | 2025-02-03 | 2025-07-31 | 32368d |  | start no earlier than 2025-02-03 |  | PP | PPC |  | 5.0 | PPC | Business & Operational Readiness | 136.33 | Green | GREEN |  |  |  |  |
| 2392 | 1.9.6.2 | Manage stakeholders |  | 129d | 2025-02-03 | 2025-07-31 |  | 2025-02-03 | 2025-07-31 | 129d | 2025-02-03 | 2025-07-31 | 32368d |  | start no earlier than 2025-02-03 |  | PP | PPC |  | 5.0 | PPC | Business & Operational Readiness | 136.33 | Green | GREEN |  |  |  |  |
| 2393 | 1.9.6.3 | Develop & implement changes to KPIs, organisation & people management |  | 129d | 2025-02-03 | 2025-07-31 |  | 2025-02-03 | 2025-07-31 | 129d | 2025-02-03 | 2025-07-31 | 32368d |  | start no earlier than 2025-02-03 |  | PP | PPC |  | 5.0 | PPC | Business & Operational Readiness | 136.33 | Green | GREEN |  |  |  |  |
| 2394 | 1.9.6.4 | Develop & test changes to business processes |  | 129d | 2025-02-03 | 2025-07-31 |  | 2025-02-03 | 2025-07-31 | 129d | 2025-02-03 | 2025-07-31 | 32368d |  | start no earlier than 2025-02-03 |  | PP | PPC |  | 5.0 | PPC | Business & Operational Readiness | 136.33 | Green | GREEN |  |  |  |  |
| 2395 | 1.9.6.5 | Develop and deliver training |  | 129d | 2025-02-03 | 2025-07-31 |  | 2025-02-03 | 2025-07-31 | 129d | 2025-02-03 | 2025-07-31 | 32368d |  | start no earlier than 2025-02-03 |  | PP | PPC |  | 5.0 | PPC | Business & Operational Readiness | 136.33 | Green | GREEN |  |  |  |  |
| 2396 | 1.9.6.6 | Programme support for PP Business Change activities |  | 129d | 2025-02-03 | 2025-07-31 |  | 2025-02-03 | 2025-07-31 | 129d | 2025-02-03 | 2025-07-31 | 32368d |  | start no earlier than 2025-02-03 |  | PPC | PP |  | 5.0 | PPC | Business & Operational Readiness | 136.33 | Green | GREEN |  |  |  |  |
| 2397 | 1.9.7 | **Transition to New Settlement Timetable (M16)** |  | 1d? | 2025-09-10 | 2025-09-11 |  | 2025-04-04 | 2027-05-28 | 560d |  |  |  |  |  | -0 | N/A | N/A |  | 5.15 | N/A | Business & Operational Readiness | -434.67 |  |  |  |  |  |  |
| 2398 | 1.9.7.1 | Elexon to produce Settlement Calendar for Settlement Year 2025/2026 | milestone | 0d | 2025-09-10 | 2025-09-10 | 2173 | 2025-04-04 | 2025-04-04 | 0d |  |  | 31778d | 0d |  |  | PP | PP, Code Bodies |  | 5.15 | Matthew Breen | Business & Operational Readiness | 355.71 | Red | RED |  |  |  |  |
| 2399 | 1.9.7.2 | Elexon monitor settlement data of migrated MPANs |  | 436d | 2025-09-11 | 2027-05-13 | 2398 | 2025-04-07 | 2026-12-07 | 436d |  |  | 31779d | 1d |  |  | PP | PP, Code Bodies |  | 5.15 | Matthew Breen | Business & Operational Readiness | 356.33 | Red | RED |  |  |  |  |
| 2400 | 1.9.7.3 | M16 Checkpoint 1 | milestone | 0d | 2026-05-14 | 2026-05-14 | 2398FS+176d | 2025-12-08 | 2025-12-08 | 0d |  |  | 31778d | 0d |  |  | PP | PP, Code Bodies |  | 5.15 | Matthew Breen | Business & Operational Readiness | 601.71 | Red | RED |  |  |  |  |
| 2401 | 1.9.7.4 | Confirm if M16 date retained as 07/12/2026 | milestone | 0d | 2026-06-11 | 2026-06-11 | 2400FS+20d | 2026-01-05 | 2026-01-05 | 0d |  |  | 31778d | 0d |  |  | CPT | PP |  | 5.15 | Matthew Breen | Business & Operational Readiness | 629.71 | Red | RED |  |  |  |  |
| 2402 | 1.9.7.5 | Readiness assessment of participants' readiness to transition to new Settlement Timetable | milestone | 0d | 2026-07-09 | 2026-07-09 | 2401FS+20d | 2026-02-02 | 2026-02-02 | 0d |  |  | 31778d | 0d |  |  | CPT | PP |  | 5.15 | Matthew Breen | Business & Operational Readiness | 657.71 | Red | RED |  |  |  |  |
| 2403 | 1.9.7.6 | Elexon to produce Settlement Calendar for Settlement Year 2026 up until day before M16 cutover | milestone | 0d | 2026-09-07 | 2026-09-07 | 2402FS+42d | 2026-04-01 | 2026-04-01 | 0d |  |  | 31778d | 0d |  |  | PP | PP, Code Bodies |  | 5.15 | Matthew Breen | Business & Operational Readiness | 717.71 | Red | RED |  |  |  |  |
| 2404 | 1.9.7.7 | M16 Checkpoint 2 | milestone | 0d | 2027-02-19 | 2027-02-19 | 2403FS+119d | 2026-09-15 | 2026-09-15 | 0d |  |  | 31778d | 0d |  |  | PP | PP, Code Bodies |  | 5.15 | Matthew Breen | Business & Operational Readiness | 882.71 | Red | RED |  |  |  |  |
| 2405 | 1.9.7.8 | Readiness assessment of participants' readiness to transition to new Settlement Timetable | milestone | 0d | 2027-03-08 | 2027-03-08 | 2404FS+11d | 2026-09-30 | 2026-09-30 | 0d |  |  | 31778d | 0d |  |  | CPT | PP |  | 5.15 | Matthew Breen | Business & Operational Readiness | 899.71 | Red | RED |  |  |  |  |
| 2406 | 1.9.7.9 | Confirm M16 Date | milestone | 0d | 2027-03-19 | 2027-03-19 | 2405FS+9d | 2026-10-13 | 2026-10-13 | 1d |  |  | 31778d | 0d |  |  | CPT | Code Bodies,CPT,PP,SRO |  | 5.3 | Matthew Breen | Business & Operational Readiness | 910.71 | Red | RED |  | T2-EL-0100 | PSG/BSC PAB | T2 |
| 2407 | 1.9.7.10 | Raise fast track change to ISD (November publish) | milestone | 0d | 2027-03-19 | 2027-03-19 | 2406 | 2026-10-13 | 2026-10-13 | 0d |  |  | 31818d | 40d |  |  | PP | PP,CPT,Code Bodies |  | 5.15 | Matthew Breen | Business & Operational Readiness | 910.71 | Red | RED |  |  |  |  |
| 2408 | 1.9.7.11 | **M16 Approval Window** |  | 31903d? | 2027-05-13 | 2149-08-26 |  | 2026-12-07 | 2027-05-28 | 124d | 2026-12-07 | 2027-05-24 |  |  |  |  | N/A | N/A |  | 5.0 | N/A | Business & Operational Readiness | 966.71 | Green | GREEN |  |  |  |  |
| 2409 | 1.9.7.11.1 | Panel approval that M16 criteria met | milestone | 0d | 2027-05-14 | 2027-05-14 | 2406FS+40d | 2026-12-07 | 2026-12-07 | 0d | 2026-12-07 | 2026-12-07 | 31778d | 0d |  |  | Panel | Code Bodies,CPT,PP,SRO |  | 5.0 | Matthew Breen | Business & Operational Readiness | 966.71 | Red | RED |  |  |  |  |
| 2410 | 1.9.7.11.2 | Cut over to new settlement timetable (M16) | milestone | 0d | 2027-05-14 | 2027-05-14 | 2409, 2177FS+40d, 2399, 2407, 2090 | 2026-12-07 | 2026-12-07 | 0d | 2026-12-07 | 2026-12-07 | 31778d | 0d |  |  | CPT | PP |  | 5.0 | Matthew Breen | Business & Operational Readiness | 966.71 | Red | RED |  | T1-EL-1000 | PSG | T1 |
| 2411 | 1.9.7.11.3 | Maximum 6-month window for approval of M16 |  | 124d | 2027-05-17 | 2027-11-04 | 2410 | 2026-12-08 | 2027-05-28 | 124d | 2026-12-08 | 2027-05-24 | 31778d | 0d |  |  | CPT |  |  | 5.0 | Matthew Breen | Business & Operational Readiness | 969.33 | Red | RED |  |  |  |  |
| 2412 | 1.9.7.11.4 | Cut over to new settlement timetable (M16*) - Late Exit | milestone | 0d | 2027-11-04 | 2027-11-04 | 2411 | 2027-05-28 | 2027-05-28 | 0d | 2027-05-24 | 2027-05-24 | 31778d |  |  |  | CPT | PP |  | 5.0 | Matthew Breen | Business & Operational Readiness | 1140.71 | Red | RED |  | T1-EL-2000 | PSG | T1 |

| ID | WBS | Task | Type | Duration | Start | Finish | Predecessors | Baseline start | Baseline finish | Baseline duration | Baseline 1 start | Baseline 1 finish | Total slack | Free slack | Responsible | Involved | Text3 | MHHS Resource Name | MHHS Programme Phase | Update Version | Task Status | Sched Status | RAG | Artefact ID | Milestone ID | Text29 | Tier |
| --- | --- | --- | --- | --- | --- | --- | --- | --- | --- | --- | --- | --- | --- | --- | --- | --- | --- | --- | --- | --- | --- | --- | --- | --- | --- | --- | --- |
| 2413 | 1.10 | **EARLY LIVE RUNNING** |  | 45d | 2027-03-16 | 2027-05-17 |  | 2024-01-02 | 2027-05-28 | 889d | 2024-01-02 | 2027-05-28 | 31901d |  | N/A | N/A | 1 Nov 2025 - 30 Apr 2026 | N/A | Early Live Running |  |  |  |  |  |  |  |  |
| 2414 | 1.10.1 | **Early Live Running Stabilisation Period** |  | 45d | 2027-03-16 | 2027-05-17 |  | 2026-10-06 | 2026-12-07 | 45d | 2026-10-06 | 2026-12-07 | 31901d |  | N/A | N/A |  | N/A | Early Live Running | 5.0 |  |  |  |  |  |  |  |
| 2415 | 1.10.1.1 | Manage Early Live Running stabilisation period |  | 45d | 2027-03-16 | 2027-05-17 | 2177 | 2026-10-06 | 2026-12-07 | 45d | 2026-10-06 | 2026-12-07 | 31901d | 0d | Code Bodies | PP |  | Matthew Breen | Early Live Running | 5.0 | 907.33 | Red | RED |  |  |  |  |
| 2416 | 1.10.1.2 | Monitor Early Live Running stabilisation period |  | 45d | 2027-03-16 | 2027-05-17 | 2415SS | 2026-10-06 | 2026-12-07 | 45d | 2026-10-06 | 2026-12-07 | 31901d |  | SI Migration | Code Bodies,PP |  | Matthew Breen | Early Live Running | 5.0 | 907.33 | Red | RED |  |  |  |  |
| 2417 | 1.11 | **PROGRAMME CLOSURE** |  | 84d | 2027-01-12 | 2027-05-07 |  | 2026-08-04 | 2026-11-30 | 85d | 2026-08-04 | 2026-11-30 | 31907d |  | N/A | N/A |  | N/A | Programme Closure |  |  |  |  |  |  |  |  |
| 2418 | 1.11.1 | **Handover Pack** |  | 84d | 2027-01-12 | 2027-05-07 |  | 2026-08-04 | 2026-11-30 | 85d | 2026-08-04 | 2026-11-30 | 31907d |  | N/A | N/A |  | N/A | Programme Closure | 5.0 |  |  |  |  |  |  |  |
| 2419 | 1.11.1.1 | **Draft Handover Pack (for M15)** |  | 40d | 2027-01-12 | 2027-03-08 |  | 2026-08-04 | 2026-09-28 | 40d | 2026-08-04 | 2026-09-28 | 31951d |  | N/A | N/A |  | N/A | Programme Closure | 5.0 |  |  |  |  |  |  |  |
| 2420 | 1.11.1.1.1 | Develop document |  | 20d | 2027-01-12 | 2027-02-08 | 2177FS-45d | 2026-08-04 | 2026-08-31 | 20d | 2026-08-04 | 2026-08-31 | 31951d | 0d | PMO | CPT |  |  | Programme Closure | 5.0 | 844.33 | Red | RED |  |  |  |  |
| 2421 | 1.11.1.1.2 | Document review and update |  | 20d | 2027-02-09 | 2027-03-08 | 2420 | 2026-09-01 | 2026-09-28 | 20d | 2026-09-01 | 2026-09-28 | 31951d | 0d | SRO | PMO,CPT,IPA,PP |  |  | Programme Closure | 5.0 | 872.33 | Red | RED |  |  |  |  |
| 2422 | 1.11.1.1.3 | Draft Handover Pack approved | milestone | 0d | 2027-03-08 | 2027-03-08 | 2421 | 2026-09-28 | 2026-09-28 | 0d | 2026-09-28 | 2026-09-28 | 31951d |  | SRO | PMO,CPT |  |  | Programme Closure | 5.0 | 899.71 | Red | RED | MHHS-ART126 |  |  |  |
| 2423 | 1.11.1.2 | **Master Handover Pack (for M16)** |  | 40d | 2027-03-15 | 2027-05-07 |  | 2026-10-06 | 2026-11-30 | 40d | 2026-10-06 | 2026-11-30 | 31907d |  | N/A | N/A |  | N/A | Programme Closure | 5.0 |  |  |  |  |  |  |  |
| 2424 | 1.11.1.2.1 | Update document |  | 20d | 2027-03-15 | 2027-04-09 | 2410FS-45d | 2026-10-06 | 2026-11-02 | 20d | 2026-10-06 | 2026-11-02 | 31907d | 0d | PMO | CPT |  |  | Programme Closure | 5.0 | 906.33 | Red | RED |  |  |  |  |
| 2425 | 1.11.1.2.2 | Document review and update |  | 20d | 2027-04-12 | 2027-05-07 | 2424 | 2026-11-03 | 2026-11-30 | 20d | 2026-11-03 | 2026-11-30 | 31907d | 0d | SRO | PMO,CPT,IPA,PP |  |  | Programme Closure | 5.0 | 934.33 | Red | RED |  |  |  |  |
| 2426 | 1.11.1.2.3 | Master Handover Pack approved | milestone | 0d | 2027-05-07 | 2027-05-07 | 2425 | 2026-11-30 | 2026-11-30 | 0d | 2026-11-30 | 2026-11-30 | 31907d |  | SRO | PMO,CPT |  |  | Programme Closure | 5.0 | 959.71 | Red | RED | MHHS-ART126 |  |  |  |
| 2427 | 1.11.2 | **Programme Lessons Learned** |  | 40d | 2027-01-12 | 2027-03-08 |  | 2026-08-04 | 2026-09-28 | 40d | 2026-08-04 | 2026-09-28 | 31951d |  | N/A | N/A |  | N/A | Programme Closure | 5.0 |  |  |  |  |  |  |  |
| 2428 | 1.11.2.1 | Develop document |  | 20d | 2027-01-12 | 2027-02-08 | 2177FS-45d | 2026-08-04 | 2026-08-31 | 20d | 2026-08-04 | 2026-08-31 | 31951d | 0d | PMO | CPT |  |  | Programme Closure | 5.0 | 844.33 | Red | RED |  |  |  |  |
| 2429 | 1.11.2.2 | Document review and update |  | 20d | 2027-02-09 | 2027-03-08 | 2428 | 2026-09-01 | 2026-09-28 | 20d | 2026-09-01 | 2026-09-28 | 31951d | 0d | SRO | PMO,CPT,IPA |  |  | Programme Closure | 5.0 | 872.33 | Red | RED |  |  |  |  |
| 2430 | 1.11.2.3 | Programme Lessons Learned document approved | milestone | 0d | 2027-03-08 | 2027-03-08 | 2429 | 2026-09-28 | 2026-09-28 | 0d | 2026-09-28 | 2026-09-28 | 31951d |  | SRO | PMO,CPT |  |  | Programme Closure | 5.0 | 899.71 | Red | RED | MHHS-ART131 |  |  |  |
| 2431 | 1.11.3 | **Programme Closure Report** |  | 40d | 2027-01-12 | 2027-03-08 |  | 2026-08-04 | 2026-09-28 | 40d | 2026-08-04 | 2026-09-28 | 31951d |  | N/A | N/A |  | N/A | Programme Closure | 5.0 |  |  |  |  |  |  |  |
| 2432 | 1.11.3.1 | Develop document |  | 20d | 2027-01-12 | 2027-02-08 | 2177FS-45d | 2026-08-04 | 2026-08-31 | 20d | 2026-08-04 | 2026-08-31 | 31951d | 0d | PMO | CPT |  |  | Programme Closure | 5.0 | 844.33 | Red | RED |  |  |  |  |
| 2433 | 1.11.3.2 | Document review and update |  | 20d | 2027-02-09 | 2027-03-08 | 2432 | 2026-09-01 | 2026-09-28 | 20d | 2026-09-01 | 2026-09-28 | 31951d | 0d | Ofgem | PMO,CPT,IPA,SRO |  |  | Programme Closure | 5.0 | 872.33 | Red | RED |  |  |  |  |
| 2434 | 1.11.3.3 | Programme Closure Report approved | milestone | 0d | 2027-03-08 | 2027-03-08 | 2433 | 2026-09-28 | 2026-09-28 | 0d | 2026-09-28 | 2026-09-28 | 31951d |  | Ofgem | PMO,CPT,IPA,SRO |  |  | Programme Closure | 5.0 | 899.71 | Red | RED | MHHS-ART130 |  |  |  |
| 2435 | 1.11.4 | **Benefit Realisation Report** |  | 45d | 2027-01-12 | 2027-03-15 |  | 2026-08-04 | 2026-10-05 | 45d | 2026-08-04 | 2026-10-05 | 31946d |  | N/A | N/A |  | N/A | Programme Closure | 5.0 |  |  |  |  |  |  |  |
| 2436 | 1.11.4.1 | Develop document |  | 20d | 2027-01-12 | 2027-02-08 | 2177FS-45d | 2026-08-04 | 2026-08-31 | 20d | 2026-08-04 | 2026-08-31 | 31946d | 0d | PMO | CPT |  |  | Programme Closure | 5.0 | 844.33 | Red | RED |  |  |  |  |
| 2437 | 1.11.4.2 | Document review and update |  | 20d | 2027-02-09 | 2027-03-08 | 2436 | 2026-09-01 | 2026-09-28 | 20d | 2026-09-01 | 2026-09-28 | 31946d | 0d | PP | PMO,CPT,IPA,SRO |  |  | Programme Closure | 5.0 | 872.33 | Red | RED |  |  |  |  |
| 2438 | 1.11.4.3 | Benefit Realisation Report approved | milestone | 0d | 2027-03-15 | 2027-03-15 | 2437FS+5d | 2026-10-05 | 2026-10-05 | 0d | 2026-10-05 | 2026-10-05 | 31946d |  | PMO | CPT,PP,IPA,SRO |  |  | Programme Closure | 5.0 | 906.71 | Red | RED | MHHS-ART124 | T3-PC-0010 | PSG | T3 |

| ID | WBS | Task | Type | Duration | Start | Finish | Predecessors | Complete | Remaining | Baseline start | Baseline finish | Baseline duration | Baseline 1 start | Baseline 1 finish | Total slack | Free slack | Constraint | Responsible | Involved | Update Version | MHHS Resource Name | MHHS Programme Phase | Task Status | Sched Status | RAG | Artefact ID | Milestone ID | Text29 | Tier | Text3 |
| --- | --- | --- | --- | --- | --- | --- | --- | --- | --- | --- | --- | --- | --- | --- | --- | --- | --- | --- | --- | --- | --- | --- | --- | --- | --- | --- | --- | --- | --- | --- |
| 2439 | 1.11.5 | **Operating Model Gap Review with recommendations** |  | 45d | 2027-01-12 | 2027-03-15 |  |  |  | 2026-08-04 | 2026-10-05 | 45d | 2026-08-04 | 2026-10-05 | 31946d |  |  | N/A | N/A | 5.0 | N/A | Programme Closure |  |  |  |  |  |  |  |  |
| 2440 | 1.11.5.1 | Develop document |  | 20d | 2027-01-12 | 2027-02-08 | 2177FS-45d |  |  | 2026-08-04 | 2026-08-31 | 20d | 2026-08-04 | 2026-08-31 | 31946d | 0d |  | PMO | CPT | 5.0 |  | Programme Closure | 844.33 | Red | RED |  |  |  |  |  |
| 2441 | 1.11.5.2 | Document review and update |  | 20d | 2027-02-09 | 2027-03-08 | 2440 |  |  | 2026-09-01 | 2026-09-28 | 20d | 2026-09-01 | 2026-09-28 | 31946d | 0d |  | PP | PMO,CPT,IPA,SRO | 5.0 |  | Programme Closure | 872.33 | Red | RED |  |  |  |  |  |
| 2442 | 1.11.5.3 | Operating Model Gap Review with recommendations approved | milestone | 0d | 2027-03-15 | 2027-03-15 | 2441FS+5d |  |  | 2026-10-05 | 2026-10-05 | 0d | 2026-10-05 | 2026-10-05 | 31946d |  |  | Paul Pettitt | CPT,PP,IPA,SRO | 5.0 | Paul Pettitt | Programme Closure | 906.71 | Red | RED | MHHS-ART128 | T3-PC-0020 | DAG | T3 |  |
| 2443 | 1.11.6 | **Post-Implementation Review** |  | 45d | 2027-01-12 | 2027-03-15 |  |  |  | 2026-08-04 | 2026-10-05 | 45d | 2026-08-04 | 2026-10-05 | 31946d |  |  | N/A | N/A | 5.0 | N/A | Programme Closure |  |  |  |  |  |  |  |  |
| 2444 | 1.11.6.1 | Develop document |  | 20d | 2027-01-12 | 2027-02-08 | 2177FS-45d |  |  | 2026-08-04 | 2026-08-31 | 20d | 2026-08-04 | 2026-08-31 | 31946d | 0d |  | PMO | CPT | 5.0 |  | Programme Closure | 844.33 | Red | RED |  |  |  |  |  |
| 2445 | 1.11.6.2 | Document review and update |  | 20d | 2027-02-09 | 2027-03-08 | 2444 |  |  | 2026-09-01 | 2026-09-28 | 20d | 2026-09-01 | 2026-09-28 | 31946d | 0d |  | PP | PMO,CPT,IPA,SRO | 5.0 |  | Programme Closure | 872.33 | Red | RED |  |  |  |  |  |
| 2446 | 1.11.6.3 | Post-Implementation Review approved | milestone | 0d | 2027-03-15 | 2027-03-15 | 2445FS+5d |  |  | 2026-10-05 | 2026-10-05 | 0d | 2026-10-05 | 2026-10-05 | 31946d |  |  | PMO | CPT,PP,IPA,SRO | 5.0 |  | Programme Closure | 906.71 | Red | RED | MHHS-ART129 | T3-PC-0030 | PSG | T3 |  |
| 2447 | 1.11.7 | **Reinforcement Guide** |  | 45d | 2027-01-12 | 2027-03-15 |  |  |  | 2026-08-04 | 2026-10-05 | 45d | 2026-08-04 | 2026-10-05 | 31946d |  |  | N/A | N/A | 5.0 | N/A | Programme Closure |  |  |  |  |  |  |  |  |
| 2448 | 1.11.7.1 | Develop document |  | 20d | 2027-01-12 | 2027-02-08 | 2177FS-45d |  |  | 2026-08-04 | 2026-08-31 | 20d | 2026-08-04 | 2026-08-31 | 31946d | 0d |  | PMO | CPT | 5.0 |  | Programme Closure | 844.33 | Red | RED |  |  |  |  |  |
| 2449 | 1.11.7.2 | Document review and update |  | 20d | 2027-02-09 | 2027-03-08 | 2448 |  |  | 2026-09-01 | 2026-09-28 | 20d | 2026-09-01 | 2026-09-28 | 31946d | 0d |  | PP | PMO,CPT,IPA,SRO | 5.0 |  | Programme Closure | 872.33 | Red | RED |  |  |  |  |  |
| 2450 | 1.11.7.3 | Reinforcement Guide approved | milestone | 0d | 2027-03-15 | 2027-03-15 | 2449FS+5d |  |  | 2026-10-05 | 2026-10-05 | 0d | 2026-10-05 | 2026-10-05 | 31946d |  |  | PMO | CPT,PP,IPA,SRO | 5.0 |  | Programme Closure | 906.71 | Red | RED | MHHS-ART133 | T3-PC-0040 | PSG | T3 |  |
| 2451 | 1.11.8 | **Material and Licenses Transfer** |  | 60d | 2027-02-15 | 2027-05-07 |  |  |  | 2026-09-08 | 2026-11-30 | 60d | 2026-09-08 | 2026-11-30 | 31907d |  |  | N/A | N/A | 5.0 | N/A | Programme Closure |  |  |  |  |  |  |  |  |
| 2452 | 1.11.8.1 | Transfer of Programme material to Elexon and perpetual licenses as appropriate |  | 60d | 2027-02-15 | 2027-05-07 | 2410FF-5d |  |  | 2026-09-08 | 2026-11-30 | 60d | 2026-09-08 | 2026-11-30 | 31907d |  |  | PMO | CPT,PP | 5.0 |  | Programme Closure | 878.33 | Red | RED | MHHS-ART139 |  |  |  |  |
| 2453 | 1.12 | **READINESS ASSESSMENTS** |  | 953d | 2023-09-05 A | 2027-04-29 |  | 23% | 737.81d | 2023-09-05 | 2026-12-04 | 849d | 2023-09-11 | 2026-12-04 | 31913d |  |  | N/A | N/A |  | N/A | Readiness Assessments |  |  |  |  |  |  |  |  |
| 2454 | 1.12.1 | **Readiness Assessment 3 - Design and Build Progress Check and CP2 Check** |  | 60d | 2023-09-05 A | 2023-11-27 A |  | 100% |  | 2023-09-05 | 2023-11-13 | 50d | 2023-09-11 | 2023-11-17 |  |  |  | N/A | N/A | 5.5 | N/A | Readiness Assessments | M5,M6 |  |  |  |  |  |  |  |
| 2455 | 1.12.1.1 | Launch Readiness Assessment survey | milestone | 0d | 2023-09-05 A | 2023-09-05 A | 1070FS-40d | 100% |  | 2023-09-05 | 2023-09-05 | 0d | 2023-09-11 | 2023-09-11 |  |  |  | PPC |  | 5.5 | PPC | Readiness Assessments |  | Complete | COMPLETE |  |  |  |  |  |
| 2456 | 1.12.1.2 | PPs submit survey responses |  | 15d | 2023-09-05 A | 2023-09-25 A | 2455 | 100% |  | 2023-09-05 | 2023-09-25 | 15d | 2023-09-11 | 2023-09-29 |  |  |  | PP | PPC | 5.5 | PPC | Readiness Assessments |  | Complete | COMPLETE |  |  |  |  |  |
| 2457 | 1.12.1.3 | Analyse survey responses |  | 15d | 2023-09-26 A | 2023-10-16 A | 2456 | 100% |  | 2023-09-26 | 2023-10-16 | 15d | 2023-10-02 | 2023-10-20 |  |  |  | PPC | CPT | 5.5 | PPC | Readiness Assessments |  | Complete | COMPLETE |  |  |  |  |  |
| 2458 | 1.12.1.4 | Conduct deep-dive interviews (sample of PPs) |  | 15d | 2023-09-26 A | 2023-10-16 A | 2456 | 100% |  | 2023-09-26 | 2023-10-16 | 15d | 2023-10-02 | 2023-10-20 |  |  |  | PPC | CPT | 5.5 | PPC | Readiness Assessments |  | Complete | COMPLETE |  |  |  |  |  |
| 2459 | 1.12.1.5 | Produce Readiness Assessment Reports (Overall Report & Individual Participant Reports) |  | 25d | 2023-10-17 A | 2023-11-20 A | 2457, 2458 | 100% |  | 2023-10-17 | 2023-11-06 | 15d | 2023-10-23 | 2023-11-10 |  |  |  | PPC |  | 5.5 | PPC | Readiness Assessments |  | Complete | COMPLETE |  |  |  |  |  |
| 2460 | 1.12.1.6 | Readiness Assessment 3 - Design & Build Checkpoint 1 - Completed (incl. Readiness Assessment Report approval) | milestone | 0d | 2023-11-27 A | 2023-11-27 A | 2459FS+5d | 100% |  | 2023-11-13 | 2023-11-13 | 0d | 2023-11-17 | 2023-11-17 |  |  |  | CPT | PPC | 5.13 | PPC | Readiness Assessments |  | Complete | COMPLETE |  | T2-RA-0200 | PSG | T2 |  |
| 2461 | 1.12.2 | **Readiness Assessment 5 / 6 - Start of Qualification and Participant Readiness for M10 and M11 and CP3/CP4 check** |  | 47d | 2025-04-21 | 2025-06-24 |  |  |  | 2024-11-12 | 2025-01-17 | 49d | 2024-11-12 | 2025-01-17 | 32395d |  |  | N/A | N/A | 5.0 | N/A | Readiness Assessments | M11 |  |  |  |  |  |  | D25 - RA6 Readiness Report |
| 2462 | 1.12.2.1 | Launch Readiness Assessment survey | milestone | 0d | 2025-04-21 | 2025-04-21 |  |  |  | 2024-11-12 | 2024-11-12 | 0d | 2024-11-12 | 2024-11-12 | 32395d | 0d | start no earlier than 2025-04-21 | PPC |  | 5.0 | PPC | Readiness Assessments | 213.33 | Red | RED |  |  |  |  |  |
| 2463 | 1.12.2.2 | PPs submit survey responses |  | 15d | 2025-04-21 | 2025-05-09 | 2462 |  |  | 2024-11-12 | 2024-12-02 | 15d | 2024-11-12 | 2024-12-02 | 32395d | 0d |  | PP | PPC | 5.0 | PPC | Readiness Assessments | 213.33 | Red | RED |  |  |  |  |  |
| 2464 | 1.12.2.3 | Analyse survey responses |  | 15d | 2025-05-12 | 2025-05-30 | 2463 |  |  | 2024-12-03 | 2024-12-23 | 15d | 2024-12-03 | 2024-12-23 | 32395d | 0d |  | PPC | CPT | 5.0 | PPC | Readiness Assessments | 234.33 | Red | RED |  |  |  |  |  |
| 2465 | 1.12.2.4 | Conduct deep-dive interviews (sample of PPs) |  | 15d | 2025-05-12 | 2025-05-30 | 2463 |  |  | 2024-12-03 | 2024-12-23 | 15d | 2024-12-03 | 2024-12-23 | 32395d | 0d |  | PPC | CPT | 5.0 | PPC | Readiness Assessments | 234.33 | Red | RED |  |  |  |  |  |
| 2466 | 1.12.2.5 | Produce Readiness Assessment Reports (Overall Report & Individual Participant Reports) |  | 15d | 2025-06-02 | 2025-06-20 | 2464, 2465 |  |  | 2024-12-24 | 2025-01-13 | 15d | 2024-12-24 | 2025-01-13 | 32395d | 0d |  | PPC |  | 5.0 | PPC | Readiness Assessments | 255.33 | Red | RED |  |  |  |  |  |
| 2467 | 1.12.2.6 | Readiness Assessment 5 / 6 - Start of Qualification and Participant Readiness for M10 and M11 and CP3/CP4 check (incl. Readiness Assessment Report approval) Completed | milestone | 0d | 2025-06-24 | 2025-06-24 | 2466FS+2d |  |  | 2025-01-17 | 2025-01-17 | 0d | 2025-01-17 | 2025-01-17 | 32395d | 0d |  | CPT | PPC | 5.18 | PPC | Readiness Assessments | 277.71 | Red | RED |  | T2-RA-0400 | PSG | T2 |  |

Notes:
- 2442: Action: 5/2 - PP said ask MB if belonged to him. MB says doesn't sit with him
- 2458: 16/11- FD confirmed activity didn't take place for RA3 because responses did not warrant follow-up
- 2460: 16/11-RA3 outputs and initial findings shared with PSG to support M9 decision making. Individual reports and final closure report being finalised. No impact to Programme timelines or activities
- 2467: 08/02/2024 Name change approval at PSG on 07/02/24 from 'Readiness Assessment 5 - Start of Qualification - Completed (incl. Readiness Assessment Report approval)'

| ID | WBS | Task | Type | Duration | Start | Finish | Predecessors | Baseline start | Baseline finish | Baseline duration | Baseline 1 start | Baseline 1 finish | Total slack | Free slack | Constraint | Responsible | Involved | Text3 | Task Status | Update Version | MHHS Resource Name | MHHS Programme Phase | Sched Status | RAG | Milestone ID | Text29 | Tier |
| --- | --- | --- | --- | --- | --- | --- | --- | --- | --- | --- | --- | --- | --- | --- | --- | --- | --- | --- | --- | --- | --- | --- | --- | --- | --- | --- | --- |
| 2468 | 1.12.3 | **Readiness Assessment 7 - Migration Checkpoint** |  | 49d | 2026-01-12 | 2026-03-19 |  | 2025-08-04 | 2025-10-09 | 49d | 2025-08-04 | 2025-10-09 | 32203d |  |  | N/A | N/A | D29 - RA8 Readiness Report | M14 | 5.0 | N/A | Readiness Assessments |  |  |  |  |  |
| 2469 | 1.12.3.1 | Launch Readiness Assessment survey | milestone | 0d | 2026-01-12 | 2026-01-12 |  | 2025-08-04 | 2025-08-04 | 0d | 2025-08-04 | 2025-08-04 | 32203d | 0d | start no earlier than 2026-01-12 | PPC |  |  | 479.33 | 5.0 | PPC | Readiness Assessments | Red | RED |  |  |  |
| 2470 | 1.12.3.2 | PPs submit survey responses |  | 15d | 2026-01-12 | 2026-01-30 | 2469 | 2025-08-04 | 2025-08-22 | 15d | 2025-08-04 | 2025-08-22 | 32203d | 0d |  | PP | PPC |  | 479.33 | 5.0 | PPC | Readiness Assessments | Red | RED |  |  |  |
| 2471 | 1.12.3.3 | Analyse survey responses |  | 15d | 2026-02-02 | 2026-02-20 | 2470 | 2025-08-25 | 2025-09-12 | 15d | 2025-08-25 | 2025-09-12 | 32203d | 0d |  | PPC | CPT |  | 500.33 | 5.0 | PPC | Readiness Assessments | Red | RED |  |  |  |
| 2472 | 1.12.3.4 | Conduct deep-dive interviews (sample of PPs) |  | 15d | 2026-02-02 | 2026-02-20 | 2470 | 2025-08-25 | 2025-09-12 | 15d | 2025-08-25 | 2025-09-12 | 32203d | 0d |  | PPC | CPT |  | 500.33 | 5.0 | PPC | Readiness Assessments | Red | RED |  |  |  |
| 2473 | 1.12.3.5 | Produce Readiness Assessment Reports (Overall Report & Individual Participant Reports) |  | 15d | 2026-02-23 | 2026-03-13 | 2471, 2472 | 2025-09-15 | 2025-10-03 | 15d | 2025-09-15 | 2025-10-03 | 32203d | 0d |  | PPC |  |  | 521.33 | 5.0 | PPC | Readiness Assessments | Red | RED |  |  |  |
| 2474 | 1.12.3.6 | Readiness Assessment 7 - Migration Checkpoint - Completed (incl. Readiness Assessment Report approval) | milestone | 0d | 2026-03-19 | 2026-03-19 | 2473FS+4d | 2025-10-09 | 2025-10-09 | 0d | 2025-10-09 | 2025-10-09 | 32203d | 0d |  | CPT | PPC |  | 545.71 | 5.0 | PPC | Readiness Assessments | Red | RED | T2-RA-0600 | PSG | T2 |
| 2475 | 1.12.4 | **Readiness Assessment 8 - Ready to Accept New MPANs** |  | 49d | 2026-06-16 | 2026-08-21 |  | 2026-01-06 | 2026-03-13 | 49d | 2026-01-06 | 2026-03-13 | 32092d |  |  | N/A | N/A | D29 - RA8 Readiness Report | M14 | 5.0 | N/A | Readiness Assessments |  |  |  |  |  |
| 2476 | 1.12.4.1 | Launch Readiness Assessment survey | milestone | 0d | 2026-06-16 | 2026-06-16 | 1792FS-60d | 2026-01-06 | 2026-01-06 | 0d | 2026-01-06 | 2026-01-06 | 32092d | 0d |  | PPC |  |  | 634.33 | 5.0 | PPC | Readiness Assessments | Red | RED |  |  |  |
| 2477 | 1.12.4.2 | PPs submit survey responses |  | 15d | 2026-06-16 | 2026-07-06 | 2476 | 2026-01-06 | 2026-01-26 | 15d | 2026-01-06 | 2026-01-26 | 32092d | 0d |  | PP | PPC |  | 634.33 | 5.0 | PPC | Readiness Assessments | Red | RED |  |  |  |
| 2478 | 1.12.4.3 | Analyse survey responses |  | 15d | 2026-07-07 | 2026-07-27 | 2477 | 2026-01-27 | 2026-02-16 | 15d | 2026-01-27 | 2026-02-16 | 32092d | 0d |  | PPC | CPT |  | 655.33 | 5.0 | PPC | Readiness Assessments | Red | RED |  |  |  |
| 2479 | 1.12.4.4 | Conduct deep-dive interviews (sample of PPs) |  | 15d | 2026-07-07 | 2026-07-27 | 2477 | 2026-01-27 | 2026-02-16 | 15d | 2026-01-27 | 2026-02-16 | 32092d | 0d |  | PPC | CPT |  | 655.33 | 5.0 | PPC | Readiness Assessments | Red | RED |  |  |  |
| 2480 | 1.12.4.5 | Produce Readiness Assessment Reports (Overall Report & Individual Participant Reports) |  | 15d | 2026-07-28 | 2026-08-17 | 2478, 2479 | 2026-02-17 | 2026-03-09 | 15d | 2026-02-17 | 2026-03-09 | 32092d | 0d |  | PPC |  |  | 676.33 | 5.0 | PPC | Readiness Assessments | Red | RED |  |  |  |
| 2481 | 1.12.4.6 | Readiness Assessment 8 - Ready to Accept New MPANs - Completed (incl. Readiness Assessment Report approval) | milestone | 0d | 2026-08-21 | 2026-08-21 | 2480FS+4d | 2026-03-13 | 2026-03-13 | 0d | 2026-03-13 | 2026-03-13 | 32092d | 0d |  | CPT | PPC |  | 700.71 | 5.0 | PPC | Readiness Assessments | Red | RED | T2-RA-0700 | PSG | T2 |
| 2482 | 1.12.5 | **Readiness Assessment 9 - Ready for New Settlement Timetable and CP5 Check** |  | 49d | 2027-02-22 | 2027-04-29 |  | 2026-09-29 | 2026-12-04 | 49d | 2026-09-29 | 2026-12-04 | 31913d |  |  | N/A | N/A | D32 - RA10 Readiness Report | M16 | 5.0 | N/A | Readiness Assessments |  |  |  |  |  |
| 2483 | 1.12.5.1 | Launch Readiness Assessment survey | milestone | 0d | 2027-02-22 | 2027-02-22 | 2410FS-60d | 2026-09-29 | 2026-09-29 | 0d | 2026-09-29 | 2026-09-29 | 31913d | 0d |  | PPC |  |  | 885.33 | 5.0 | PPC | Readiness Assessments | Red | RED |  |  |  |
| 2484 | 1.12.5.2 | PPs submit survey responses |  | 15d | 2027-02-22 | 2027-03-12 | 2483 | 2026-09-29 | 2026-10-19 | 15d | 2026-09-29 | 2026-10-19 | 31913d | 0d |  | PP | PPC |  | 885.33 | 5.0 | PPC | Readiness Assessments | Red | RED |  |  |  |
| 2485 | 1.12.5.3 | Analyse survey responses |  | 15d | 2027-03-15 | 2027-04-02 | 2484 | 2026-10-20 | 2026-11-09 | 15d | 2026-10-20 | 2026-11-09 | 31913d | 0d |  | PPC | CPT |  | 906.33 | 5.0 | PPC | Readiness Assessments | Red | RED |  |  |  |
| 2486 | 1.12.5.4 | Conduct deep-dive interviews (sample of PPs) |  | 15d | 2027-03-15 | 2027-04-02 | 2484 | 2026-10-20 | 2026-11-09 | 15d | 2026-10-20 | 2026-11-09 | 31913d | 0d |  | PPC | CPT |  | 906.33 | 5.0 | PPC | Readiness Assessments | Red | RED |  |  |  |
| 2487 | 1.12.5.5 | Produce Readiness Assessment Reports (Overall Report & Individual Participant Reports) |  | 15d | 2027-04-05 | 2027-04-23 | 2485, 2486 | 2026-11-10 | 2026-11-30 | 15d | 2026-11-10 | 2026-11-30 | 31913d | 0d |  | PPC |  |  | 927.33 | 5.0 | PPC | Readiness Assessments | Red | RED |  |  |  |
| 2488 | 1.12.5.6 | Readiness Assessment 9 - Readiness for New Settlement Timetable - Completed (incl. Readiness Assessment Report approval) | milestone | 0d | 2027-04-29 | 2027-04-29 | 2487FS+4d | 2026-12-04 | 2026-12-04 | 0d | 2026-12-04 | 2026-12-04 | 31913d | 0d |  | CPT | PPC |  | 951.71 | 5.0 | PPC | Readiness Assessments | Red | RED | T2-RA-0800 | PSG | T2 |
| 2489 | 1.12.6 | **Readiness Assessments - Tier 1 Milestones** |  | 482d | 2025-06-24 | 2027-04-29 |  | 2023-11-13 | 2026-12-04 | 799d | 2023-11-17 | 2026-12-04 | 31913d |  |  | N/A | N/A |  |  | 5.0 | N/A | Readiness Assessments |  |  |  |  |  |
| 2490 | 1.12.6.1 | Readiness Assessment 6 - Start of Migration - Completed (incl. Readiness Assessment Report approval) | milestone | 0d | 2025-06-24 | 2025-06-24 | 2467 | 2025-04-04 | 2025-04-04 | 0d | 2025-04-04 | 2025-04-04 | 32395d |  | finish no earlier than 2025-04-04 | CPT | PPC |  | 277.71 | 5.0 | PPC | Readiness Assessments | Red | RED | T2-RA-0500 | PSG | T2 |
| 2491 | 1.12.6.2 | Readiness Assessment 7 - Migration Checkpoint - Completed (incl. Readiness Assessment Report approval) | milestone | 0d | 2026-03-19 | 2026-03-19 | 2474 | 2025-10-09 | 2025-10-09 | 0d | 2025-10-09 | 2025-10-09 | 32203d |  |  | CPT | PPC |  | 545.71 | 5.0 | PPC | Readiness Assessments | Red | RED | T2-RA-0600 | PSG | T2 |
| 2492 | 1.12.6.3 | Readiness Assessment 8 - Ready to Accept New MPANs - Completed (incl. Readiness Assessment Report approval) | milestone | 0d | 2026-08-21 | 2026-08-21 | 2481 | 2026-03-13 | 2026-03-13 | 0d | 2026-03-13 | 2026-03-13 | 32092d |  |  | CPT | PPC |  | 700.71 | 5.0 | PPC | Readiness Assessments | Red | RED | T2-RA-0700 | PSG | T2 |
| 2493 | 1.12.6.4 | Readiness Assessment 9 - Readiness for New Settlement Timetable - Completed (incl. Readiness Assessment Report approval) | milestone | 0d | 2027-04-29 | 2027-04-29 | 2488 | 2026-12-04 | 2026-12-04 | 0d | 2026-12-04 | 2026-12-04 | 31913d |  |  | CPT | PPC |  | 951.71 | 5.0 | PPC | Readiness Assessments | Red | RED | T2-RA-0800 | PSG | T2 |

| ID | WBS | Task | Type | Duration | Start | Finish | Predecessors | Complete | Remaining | Baseline start | Baseline finish | Baseline duration | Baseline 1 start | Baseline 1 finish | Total slack | Free slack | Constraint | Responsible | Involved | MHHS Resource Name | MHHS Programme Phase | Update Version | Sched Status | RAG | Text3 | Milestone ID | Text29 | Tier | Task Status |
| --- | --- | --- | --- | --- | --- | --- | --- | --- | --- | --- | --- | --- | --- | --- | --- | --- | --- | --- | --- | --- | --- | --- | --- | --- | --- | --- | --- | --- | --- |
| 2494 | 1.13 | **CONTROL POINTS** |  | 1169d | 2022-11-10 A | 2027-05-05 |  | 51% | 574.59d | 2022-11-10 | 2026-12-07 | 1063d | 2022-11-10 | 2026-12-07 | 31910d |  |  | N/A | N/A | N/A | Control Points |  |  |  |  |  |  |  |  |
| 2495 | 1.13.1 | **Control Point 1 - Start of System Design, Build & Test** |  | 20d | 2022-11-10 A | 2022-12-07 A |  | 100% |  | 2022-11-10 | 2022-12-07 | 20d | 2022-11-10 | 2022-12-07 |  |  |  | N/A | N/A | N/A | Control Points | 5.0 |  |  |  |  |  |  |  |
| 2496 | 1.13.1.1 | Control Point 1 Preparation (incl. Control Point Report development and review) |  | 15d | 2022-11-10 A | 2022-11-30 A | 2497SS-20d | 100% |  | 2022-11-10 | 2022-11-30 | 15d | 2022-11-10 | 2022-11-30 |  |  |  | CPT | PMO | PMO | Control Points | 5.0 | Complete | COMPLETE |  |  |  |  |  |
| 2497 | 1.13.1.2 | Control Point 1 - Start of System Design, Build & Test (incl. Control Point Report approval) | milestone | 0d | 2022-12-07 A | 2022-12-07 A |  | 100% |  | 2022-12-07 | 2022-12-07 | 0d | 2022-12-07 | 2022-12-07 |  |  | must finish on 2022-12-07 | CPT | PMO | PMO | Control Points | 5.0 | Complete | COMPLETE | D24 - CP2 Approval | T1-CP-1000 | PSG | T1 |  |
| 2498 | 1.13.2 | **Control Point 2 - Start of Integration & Test** |  | 20d | 2023-10-02 A | 2023-10-30 A |  | 100% |  | 2023-10-03 | 2023-10-30 | 20d | 2023-10-02 | 2023-10-30 |  |  |  | N/A | N/A | N/A | Control Points | 5.0 |  |  |  |  |  |  |  |
| 2499 | 1.13.2.1 | Control Point 2 Preparation (incl. Control Point Report development and review) |  | 15d | 2023-10-02 A | 2023-10-20 A | 2500SS-20d | 100% |  | 2023-10-03 | 2023-10-23 | 15d | 2023-10-02 | 2023-10-20 |  |  |  | CPT | PMO | PMO | Control Points | 5.0 | Complete | COMPLETE |  |  |  |  |  |
| 2500 | 1.13.2.2 | Control Point 2 - Start of Integration & Test (incl. Control Point Report approval) | milestone | 0d | 2023-10-30 A | 2023-10-30 A | 1070 | 100% |  | 2023-10-30 | 2023-10-30 | 0d | 2023-10-30 | 2023-10-30 |  |  |  | CPT | PMO | PMO | Control Points | 5.11 | Complete | COMPLETE | D24 - CP2 Approval | T1-CP-2000 | PSG | T1 |  |
| 2501 | 1.13.3 | **Control Point 3/4 - Readiness for Migration** |  | 20d | 2025-07-10 | 2025-08-07 |  |  |  | 2025-03-03 | 2025-03-28 | 20d | 2025-03-03 | 2025-03-28 | 32364d |  |  | N/A | N/A | N/A | Control Points | 5.0 |  |  | D26 - CP3 Approval |  |  |  |  |
| 2502 | 1.13.3.1 | Control Point 3/4 Preparation (incl. Control Point Report development and review) |  | 14d | 2025-07-10 | 2025-07-29 | 2503SS-20d |  |  | 2025-03-03 | 2025-03-20 | 14d | 2025-03-03 | 2025-03-21 | 32370d |  |  | CPT | PMO | PMO | Control Points | 5.0 | Red | RED |  |  |  |  | 293.33 |
| 2503 | 1.13.3.2 | Control Point 3/4 - Readiness for Migration (incl. Control Point Report approval) | milestone | 0d | 2025-08-07 | 2025-08-07 | 1317FS-5d |  |  | 2025-03-28 | 2025-03-28 | 0d | 2025-03-28 | 2025-03-28 | 32364d | 0d |  | CPT | PMO | PMO | Control Points | 5.0 | Red | RED |  | T1-CP-3000 | PSG | T1 | 321.33 |
| 2504 | 1.13.4 | **Control Point 5 - Cut Over to New Settlement Timetable** |  | 20d | 2027-04-07 | 2027-05-05 |  |  |  | 2026-11-10 | 2026-12-07 | 20d | 2026-11-10 | 2026-12-07 | 31910d |  |  | N/A | N/A | N/A | Control Points | 5.0 |  |  | D33 - Control Point 6 Approval |  |  |  | M16 |
| 2505 | 1.13.4.1 | Control Point 5 Preparation (incl. Control Point Report development and review) |  | 15d | 2027-04-07 | 2027-04-27 | 2506SS-20d |  |  | 2026-11-10 | 2026-11-30 | 15d | 2026-11-10 | 2026-11-30 | 31915d |  |  | CPT | PP | PMO | Control Points | 5.0 | Red | RED |  |  |  |  | 929.33 |
| 2506 | 1.13.4.2 | Control Point 5 - Cut Over to New Settlement Timetable (incl. Control Point Report approval) | milestone | 0d | 2027-05-05 | 2027-05-05 | 2410FS-8d |  |  | 2026-12-07 | 2026-12-07 | 0d | 2026-12-07 | 2026-12-07 | 31910d | 0d |  | CPT | CPT | PMO | Control Points | 5.0 | Red | RED | D33 - Control Point 6 Approval | T1-CP-4000 | PSG | T1 | 957.33 |
| 2507 | 1.13.5 | **Control Points - Tier 1 Milestones** |  | 1149d | 2022-12-07 A | 2027-05-05 |  |  | 1149d | 2022-12-07 | 2026-12-07 | 1043d | 2022-12-07 | 2026-12-07 | 31910d |  |  | N/A | N/A | N/A | Control Points | 5.0 |  |  |  |  |  |  |  |
| 2508 | 1.13.5.1 | Control Point 1 - Start of System Design, Build & Test (incl. Control Point Report approval) | milestone | 0d | 2022-12-07 A | 2022-12-07 A | 2497SS | 100% |  | 2022-12-07 | 2022-12-07 | 0d | 2022-12-07 | 2022-12-07 |  |  |  | CPT | PMO | PMO | Control Points | 5.0 | Complete | COMPLETE |  | T1-CP-1000 | PSG | T1 |  |
| 2509 | 1.13.5.2 | Control Point 2 - Start of Integration & Test (incl. Control Point Report approval) | milestone | 0d | 2023-10-30 A | 2023-10-30 A | 2500SS | 100% |  | 2023-10-30 | 2023-10-30 | 0d | 2023-10-30 | 2023-10-30 |  |  |  | CPT | PMO | PMO | Control Points | 5.11 | Complete | COMPLETE | D24 - CP2 Approval | T1-CP-2000 | PSG | T1 |  |
| 2510 | 1.13.5.3 | Control Point 3/4 - Readiness for Migration (incl. Control Point Report approval) | milestone | 0d | 2025-08-07 | 2025-08-07 | 2503SS |  |  | 2025-03-28 | 2025-03-28 | 0d | 2025-03-28 | 2025-03-28 | 32364d |  |  | CPT | PMO | PMO | Control Points | 5.0 | Red | RED |  | T1-CP-3000 | PSG | T1 | 321.33 |
| 2511 | 1.13.5.4 | Control Point 5 - Cut Over to New Settlement Timetable (incl. Control Point Report approval) | milestone | 0d | 2027-05-05 | 2027-05-05 | 2506SS |  |  | 2026-12-07 | 2026-12-07 | 0d | 2026-12-07 | 2026-12-07 | 31910d |  |  | CPT | CPT | PMO | Control Points | 5.0 | Red | RED | D33 - Control Point 6 Approval | T1-CP-4000 | PSG | T1 | 957.33 |
| 2512 | 1.14 | **MILESTONE RANGE CHECKPOINTS** |  | 437d | 2025-06-19 | 2027-02-22 |  |  |  | 2025-01-13 | 2026-09-15 | 436d | 2025-01-13 | 2026-09-15 | 31962d |  |  | N/A | N/A | N/A | Milestone Range Checkpoints |  |  |  |  |  |  |  |  |
| 2513 | 1.14.1 | **M10, M11, M12 and M13 milestone checkpoint** |  | 0d | 2025-06-19 | 2025-06-19 |  |  |  | 2025-01-13 | 2025-01-13 | 0d | 2025-01-13 | 2025-01-13 | 32399d |  |  | N/A | N/A | N/A | Milestone Range Checkpoints | 5.0 |  |  |  |  |  |  |  |
| 2514 | 1.14.1.1 | M10, M11, M12, and M13 milestone checkpoint - date approval | milestone | 0d | 2025-06-19 | 2025-06-19 | 2173FS-3mo, 2175FS-3mo, 2171FS-3mo, 1317FS-3mo |  |  | 2025-01-13 | 2025-01-13 | 0d | 2025-01-13 | 2025-01-13 | 32399d |  |  | CPT | CPT | PMO | Milestone Range Checkpoints | 5.0 | Red | RED |  | T2-MR-0100 | PSG | T2 | 272.33 |
| 2515 | 1.14.2 | **M14 milestone checkpoint** |  | 0d | 2026-06-16 | 2026-06-16 |  |  |  | 2025-12-23 | 2025-12-23 | 0d | 2025-12-23 | 2025-12-23 | 32141d |  |  | N/A | N/A | N/A | Milestone Range Checkpoints | 5.0 |  |  |  |  |  |  |  |
| 2516 | 1.14.2.1 | M14 milestone checkpoint - date approval | milestone | 0d | 2026-06-16 | 2026-06-16 | 1792FS-3mo |  |  | 2025-12-23 | 2025-12-23 | 0d | 2025-12-23 | 2025-12-23 | 32141d |  |  | CPT | CPT | PMO | Milestone Range Checkpoints | 5.0 | Red | RED |  | T2-MR-0200 | PSG | T2 | 634.33 |
| 2517 | 1.14.3 | **M15 milestone checkpoint** |  | 0d | 2026-12-22 | 2026-12-22 |  |  |  | 2026-07-14 | 2026-07-14 | 0d | 2026-07-14 | 2026-07-14 | 32006d |  |  | N/A | N/A | N/A | Milestone Range Checkpoints | 5.0 |  |  |  |  |  |  |  |
| 2518 | 1.14.3.1 | M15 milestone checkpoint - date approval | milestone | 0d | 2026-12-22 | 2026-12-22 | 2177FS-3mo |  |  | 2026-07-14 | 2026-07-14 | 0d | 2026-07-14 | 2026-07-14 | 32006d |  |  | CPT | CPT | PMO | Milestone Range Checkpoints | 5.0 | Red | RED |  | T2-MR-0300 | PSG | T2 | 823.33 |

| ID | WBS | Task | Type | Duration | Start | Finish | Predecessors | Baseline start | Baseline finish | Baseline duration | Baseline 1 start | Baseline 1 finish | Total slack | Responsible | Involved | Update Version | MHHS Resource Name | MHHS Programme Phase | Task Status | Sched Status | RAG | Milestone ID | Text29 | Tier |
| --- | --- | --- | --- | --- | --- | --- | --- | --- | --- | --- | --- | --- | --- | --- | --- | --- | --- | --- | --- | --- | --- | --- | --- | --- |
| 2519 | 1.14.4 | **M16 milestone checkpoint** |  | 0d | 2027-02-22 | 2027-02-22 |  | 2026-09-15 | 2026-09-15 | 0d | 2026-09-15 | 2026-09-15 | 31962d | N/A | N/A | 5.0 | N/A | Milestone Range Checkpoints |  |  |  |  |  |  |
| 2520 | 1.14.4.1 | M16 milestone checkpoint - date approval | milestone | 0d | 2027-02-22 | 2027-02-22 | 2410FS-3mo | 2026-09-15 | 2026-09-15 | 0d | 2026-09-15 | 2026-09-15 | 31962d | CPT | CPT | 5.0 | PMO | Milestone Range Checkpoints | 885.33 | Red | RED | T2-MR-0400 | PSG | T2 |
